# Outline ELEXON Plan_kc

How a schedule from MS Project changed from version to version. A marks actual dates.

## Version 1 (data date 2024-10-21, saved 2025-02-13, file MHHS-DEL1139 - MHHS Plan v6.18.mpp)

| ID | WBS | Task | Duration | Start | Finish | Predecessors | Complete | Total float | Constraint |
| --- | --- | --- | --- | --- | --- | --- | --- | --- | --- |
| 1 | 1 | **PROGRAMME PLAN.** | 1344d? | 2022-10-31 A | 2027-12-23 |  | 56% |  |  |
| 2 |  | MHHS Programme Start | 0d | 2022-10-31 A | 2022-10-31 A |  | 100% |  |  |
| 3 | 1.2 | **PROGRAMME MANAGEMENT** | 1089d | 2022-10-31 A | 2026-12-31 |  | 44% | 255d |  |
| 4 | 1.2.1 | **Programme Management** | 1089d | 2022-10-31 A | 2026-12-31 |  | 43% | 255d |  |
| 5 |  | Sprint-based prioritisation planning and execution | 1089d | 2022-10-31 A | 2026-12-31 |  | 43% | 255d | finish no earlier than 2026-12-31 |
| 6 |  | Programme governance secretariat | 1089d | 2022-10-31 A | 2026-12-31 |  | 43% | 255d |  |
| 7 |  | RAID management and reporting | 1089d | 2022-10-31 A | 2026-12-31 |  | 43% | 255d |  |
| 8 |  | Tracking against Programme outcomes and KPIs | 1089d | 2022-10-31 A | 2026-12-31 |  | 43% | 255d |  |
| 9 |  | Change control and reporting | 1089d | 2022-10-31 A | 2026-12-31 |  | 43% | 255d |  |
| 10 |  | Ongoing identification of lessons learned relating to the PMO and implementation of improvements | 1089d | 2022-10-31 A | 2026-12-31 |  | 43% | 255d |  |
| 11 | 1.2.2 | **Programme Internal Assurance Reviews** | 1089d | 2022-10-31 A | 2026-12-31 |  | 43% | 255d |  |
| 12 |  | Programme Internal Assurance Reviews | 1089d | 2022-10-31 A | 2026-12-31 |  | 43% | 255d |  |
| 13 | 1.2.3 | **Engagement with PPs** | 1089d | 2022-10-31 A | 2026-12-31 |  | 43% | 255d |  |
| 14 |  | Ongoing PP liaison activities | 1089d | 2022-10-31 A | 2026-12-31 |  | 43% | 255d |  |
| 15 |  | Milestone and Control Point objective setting | 1089d | 2022-10-31 A | 2026-12-31 |  | 43% | 255d |  |
| 16 |  | Reporting | 1089d | 2022-10-31 A | 2026-12-31 |  | 43% | 255d |  |
| 17 | 1.2.3.4 | **PP Engagement Events** | 1089d | 2022-10-31 A | 2026-12-31 |  | 43% | 255d |  |
| 18 |  | Bilateral meetings | 1089d | 2022-10-31 A | 2026-12-31 |  | 43% | 255d |  |
| 19 |  | Monthly webinars | 1089d | 2022-10-31 A | 2026-12-31 |  | 43% | 255d |  |
| 20 |  | Open days | 1089d | 2022-10-31 A | 2026-12-31 |  | 43% | 255d |  |
| 21 | 1.2.3.5 | **PP Communications** | 1088d | 2022-10-31 A | 2026-12-30 |  | 43% | 256d |  |
| 22 |  | The Clock updates (weekly) | 1088d | 2022-10-31 A | 2026-12-30 |  | 43% | 256d |  |
| 23 |  | Maintain and update content on public-facing Portal (and ongoing feedback reviews to identify and implement Portal improvements) | 1088d | 2022-10-31 A | 2026-12-30 |  | 43% | 256d |  |
| 24 | 1.2.4 | **Code Change Support / Other Programme Alignment** | 1089d | 2022-10-31 A | 2026-12-31 |  | 43% | 255d |  |
| 25 |  | Support DCC/BEIS on SEC change | 1089d | 2022-10-31 A | 2026-12-31 |  | 43% | 255d |  |
| 26 |  | Support on Smart Meters Act changes | 1089d | 2022-10-31 A | 2026-12-31 |  | 43% | 255d |  |
| 27 |  | Support DCC/RECCo on CSS change | 1089d | 2022-10-31 A | 2026-12-31 |  | 43% | 255d |  |
| 28 |  | Support Elexon on BSC change | 1089d | 2022-10-31 A | 2026-12-31 |  | 43% | 255d |  |
| 29 |  | Support code change inside & outside CCIAG | 1089d | 2022-10-31 A | 2026-12-31 |  | 43% | 255d |  |
| 30 |  | Support code change inside & outside CCAG | 1089d | 2022-10-31 A | 2026-12-31 |  | 43% | 255d |  |
| 31 | 1.2.5 | **Programme Replan Baseline** | 163d | 2022-10-31 A | 2023-06-14 A |  | 100% |  |  |
| 32 |  | Round 3 consultation preparation | 32d | 2022-10-31 A | 2022-12-13 A |  | 100% |  |  |
| 33 |  | PSG decision to launch Round 3 consultation | 0d | 2022-12-07 A | 2022-12-07 A | 32FS-5d | 100% |  |  |
| 34 |  | Round 3 consultation (incl. walkthroughs and Q&A) | 35d | 2022-12-14 A | 2023-01-31 A | 33FS+5d | 100% |  |  |
| 35 |  | Review and uplift of foundational testing documents to align with replan approach | 92d | 2022-12-14 A | 2023-04-20 A | 34SS | 100% |  |  |
| 36 |  | Round 3 consultation responses analysis (incl. identification of SIT volunteers) | 10d | 2023-02-01 A | 2023-02-14 A | 34 | 100% |  |  |
| 37 |  | Replan re-drafting and supporting artefact updates (incl. engagement with Ofgem) | 26d | 2023-02-15 A | 2023-03-22 A | 36 | 100% |  |  |
| 38 |  | Draft Replan Change Request | 31d | 2023-02-15 A | 2023-03-29 A | 36 | 100% |  |  |
| 39 |  | PSG decision to issue CR for industry impact assessment | 0d | 2023-04-05 A | 2023-04-05 A | 38FS+5d | 100% |  |  |
| 40 |  | Industry impact assessment | 10d | 2023-04-06 A | 2023-04-19 A | 39 | 100% |  |  |
| 41 |  | Replan playbacks (to assist PPs in impact assessment) | 5d | 2023-04-11 A | 2023-04-17 A | 40SS+3d | 100% |  |  |
| 42 |  | Industry impact assessment responses analysis | 5d | 2023-04-20 A | 2023-04-26 A | 40 | 100% |  |  |
| 43 |  | Extraordinary PSG decision to agree baseline recommendation | 0d | 2023-05-03 A | 2023-05-03 A | 42FS+5d | 100% |  |  |
| 44 |  | Programme Replan playbacks and drop-in sessions | 5d | 2023-06-08 A | 2023-06-14 A |  | 100% |  |  |
| 45 | 1.3 | **DESIGN, BUILD & TEST (PIT)** | 1221d? | 2022-10-31 A | 2027-07-05 |  | 77% | 123d |  |
| 46 | 1.3.1 | **Design Baseline & Enduring PP Support** | 1101d | 2022-10-31 A | 2027-01-18 |  | 71% | 243d |  |
| 47 |  | Physical design baselined (M5) | 0d | 2022-10-31 A | 2022-10-31 A |  | 100% |  |  |
| 48 | 1.3.1.2 | **M5 Design Work-Off Plan Implementation & Approval** | 79d | 2022-10-31 A | 2023-02-16 A |  | 100% |  |  |
| 49 |  | Implementation of M5 design Work-Off Plan | 74d | 2022-10-31 A | 2023-02-09 A | 47 | 100% |  |  |
| 50 |  | M5 design Work-Off Plan completion approved | 0d | 2023-02-16 A | 2023-02-16 A | 49FS+5d | 100% |  |  |
| 51 | 1.3.1.3 | **Enduring PP Design Support** | 1089d | 2022-10-31 A | 2026-12-31 A |  | 100% |  |  |
| 52 |  | Design playbacks and drop-in sessions | 45d | 2022-10-31 A | 2022-12-30 A | 47 | 100% |  |  |
| 53 |  | Support participants on E2E MHHS Design | 1089d | 2022-10-31 A | 2026-12-31 A | 47 | 100% |  |  |
| 54 |  | DIP Onboarding Support | 70d | 2022-11-14 A | 2023-02-17 A |  | 100% |  | must start on 2022-11-14 |
| 55 |  | iServer Launch | 0d | 2023-02-16 A | 2023-02-16 A | 50 | 100% |  |  |
| 56 | 1.3.1.4 | **Establish Design Change Management Processes** | 1101d | 2022-10-31 A | 2027-01-18 |  | 36% | 243d |  |
| 57 |  | Internal review of internal change management processes | 35d | 2022-10-31 A | 2022-12-16 A |  | 100% |  |  |
| 58 |  | SRO approval of internal change management processes | 0d | 2022-12-16 A | 2022-12-16 A | 57FF | 100% |  |  |
| 59 |  | Change Process Webinar | 0d | 2023-01-16 A | 2023-01-16 A |  | 100% |  | must start on 2023-01-16 |
| 60 |  | Enduring change management process approved | 0d | 2023-02-16 A | 2023-02-16 A | 50FF | 100% |  |  |
| 61 |  | Maintain E2E MHHS Design (post-M5 design change management processes operational) | 1022d | 2023-02-17 A | 2027-01-18 | 60 | 34% | 243d |  |
| 62 | 1.3.1.5 | **Design Authority Mobilisation** | 29d | 2022-12-14 A | 2023-01-23 A |  | 100% |  |  |
| 63 |  | Design Authority ToR approved | 0d | 2022-12-14 A | 2022-12-14 A |  | 100% |  | must start on 2022-12-14 |
| 64 |  | Inaugural Design Authority | 0d | 2023-01-23 A | 2023-01-23 A | 63FS+29d | 100% |  |  |
| 65 | 1.3.1.6 | **Network Operation Services Adaptor Procurement** | 0d | 2023-05-23 A | 2023-05-23 A |  | 100% |  |  |
| 66 |  | All SIT LDSOs have procured their adapter providers | 0d | 2023-05-23 A | 2023-05-23 A | 618SS | 100% |  |  |
| 67 | 1.3.2 | **PP Mobilisation** | 67d | 2022-10-31 A | 2023-01-31 A |  | 100% |  |  |
| 68 |  | Set up governance | 67d | 2022-10-31 A | 2023-01-31 A |  | 100% |  |  |
| 69 |  | Set up reporting | 67d | 2022-10-31 A | 2023-01-31 A |  | 100% |  |  |
| 70 |  | Obtain funding | 67d | 2022-10-31 A | 2023-01-31 A |  | 100% |  |  |

| ID | WBS | Task | Duration | Start | Finish | Predecessors | Complete | Total float | Constraint |
| --- | --- | --- | --- | --- | --- | --- | --- | --- | --- |
| 71 |  | Earmark resources | 67d | 2022-10-31 A | 2023-01-31 A |  | 100% |  |  |
| 72 |  | Mobilise initial team | 67d | 2022-10-31 A | 2023-01-31 A |  | 100% |  |  |
| 73 | 1.3.3 | **PIT Stub Specification and Delivery** | 435d | 2022-10-31 A | 2024-06-28 A |  | 100% |  |  |
| 74 | 1.3.3.1 | **DIP Simulator** | 108d | 2022-10-31 A | 2023-03-29 A |  | 100% |  |  |
| 75 |  | Build & Test | 95d | 2022-10-31 A | 2023-03-10 A | 47 | 100% |  |  |
| 76 |  | UAT | 85d | 2022-11-14 A | 2023-03-10 A | 75SS+10d | 100% |  |  |
| 77 |  | Beta test | 95d | 2022-10-31 A | 2023-03-10 A | 75SS | 100% |  |  |
| 78 |  | Prepare for release | 18d | 2023-03-06 A | 2023-03-29 A | 77FS-5d | 100% |  |  |
| 79 |  | DIP Simulator released | 0d | 2023-03-29 A | 2023-03-29 A | 78FF | 100% |  | start no earlier than 2023-01-30 |
| 80 | 1.3.3.2 | **DIP Simulator Uplifts** | 257d | 2023-07-06 A | 2024-06-28 A |  | 100% |  |  |
| 81 |  | DIP Simulator uplifted to align with design releases - design/build/test | 27d | 2023-07-06 A | 2023-08-11 A | 117 | 100% |  |  |
| 82 |  | DIP Simulator uplifted to align with Interim Release 2 | 0d | 2023-08-11 A | 2023-08-11 A | 81 | 100% |  |  |
| 83 |  | DIP Simulator uplifted to align with design releases - design/build/test | 20d | 2023-10-09 A | 2023-11-03 A | 126FS+2d | 100% |  |  |
| 84 |  | DIP Simulator uplifted to align with Interim Release 5 | 0d | 2023-11-03 A | 2023-11-03 A | 83 | 100% |  |  |
| 85 |  | DIP Simulator uplifted to align with design releases - design/build/test | 37d | 2024-02-01 A | 2024-03-22 A | 134 | 100% |  |  |
| 86 |  | DIP Simulator uplifted to align with Interim Release 7 | 0d | 2024-03-22 A | 2024-03-22 A | 85 | 100% |  |  |
| 87 |  | DIP Simulator uplifted to align with design releases - design/build/test | 57d | 2024-04-04 A | 2024-06-21 A | 138 | 100% |  |  |
| 88 |  | DIP Simulator uplifted to align with Interim Release 8 | 0d | 2024-06-28 A | 2024-06-28 A | 87FS+5d | 100% |  |  |
| 89 | 1.3.3.3 | **Data Generator** | 130d | 2022-12-01 A | 2023-05-31 A |  | 100% |  |  |
| 90 |  | Design | 15d | 2022-12-01 A | 2022-12-21 A |  | 100% |  |  |
| 91 |  | Build & Test | 50d | 2023-02-16 A | 2023-04-26 A | 90FS+40d | 100% |  |  |
| 92 |  | UAT | 10d | 2023-04-27 A | 2023-05-10 A | 91 | 100% |  |  |
| 93 |  | Beta test | 45d | 2023-03-30 A | 2023-05-31 A | 91FS-20d, 95FF | 100% |  |  |
| 94 |  | Prepare for release | 24d | 2023-04-27 A | 2023-05-30 A | 92SS | 100% |  |  |
| 95 |  | Data Generator released | 0d | 2023-05-31 A | 2023-05-31 A | 94FS+1d | 100% |  |  |
| 96 | 1.3.4 | **Design Artefact Releases** | 536d? | 2023-02-22 A | 2025-03-12 |  | 94% | 726d |  |
| 97 | 1.3.4.1 | **Interim release 1** | 79d | 2023-02-22 A | 2023-06-12 A |  | 100% |  |  |
| 98 |  | Prioritise DINs and CR | 1d | 2023-02-22 A | 2023-02-22 A |  | 100% |  | must start on 2023-02-22 |
| 99 | 1.3.4.1.2 | **Industry input session** | 7d | 2023-02-23 A | 2023-03-03 A |  | 100% |  |  |
| 100 |  | Raise a CR covering prioritized assessment cluster | 1d | 2023-02-23 A | 2023-02-23 A | 98 | 100% |  |  |
| 101 |  | Organize Industry Input session to go through significant items to reach consensus | 1d | 2023-02-23 A | 2023-02-23 A | 100SS | 100% |  |  |
| 102 |  | Conduct Meeting | 1d | 2023-03-03 A | 2023-03-03 A | 101FS+5d | 100% |  |  |
| 103 |  | Update baselined artefacts | 10d | 2023-03-24 A | 2023-04-06 A |  | 100% |  |  |
| 104 | 1.3.4.1.4 | **Participant review and impact assess changes** | 18d | 2023-04-14 A | 2023-05-09 A |  | 100% |  |  |
| 105 |  | Issue Redline Version of documents | 1d | 2023-04-14 A | 2023-04-14 A | 103FS+5d | 100% |  |  |
| 106 |  | Participants provide review comments to common log | 17d | 2023-04-17 A | 2023-05-09 A | 105 | 100% |  |  |
| 107 | 1.3.4.1.5 | **Assurance review** | 19d | 2023-05-10 A | 2023-06-05 A |  | 100% |  |  |
| 108 |  | SI Design Review and Respond to Comments | 5d | 2023-05-10 A | 2023-05-16 A | 106 | 100% |  |  |
| 109 |  | Prep for Assurance Review Meeting | 7d | 2023-05-17 A | 2023-05-25 A | 108 | 100% |  |  |
| 110 |  | Conduct Assurance Review Meeting | 1d | 2023-05-26 A | 2023-05-26 A | 109 | 100% |  |  |
| 111 |  | Update Artefacts following Assurance Review | 6d | 2023-05-29 A | 2023-06-05 A | 110 | 100% |  |  |
| 112 |  | PSG Approval of interim release plan | 1d | 2023-06-08 A | 2023-06-08 A |  | 100% |  | must start on 2023-06-08 |
| 113 |  | Publish updated baselined artefacts | 0d | 2023-06-06 A | 2023-06-12 A | 111 | 100% |  |  |
| 114 |  | Interim release 1 Go live | 0d | 2023-06-12 A | 2023-06-12 A | 113 | 100% |  |  |
| 115 | 1.3.4.2 | **Interim release 2** | 27d | 2023-05-30 A | 2023-07-05 A |  | 100% |  |  |
| 116 |  | Update baselined artefacts | 27d | 2023-05-30 A | 2023-07-05 A |  | 100% |  | must start on 2023-05-30 |
| 117 |  | Interim release 2 Go live | 0d | 2023-07-05 A | 2023-07-05 A | 116 | 100% |  |  |
| 118 | 1.3.4.3 | **Interim release 3** | 35d | 2023-06-15 A | 2023-08-02 A |  | 100% |  |  |
| 119 |  | Update baselined artefacts | 35d | 2023-06-15 A | 2023-08-02 A |  | 100% |  | must start on 2023-06-15 |
| 120 |  | Interim release 3 Go live | 0d | 2023-08-02 A | 2023-08-02 A | 119 | 100% |  |  |
| 121 | 1.3.4.4 | **Interim release 4** | 36d | 2023-07-12 A | 2023-08-30 A |  | 100% |  |  |
| 122 |  | Update baselined artefacts | 36d | 2023-07-12 A | 2023-08-30 A |  | 100% |  | must start on 2023-07-12 |
| 123 |  | Interim release 4 Go live | 0d | 2023-08-30 A | 2023-08-30 A | 122 | 100% |  |  |
| 124 | 1.3.4.5 | **Interim release 5** | 147d | 2023-08-17 A | 2024-03-08 A |  | 100% |  |  |
| 125 |  | Update baselined artefacts | 35d | 2023-08-17 A | 2023-10-04 A |  | 100% |  | must start on 2023-08-17 |
| 126 |  | Interim release 5 Go live | 0d | 2023-10-04 A | 2023-10-04 A | 125 | 100% |  |  |
| 127 |  | Interim Release 5 Deployed to SIT | 10d | 2024-02-26 A | 2024-03-08 A | 126FS+102d | 100% |  |  |
| 128 | 1.3.4.6 | **Interim release 6** | 192d | 2023-09-14 A | 2024-06-07 A |  | 100% |  |  |
| 129 |  | Update baselined artefacts | 35d | 2023-09-14 A | 2023-11-01 A |  | 100% |  | must start on 2023-09-14 |
| 130 |  | Interim release 6 Go live | 0d | 2023-11-01 A | 2023-11-01 A | 129 | 100% |  |  |
| 131 |  | Interim Release 6 Deployed to SIT | 10d | 2024-05-27 A | 2024-06-07 A | 130FS+147d | 100% |  |  |
| 132 | 1.3.4.7 | **Interim release 7** | 168d | 2023-10-18 A | 2024-06-07 A |  | 100% |  |  |
| 133 |  | Update baselined artefacts | 76d | 2023-10-18 A | 2024-01-31 A |  | 100% |  | start no earlier than 2023-10-18 |
| 134 |  | Interim release 7 Go live | 0d | 2024-01-31 A | 2024-01-31 A | 133 | 100% |  |  |
| 135 |  | Interim Release 7 Deployed to SIT | 10d | 2024-05-27 A | 2024-06-07 A | 134FS+82d | 100% |  |  |
| 136 | 1.3.4.8 | **Interim release 8** | 281d? | 2024-02-14 A | 2025-03-12 |  | 74% | 726d |  |
| 137 |  | Update baselined artefacts | 36d | 2024-02-14 A | 2024-04-03 A |  | 100% |  | start no earlier than 2024-02-14 |
| 138 |  | Interim release 8 Go live | 0d | 2024-04-03 A | 2024-04-03 A | 137 | 100% |  | start no earlier than 2024-01-10 |
| 139 | 1.3.4.8.3 | **Interim Release 8.3 - Maintenance Window** | 11d | 2024-10-07 A | 2024-10-21 A |  | 100% |  |  |
| 140 |  | Interim Release 8.3 'effective from date' to SIT A | 0d | 2024-10-21 A | 2024-10-21 A | 138FS+143d | 100% |  |  |

| ID | WBS | Task | Duration | Start | Finish | Predecessors | Complete | Total float | Constraint |
| --- | --- | --- | --- | --- | --- | --- | --- | --- | --- |
| 141 |  | Interim Release 8.3 'effective from date' to SIT B | 0d | 2024-10-07 A | 2024-10-07 A | 140SS-11d | 100% |  |  |
| 142 | 1.3.4.8.4 | **Interim Release 8.4** | 49d | 2024-09-25 A | 2024-12-02 A |  | 100% |  |  |
| 143 |  | Update baselined artefacts | 8d | 2024-09-25 A | 2024-10-04 A |  | 100% |  | start no earlier than 2024-09-25 |
| 144 |  | Interim Release 8.4 Published | 0d | 2024-10-16 A | 2024-10-16 A | 143FS+8d | 100% |  | start no earlier than 2024-10-09 |
| 145 |  | Interim Release 8.4 Deployed to SIT by Participants | 6d | 2024-11-25 A | 2024-12-02 A | 144FS+25d | 100% |  |  |
| 146 | 1.3.4.8.5 | **Interim Release 8.5** | 71d | 2024-10-16 A | 2025-01-22 A |  | 100% |  |  |
| 147 |  | Update baselined artefacts | 8d | 2024-10-16 A | 2024-10-25 A |  | 100% |  | start no earlier than 2024-10-16 |
| 148 |  | Interim Release 8.5 Published | 0d | 2024-11-06 A | 2024-11-06 A | 147FS+8d | 100% |  |  |
| 149 |  | Interim Release 8.5 Deployed to SIT by Participants | 3d | 2025-01-20 A | 2025-01-22 A | 148FS+52d | 100% |  |  |
| 150 | 1.3.4.8.6 | **Interim Release 8.6** | 45d? | 2024-11-21 A | 2025-01-22 A |  | 100% |  |  |
| 151 |  | Update baselined artefacts | 2d? | 2024-11-21 A | 2024-11-22 A |  | 100% |  | start no earlier than 2024-11-21 |
| 152 |  | Interim Release 8.6 Published | 1d? | 2024-11-25 A | 2024-11-25 A | 151 | 100% |  |  |
| 153 |  | Interim Release 8.6 Deployed to SIT by Participants | 3d | 2025-01-20 A | 2025-01-22 A | 152FS+39d | 100% |  |  |
| 154 | 1.3.4.8.7 | **Interim Release 8.7** | 5d | 2025-01-20 A | 2025-01-24 A |  | 100% |  |  |
| 155 |  | Update baselined artefacts | 2d | 2025-01-20 A | 2025-01-21 A |  | 100% |  | start no earlier than 2025-01-20 |
| 156 |  | Interim Release 8.7 Published | 1d | 2025-01-22 A | 2025-01-22 A | 155 | 100% |  |  |
| 157 |  | Interim Release 8.7 Deployed to SIT by Participants | 3d | 2025-01-22 A | 2025-01-24 A | 156FS-1d | 100% |  |  |
| 158 | 1.3.4.8.8 | **Interim Release 8.8** | 26d? | 2025-02-05 | 2025-03-12 |  |  | 726d |  |
| 159 |  | Update baselined artefacts | 4d | 2025-02-05 | 2025-02-10 |  |  | 726d | start no earlier than 2025-02-05 |
| 160 |  | Interim Release 8.8 Published | 1d? | 2025-02-12 | 2025-02-12 | 159FS+1d |  | 726d |  |
| 161 |  | Interim Release 8.8 Deployed to SIT by Participants | 20d | 2025-02-13 | 2025-03-12 | 160 |  | 726d |  |
| 162 | 1.3.5 | **Queries Support / Knowledgebase & Tool Roll-Out (Systems)** | 325d | 2023-01-03 A | 2024-04-01 A |  | 100% |  |  |
| 163 | 1.3.5.1 | **Query Management** | 325d | 2023-01-03 A | 2024-04-01 A |  | 100% |  |  |
| 164 |  | Respond to Participant Queries | 325d | 2023-01-03 A | 2024-04-01 A |  | 100% |  | must start on 2023-01-03 |
| 165 |  | Respond to Programme Queries | 325d | 2023-01-03 A | 2024-04-01 A | 164SS | 100% |  |  |
| 166 | 1.3.5.2 | **Query Support tooling (FreshDesk)** | 23d | 2023-06-01 A | 2023-07-03 A |  | 100% |  |  |
| 167 |  | Migrate to Standalone Freshdesk | 10d | 2023-06-01 A | 2023-06-14 A |  | 100% |  | must start on 2023-06-01 |
| 168 |  | Develop reporting dashboard | 5d | 2023-06-15 A | 2023-06-21 A | 167 | 100% |  |  |
| 169 |  | Issue to SRO for Review | 5d | 2023-06-22 A | 2023-06-28 A | 168 | 100% |  |  |
| 170 |  | Update following review | 2d | 2023-06-29 A | 2023-06-30 A | 169 | 100% |  |  |
| 171 |  | Sign off | 1d | 2023-07-03 A | 2023-07-03 A | 170 | 100% |  |  |
| 172 | 1.3.5.3 | **KnowledgeBase Development** | 72d | 2023-06-01 A | 2023-09-08 A |  | 100% |  |  |
| 173 |  | Define Scope of KB | 1d | 2023-06-01 A | 2023-06-01 A | 167SS | 100% |  |  |
| 174 |  | Capture Existing KB artefacts | 20d | 2023-06-02 A | 2023-06-29 A | 173 | 100% |  |  |
| 175 |  | Tag artefacts | 5d | 2023-06-30 A | 2023-07-06 A | 174 | 100% |  |  |
| 176 |  | Develop Participant Interfaces | 20d | 2023-07-07 A | 2023-08-03 A | 175 | 100% |  |  |
| 177 |  | Promote to Collaboration Portal | 21d | 2023-08-04 A | 2023-09-01 A | 176 | 100% |  |  |
| 178 |  | Link into FreshDesk | 5d | 2023-09-04 A | 2023-09-08 A | 177 | 100% |  |  |
| 179 | 1.3.6 | **PP Design, Build & Test (DBT)** | 1221d? | 2022-10-31 A | 2027-07-05 |  | 74% | 123d |  |
| 180 | 1.3.6.1 | **PP Impact Assessment, Planning & Procurement** | 110d | 2022-10-31 A | 2023-03-31 A |  | 100% |  |  |
| 181 | 1.3.6.1.1 | **PP Impact Assessment** | 67d | 2022-10-31 A | 2023-01-31 A |  | 100% |  |  |
| 182 |  | Develop heatmap for impact of MHHS | 67d | 2022-10-31 A | 2023-01-31 A | 47 | 100% |  |  |
| 183 |  | Develop detailed impact assessment | 67d | 2022-10-31 A | 2023-01-31 A | 47 | 100% |  |  |
| 184 | 1.3.6.1.2 | **PP Planning** | 67d | 2022-10-31 A | 2023-01-31 A |  | 100% |  |  |
| 185 |  | Develop detailed short-term plan | 23d | 2022-10-31 A | 2022-11-30 A | 47 | 100% |  |  |
| 186 |  | Develop overall project plan for implementation | 67d | 2022-10-31 A | 2023-01-31 A | 47 | 100% |  |  |
| 187 |  | Develop procurement plan | 67d | 2022-10-31 A | 2023-01-31 A | 47 | 100% |  |  |
| 188 | 1.3.6.1.3 | **PP Software/Service Procurement** | 110d | 2022-10-31 A | 2023-03-31 A |  | 100% |  |  |
| 189 |  | Run tender process | 67d | 2022-10-31 A | 2023-01-31 A | 47 | 100% |  |  |
| 190 |  | Select provider & sign commercials | 43d | 2023-02-01 A | 2023-03-31 A | 189 | 100% |  |  |
| 191 | 1.3.6.2 | **Design Handover** | 850d? | 2024-04-02 A | 2027-07-05 |  | 17% | 123d |  |
| 192 | 1.3.6.2.1 | **Creation of the Configuration Management Database** | 14d | 2024-09-02 A | 2024-09-19 A |  | 100% |  |  |
| 193 |  | Identify all baselined design artefacts | 9d | 2024-09-02 A | 2024-09-12 A |  | 100% |  | start no earlier than 2024-09-02 |
| 194 |  | Create CMBD | 5d | 2024-09-13 A | 2024-09-19 A | 193 | 100% |  |  |
| 195 | 1.3.6.2.2 | **Knowledge Transfer** | 86d? | 2025-01-06 A | 2025-05-05 |  | 10% | 688d |  |
| 196 |  | Elexon to document knowledge transfer requirements | 4d | 2025-01-06 A | 2025-01-09 A |  | 100% |  | start no earlier than 2024-09-02 |
| 197 |  | Review Requirements | 5d | 2025-01-10 A | 2025-01-16 A | 196 | 100% |  |  |
| 198 |  | Agree Success Criteria | 31d | 2025-01-17 | 2025-02-28 | 197 |  | 688d |  |
| 199 |  | Identify Key personel with Elexon | 3d | 2025-03-03 | 2025-03-05 | 198 |  | 688d |  |
| 200 |  | Draft Agenda for initial meeting | 1d? | 2025-03-06 | 2025-03-06 | 199 |  | 688d |  |
| 201 |  | Define cadence for handover sessions | 2d | 2025-03-07 | 2025-03-10 | 200 |  | 688d |  |
| 202 |  | Share Design Information | 20d | 2025-03-11 | 2025-04-07 | 201 |  | 688d | start no earlier than 2024-09-02 |
| 203 |  | Conduct Initial Handover Session | 20d? | 2025-04-08 | 2025-05-05 | 202 |  | 688d | start no earlier than 2024-10-01 |
| 204 | 1.3.6.2.3 | **Triage Sessions** | 391d | 2024-04-02 | 2025-09-30 |  |  | 582d |  |
| 205 |  | Design Triage Sessions | 261d | 2024-10-01 | 2025-09-30 |  |  | 582d | start no earlier than 2024-10-01 |
| 206 |  | Test Triage Sessions | 261d | 2024-04-02 | 2025-04-01 |  |  | 712d | finish no earlier than 2025-04-01 |
| 207 | 1.3.6.2.4 | **Knowledge Base** | 9d | 2024-09-02 A | 2024-09-12 A |  | 100% |  |  |
| 208 |  | Document Knowledge base update process | 4d | 2024-09-02 A | 2024-09-05 A |  | 100% |  | start no earlier than 2024-09-02 |
| 209 |  | Document Design updates to Collaboration Base | 5d | 2024-09-06 A | 2024-09-12 A |  | 100% |  | start no earlier than 2024-09-06 |
| 210 | 1.3.6.2.5 | **FreshDesk** | 26d? | 2025-08-20 | 2025-09-24 |  |  | 586d |  |

| ID | WBS | Task | Duration | Start | Finish | Predecessors | Complete | Total float | Constraint |
| --- | --- | --- | --- | --- | --- | --- | --- | --- | --- |
| 211 |  | Agree Indicative Handover of FreshDesk Calls to Service Now | 4d | 2025-08-20 | 2025-08-25 |  |  | 586d | start no earlier than 2025-08-20 |
| 212 |  | Prepare Comms to Industry | 10d | 2025-08-26 | 2025-09-08 | 211 |  | 586d | start no earlier than 2025-02-07 |
| 213 |  | Issue Comms to Industry | 1d? | 2025-09-09 | 2025-09-09 | 212 |  | 586d | start no earlier than 2025-02-21 |
| 214 |  | Redirect Design Mailbox to Service Now | 1d? | 2025-09-10 | 2025-09-10 | 213 |  | 586d | start no earlier than 2025-03-03 |
| 215 |  | Archive Freshdesk calls | 5d | 2025-09-11 | 2025-09-17 | 214 |  | 586d | start no earlier than 2025-03-03 |
| 216 |  | Decommission FreshDesk | 5d | 2025-09-18 | 2025-09-24 | 215 |  | 586d | start no earlier than 2025-03-10 |
| 217 | 1.3.6.2.6 | **iServer** | 611d? | 2025-03-03 A | 2027-07-05 |  | 88% |  |  |
| 218 |  | Gather Licensing information | 88d? | 2025-03-03 A | 2025-07-02 A |  | 100% |  | start no earlier than 2025-03-03 |
| 219 |  | Inform Orbus of iServer support termination | 1d? | 2025-07-03 A | 2025-07-03 A | 218 | 100% |  |  |
| 220 |  | Produce iServer decomissioning pack | 4d | 2025-07-04 A | 2025-07-09 A | 219 | 100% |  |  |
| 221 |  | Publish iServer decommising pack on the Clock | 1d? | 2025-07-31 | 2025-07-31 | 220FS+15d |  | 625d |  |
| 222 |  | Clear down old information | 1d? | 2025-03-03 | 2025-03-03 |  |  | 731d |  |
| 223 |  | Clear down accounts | 2d | 2025-03-10 | 2025-03-11 | 222 |  | 727d | start no earlier than 2025-03-10 |
| 224 |  | Identify Collaboration Base Design Dependencies on iServer | 2d | 2025-04-01 A | 2025-04-02 A | 223 | 100% |  | start no earlier than 2025-04-01 |
| 225 |  | Remove Design dependencies | 5d | 2025-04-03 A | 2025-04-09 | 224 | 20% | 701d | start no earlier than 2025-04-03 |
| 226 |  | Close down iServer | 5d | 2025-04-10 | 2025-04-16 | 225 |  | 701d | start no earlier than 2025-04-10 |
| 227 | 1.3.6.3 | **Central Systems DBT** | 325d | 2022-10-31 A | 2024-01-26 A |  | 100% |  |  |
| 228 | 1.3.6.3.1 | **Elexon Central Systems DBT CIT (Entering at Interval 1)** | 248d | 2022-10-31 A | 2023-10-11 A |  | 100% |  |  |
| 229 | 1.3.6.3.1.1 | **Design and Build** | 235d | 2022-10-31 A | 2023-09-22 A |  | 100% |  |  |
| 230 |  | Helix Design and Build | 235d | 2022-10-31 A | 2023-09-22 A | 2 | 100% |  |  |
| 231 | 1.3.6.3.1.2 | **Test Approach & Plan** | 235d | 2022-10-31 A | 2023-09-22 A |  | 100% |  |  |
| 232 |  | Develop Test Approach & Plan | 180d | 2022-10-31 A | 2023-07-07 A |  | 100% |  |  |
| 233 |  | Elexon Central Systems Test Approach & Plan (PIT) submitted to Programme for assurance | 0d | 2023-07-13 A | 2023-07-13 A | 232FF+4d | 100% |  |  |
| 234 |  | Elexon Central Systems Test Approach & Plan (PIT) V2 resubmitted to Programme for assurance | 0d | 2023-07-27 A | 2023-07-27 A | 233FS+9d | 100% |  |  |
| 235 |  | Elexon Central Systems Test Approach & Plan (PIT) V3 resubmitted to Programme for assurance | 0d | 2023-08-18 A | 2023-08-18 A | 234FS+17d | 100% |  |  |
| 236 |  | Elexon Central Systems Test approach and plan MHHS Review Completed | 0d | 2023-09-22 A | 2023-09-22 A | 235FS+25d | 100% |  |  |
| 237 | 1.3.6.3.1.3 | **Test Readiness Report** | 16d | 2023-07-28 A | 2023-08-18 A |  | 100% |  |  |
| 238 |  | Test readiness reporting | 16d | 2023-07-28 A | 2023-08-18 A | 233FS+10d | 100% |  |  |
| 239 | 1.3.6.3.1.4 | **Requirements to test Traceability Matrix (RTTM)** | 35d | 2023-08-04 A | 2023-09-22 A |  | 100% |  |  |
| 240 |  | Elexon Central Systems RTTM submitted to Programme for assurance | 0d | 2023-08-04 A | 2023-08-04 A | 233 | 100% |  | start no earlier than 2023-04-28 |
| 241 |  | Elexon Central Systems RTTM MHHS Review Completed | 0d | 2023-09-22 A | 2023-09-22 A | 240FS+35d | 100% |  |  |
| 242 | 1.3.6.3.1.5 | **Test Scenarios** | 35d | 2023-08-04 A | 2023-09-22 A |  | 100% |  |  |
| 243 |  | Elexon Central Systems test scenarios submitted to Programme for assurance | 0d | 2023-08-04 A | 2023-08-04 A | 233 | 100% |  |  |
| 244 |  | Elexon Central Systems Test scenarios MHHS Review Completed | 0d | 2023-09-22 A | 2023-09-22 A | 243FS+35d | 100% |  |  |
| 245 | 1.3.6.3.1.6 | **PIT Execution** | 38d | 2023-08-21 A | 2023-10-11 A |  | 100% |  |  |
| 246 |  | PIT Test Execution Progress Report | 18d | 2023-09-04 A | 2023-09-27 A | 238FS+10d | 100% |  |  |
| 247 |  | Elexon Central Systems PIT Execution | 28d | 2023-08-21 A | 2023-09-27 A | 238 | 100% |  |  |
| 248 |  | Elexon Central Systems PIT Completion Report submitted to Programme for assurance | 0d | 2023-09-27 A | 2023-09-27 A | 247 | 100% |  |  |
| 249 |  | Elexon Central Systems PIT Completion Report MHHS Review Completed | 0d | 2023-10-11 A | 2023-10-11 A | 241, 244, 246, 248FS+10d, 236 | 100% |  |  |
| 250 | 1.3.6.3.2 | **DIP DBT CIT (Entering at Interval 1)** | 221d | 2023-01-02 A | 2023-11-06 A |  | 100% |  |  |
| 251 |  | Design | 80d | 2023-01-02 A | 2023-04-21 A |  | 100% |  | must start on 2023-01-02 |
| 252 |  | Build | 155d | 2023-01-09 A | 2023-08-11 A | 251SS+5d | 100% |  |  |
| 253 | 1.3.6.3.2.3 | **Test Approach & Plan** | 9d | 2023-07-07 A | 2023-07-20 A |  | 100% |  |  |
| 254 |  | DIP Test Approach & Plan (PIT) submitted to Programme for assurance | 0d | 2023-07-07 A | 2023-07-07 A |  | 100% |  |  |
| 255 |  | DIP Test Approach & Plan (PIT) MHHS Review Completed | 0d | 2023-07-20 A | 2023-07-20 A | 254FS+9d | 100% |  |  |
| 256 | 1.3.6.3.2.4 | **PIT Test Readiness Report** | 31d | 2023-07-21 A | 2023-09-01 A |  | 100% |  |  |
| 257 |  | Test readiness reporting | 31d | 2023-07-21 A | 2023-09-01 A | 254FS+9d | 100% |  |  |
| 258 | 1.3.6.3.2.5 | **Requirements to test Traceability Matrix (RTTM)** | 18d | 2023-08-04 A | 2023-08-30 A |  | 100% |  |  |
| 259 |  | DIP RTTM submitted to Programme for assurance | 0d | 2023-08-04 A | 2023-08-04 A | 254FS+15d | 100% |  |  |
| 260 |  | DIP RTTM MHHS Review Completed | 0d | 2023-08-30 A | 2023-08-30 A | 259FS+18d | 100% |  |  |
| 261 | 1.3.6.3.2.6 | **Test Scenarios** | 22d | 2023-07-31 A | 2023-08-30 A |  | 100% |  |  |
| 262 |  | DIP PIT test scenarios submitted to Programme for assurance | 0d | 2023-07-31 A | 2023-07-31 A | 254FS+15d | 100% |  |  |
| 263 |  | DIP Test scenarios MHHS Review Completed | 0d | 2023-08-30 A | 2023-08-30 A | 262FS+22d | 100% |  |  |
| 264 | 1.3.6.3.2.7 | **PIT execution** | 50d | 2023-08-29 A | 2023-11-06 A |  | 100% |  |  |
| 265 |  | PIT Test Execution Progress Report | 37d | 2023-09-01 A | 2023-10-23 A | 266FF, 257 | 100% |  | start no earlier than 2023-08-29 |
| 266 |  | PIT Execution (Interim Release 1) | 30d | 2023-08-29 A | 2023-10-09 A |  | 100% |  | start no earlier than 2023-08-29 |
| 267 |  | PIT Execution (Interim Release 2) | 10d | 2023-10-10 A | 2023-10-23 A | 266 | 100% |  |  |
| 268 |  | DIP PIT Completion Report (Interim Release 1) submitted to Programme for assurance | 0d | 2023-10-09 A | 2023-10-09 A | 266 | 100% |  |  |
| 269 |  | DIP PIT Completion Report (Interim Release 1) MHHS Review Completed | 0d | 2023-10-23 A | 2023-10-23 A | 268FS+10d | 100% |  |  |
| 270 |  | DIP PIT Completion Report (Interim Release 2) submitted to Programme for assurance | 0d | 2023-10-23 A | 2023-10-23 A | 267, 265 | 100% |  |  |
| 271 |  | DIP PIT Completion Report (Interim Release 2) MHHS Review Completed | 0d | 2023-11-06 A | 2023-11-06 A | 270FS+10d | 100% |  |  |
| 272 | 1.3.6.3.3 | **DCC (DSP) DBT SIT Functional (Entering at SIT Functional)** | 325d | 2022-10-31 A | 2024-01-26 A |  | 100% |  |  |
| 273 |  | Design | 67d | 2022-10-31 A | 2023-01-31 A |  | 100% |  |  |
| 274 | 1.3.6.3.3.2 | **Test Approach & Plan** | 20d | 2023-11-17 A | 2023-12-15 A |  | 100% |  |  |
| 275 |  | DCC Test Approach & Plan (PIT) submitted to Programme for assurance | 0d | 2023-11-17 A | 2023-11-17 A | 273FS+208d | 100% |  |  |
| 276 |  | DCC Test Approach & Plan (PIT) MHHS Review Completed | 0d | 2023-12-15 A | 2023-12-15 A | 275FS+20d | 100% |  |  |
| 277 | 1.3.6.3.3.3 | **Test Readiness Report** | 22d | 2023-12-04 A | 2024-01-02 A |  | 100% |  |  |
| 278 |  | Test readiness reporting | 22d | 2023-12-04 A | 2024-01-02 A | 275FS+10d | 100% |  |  |
| 279 | 1.3.6.3.3.4 | **Requirements to test Traceability Matrix (RTTM)** | 30d | 2023-12-15 A | 2024-01-26 A |  | 100% |  |  |
| 280 |  | DCC RTTM submitted to Programme for assurance | 0d | 2023-12-15 A | 2023-12-15 A | 275FS+20d | 100% |  | start no earlier than 2023-04-28 |

| ID | WBS | Task | Duration | Start | Finish | Predecessors | Complete | Total float | Constraint |
| --- | --- | --- | --- | --- | --- | --- | --- | --- | --- |
| 281 |  | DCC RTTM MHHS Review Completed | 0d | 2024-01-26 A | 2024-01-26 A | 280FS+30d | 100% |  |  |
| 282 | 1.3.6.3.3.5 | **Test Scenarios** | 30d | 2023-12-15 A | 2024-01-26 A |  | 100% |  |  |
| 283 |  | DCC test scenarios submitted to Programme for assurance | 0d | 2023-12-15 A | 2023-12-15 A | 275FS+20d | 100% |  |  |
| 284 |  | DCC Test Scenarios MHHS Review Completed | 0d | 2024-01-26 A | 2024-01-26 A | 283FS+30d | 100% |  |  |
| 285 | 1.3.6.3.4 | **RECCo (EES) DBT CIT (Entering at Interval 6)** | 71d | 2023-10-13 A | 2024-01-19 A |  | 100% |  |  |
| 286 | 1.3.6.3.4.1 | **Test Approach & Plan** | 20d | 2023-10-13 A | 2023-11-09 A |  | 100% |  |  |
| 287 |  | EES Test Approach & Plan (PIT) submitted to Programme for assurance | 0d | 2023-10-13 A | 2023-10-13 A |  | 100% |  | start no earlier than 2023-10-13 |
| 288 |  | EES Test approach and plan (PIT) MHHS Review Completed | 0d | 2023-11-09 A | 2023-11-09 A | 287FS+20d | 100% |  |  |
| 289 | 1.3.6.3.4.2 | **Test Readiness Report** | 10d | 2023-10-27 A | 2023-11-09 A |  | 100% |  |  |
| 290 |  | Test readiness reporting | 10d | 2023-10-27 A | 2023-11-09 A | 287FS+10d | 100% |  |  |
| 291 | 1.3.6.3.4.3 | **Requirements to test Traceability Matrix (RTTM)** | 20d | 2023-11-02 A | 2023-11-30 A |  | 100% |  |  |
| 292 |  | EES RTTM submitted to Programme for assurance | 0d | 2023-11-02 A | 2023-11-02 A | 287FS+15d | 100% |  |  |
| 293 |  | EES RTTM MHHS Review Completed | 0d | 2023-11-30 A | 2023-11-30 A | 292FS+20d | 100% |  |  |
| 294 | 1.3.6.3.4.4 | **Test Scenarios** | 20d | 2023-11-02 A | 2023-11-30 A |  | 100% |  |  |
| 295 |  | EES test scenarios submitted to Programme for assurance | 0d | 2023-11-02 A | 2023-11-02 A | 287FS+15d | 100% |  |  |
| 296 |  | EES Test scenarios MHHS Review Completed | 0d | 2023-11-30 A | 2023-11-30 A | 295FS+20d | 100% |  |  |
| 297 | 1.3.6.3.4.5 | **PIT execution** | 51d | 2023-11-10 A | 2024-01-19 A |  | 100% |  |  |
| 298 |  | PIT Test Execution Progress Report | 41d | 2023-11-10 A | 2024-01-05 A | 290 | 100% |  |  |
| 299 |  | PIT Execution | 41d | 2023-11-10 A | 2024-01-05 A | 295FS+5d | 100% |  |  |
| 300 |  | EES PIT Completion Report submitted to Programme for assurance | 0d | 2024-01-05 A | 2024-01-05 A | 298, 299 | 100% |  |  |
| 301 |  | EES PIT Completion Report MHHS Review Completed | 0d | 2024-01-19 A | 2024-01-19 A | 288, 293, 296, 300FS+10d | 100% |  |  |
| 302 | 1.3.6.3.5 | **Registration Services DBT CIT (Entering at Interval 2)** | 70d | 2023-07-28 A | 2023-11-03 A |  | 100% |  |  |
| 303 | 1.3.6.3.5.1 | **Test Approach & Plan** | 40d | 2023-07-28 A | 2023-09-22 A |  | 100% |  |  |
| 304 |  | Registration Services Test Approach & Plan (PIT) submitted to Programme for assurance | 0d | 2023-07-28 A | 2023-07-28 A |  | 100% |  |  |
| 305 |  | Registration Services Test approach and plan MHHS Review Completed | 0d | 2023-09-22 A | 2023-09-22 A | 304FS+40d | 100% |  |  |
| 306 | 1.3.6.3.5.2 | **Test Readiness Report** | 20d | 2023-08-14 A | 2023-09-08 A |  | 100% |  |  |
| 307 |  | Test readiness reporting | 20d | 2023-08-14 A | 2023-09-08 A | 304FS+10d | 100% |  |  |
| 308 | 1.3.6.3.5.3 | **Requirements to test Traceability Matrix (RTTM)** | 20d | 2023-09-01 A | 2023-09-29 A |  | 100% |  |  |
| 309 |  | Registration Services RTTM submitted to Programme for assurance | 0d | 2023-09-01 A | 2023-09-01 A | 304FS+15d | 100% |  | start no earlier than 2023-04-28 |
| 310 |  | Registration Services RTTM MHHS Review Completed | 0d | 2023-09-29 A | 2023-09-29 A | 309FS+20d | 100% |  |  |
| 311 | 1.3.6.3.5.4 | **Test Scenarios** | 20d | 2023-09-01 A | 2023-09-29 A |  | 100% |  |  |
| 312 |  | Registration Services test scenarios submitted to Programme for assurance | 0d | 2023-09-01 A | 2023-09-01 A | 304FS+15d | 100% |  |  |
| 313 |  | Registration Services Test scenarios MHHS Review Completed | 0d | 2023-09-29 A | 2023-09-29 A | 312FS+20d | 100% |  |  |
| 314 | 1.3.6.3.5.5 | **PIT execution** | 40d | 2023-09-11 A | 2023-11-03 A |  | 100% |  |  |
| 315 |  | PIT Test Execution Progress Report | 33d | 2023-09-11 A | 2023-10-25 A | 307 | 100% |  |  |
| 316 |  | PIT Execution | 30d | 2023-09-11 A | 2023-10-20 A | 312FS+5d | 100% |  |  |
| 317 |  | Registration Services PIT (CIT interval 2) Completion Report submitted to Programme for assurance | 0d | 2023-10-25 A | 2023-10-25 A | 315, 316 | 100% |  |  |
| 318 |  | Registration Services PIT (CIT interval 2) Completion Report MHHS Review Completed | 0d | 2023-11-03 A | 2023-11-03 A | 305, 310, 313, 317FS+7d | 100% |  |  |
| 319 | 1.3.6.4 | **SIT Participants DBT** | 401d | 2023-08-11 A | 2025-02-21 |  | 80% | 739d |  |
| 320 | 1.3.6.4.1 | **All Data Services DBT CIT (Entering at Interval 3)** | 71d | 2023-08-11 A | 2023-11-17 A |  | 100% |  |  |
| 321 | 1.3.6.4.1.1 | **Test Approach & Plan** | 30d | 2023-08-11 A | 2023-09-21 A |  | 100% |  |  |
| 322 |  | All Data Services Test Approach & Plans (PIT) submitted to Programme for assurance | 0d | 2023-08-11 A | 2023-08-11 A |  | 100% |  | start no earlier than 2023-08-11 |
| 323 |  | All Data Services Test approach and plans MHHS Review Completed | 0d | 2023-09-21 A | 2023-09-21 A | 322FS+30d | 100% |  |  |
| 324 | 1.3.6.4.1.2 | **Test Readiness Report** | 11d | 2023-08-25 A | 2023-09-08 A |  | 100% |  |  |
| 325 |  | Test readiness reporting | 11d | 2023-08-25 A | 2023-09-08 A | 322FS+10d | 100% |  |  |
| 326 | 1.3.6.4.1.3 | **Requirements to test Traceability Matrix (RTTM)** | 7d | 2023-09-20 A | 2023-09-29 A |  | 100% |  |  |
| 327 |  | All Data Services RTTMs submitted to Programme for assurance | 0d | 2023-09-20 A | 2023-09-20 A | 322FS+29d | 100% |  |  |
| 328 |  | All Data Services RTTMs MHHS Review Completed | 0d | 2023-09-29 A | 2023-09-29 A | 327FS+7d | 100% |  |  |
| 329 | 1.3.6.4.1.4 | **Test Scenarios** | 6d | 2023-09-20 A | 2023-09-28 A |  | 100% |  |  |
| 330 |  | All Data Services test scenarios' submitted to Programme for assurance | 0d | 2023-09-20 A | 2023-09-20 A | 322FS+29d | 100% |  |  |
| 331 |  | All Data Services Test scenarios' MHHS Review Completed | 0d | 2023-09-28 A | 2023-09-28 A | 330FS+6d | 100% |  |  |
| 332 | 1.3.6.4.1.5 | **PIT execution** | 50d | 2023-09-11 A | 2023-11-17 A |  | 100% |  |  |
| 333 |  | PIT Test Execution Progress Report | 40d | 2023-09-11 A | 2023-11-03 A | 325 | 100% |  |  |
| 334 |  | PIT Execution | 27d | 2023-09-28 A | 2023-11-03 A | 330FS+5d | 100% |  |  |
| 335 |  | All Data Services PIT Completion Reports submitted to Programme for assurance | 0d | 2023-11-03 A | 2023-11-03 A | 333, 334 | 100% |  |  |
| 336 |  | All Data Services PIT Completion Reports MHHS Review Completed | 0d | 2023-11-17 A | 2023-11-17 A | 323, 328, 331, 335FS+10d | 100% |  |  |
| 337 | 1.3.6.4.2 | **All Metering Services DBT CIT (Entering at Interval 4)** | 70d | 2023-08-25 A | 2023-12-01 A |  | 100% |  |  |
| 338 | 1.3.6.4.2.1 | **Test Approach & Plan** | 40d | 2023-08-25 A | 2023-10-20 A |  | 100% |  |  |
| 339 |  | All Metering Services Test Approach & Plans (PIT) submitted to Programme for assurance | 0d | 2023-08-25 A | 2023-08-25 A |  | 100% |  |  |
| 340 |  | All Metering Services Test approach and plans MHHS Review Completed | 0d | 2023-10-20 A | 2023-10-20 A | 339FS+40d | 100% |  |  |
| 341 | 1.3.6.4.2.2 | **Test Readiness Report** | 11d | 2023-09-11 A | 2023-09-25 A |  | 100% |  |  |
| 342 |  | Test readiness reporting | 11d | 2023-09-11 A | 2023-09-25 A | 339FS+10d | 100% |  |  |
| 343 | 1.3.6.4.2.3 | **Requirements to test Traceability Matrix (RTTM)** | 30d | 2023-09-15 A | 2023-10-27 A |  | 100% |  |  |
| 344 |  | All Metering Services RTTMs submitted to Programme for assurance | 0d | 2023-09-15 A | 2023-09-15 A | 339FS+15d | 100% |  |  |
| 345 |  | All Metering Services MHHS Reviews Completed | 0d | 2023-10-27 A | 2023-10-27 A | 344FS+30d | 100% |  |  |
| 346 | 1.3.6.4.2.4 | **Test Scenarios** | 30d | 2023-09-15 A | 2023-10-27 A |  | 100% |  |  |
| 347 |  | All Metering Services test scenarios' submitted to Programme for assurance | 0d | 2023-09-15 A | 2023-09-15 A | 339FS+15d | 100% |  |  |
| 348 |  | All Metering Services Test scenarios' MHHS Review Completed | 0d | 2023-10-27 A | 2023-10-27 A | 347FS+30d | 100% |  |  |
| 349 | 1.3.6.4.2.5 | **PIT execution** | 50d | 2023-09-25 A | 2023-12-01 A |  | 100% |  |  |
| 350 |  | PIT Test Execution Progress Report | 39d | 2023-09-26 A | 2023-11-17 A | 342 | 100% |  |  |

| ID | WBS | Task | Duration | Start | Finish | Predecessors | Complete | Total float | Constraint |
| --- | --- | --- | --- | --- | --- | --- | --- | --- | --- |
| 351 |  | PIT Execution | 40d | 2023-09-25 A | 2023-11-17 A | 347FS+5d | 100% |  |  |
| 352 |  | All Metering Services PIT Completion Reports submitted to Programme for assurance | 0d | 2023-11-17 A | 2023-11-17 A | 350, 351 | 100% |  |  |
| 353 |  | All Metering Services PIT Completion Reports MHHS Review Completed | 0d | 2023-12-01 A | 2023-12-01 A | 340, 345, 348, 352FS+10d | 100% |  |  |
| 354 | 1.3.6.4.3 | **All SIT Programme Participants PIT (SIT Functional)** | 331d | 2023-11-17 A | 2025-02-21 |  | 62% | 739d |  |
| 355 | 1.3.6.4.3.1 | **Test Approach & Plans** | 40d | 2023-11-17 A | 2024-01-11 A |  | 100% |  |  |
| 356 |  | SIT Functional PIT Test Approach & Plan (PIT) submitted to Programme for assurance | 0d | 2023-11-17 A | 2023-11-17 A |  | 100% |  | start no earlier than 2023-11-17 |
| 357 |  | All SIT Functional Test approach and plans MHHS Reviews Completed | 0d | 2024-01-11 A | 2024-01-11 A | 356FS+40d | 100% |  |  |
| 358 | 1.3.6.4.3.2 | **Test Readiness Reports** | 11d | 2023-12-01 A | 2023-12-15 A |  | 100% |  |  |
| 359 |  | Test readiness reporting | 11d | 2023-12-01 A | 2023-12-15 A | 356FS+10d | 100% |  |  |
| 360 | 1.3.6.4.3.3 | **Requirements to test Traceability Matrices (RTTM)** | 30d | 2023-12-07 A | 2024-01-18 A |  | 100% |  |  |
| 361 |  | SIT Functional PIT RTTM submitted to Programme for assurance | 0d | 2023-12-07 A | 2023-12-07 A | 356FS+15d | 100% |  |  |
| 362 |  | All SIT Functional RTTMs MHHS Reviews Completed | 0d | 2024-01-18 A | 2024-01-18 A | 361FS+30d | 100% |  |  |
| 363 | 1.3.6.4.3.4 | **Test Scenarios** | 30d | 2023-12-07 A | 2024-01-18 A |  | 100% |  |  |
| 364 |  | SIT Functional PIT test scenarios submitted to Programme for assurance | 0d | 2023-12-07 A | 2023-12-07 A | 356FS+15d | 100% |  |  |
| 365 |  | All SIT Functional Test scenarios' MHHS Reviews Completed | 0d | 2024-01-18 A | 2024-01-18 A | 364FS+30d | 100% |  |  |
| 366 | 1.3.6.4.3.5 | **PIT execution** | 51d | 2023-12-15 A | 2024-02-23 A |  | 100% |  |  |
| 367 |  | PIT Test Execution Progress Reports | 40d | 2023-12-18 A | 2024-02-09 A | 359 | 100% |  |  |
| 368 |  | PIT Execution | 41d | 2023-12-15 A | 2024-02-09 A | 364FS+5d | 100% |  |  |
| 369 |  | All SIT Functional PIT Completion Reports submitted to Programme for Assurance | 0d | 2024-02-09 A | 2024-02-09 A | 367, 368 | 100% |  |  |
| 370 |  | All SIT Functional PIT Completion Reports MHHS Review Completed | 0d | 2024-02-23 A | 2024-02-23 A | 357, 362, 365, 369FS+10d | 100% |  |  |
| 371 | 1.3.6.4.3.6 | **All SIT Programme Participants PIT (SIT Migration)** | 71d | 2024-02-16 A | 2024-05-24 A |  | 100% |  |  |
| 372 | 1.3.6.4.3.6.1 | **Test Approach & Plans** | 40d | 2024-02-16 A | 2024-04-11 A |  | 100% |  |  |
| 373 |  | All SIT Migration PIT Test Approach & Plans submitted to Programme for assurance | 0d | 2024-02-16 A | 2024-02-16 A |  | 100% |  | start no earlier than 2024-02-16 |
| 374 |  | All SIT Migration PIT Test approach and plans MHHS Reviews Completed | 0d | 2024-04-11 A | 2024-04-11 A | 373FS+40d | 100% |  |  |
| 375 | 1.3.6.4.3.6.2 | **Test Readiness Reports** | 11d | 2024-03-01 A | 2024-03-15 A |  | 100% |  |  |
| 376 |  | Test readiness reporting | 11d | 2024-03-01 A | 2024-03-15 A | 373FS+10d | 100% |  |  |
| 377 | 1.3.6.4.3.6.3 | **Requirements to test Traceability Matrices (RTTM)** | 30d | 2024-03-07 A | 2024-04-18 A |  | 100% |  |  |
| 378 |  | All SIT Migration PIT RTTMs submitted to Programme for assurance | 0d | 2024-03-07 A | 2024-03-07 A | 373FS+15d | 100% |  |  |
| 379 |  | All SIT Migration RTTMs MHHS Reviews Completed | 0d | 2024-04-18 A | 2024-04-18 A | 378FS+30d | 100% |  |  |
| 380 | 1.3.6.4.3.6.4 | **Test Scenarios** | 30d | 2024-03-07 A | 2024-04-18 A |  | 100% |  |  |
| 381 |  | All SIT Migration PIT test scenarios submitted to Programme for assurance | 0d | 2024-03-07 A | 2024-03-07 A | 373FS+15d | 100% |  |  |
| 382 |  | All SIT Migration Test scenarios MHHS Reviews Completed | 0d | 2024-04-18 A | 2024-04-18 A | 381FS+30d | 100% |  |  |
| 383 | 1.3.6.4.3.6.5 | **PIT execution** | 51d | 2024-03-15 A | 2024-05-24 A |  | 100% |  |  |
| 384 |  | PIT Test Execution Progress Reports | 40d | 2024-03-18 A | 2024-05-10 A | 376 | 100% |  |  |
| 385 |  | PIT Execution | 41d | 2024-03-15 A | 2024-05-10 A | 381FS+5d | 100% |  |  |
| 386 |  | All SIT Migration PIT Completion Reports submitted to Programme for assurance | 0d | 2024-05-10 A | 2024-05-10 A | 384, 385 | 100% |  |  |
| 387 |  | All SIT Migration PIT Completion Reports MHHS Review Completed | 0d | 2024-05-24 A | 2024-05-24 A | 374, 379, 382, 386FS+10d | 100% |  |  |
| 388 | 1.3.6.4.3.7 | **All SIT Programme Participants PIT (SIT Non Functional)** | 161d | 2024-07-12 A | 2025-02-21 |  | 63% | 739d |  |
| 389 | 1.3.6.4.3.7.1 | **Test Approach & Plan** | 41d | 2024-09-27 A | 2024-11-22 |  |  | 30d |  |
| 390 |  | SIT Non-Functional PIT Test Approach & Plan (PIT) submitted to Programme for assurance | 0d | 2024-09-27 A | 2024-09-27 A |  | 100% |  | start no earlier than 2024-05-10 |
| 391 |  | SIT Non-Functional Test approach and plan MHHS Review Completed | 1d | 2024-11-21 A | 2024-11-22 | 390FS+40d |  | 30d |  |
| 392 | 1.3.6.4.3.7.2 | **Test Readiness Report** | 13d | 2024-10-04 A | 2024-10-22 |  | 85% | 0d |  |
| 393 |  | Test readiness reporting | 13d | 2024-10-04 A | 2024-10-22 | 390FS+10d | 85% | 0d |  |
| 394 | 1.3.6.4.3.7.3 | **Requirements to test Traceability Matrix (RTTM)** | 20d | 2024-11-01 A | 2024-11-29 |  |  | 25d |  |
| 395 |  | SIT Non-Functional PIT RTTM submitted to Programme for assurance | 0d | 2024-11-01 A | 2024-11-01 A | 390FS+26d | 100% |  |  |
| 396 |  | SIT Non-Functional RTTM MHHS Review Completed | 0d | 2024-11-29 | 2024-11-29 | 395FS+20d |  | 25d | start no earlier than 2024-11-29 |
| 397 | 1.3.6.4.3.7.4 | **Test Scenarios** | 20d | 2024-11-01 A | 2024-11-29 |  |  | 25d |  |
| 398 |  | SIT Non-Functional PIT test scenarios submitted to Programme for assurance | 0d | 2024-11-01 A | 2024-11-01 A | 390FS+26d | 100% |  |  |
| 399 |  | SIT Non-Functional Test scenarios MHHS Review Completed | 0d | 2024-11-29 | 2024-11-29 | 398FS+20d |  | 25d |  |
| 400 | 1.3.6.4.3.7.5 | **PIT execution** | 161d | 2024-07-12 A | 2025-02-21 |  | 61% | 739d |  |
| 401 |  | PIT Test Execution Progress Report | 50d | 2024-07-15 A | 2024-11-21 | 393 | 56% | 805d | finish no earlier than 2024-11-21 |
| 402 |  | PIT Execution | 44d | 2024-07-12 A | 2024-11-29 | 398FS+5d | 66% | 799d | finish no earlier than 2024-11-29 |
| 403 |  | SIT Non-Functional PIT Completion Report submitted to Programme for assurance | 0d | 2024-11-29 A | 2024-11-29 A | 401, 402 | 100% |  |  |
| 404 |  | SIT Non-Functional PIT Completion Report Theme 1 MHHS Review Completed | 0d | 2024-12-20 A | 2024-12-20 | 391, 396, 399, 403FS+15d | 50% | 10d |  |
| 405 |  | SIT Non-Functional PIT Completion Report Theme 2 & 3 MHHS Review Completed | 0d | 2025-02-21 | 2025-02-21 | 391, 396, 399, 403FS+60d |  | 734d |  |
| 406 | 1.3.6.4.3.8 | **SIT Programme Participants PIT (SIT Operational Theme 1, 2, 3 (Batch 2))** | 146d | 2024-07-12 A | 2025-01-31 |  | 46% | 61d |  |
| 407 | 1.3.6.4.3.8.1 | **Test Approach & Plan** | 40d | 2024-09-27 A | 2024-11-21 |  |  | 112d |  |
| 408 |  | SIT Operational PIT Test Approach & Plan (PIT) submitted to Programme for assurance | 0d | 2024-09-27 A | 2024-09-27 A |  | 100% |  | start no earlier than 2024-09-27 |
| 409 |  | SIT Operational Test approach and plan MHHS Review Completed | 0d | 2024-11-21 | 2024-11-21 | 408FS+40d |  | 112d |  |
| 410 | 1.3.6.4.3.8.2 | **Test Readiness Report** | 13d | 2024-10-04 A | 2024-10-22 |  | 42% | 0d |  |
| 411 |  | Test readiness reporting | 13d | 2024-10-04 A | 2024-10-22 | 408FS+10d | 42% | 0d |  |
| 412 | 1.3.6.4.3.8.3 | **Requirements to test Traceability Matrix (RTTM)** | 20d | 2024-11-01 | 2024-11-29 |  |  | 106d |  |
| 413 |  | SIT Operational PIT RTTM submitted to Programme for assurance | 0d | 2024-11-01 | 2024-11-01 | 408FS+26d |  | 106d |  |
| 414 |  | SIT Operational RTTM MHHS Review Completed | 0d | 2024-11-29 | 2024-11-29 | 413FS+20d |  | 106d |  |
| 415 | 1.3.6.4.3.8.4 | **Test Scenarios** | 20d | 2024-11-01 | 2024-11-29 |  |  | 0d |  |
| 416 |  | SIT Operational PIT test scenarios submitted to Programme for assurance | 0d | 2024-11-01 | 2024-11-01 | 408FS+26d |  | 0d |  |
| 417 |  | SIT Operational Test scenarios MHHS Review Completed | 0d | 2024-11-29 | 2024-11-29 | 416FS+20d |  | 106d |  |
| 418 | 1.3.6.4.3.8.5 | **PIT execution** | 146d | 2024-07-12 A | 2025-01-31 |  | 47% | 61d |  |
| 419 |  | PIT Test Execution Progress Report | 40d | 2024-07-15 A | 2024-11-21 | 411 | 45% | 99d |  |
| 420 |  | PIT Execution | 39d | 2024-07-12 A | 2024-11-29 | 416 | 49% | 61d |  |

| ID | WBS | Task | Duration | Start | Finish | Predecessors | Complete | Total float | Constraint |
| --- | --- | --- | --- | --- | --- | --- | --- | --- | --- |
| 421 |  | SIT Operational Theme 1, 2, 3 (Batch 2) PIT Completion Report submitted to Programme for assurance | 0d | 2025-01-14 | 2025-01-14 | 419, 420FS+32d |  | 61d |  |
| 422 |  | SIT Operational Theme 1, 2, 3 (Batch 2) PIT Completion Report MHHS Review Completed | 0d | 2025-01-31 | 2025-01-31 | 409, 414, 417, 421FS+13d |  | 61d |  |
| 423 | 1.3.6.4.3.9 | **SIT Programme Participants PIT (SIT Operational Theme 3 (Batch 1))** | 76d | 2024-09-27 A | 2025-01-10 |  |  | 769d |  |
| 424 | 1.3.6.4.3.9.1 | **Test Approach & Plan** | 40d | 2024-09-27 A | 2024-11-21 A |  | 100% |  |  |
| 425 |  | SIT Operational PIT Test Approach& Plan (PIT) submitted to Programme for assurance | 0d | 2024-09-27 A | 2024-09-27 A |  | 100% |  | start no earlier than 2024-09-27 |
| 426 |  | SIT Operational Test approach and plan MHHS Review Completed | 0d | 2024-11-21 A | 2024-11-21 A | 425FS+40d | 100% |  |  |
| 427 | 1.3.6.4.3.9.2 | **Test Readiness Report** | 13d | 2024-10-04 | 2024-10-22 |  |  | 787d |  |
| 428 |  | Test readiness reporting | 13d | 2024-10-04 | 2024-10-22 | 425FS+5d |  | 787d |  |
| 429 | 1.3.6.4.3.9.3 | **Requirements to test Traceability Matrix (RTTM)** | 20d | 2024-11-01 A | 2024-11-29 A |  | 100% |  |  |
| 430 |  | SIT Operational PIT RTTM submitted to Programme for assurance | 0d | 2024-11-01 A | 2024-11-01 A | 425FS+26d | 100% |  |  |
| 431 |  | SIT Operational RTTM MHHS Review Completed | 0d | 2024-11-29 A | 2024-11-29 A | 430FS+20d | 100% |  |  |
| 432 | 1.3.6.4.3.9.4 | **Test Scenarios** | 20d | 2024-11-01 A | 2024-11-29 A |  | 100% |  |  |
| 433 |  | SIT Operational PIT test scenarios submitted to Programme for assurance | 0d | 2024-11-01 A | 2024-11-01 A | 425FS+26d | 100% |  |  |
| 434 |  | SIT Operational Test scenarios MHHS Review Completed | 0d | 2024-11-29 A | 2024-11-29 A | 433FS+20d | 100% |  |  |
| 435 | 1.3.6.4.3.9.5 | **PIT execution** | 58d | 2024-10-23 A | 2025-01-10 |  |  | 769d |  |
| 436 |  | PIT Test Execution Progress Report | 40d | 2024-10-23 | 2024-12-17 | 428 |  | 787d |  |
| 437 |  | PIT Execution | 39d | 2024-11-04 | 2024-12-26 | 433 |  | 780d |  |
| 438 |  | SIT Operational Theme 3 (Batch 1) PIT Completion Report submitted to Programme for assurance | 0d | 2025-01-10 A | 2025-01-10 A | 419, 420FS+30d | 100% |  |  |
| 439 |  | SIT Operational Theme 3 (Batch 1) PIT Completion Report MHHS Review Completed | 0d | 2025-01-10 | 2025-01-10 | 443, 448, 451, 455, 438 |  | 769d |  |
| 440 | 1.3.6.4.4 | **All Suppliers DBT CIT (Entering at Interval 5)** | 71d | 2023-09-15 A | 2023-12-22 A |  | 100% |  |  |
| 441 | 1.3.6.4.4.1 | **Test Approach & Plan** | 20d | 2023-09-15 A | 2023-10-12 A |  | 100% |  |  |
| 442 |  | All SIT Suppliers Test Approach & Plans (PIT) submitted to Programme for assurance | 0d | 2023-09-15 A | 2023-09-15 A |  | 100% |  | start no earlier than 2023-09-15 |
| 443 |  | All SIT Suppliers Test Approach & Plans MHHS Review Completed | 0d | 2023-10-12 A | 2023-10-12 A | 442FS+20d | 100% |  |  |
| 444 | 1.3.6.4.4.2 | **Test Readiness Report** | 11d | 2023-09-29 A | 2023-10-13 A |  | 100% |  |  |
| 445 |  | Test readiness reporting | 11d | 2023-09-29 A | 2023-10-13 A | 442FS+10d | 100% |  |  |
| 446 | 1.3.6.4.4.3 | **Requirements to test Traceability Matrix (RTTM)** | 20d | 2023-10-06 A | 2023-11-03 A |  | 100% |  |  |
| 447 |  | All SIT Suppliers RTTMs submitted to Programme for assurance | 0d | 2023-10-06 A | 2023-10-06 A | 442FS+16d | 100% |  |  |
| 448 |  | All SIT Suppliers RTTMs MHHS Review Completed | 0d | 2023-11-03 A | 2023-11-03 A | 447FS+20d | 100% |  |  |
| 449 | 1.3.6.4.4.4 | **Test Scenarios** | 20d | 2023-10-05 A | 2023-11-02 A |  | 100% |  |  |
| 450 |  | All SIT Suppliers test scenarios' submitted to Programme for assurance | 0d | 2023-10-05 A | 2023-10-05 A | 442FS+15d | 100% |  |  |
| 451 |  | All SIT Suppliers Test scenarios' MHHS Review Completed | 0d | 2023-11-02 A | 2023-11-02 A | 450FS+20d | 100% |  |  |
| 452 | 1.3.6.4.4.5 | **PIT execution** | 51d | 2023-10-13 A | 2023-12-22 A |  | 100% |  |  |
| 453 |  | PIT Test Execution Progress Report | 40d | 2023-10-16 A | 2023-12-08 A | 450FS+5d, 445 | 100% |  |  |
| 454 |  | PIT Execution | 41d | 2023-10-13 A | 2023-12-08 A | 450FS+5d | 100% |  |  |
| 455 |  | All SIT Suppliers PIT Completion Reports submitted to Programme for assurance | 0d | 2023-12-08 A | 2023-12-08 A | 454, 453 | 100% |  |  |
| 456 |  | All SIT Suppliers PIT Completion Reports MHHS Review Completed | 0d | 2023-12-22 A | 2023-12-22 A | 455FS+10d, 443, 448, 451 | 100% |  |  |
| 457 | 1.3.6.4.5 | **All LDSO Network Operations DBT CIT (Entering at Interval 5)** | 71d | 2023-09-15 A | 2023-12-22 A |  | 100% |  |  |
| 458 | 1.3.6.4.5.1 | **Test Approach & Plan** | 71d | 2023-09-15 A | 2023-12-22 A |  | 100% |  |  |
| 459 |  | All Network Operation Test Approach & Plans (PIT) submitted to Programme for assurance | 0d | 2023-09-15 A | 2023-09-15 A |  | 100% |  | start no earlier than 2023-09-15 |
| 460 |  | All Network Operation Test Approach & Plans MHHS Review Completed | 0d | 2023-10-12 A | 2023-10-12 A | 459FS+20d | 100% |  |  |
| 461 | 1.3.6.4.5.1.3 | **Test Readiness Report** | 11d | 2023-09-29 A | 2023-10-13 A |  | 100% |  |  |
| 462 |  | Test readiness reporting | 11d | 2023-09-29 A | 2023-10-13 A | 459FS+10d | 100% |  |  |
| 463 | 1.3.6.4.5.1.4 | **Requirements to test Traceability Matrix (RTTM)** | 20d | 2023-10-05 A | 2023-11-02 A |  | 100% |  |  |
| 464 |  | All Network Operation RTTMs submitted to Programme for assurance | 0d | 2023-10-05 A | 2023-10-05 A | 459FS+15d | 100% |  | start no earlier than 2023-04-28 |
| 465 |  | All Network Operation RTTMs MHHS Review Completed | 0d | 2023-11-02 A | 2023-11-02 A | 464FS+20d | 100% |  |  |
| 466 | 1.3.6.4.5.1.5 | **Test Scenarios** | 20d | 2023-10-05 A | 2023-11-02 A |  | 100% |  |  |
| 467 |  | All Network Operation test scenarios' submitted to Programme for assurance | 0d | 2023-10-05 A | 2023-10-05 A | 459FS+15d | 100% |  |  |
| 468 |  | All Network Operation test scenarios' MHHS Review Completed | 0d | 2023-11-02 A | 2023-11-02 A | 467FS+20d | 100% |  |  |
| 469 | 1.3.6.4.5.1.6 | **PIT execution** | 51d | 2023-10-13 A | 2023-12-22 A |  | 100% |  |  |
| 470 |  | PIT Test Execution Progress Report | 40d | 2023-10-16 A | 2023-12-08 A | 467FS+5d, 462 | 100% |  |  |
| 471 |  | PIT Execution | 41d | 2023-10-13 A | 2023-12-08 A | 467FS+5d | 100% |  |  |
| 472 |  | All Network Operation PIT (CIT interval 5) Completion Reports submitted to Programme for assurance | 0d | 2023-12-08 A | 2023-12-08 A | 471, 470 | 100% |  |  |
| 473 |  | All Network Operation PIT (CIT interval 5) Completion Reports MHHS Review Completed | 0d | 2023-12-22 A | 2023-12-22 A | 472FS+10d, 460, 465, 468 | 100% |  |  |
| 474 | 1.3.6.4.6 | **All UMSO DBT CIT (Entering at Interval 6)** | 81d | 2023-09-29 | 2024-01-19 A |  | 100% |  |  |
| 475 | 1.3.6.4.6.1 | **Test Approach & Plan** | 20d | 2023-10-13 A | 2023-11-09 A |  | 100% |  |  |
| 476 |  | All UMSO Test Approach & Plans (PIT) submitted to Programme for assurance | 0d | 2023-10-13 A | 2023-10-13 A |  | 100% |  | start no earlier than 2023-10-13 |
| 477 |  | All UMSO Test Approach & Plans MHHS Review Completed | 0d | 2023-11-09 A | 2023-11-09 A | 476FS+20d | 100% |  |  |
| 478 | 1.3.6.4.6.2 | **Test Readiness Report** | 11d | 2023-09-29 | 2023-10-13 |  | 100% |  |  |
| 479 |  | Test readiness reporting | 11d | 2023-10-27 A | 2023-11-10 A | 476FS+10d | 100% |  |  |
| 480 | 1.3.6.4.6.3 | **Requirements to test Traceability Matrix (RTTM)** | 20d | 2023-10-05 | 2023-11-01 |  | 100% |  |  |
| 481 |  | All UMSO RTTMs submitted to Programme for assurance | 0d | 2023-11-02 A | 2023-11-02 A | 476FS+15d | 100% |  |  |
| 482 |  | All UMSO RTTMs MHHS Review Completed | 0d | 2023-11-30 A | 2023-11-30 A | 481FS+20d | 100% |  |  |
| 483 | 1.3.6.4.6.4 | **Test Scenarios** | 20d | 2023-10-05 | 2023-11-01 |  | 100% |  |  |
| 484 |  | All UMSO test scenarios' submitted to Programme for assurance | 0d | 2023-11-02 A | 2023-11-02 A | 476FS+15d | 100% |  |  |
| 485 |  | All UMSO Test scenarios' MHHS Review Completed | 0d | 2023-11-30 A | 2023-11-30 A | 484FS+20d | 100% |  |  |
| 486 | 1.3.6.4.6.5 | **PIT execution** | 51d | 2023-11-10 A | 2024-01-19 A |  | 100% |  |  |
| 487 |  | PIT Test Execution Progress Report | 40d | 2023-11-13 A | 2024-01-05 A | 484FS+5d, 479 | 100% |  |  |
| 488 |  | PIT Execution | 40d | 2023-11-10 A | 2024-01-04 A | 484FS+5d | 100% |  |  |
| 489 |  | All UMSO PIT (CIT interval 6) Completion Reports submitted to Programme for assurance | 0d | 2024-01-05 A | 2024-01-05 A | 488, 487 | 100% |  |  |
| 490 |  | All UMSO PIT (CIT interval 6) Completion Reports MHHS Review Completed | 0d | 2024-01-19 A | 2024-01-19 A | 477, 482, 485, 489FS+10d | 100% |  |  |

| ID | WBS | Task | Duration | Start | Finish | Predecessors | Complete | Total float | Constraint |
| --- | --- | --- | --- | --- | --- | --- | --- | --- | --- |
| 491 | 1.3.7 | **DBT Monitoring and Assurance** | 842d | 2022-10-31 A | 2026-01-20 |  | 69% | 502d |  |
| 492 | 1.3.7.1 | **Planning and DBT Progress Monitoring of PPs** | 696d | 2022-10-31 A | 2025-06-30 |  | 67% | 648d |  |
| 493 |  | Monitor Non-SIT PPs Planning and DBT1 progress (to inform confirmation of Qualification Testing Tranche participants milestones) | 696d | 2022-10-31 A | 2025-06-30 | 185SS | 67% | 648d |  |
| 494 | 1.3.7.2 | **DBT Progress Monitoring of Consequential Change** | 774d | 2023-02-02 A | 2026-01-20 |  | 51% | 502d |  |
| 495 |  | Monitor & report data cleanse progress | 774d | 2023-02-02 A | 2026-01-20 |  | 51% | 502d |  |
| 496 | 1.3.7.3 | **Design Assurance** | 713d | 2022-11-14 A | 2025-08-06 |  | 80% | 621d |  |
| 497 | 1.3.7.3.1 | **Design Assurance Readiness Assessment Preparation** | 39d | 2023-02-28 A | 2023-04-21 A |  | 100% |  |  |
| 498 |  | Set up FTIG | 15d | 2023-04-03 A | 2023-04-21 A |  | 100% |  | must start on 2023-04-03 |
| 499 |  | Produce Draft Questions | 10d | 2023-02-28 A | 2023-03-13 A |  | 100% |  | must start on 2023-02-28 |
| 500 |  | Pilot with SRO | 1d | 2023-03-14 A | 2023-03-14 A | 499 | 100% |  |  |
| 501 |  | Finalise questions | 10d | 2023-03-15 A | 2023-03-28 A | 500 | 100% |  |  |
| 502 |  | Prepare on-line RA tooling | 10d | 2023-03-29 A | 2023-04-11 A | 501 | 100% |  |  |
| 503 |  | Prepare webinar content | 5d | 2023-03-20 A | 2023-03-24 A | 499FS+4d | 100% |  |  |
| 504 |  | Conduct webinar | 1d | 2023-03-30 A | 2023-03-30 A | 503FS+3d | 100% |  |  |
| 505 | 1.3.7.3.2 | **Participant Design Assurance Approach** | 43d | 2022-11-14 A | 2023-01-11 A |  | 100% |  |  |
| 506 |  | Develop document | 20d | 2022-11-14 A | 2022-12-09 A | 47FS+10d | 100% |  | start no earlier than 2022-11-14 |
| 507 |  | Review document | 18d | 2022-12-12 A | 2023-01-04 A | 506 | 100% |  |  |
| 508 |  | Participant Design Assurance Approach approved | 0d | 2023-01-11 A | 2023-01-11 A | 507FF+5d | 100% |  |  |
| 509 | 1.3.7.3.3 | **Phase 1 - SIT Volunteers (Core Providers)** | 145d | 2023-04-10 A | 2023-10-27 A |  | 100% |  |  |
| 510 |  | Send on-line questionnaire to core capability providers and current SIT volunteers (from Round 3 consultation) | 1d | 2023-04-10 A | 2023-04-10 A |  | 100% |  | must start on 2023-04-10 |
| 511 |  | Participants Provide Responses to questionnaires | 15d | 2023-04-11 A | 2023-05-01 A | 510 | 100% |  |  |
| 512 |  | Assess on-line responses and provided evidence | 5d | 2023-05-02 A | 2023-05-08 A | 511 | 100% |  |  |
| 513 |  | Bi-lateral meeting with each responder, to walk and navigate through provided materials | 31d | 2023-05-09 A | 2023-06-20 A | 512 | 100% |  |  |
| 514 |  | Plan for, create and execute deep dive assurance interviews based on agreed priorities (participants, design areas) | 62d | 2023-06-07 A | 2023-08-31 A | 513FS-10d | 100% |  |  |
| 515 |  | SI endorsement of participants’ design – assurance reports | 43d | 2023-08-02 A | 2023-09-29 A | 514FS-22d | 100% |  |  |
| 516 |  | Post-assurance review of recommendations take-up by assured participants | 44d | 2023-08-29 A | 2023-10-27 A | 515SS+19d | 100% |  |  |
| 517 |  | Phase 1 - SIT Volunteers (Core Providers) complete | 0d | 2023-10-27 A | 2023-10-27 A | 516 | 100% |  |  |
| 518 | 1.3.7.3.4 | **Phase 2 - SIT all other participants** | 143d | 2023-05-08 A | 2023-11-22 A |  | 100% |  |  |
| 519 |  | Send on-line questionnaire to core capability providers and current SIT volunteers (from Round 3 consultation) | 1d | 2023-05-08 A | 2023-05-08 A |  | 100% |  | must start on 2023-05-08 |
| 520 |  | Participants Provide Responses to questionnaires | 15d | 2023-05-09 A | 2023-05-29 A | 519 | 100% |  |  |
| 521 |  | Assess on-line responses and provided evidence | 5d | 2023-05-30 A | 2023-06-05 A | 520 | 100% |  |  |
| 522 |  | Bi-lateral meeting with each responder, to walk and navigate through provided materials | 84d | 2023-06-06 A | 2023-09-29 A | 521 | 100% |  |  |
| 523 |  | Plan for, create and execute deep dive assurance interviews based on agreed priorities (participants, design areas) | 69d | 2023-06-27 A | 2023-09-29 A | 522SS+15d | 100% |  |  |
| 524 |  | SI endorsement of participants’ design – assurance reports | 54d | 2023-07-18 A | 2023-09-29 A | 523SS+15d | 100% |  |  |
| 525 |  | Post-assurance review of recommendations take-up by assured participants | 73d | 2023-08-14 A | 2023-11-22 A | 524SS+19d | 100% |  |  |
| 526 |  | SIT PPs design assurance (excl Migration/Reverse Migration) complete | 0d | 2023-11-22 A | 2023-11-22 A | 525 | 100% |  |  |
| 527 | 1.3.7.3.5 | **Non-SIT PPs design assurance** | 445d | 2023-11-23 A | 2025-08-06 |  | 53% | 621d |  |
| 528 |  | Non-SIT PPs design assurance (risk-based sample) | 445d | 2023-11-23 A | 2025-08-06 | 526 | 53% | 621d |  |
| 529 | 1.3.7.4 | **Test Assurance** | 629d | 2023-02-01 A | 2025-06-30 |  | 71% | 648d |  |
| 530 |  | Non-SIT PPs test assurance | 629d | 2023-02-01 A | 2025-06-30 |  | 71% | 648d |  |
| 531 | 1.3.7.5 | **Pre-Qualification Guidance (PIT Guidance)** | 67d | 2022-10-31 A | 2023-01-31 A |  | 100% |  |  |
| 532 |  | Develop document (incl. collaboration with code bodies, as required) | 56d | 2022-10-31 A | 2023-01-16 A |  | 100% |  |  |
| 533 |  | Review, update and agree Pre-Qualification Guidance internally | 11d | 2023-01-17 A | 2023-01-31 A | 532 | 100% |  |  |
| 534 | 1.3.7.6 | **External Programme Dependency Management** | 0d | 2022-11-03 A | 2022-11-03 A |  | 100% |  |  |
| 535 | 1.3.7.6.1 | **SLC47** | 0d | 2022-11-03 A | 2022-11-03 A |  | 100% |  |  |
| 536 |  | SLC47 implementation date | 0d | 2022-11-03 A | 2022-11-03 A |  | 100% |  | start no earlier than 2022-11-03 |
| 537 | 1.4 | **SYSTEMS INTEGRATION TESTING (SIT)** | 910d? | 2022-10-31 A | 2026-04-24 |  | 73% |  |  |
| 538 | 1.4.1 | **SIT Preparation** | 665d? | 2022-10-31 A | 2025-05-16 |  | 97% | 679d |  |
| 539 | 1.4.1.1 | **Test Artefact Development** | 472d | 2022-10-31 A | 2024-08-21 A |  | 100% |  |  |
| 540 | 1.4.1.1.1 | **Environment Approach & Plan** | 460d | 2022-11-16 A | 2024-08-21 A |  | 100% |  |  |
| 541 |  | Environment Approach & Plan approved | 0d | 2022-11-16 A | 2022-11-16 A |  | 100% |  | start no earlier than 2022-11-16 |
| 542 |  | Environment Approach & Plan - Work Off | 157d | 2022-11-17 A | 2023-06-23 A | 541FS+1d | 100% |  |  |
| 543 |  | Environment Approach & Plan - Work Off Approved | 0d | 2023-08-16 A | 2023-08-16 A | 542FS+5d | 100% |  | start no earlier than 2023-08-16 |
| 544 |  | Environment Approach and Plan - SIT Functional | 0d | 2023-11-20 A | 2023-11-20 A |  | 100% |  | start no earlier than 2023-11-20 |
| 545 |  | Define Approach to Simulator for Non-SIT LDSO | 0d | 2023-11-15 A | 2023-11-15 A |  | 100% |  | start no earlier than 2023-11-15 |
| 546 |  | Environment Approach and Plan - Non SIT LDSO Testing | 0d | 2024-04-17 A | 2024-04-17 A |  | 100% |  | start no earlier than 2024-04-17 |
| 547 |  | Environment Approach and Plan - S and A Testing | 0d | 2024-07-17 A | 2024-07-17 A |  | 100% |  | start no earlier than 2024-07-17 |
| 548 |  | Environment Approach and Plan - SIT Non Functional | 0d | 2024-06-19 A | 2024-06-19 A |  | 100% |  | start no earlier than 2024-06-19 |
| 549 |  | Environment Approach and Plan - Sandbox | 0d | 2024-08-21 A | 2024-08-21 A |  | 100% |  | start no earlier than 2024-08-21 |
| 550 | 1.4.1.1.2 | **Overarching Test Scope (for all stages)** | 65d | 2022-10-31 A | 2023-01-27 A |  | 100% |  |  |
| 551 | 1.4.1.1.2.1 | **Overarching Test Scope (excl. Migration/Reverse Migration, NFT and Ops components)** | 65d | 2022-10-31 A | 2023-01-27 A |  | 100% |  |  |
| 552 |  | Develop document (excl Migration/Reverse Migration, NFT and Ops components) | 55d | 2022-10-31 A | 2023-01-13 A | 47 | 100% |  |  |
| 553 |  | Review, update & agree document (excl Migration/Reverse Migration, NFT and Ops components) | 10d | 2023-01-16 A | 2023-01-27 A | 552 | 100% |  |  |
| 554 | 1.4.1.1.3 | **Configuration and Release Management Approach & Plan** | 164d | 2022-11-01 A | 2023-06-16 A |  | 100% |  |  |
| 555 |  | Develop document | 69d | 2022-11-01 A | 2023-06-16 A |  | 100% |  | start no earlier than 2022-11-01 |
| 556 |  | Review, update and agree Configuration and Release Management Approach & Plan internally | 63d | 2023-02-01 A | 2023-04-28 A | 555 | 100% |  |  |
| 557 | 1.4.1.1.4 | **Test Data Overarching Approach & Plan** | 179d | 2022-11-14 A | 2023-07-20 A |  | 100% |  |  |
| 558 |  | Develop document | 20d | 2022-11-14 A | 2022-12-09 A |  | 100% |  | start no earlier than 2022-11-14 |
| 559 |  | Document review and update | 155d | 2022-12-12 A | 2023-07-14 A | 558 | 100% |  |  |
| 560 |  | Test Data Overarching Approach & Plan approved by TMAG | 0d | 2023-07-19 A | 2023-07-19 A | 559FS+3d | 100% |  |  |

| ID | WBS | Task | Duration | Start | Finish | Predecessors | Complete | Total float | Constraint |
| --- | --- | --- | --- | --- | --- | --- | --- | --- | --- |
| 561 |  | Document publication final version | 1d | 2023-07-20 A | 2023-07-20 A | 560 | 100% |  |  |
| 562 | 1.4.1.1.5 | **Interface Code of Connection (dates subject to DIP Service Provider's plan)** | 48d | 2023-03-01 A | 2023-05-05 A |  | 100% |  |  |
| 563 |  | Develop Interface Code of Connection with DIP Service Provider | 43d | 2023-03-01 A | 2023-04-28 A |  | 100% |  | must start on 2023-03-01 |
| 564 |  | Interface Code of Connection approved at SDWG | 0d | 2023-05-05 A | 2023-05-05 A | 563FS+5d | 100% |  |  |
| 565 | 1.4.1.1.6 | **Test Traceability** | 165d | 2023-06-01 A | 2024-01-17 A |  | 100% |  |  |
| 566 |  | RTM containing Method Statement Implied Requirements into Azure DevOps | 22d | 2023-06-01 A | 2023-06-30 A |  | 100% |  | must start on 2023-06-01 |
| 567 |  | RTM Containing Interface Catalogue Implied Requirements | 27d | 2023-06-01 A | 2023-07-07 A |  | 100% |  | must start on 2023-06-01 |
| 568 |  | SIT CIT Full Traceability & Coverage complete | 118d | 2023-07-10 A | 2023-12-20 A | 567, 566 | 100% |  |  |
| 569 |  | SIT Functional Full Traceability & Coverage complete | 138d | 2023-07-10 A | 2024-01-17 A | 567, 566 | 100% |  |  |
| 570 | 1.4.1.2 | **Test Tool Development** | 256d? | 2022-10-31 A | 2023-10-23 A |  | 100% |  |  |
| 571 | 1.4.1.2.1 | **Test Management Tool** | 256d | 2022-10-31 A | 2023-10-23 A |  | 100% |  |  |
| 572 | 1.4.1.2.1.1 | **Test Management Tool Implementation** | 256d | 2022-10-31 A | 2023-10-23 A |  | 100% |  |  |
| 573 |  | Requirements identification | 40d | 2022-10-31 A | 2022-12-23 A |  | 100% |  |  |
| 574 |  | Development | 125d | 2023-01-02 A | 2023-06-23 A | 573FS+5d | 100% |  |  |
| 575 |  | Testing | 125d | 2023-01-02 A | 2023-06-23 A | 574FF | 100% |  |  |
| 576 |  | Accept tool | 0d | 2023-06-23 A | 2023-06-23 A | 575FF | 100% |  |  |
| 577 |  | Implementation | 1d | 2023-10-23 A | 2023-10-23 A | 576FS+85d | 100% |  |  |
| 578 | 1.4.1.2.1.2 | **Test Management Tool User Guide** | 115d | 2023-01-02 A | 2023-06-09 A |  | 100% |  |  |
| 579 |  | Develop document | 100d | 2023-01-02 A | 2023-05-19 A | 574SS, 575SS | 100% |  | start no earlier than 2023-01-02 |
| 580 |  | Review, update and agree Test Management Tool User Guide internally | 15d | 2023-05-22 A | 2023-06-09 A | 579 | 100% |  |  |
| 581 | 1.4.1.2.1.3 | **Test Management Tool Configuration Guide** | 60d | 2023-01-02 A | 2023-03-24 A |  | 100% |  |  |
| 582 |  | Develop document | 45d | 2023-01-02 A | 2023-03-03 A | 573 | 100% |  | start no earlier than 2023-01-02 |
| 583 |  | Review, update and agree Test Management Tool Configuration Guide internally | 15d | 2023-03-06 A | 2023-03-24 A | 582 | 100% |  |  |
| 584 | 1.4.1.2.2 | **Secure Volunteer SIT Participants** | 163d? | 2023-01-31 A | 2023-09-14 A |  | 100% |  |  |
| 585 |  | PPs decide whether to volunteer to participate in SIT and inform Programme of decision via Round 3 Replan consultation | 1d? | 2023-01-31 A | 2023-01-31 A |  | 100% |  | finish no earlier than 2023-01-31 |
| 586 |  | Assurance of SIT volunteers' plans (submitted via Round 3 Replan Consultation) | 1d? | 2023-02-14 A | 2023-02-14 A |  | 100% |  | finish no earlier than 2023-02-14 |
| 587 |  | SIT Participant Volunteers Identified | 1d? | 2023-02-14 A | 2023-02-14 A |  | 100% |  | start no earlier than 2023-02-14 |
| 588 |  | Engagement with SIT volunteers | 1d? | 2023-05-23 A | 2023-05-23 A |  | 100% |  | finish no earlier than 2023-05-23 |
| 589 |  | SIT Participants Agreed | 1d? | 2023-05-23 A | 2023-05-23 A |  | 100% |  | start no earlier than 2023-05-23 |
| 590 | 1.4.1.2.2.6 | **Data Protection Impact Assessment (DPIA)** | 11d? | 2023-06-30 A | 2023-07-14 A |  | 100% |  |  |
| 591 |  | Conduct DPIA on Overall Test Data Approach | 1d? | 2023-06-30 A | 2023-06-30 A |  | 100% |  | finish no earlier than 2023-06-30 |
| 592 |  | Revise Overarching Test Data Approach& plan for DPIA (if required), including engagement with DWG | 1d? | 2023-07-13 A | 2023-07-13 A |  | 100% |  | finish no earlier than 2023-07-13 |
| 593 |  | Review (internal), update and approve revised Overarching Test Data Approach& Plan (if required) | 1d? | 2023-07-14 A | 2023-07-14 A |  | 100% |  | start no earlier than 2023-07-14 |
| 594 | 1.4.1.2.2.7 | **Data Sharing Agreements** | 30d? | 2023-08-04 A | 2023-09-14 A |  | 100% |  |  |
| 595 |  | Produce Data Sharing Agreement for Industry Review | 1d? | 2023-08-04 A | 2023-08-04 A |  | 100% |  | finish no earlier than 2023-08-04 |
| 596 |  | Manage Participant Queries and Contract Agreement Execution | 1d? | 2023-09-14 A | 2023-09-14 A |  | 100% |  | finish no earlier than 2023-09-14 |
| 597 |  | Data Sharing Agreements Complete | 1d? | 2023-09-14 A | 2023-09-14 A |  | 100% |  | start no earlier than 2023-09-14 |
| 598 | 1.4.1.2.2.8 | **Production Data Cut & Data Obfuscation** | 55d? | 2023-06-19 A | 2023-09-01 A |  | 100% |  |  |
| 599 | 1.4.1.2.2.8.1 | **SI Data Cut Preparation& Infrastructure** | 45d? | 2023-06-19 A | 2023-08-18 A |  | 100% |  |  |
| 600 |  | SI Data Cut Planning activities (incl. pre-cut and post-cut cleansing and population approach) | 1d? | 2023-06-19 A | 2023-06-19 A |  | 100% |  | finish no earlier than 2023-06-19 |
| 601 |  | Set up SI database and transmission structure | 1d? | 2023-08-17 A | 2023-08-17 A |  | 100% |  | finish no earlier than 2023-08-17 |
| 602 |  | Mechanism for transfer of data in place | 1d? | 2023-08-18 A | 2023-08-18 A |  | 100% |  | start no earlier than 2023-08-18 |
| 603 |  | SI Data Cut Preparation& Infrastructure Complete | 1d? | 2023-08-18 A | 2023-08-18 A |  | 100% |  | start no earlier than 2023-08-18 |
| 604 | 1.4.1.2.2.8.2 | **Production Data Cut** | 55d? | 2023-06-19 A | 2023-09-01 A |  | 100% |  |  |
| 605 |  | Notification of Production Data Cut issued to relevant participants | 1d? | 2023-06-19 A | 2023-06-19 A |  | 100% |  | start no earlier than 2023-06-19 |
| 606 |  | Coordinate relevant participants taking data cut from production systems | 1d? | 2023-08-11 A | 2023-08-11 A |  | 100% |  | finish no earlier than 2023-08-11 |
| 607 |  | Production data cut GONG decision | 1d? | 2023-08-16 A | 2023-08-16 A |  | 100% |  | start no earlier than 2023-08-16 |
| 608 |  | Relevant participants take data cut from production systems (Saturday 19 August) | 1d? | 2023-08-21 A | 2023-08-21 A |  | 100% |  | start no earlier than 2023-08-21 |
| 609 |  | EES transmit request data to SI | 1d? | 2023-08-25 A | 2023-08-25 A |  | 100% |  | finish no earlier than 2023-08-25 |
| 610 |  | Check data alignment and integrity of data cut | 1d? | 2023-09-01 A | 2023-09-01 A |  | 100% |  | finish no earlier than 2023-09-01 |
| 611 |  | Data cut from relevant participants' production systems completed (Saturday 19 August) | 1d? | 2023-08-21 A | 2023-08-21 A |  | 100% |  | start no earlier than 2023-08-21 |
| 612 |  | Production Data Cut Complete | 1d? | 2023-08-21 A | 2023-08-21 A |  | 100% |  | start no earlier than 2023-08-21 |
| 613 | 1.4.1.3 | **SIT Participation** | 147d | 2022-10-31 A | 2023-05-23 A |  | 100% |  |  |
| 614 |  | PPs decide whether to volunteer to participate in SIT and inform Programme of decision via Round 3 Replan consultation | 67d | 2022-10-31 A | 2023-01-31 A | 34FF | 100% |  |  |
| 615 |  | Assurance of SIT volunteers' plans (submitted via Round 3 Replan Consultation) | 10d | 2023-02-01 A | 2023-02-14 A | 614, 34 | 100% |  |  |
| 616 |  | SIT Participant Volunteers Identified | 0d | 2023-02-14 A | 2023-02-14 A | 615FF | 100% |  |  |
| 617 |  | Engagement with SIT volunteers | 147d | 2022-10-31 A | 2023-05-23 A |  | 100% |  |  |
| 618 |  | SIT Participants Agreed | 0d | 2023-05-23 A | 2023-05-23 A | 617, 652FS-74d | 100% |  |  |
| 619 | 1.4.1.4 | **SIT Stage-Specific Preparation** | 665d? | 2022-10-31 A | 2025-05-16 |  | 96% | 679d |  |
| 620 | 1.4.1.4.1 | **SIT Component Integration Preparation** | 320d | 2022-10-31 A | 2024-01-19 A |  | 100% |  |  |
| 621 | 1.4.1.4.1.1 | **Test Approach & Plan** | 188d | 2022-10-31 A | 2023-07-19 A |  | 100% |  |  |
| 622 |  | Develop document with SITWG | 159d | 2022-10-31 A | 2023-06-08 A |  | 100% |  |  |
| 623 |  | Industry consultation | 10d | 2023-06-09 A | 2023-06-22 A | 622 | 100% |  |  |
| 624 |  | Artefact review (via TMAG) and updates | 19d | 2023-06-23 A | 2023-07-19 A | 623 | 100% |  | finish no earlier than 2023-07-06 |
| 625 |  | SIT Component Integration Testing Test Approach & Plan approved | 0d | 2023-07-19 A | 2023-07-19 A | 624 | 100% |  | finish no earlier than 2023-07-19 |
| 626 | 1.4.1.4.1.2 | **Test Data Approach & Plan** | 29d | 2023-06-09 A | 2023-07-19 A |  | 100% |  |  |
| 627 |  | Industry consultation | 10d | 2023-06-09 A | 2023-06-22 A | 623SS | 100% |  |  |
| 628 |  | Artefact review (via TMAG) and updates | 19d | 2023-06-23 A | 2023-07-19 A | 627 | 100% |  |  |
| 629 |  | SIT Component Integration Testing Test Data Approach & Plan approved | 0d | 2023-07-19 A | 2023-07-19 A | 628 | 100% |  |  |
| 630 | 1.4.1.4.1.3 | **Test scenarios** | 173d | 2023-01-02 A | 2023-08-30 A |  | 100% |  |  |

| ID | WBS | Task | Duration | Start | Finish | Predecessors | Complete | Constraint |
| --- | --- | --- | --- | --- | --- | --- | --- | --- |
| 631 |  | Development of test scenarios | 0d | 2023-01-02 A | 2023-04-28 A | 622SS+45d | 100% |  |
| 632 |  | Review test scenarios with SIT Working Group | 11d | 2023-02-01 A | 2023-08-09 A | 631SS+22d | 100% |  |
| 633 |  | SIT Component Integration Testing Test scenarios approved | 0d | 2023-08-30 A | 2023-08-30 A | 632FS+15d | 100% |  |
| 634 | 1.4.1.4.1.4 | **Test cases** | 160d | 2023-05-01 A | 2023-12-08 A |  | 100% |  |
| 635 | 1.4.1.4.1.4.1 | **SI Test cases** | 160d | 2023-05-01 A | 2023-12-08 A |  | 100% |  |
| 636 | 1.4.1.4.1.4.1.1 | **Batch 1 (CIT Intervals 1 and 2)** | 110d | 2023-05-01 A | 2023-09-29 A |  | 100% |  |
| 637 |  | Develop Test cases | 100d | 2023-05-01 A | 2023-09-15 A | 631 | 100% |  |
| 638 |  | Review Test cases with SIT Working Group | 9d | 2023-09-18 A | 2023-09-28 A | 637 | 100% |  |
| 639 |  | SIT Component Integration Testing Test cases Batch 1 (CIT Intervals 1 and 2) approved at ETMAG | 0d | 2023-09-29 A | 2023-09-29 A | 638FS+1d | 100% |  |
| 640 | 1.4.1.4.1.4.1.2 | **Batch 2 (CIT Intervals 3 and 4)** | 25d | 2023-10-02 A | 2023-11-03 A |  | 100% |  |
| 641 |  | Develop Test cases | 15d | 2023-10-02 A | 2023-10-20 A | 639 | 100% |  |
| 642 |  | Review Test cases with SIT Working Group | 9d | 2023-10-23 A | 2023-11-02 A | 641 | 100% |  |
| 643 |  | SIT Component Integration Testing Test cases Batch 2 (CIT Intervals 3 and 4) approved at ETMAG | 0d | 2023-11-03 A | 2023-11-03 A | 642FS+1d | 100% |  |
| 644 | 1.4.1.4.1.4.1.3 | **Batch 3 (CIT Intervals 5 and 6)** | 25d | 2023-11-03 A | 2023-12-08 A |  | 100% |  |
| 645 |  | Develop Test cases | 15d | 2023-11-03 A | 2023-11-24 A | 643 | 100% |  |
| 646 |  | Review Test cases with SIT Working Group | 9d | 2023-11-27 A | 2023-12-07 A | 645 | 100% |  |
| 647 |  | SIT Component Integration Testing Test cases Batch 3 (CIT Intervals 5 and 6) approved at ETMAG | 0d | 2023-12-08 A | 2023-12-08 A | 646FS+1d | 100% |  |
| 648 | 1.4.1.4.1.5 | **CIT Interval 1 Preparation** | 283d | 2022-11-16 A | 2023-12-15 A |  | 100% |  |
| 649 | 1.4.1.4.1.5.1 | **Environments (SIT A)** | 246d | 2022-11-16 A | 2023-10-25 A |  | 100% |  |
| 650 |  | PPs register PKI Officers and request PKI certificates | 5d | 2023-10-09 A | 2023-10-13 A |  | 100% | start no earlier than 2023-10-09 |
| 651 |  | PPs register PKI Officers and request PKI certificates Complete - Interval 1 | 0d | 2023-10-25 A | 2023-10-25 A | 650FS+8d | 100% |  |
| 652 |  | PP SIT A environment preparation (incl. security certificates and security compliance) | 238d | 2022-11-16 A | 2023-10-13 A | 541 | 100% |  |
| 653 |  | SI coordinate SIT Participants' SIT A environment preparation | 238d | 2022-11-16 A | 2023-10-13 A | 652SS | 100% |  |
| 654 |  | PP submit self-declaration of environment preparation complete (incl. security certificates and security compliance) to Programme for assurance | 0d | 2023-10-13 A | 2023-10-13 A | 652FF | 100% | start no earlier than 2023-10-13 |
| 655 |  | SI assure PPs' self-declaration of environment preparation complete (incl. security certificates and security compliance) | 5d | 2023-10-16 A | 2023-10-20 A | 654FF+5d | 100% |  |
| 656 |  | SIT Participants' SIT A environments ready to start connectivity proving CIT Interval 1 | 0d | 2023-09-01 A | 2023-09-01 A | 654SS | 100% |  |
| 657 |  | PP SIT A environment connectivity proving | 10d | 2023-09-04 A | 2023-09-15 A | 656 | 100% |  |
| 658 |  | SI coordinate SIT Participants' SIT A environment connectivity proving | 10d | 2023-09-04 A | 2023-09-15 A | 657SS | 100% |  |
| 659 |  | PP deployment of MHHS solution code to SIT A environments | 10d | 2023-09-25 A | 2023-10-06 A | 700FF | 100% |  |
| 660 |  | SI coordinate deployment of MHHS solution code to SIT Participants' SIT A environments | 10d | 2023-09-25 A | 2023-10-06 A | 700FF | 100% |  |
| 661 |  | PP submit evidence of SIT A environment connectivity proving and code deployment completion to Programme for assurance | 30d | 2023-09-04 A | 2023-10-13 A | 657SS | 100% |  |
| 662 |  | SI assurance of SIT Participants' SIT A environment connectivity proving and code deployment completion | 25d | 2023-09-18 A | 2023-10-20 A | 661FF+5d | 100% |  |
| 663 | 1.4.1.4.1.5.2 | **Test Data - ISD Creation** | 9d | 2023-08-22 A | 2023-09-01 A |  | 100% |  |
| 664 |  | Set-up Market Participants and DIP ID Data | 8d | 2023-08-22 A | 2023-08-31 A |  | 100% |  |
| 665 |  | Distribute ISD Data to Participants | 1d | 2023-09-01 A | 2023-09-01 A | 664 | 100% |  |
| 666 |  | Test Data - ISD Creation Complete | 0d | 2023-09-01 A | 2023-09-01 A | 665 | 100% |  |
| 667 | 1.4.1.4.1.5.3 | **Test Data - SFTP Onboarding** | 70d | 2023-08-21 A | 2023-11-24 A |  | 100% |  |
| 668 |  | Create Containers and Keys for Participants | 3d | 2023-08-21 A | 2023-08-23 A |  | 100% |  |
| 669 |  | Share SFTP Access with Participants | 5d | 2023-08-24 A | 2023-08-30 A | 668 | 100% |  |
| 670 |  | Test SFTP Connectivity | 5d | 2023-08-31 A | 2023-09-06 A | 669 | 100% |  |
| 671 |  | Test Data - SFTP Onboarding Complete | 0d | 2023-11-24 A | 2023-11-24 A | 670FS+57d | 100% |  |
| 672 | 1.4.1.4.1.5.4 | **Test Data - Provide Sample Files** | 10d | 2023-08-21 A | 2023-09-01 A |  | 100% |  |
| 673 |  | Generate Sample Files off IF Messages | 8d | 2023-08-21 A | 2023-08-30 A |  | 100% |  |
| 674 |  | Transmit Sample Files off IF Messages to Participants (More detail needs to be planned for a POC) | 2d | 2023-08-31 A | 2023-09-01 A | 673 | 100% |  |
| 675 |  | Test Data - Provide Sample Files Complete | 0d | 2023-09-01 A | 2023-09-01 A | 674 | 100% |  |
| 676 | 1.4.1.4.1.5.5 | **Test Data - Detailed SIT Data Load Guidance** | 65d | 2023-09-07 A | 2023-12-06 A |  | 100% |  |
| 677 |  | Document Guidance | 21d | 2023-09-07 A | 2023-10-05 A | 675FS+3d | 100% |  |
| 678 |  | Provide Guidance to PPs | 1d | 2023-10-06 A | 2023-10-06 A | 677 | 100% |  |
| 679 |  | Test Data - Detailed SIT Functional Data Load Guidance Complete | 0d | 2023-12-06 A | 2023-12-06 A | 678FS+43d | 100% |  |
| 680 | 1.4.1.4.1.5.6 | **Test Data - Population of Data Items for Testing Guidance - Draft** | 80d | 2023-08-17 A | 2023-12-06 A |  | 100% |  |
| 681 |  | Document Guidance - Draft | 11d | 2023-08-17 A | 2023-08-31 A | 870 | 100% |  |
| 682 |  | Provide Guidance to PPs - Draft | 1d | 2023-09-01 A | 2023-09-01 A | 681 | 100% |  |
| 683 |  | Test Data - Population of Data Items for Testing Guidance - Draft Complete | 0d | 2023-12-06 A | 2023-12-06 A | 682FS+68d | 100% |  |
| 684 | 1.4.1.4.1.5.7 | **Test Data - Population of Data Items for Testing Guidance - Final** | 87d | 2023-08-17 A | 2023-12-15 A |  | 100% |  |
| 685 |  | Update Document Guidance With PPS Feedback | 81d | 2023-08-17 A | 2023-12-07 A | 681SS | 100% |  |
| 686 |  | Provide Final Guidance to PPs | 1d | 2023-12-08 A | 2023-12-08 A | 685 | 100% |  |
| 687 |  | Test Data - Population of Data Items for Testing Guidance - Final Complete | 0d | 2023-12-15 A | 2023-12-15 A | 686FS+5d | 100% |  |
| 688 | 1.4.1.4.1.5.8 | **Test Data (SIT A) Interval 1** | 40d | 2023-09-04 A | 2023-10-27 A |  | 100% |  |
| 689 |  | Run data allocation | 4d | 2023-09-04 A | 2023-09-07 A | 629, 666 | 100% |  |
| 690 |  | Cleanse, anonymise and populate data post cut | 4d | 2023-09-08 A | 2023-09-13 A | 689 | 100% |  |
| 691 |  | Transmit data sets to PPs | 3d | 2023-09-15 A | 2023-09-19 A | 690 | 100% |  |
| 692 |  | PP - Load test data to test environments | 7d | 2023-09-20 A | 2023-09-28 A | 691, 675 | 100% |  |
| 693 |  | PP Check data integrity on test environment | 1d | 2023-09-29 A | 2023-09-29 A | 692 | 100% |  |
| 694 |  | PP submit self-declaration to Programme to confirm loading & verification of test data | 0d | 2023-09-29 A | 2023-09-29 A | 693FF | 100% |  |
| 695 |  | Test Data (SIT A) Interval 1 Complete | 0d | 2023-10-27 A | 2023-10-27 A | 694FS+20d | 100% |  |
| 696 | 1.4.1.4.1.5.9 | **Other Preparation** | 45d | 2023-07-03 A | 2023-09-01 A |  | 100% |  |
| 697 |  | Onboarding of Test Participants to Test Management Tool (Azure DevOps) | 45d | 2023-07-03 A | 2023-09-01 A | 656SF | 100% |  |
| 698 |  | Test Management Tool onboarding | 45d | 2023-07-03 A | 2023-09-01 A | 656SF | 100% |  |
| 699 | 1.4.1.4.1.5.10 | **SIT Component Integration Test Readiness Report** | 28d | 2023-09-14 A | 2023-10-23 A |  | 100% |  |
| 700 |  | PP submit Test Readiness Report to Programme for assurance | 0d | 2023-10-20 A | 2023-10-20 A | 698, 639, 695 | 100% | start no earlier than 2023-10-09 |

| ID | WBS | Task | Duration | Start | Finish | Predecessors | Complete | Constraint |
| --- | --- | --- | --- | --- | --- | --- | --- | --- |
| 701 |  | SI assure Test Participants' Test Readiness Reports | 1d | 2023-10-23 A | 2023-10-23 A | 700SS | 100% |  |
| 702 |  | SI develop Overarching SIT Component Integration Test Readiness Report | 23d | 2023-09-14 A | 2023-10-16 A | 625FS+40d | 100% |  |
| 703 |  | Artefact review (via TMAG) and updates | 4d | 2023-10-17 A | 2023-10-20 A | 702 | 100% |  |
| 704 |  | SIT Component Integration Testing 1 Preparation Complete (incl. approval of SI SIT Component Integration Test Readiness Report) | 0d | 2023-10-27 A | 2023-10-27 A | 703FS+1d, 700, 656, 698, 695, 255, 260, 249, 269, 270, 701 | 100% |  |
| 705 | 1.4.1.4.1.6 | **CIT Interval 2 Preparation** | 103d | 2023-07-03 A | 2023-11-22 A |  | 100% |  |
| 706 | 1.4.1.4.1.6.1 | **Environments (SIT A)** | 43d | 2023-09-22 A | 2023-11-22 A |  | 100% |  |
| 707 |  | SIT Participants' SIT A environments ready to start connectivity proving CIT Interval 2 | 0d | 2023-09-22 A | 2023-09-22 A |  | 100% |  |
| 708 |  | Programme Participants Ready to Start Connectivity Proving | 0d | 2023-09-22 A | 2023-09-22 A |  | 100% | finish no earlier than 2023-09-22 |
| 709 |  | Internal Connectivity Proving Phase | 10d | 2023-09-25 A | 2023-10-06 A | 708 | 100% |  |
| 710 |  | Internal Connectivity Proving Phase Complete | 0d | 2023-10-06 A | 2023-10-06 A | 709 | 100% | start no earlier than 2023-10-06 |
| 711 |  | DIP Onboarding Activity (1. PKI Officers and Certificates, 2. Set-up Validation, 3. End Point Creation, 4. Controlled Smoke Test ) | 28d | 2023-10-16 A | 2023-11-22 A | 710FS+5d | 100% |  |
| 712 |  | DIP Onboarding Complete | 0d | 2023-11-22 A | 2023-11-22 A | 711 | 100% |  |
| 713 |  | PPs Register PKI Officers and request PKI certificates Complete - Interval 2 | 0d | 2023-11-22 A | 2023-11-22 A | 712 | 100% |  |
| 714 |  | PP Code Deployment | 0d | 2023-10-20 A | 2023-10-20 A |  | 100% | start no earlier than 2023-10-20 |
| 715 | 1.4.1.4.1.6.2 | **Test Data (SIT A) Interval 2** | 43d | 2023-09-20 A | 2023-11-17 A |  | 100% |  |
| 716 |  | Run data allocation | 7d | 2023-09-20 A | 2023-09-28 A | 692SS | 100% |  |
| 717 |  | Cleanse and populate data post cut | 2d | 2023-09-29 A | 2023-10-02 A | 716 | 100% |  |
| 718 |  | Transmit data sets to PPs | 1d | 2023-10-03 A | 2023-10-03 A | 717 | 100% |  |
| 719 |  | PP - Load test data to test environments | 33d | 2023-10-04 A | 2023-11-17 A | 718 | 100% |  |
| 720 |  | PP Check data integrity on test environment | 15d | 2023-10-23 A | 2023-11-17 A | 719FF | 100% |  |
| 721 |  | PP submit self-declaration to Programme to confirm loading & verification of test data | 0d | 2023-11-17 A | 2023-11-17 A | 720FF | 100% |  |
| 722 |  | Test Data (SIT A) Interval 2 Complete | 0d | 2023-11-17 A | 2023-11-17 A | 721 | 100% |  |
| 723 | 1.4.1.4.1.6.3 | **Other Preparation** | 87d | 2023-07-03 A | 2023-10-31 A |  | 100% |  |
| 724 |  | Onboarding of Test Participants to Test Management Tool (Azure DevOps) | 60d | 2023-07-03 A | 2023-09-22 A | 707SF | 100% |  |
| 725 |  | Test Management Tool onboarding | 27d | 2023-09-25 A | 2023-10-31 A | 724 | 100% |  |
| 726 | 1.4.1.4.1.6.4 | **SIT Component Integration Test Readiness Report** | 25d | 2023-10-02 A | 2023-11-03 A |  | 100% |  |
| 727 |  | PP submit Test Readiness Report to Programme for assurance | 0d | 2023-10-25 A | 2023-10-25 A | 639FS+18d | 100% |  |
| 728 |  | SI assure Test Participants' Test Readiness Reports | 2d | 2023-10-26 A | 2023-10-27 A | 727 | 100% |  |
| 729 |  | SI develop Overarching SIT Component Integration Test Readiness Report | 20d | 2023-10-02 A | 2023-10-27 A | 728FF | 100% |  |
| 730 |  | Artefact review (via TMAG) and updates | 5d | 2023-10-30 A | 2023-11-03 A | 729 | 100% |  |
| 731 |  | SIT Component Integration Testing 2 Preparation Complete (incl. approval of SI SIT Component Integration Test Readiness Report) | 0d | 2023-11-06 A | 2023-11-06 A | 725, 730FS+1d, 707, 318 | 100% |  |
| 732 | 1.4.1.4.1.7 | **CIT Interval 3 Preparation** | 54d | 2023-10-03 A | 2023-12-15 A |  | 100% |  |
| 733 | 1.4.1.4.1.7.1 | **PIT Test Completion Report (incl. evidence)** | 26d | 2023-10-13 A | 2023-11-17 A |  | 100% |  |
| 734 |  | Submit draft PIT Test Completion Report (incl. evidence) and submit to Programme for assurance | 11d | 2023-10-13 A | 2023-10-27 A |  | 100% | must start on 2023-10-13 |
| 735 |  | Finalise PIT Test Completion Report (incl. evidence) | 5d | 2023-10-30 A | 2023-11-03 A | 734 | 100% |  |
| 736 |  | PP PIT Completion Report (excl. Migration/Reverse Migration) submitted to Programme for assurance CIT Interval 3 | 0d | 2023-11-03 A | 2023-11-03 A | 735, 79, 95 | 100% |  |
| 737 |  | PP Final PIT Completion Reports assured by SI | 10d | 2023-11-06 A | 2023-11-17 A | 736 | 100% |  |
| 738 | 1.4.1.4.1.7.2 | **Environments (SIT A)** | 51d | 2023-10-06 A | 2023-12-15 A |  | 100% |  |
| 739 |  | Programme Participants Ready to Start Connectivity Proving | 0d | 2023-10-06 A | 2023-10-06 A |  | 100% | start no earlier than 2023-10-06 |
| 740 |  | SIT Participants' SIT A environments ready to start connectivity proving CIT Interval 3 | 0d | 2023-10-06 A | 2023-10-06 A | 739 | 100% |  |
| 741 |  | Internal Connectivity Proving Phase | 10d | 2023-10-09 A | 2023-10-20 A | 739FS+1d | 100% |  |
| 742 |  | Internal Connectivity Proving Phase Complete | 0d | 2023-10-20 A | 2023-10-20 A | 741 | 100% |  |
| 743 |  | DIP Onboarding Activity (1. PKI Officers and Certificates, 2. Set-up Validation, 3. End Point Creation, 4. Controlled Smoke Test ) | 35d | 2023-10-30 A | 2023-12-15 A | 742FS+5d | 100% |  |
| 744 |  | DIP Onboarding Complete | 0d | 2023-12-15 A | 2023-12-15 A | 743 | 100% |  |
| 745 |  | PPs Register PKI Officers and Request PKI certificates Complete - Interval 3 | 0d | 2023-12-15 A | 2023-12-15 A | 744FF | 100% |  |
| 746 |  | PP Code Deployment | 0d | 2023-11-10 A | 2023-11-10 A | 742FS+15d | 100% | start no earlier than 2023-10-20 |
| 747 | 1.4.1.4.1.7.3 | **Test Data (SIT A) Interval 3** | 34d | 2023-10-03 A | 2023-11-17 A |  | 100% |  |
| 748 |  | Run data allocation | 4d | 2023-10-03 A | 2023-10-06 A | 718SS | 100% |  |
| 749 |  | Cleanse and populate data post cut | 5d | 2023-10-09 A | 2023-10-13 A | 748 | 100% |  |
| 750 |  | Transmit data sets to PPs | 2d | 2023-10-16 A | 2023-10-17 A | 749 | 100% |  |
| 751 |  | PP - Load test data to test environments | 8d | 2023-10-18 A | 2023-10-27 A | 750 | 100% |  |
| 752 |  | PP Check data integrity on test environment | 15d | 2023-10-30 A | 2023-11-17 A | 751 | 100% |  |
| 753 |  | PP submit self-declaration to Programme to confirm loading & verification of test data | 0d | 2023-11-17 A | 2023-11-17 A | 752FF | 100% |  |
| 754 |  | Test Data (SIT A) Interval 3 Complete | 0d | 2023-11-17 A | 2023-11-17 A | 753 | 100% |  |
| 755 | 1.4.1.4.1.7.4 | **Other Preparation** | 25d | 2023-10-16 A | 2023-11-17 A |  | 100% |  |
| 756 |  | Onboarding of Test Participants to Test Management Tool (Azure DevOps) | 25d | 2023-10-16 A | 2023-11-17 A |  | 100% | start no earlier than 2023-10-16 |
| 757 |  | Test Management Tool onboarding | 25d | 2023-10-16 A | 2023-11-17 A |  | 100% | start no earlier than 2023-10-16 |
| 758 | 1.4.1.4.1.7.5 | **SIT Component Integration Test Readiness Report** | 25d | 2023-10-16 A | 2023-11-17 A |  | 100% |  |
| 759 |  | PP submit Test Readiness Report to Programme for assurance | 0d | 2023-11-03 A | 2023-11-03 A | 643 | 100% |  |
| 760 |  | SI assure Test Participants' Test Readiness Reports | 5d | 2023-11-06 A | 2023-11-10 A | 759FF+5d | 100% |  |
| 761 |  | SI develop Overarching SIT Component Integration Test Readiness Report | 20d | 2023-10-16 A | 2023-11-10 A | 760FF | 100% |  |
| 762 |  | Artefact review (via TMAG) and updates | 5d | 2023-11-13 A | 2023-11-17 A | 761 | 100% |  |
| 763 |  | SIT Component Integration Testing 3 Preparation Complete (incl. approval of SI SIT Component Integration Test Readiness Report) | 0d | 2023-11-20 A | 2023-11-20 A | 762FS+1d, 736, 740, 759, 757, 754, 336 | 100% |  |
| 764 | 1.4.1.4.1.8 | **CIT Interval 4 Preparation** | 36d | 2023-10-16 A | 2023-12-04 A |  | 100% |  |
| 765 | 1.4.1.4.1.8.1 | **PIT Test Completion Report (incl. evidence)** | 21d | 2023-10-27 A | 2023-11-24 A |  | 100% |  |
| 766 |  | Submit draft PIT Test Completion Report (incl. evidence) and submit to Programme for assurance | 1d | 2023-10-27 A | 2023-10-27 A |  | 100% | must start on 2023-10-27 |
| 767 |  | Finalise PIT Test Completion Report (incl. evidence) | 15d | 2023-10-30 A | 2023-11-17 A | 766 | 100% |  |
| 768 |  | PP PIT Completion Report (excl. Migration/Reverse Migration) submitted to Programme for assurance CIT Interval 4 | 0d | 2023-11-17 A | 2023-11-17 A | 767, 79, 95 | 100% |  |
| 769 |  | PP Final PIT Completion Reports assured by SI | 5d | 2023-11-20 A | 2023-11-24 A | 768 | 100% |  |
| 770 | 1.4.1.4.1.8.2 | **Environments (SIT A)** | 25d | 2023-10-23 A | 2023-11-24 A |  | 100% |  |

| ID | WBS | Task | Duration | Start | Finish | Predecessors | Complete | Constraint |
| --- | --- | --- | --- | --- | --- | --- | --- | --- |
| 771 |  | Programme Participants Ready to Start Connectivity Proving | 0d | 2023-10-23 A | 2023-10-23 A |  | 100% | start no earlier than 2023-10-23 |
| 772 |  | SIT Participants' SIT A environments ready to start connectivity proving CIT Interval 4 | 0d | 2023-10-23 A | 2023-10-23 A | 771 | 100% |  |
| 773 |  | Internal Connectivity Proving Phase | 10d | 2023-10-23 A | 2023-11-03 A | 772 | 100% |  |
| 774 |  | Internal Connectivity Proving Phase Complete | 0d | 2023-11-03 A | 2023-11-03 A | 773 | 100% |  |
| 775 |  | DIP Onboarding Activity (1. PKI Officers and Certificates, 2. Set-up Validation, 3. End Point Creation, 4. Controlled Smoke Test ) | 10d | 2023-11-13 A | 2023-11-24 A | 774FS+5d | 100% |  |
| 776 |  | DIP Onboarding Complete | 0d | 2023-11-24 A | 2023-11-24 A | 775 | 100% |  |
| 777 |  | PPs register PKI Officers and Request PKI Certificates Complete - Interval 4 | 0d | 2023-11-24 A | 2023-11-24 A | 776 | 100% |  |
| 778 |  | PP Code Deployment | 0d | 2023-11-17 A | 2023-11-17 A |  | 100% | start no earlier than 2023-11-17 |
| 779 | 1.4.1.4.1.8.3 | **Test Data (SIT A) Interval 4** | 30d | 2023-10-23 A | 2023-12-01 A |  | 100% |  |
| 780 |  | Run data allocation | 5d | 2023-10-23 A | 2023-10-27 A | 749FS+5d | 100% |  |
| 781 |  | Cleanse and populate data post cut | 2d | 2023-10-30 A | 2023-10-31 A | 780 | 100% |  |
| 782 |  | Transmit data sets to PPs | 5d | 2023-11-01 A | 2023-11-07 A | 781 | 100% |  |
| 783 |  | PP - Load test data to test environments | 5d | 2023-11-08 A | 2023-11-14 A | 782 | 100% |  |
| 784 |  | PP Check data integrity on test environment | 13d | 2023-11-15 A | 2023-12-01 A | 783 | 100% |  |
| 785 |  | PP submit self-declaration to Programme to confirm loading & verification of test data | 0d | 2023-12-01 A | 2023-12-01 A | 784FF | 100% |  |
| 786 |  | Test Data (SIT A) Interval 4 Complete | 0d | 2023-12-01 A | 2023-12-01 A | 785 | 100% |  |
| 787 | 1.4.1.4.1.8.4 | **Other Preparation** | 25d | 2023-10-30 A | 2023-12-01 A |  | 100% |  |
| 788 |  | Onboarding of Test Participants to Test Management Tool (Azure DevOps) | 25d | 2023-10-30 A | 2023-12-01 A |  | 100% | start no earlier than 2023-10-30 |
| 789 |  | Test Management Tool onboarding | 25d | 2023-10-30 A | 2023-12-01 A |  | 100% | start no earlier than 2023-10-30 |
| 790 | 1.4.1.4.1.8.5 | **SIT Component Integration Test Readiness Report** | 27d | 2023-10-16 A | 2023-11-21 A |  | 100% |  |
| 791 |  | PP submit Test Readiness Report to Programme for assurance | 0d | 2023-11-03 A | 2023-11-03 A | 643 | 100% |  |
| 792 |  | SI assure Test Participants' Test Readiness Reports | 5d | 2023-11-06 A | 2023-11-10 A | 791FF+5d | 100% |  |
| 793 |  | SI develop Overarching SIT Component Integration Test Readiness Report | 20d | 2023-10-16 A | 2023-11-10 A | 792FF | 100% |  |
| 794 |  | Artefact review (via SITAG) and updates | 7d | 2023-11-13 A | 2023-11-21 A | 793 | 100% |  |
| 795 |  | SIT Component Integration Testing 4 Preparation Complete (incl. approval of SI SIT Component Integration Test Readiness Report) | 0d | 2023-12-04 A | 2023-12-04 A | 794FS+2d, 768, 772, 791, 786, 353FS+1d | 100% |  |
| 796 | 1.4.1.4.1.9 | **CIT Interval 5 Preparation** | 53d | 2023-11-01 A | 2024-01-12 A |  | 100% |  |
| 797 | 1.4.1.4.1.9.1 | **PIT Test Completion Report (incl. evidence)** | 21d | 2023-11-17 A | 2023-12-15 A |  | 100% |  |
| 798 |  | Submit draft PIT Test Completion Report (incl. evidence) and submit to Programme for assurance | 1d | 2023-11-17 A | 2023-11-17 A |  | 100% | must start on 2023-11-17 |
| 799 |  | Finalise PIT Test Completion Report (incl. evidence) | 15d | 2023-11-20 A | 2023-12-08 A | 798 | 100% |  |
| 800 |  | PP PIT Completion Report (excl. Migration/Reverse Migration) submitted to Programme for assurance CIT Interval 5 | 0d | 2023-12-08 A | 2023-12-08 A | 799, 79, 95 | 100% |  |
| 801 |  | PP Final PIT Completion Reports assured by SI | 5d | 2023-12-11 A | 2023-12-15 A | 800 | 100% |  |
| 802 | 1.4.1.4.1.9.2 | **Environments (SIT A)** | 21d | 2023-11-10 A | 2023-12-08 A |  | 100% |  |
| 803 |  | Programme Participants Ready to Start Connectivity Proving | 0d | 2023-11-10 A | 2023-11-10 A |  | 100% | start no earlier than 2023-11-10 |
| 804 |  | SIT Participants' SIT A environments ready to start connectivity proving CIT Interval 5 | 0d | 2023-11-10 A | 2023-11-10 A | 803 | 100% |  |
| 805 |  | Internal Connectivity Proving Phase | 10d | 2023-11-13 A | 2023-11-24 A | 803FS+1d | 100% |  |
| 806 |  | Internal Connectivity Proving Phase Complete | 0d | 2023-11-24 A | 2023-11-24 A | 805 | 100% |  |
| 807 |  | DIP Onboarding Activity (1. PKI Officers and Certificates, 2. Set-up Validation, 3. End Point Creation, 4. Controlled Smoke Test ) | 10d | 2023-11-27 A | 2023-12-08 A | 806 | 100% |  |
| 808 |  | DIP Onboarding Complete | 0d | 2023-12-08 A | 2023-12-08 A | 807 | 100% |  |
| 809 |  | PPs register PKI Officers and Request PKI Certificates Complete - Interval 5 | 0d | 2023-12-08 A | 2023-12-08 A | 808 | 100% |  |
| 810 |  | PP Code Deployment | 0d | 2023-12-08 A | 2023-12-08 A | 809 | 100% | start no earlier than 2023-10-20 |
| 811 | 1.4.1.4.1.9.3 | **Test Data (SIT A) Interval 5** | 33d | 2023-11-01 A | 2023-12-15 A |  | 100% |  |
| 812 |  | Run data allocation | 5d | 2023-11-01 A | 2023-11-07 A | 782SS | 100% |  |
| 813 |  | Cleanse and populate data post cut | 8d | 2023-11-08 A | 2023-11-17 A | 812 | 100% |  |
| 814 |  | Transmit data sets to PPs | 2d | 2023-11-20 A | 2023-11-21 A | 813 | 100% |  |
| 815 |  | PP - Load test data to test environments | 8d | 2023-11-22 A | 2023-12-01 A | 814 | 100% |  |
| 816 |  | PP Check data integrity on test environment | 10d | 2023-12-04 A | 2023-12-15 A | 815 | 100% |  |
| 817 |  | PP submit self-declaration to Programme to confirm loading & verification of test data | 0d | 2023-12-15 A | 2023-12-15 A | 816FF | 100% |  |
| 818 |  | Test Data (SIT A) Interval 5 Complete | 0d | 2023-12-15 A | 2023-12-15 A | 817 | 100% |  |
| 819 | 1.4.1.4.1.9.4 | **Other Preparation** | 40d | 2023-11-20 A | 2024-01-12 A |  | 100% |  |
| 820 |  | Onboarding of Test Participants to Test Management Tool (Azure DevOps) | 40d | 2023-11-20 A | 2024-01-12 A |  | 100% | start no earlier than 2023-11-20 |
| 821 |  | Test Management Tool onboarding | 36d | 2023-11-20 A | 2024-01-08 A |  | 100% | start no earlier than 2023-11-20 |
| 822 | 1.4.1.4.1.9.5 | **SIT Component Integration Test Readiness Report** | 35d | 2023-11-20 A | 2024-01-05 A |  | 100% |  |
| 823 |  | PP submit Test Readiness Report to Programme for assurance | 0d | 2023-12-08 A | 2023-12-08 A | 647 | 100% |  |
| 824 |  | SI assure Test Participants' Test Readiness Reports | 5d | 2023-12-11 A | 2023-12-15 A | 823FF+5d | 100% |  |
| 825 |  | SI develop Overarching SIT Component Integration Test Readiness Report | 20d | 2023-11-20 A | 2023-12-15 A | 824FF | 100% |  |
| 826 |  | Artefact review (via SITAG) and updates | 15d | 2023-12-18 A | 2024-01-05 A | 825 | 100% |  |
| 827 |  | SIT Component Integration Testing 5 Preparation Complete (incl. approval of SI SIT Component Integration Test Readiness Report) | 0d | 2024-01-08 A | 2024-01-08 A | 826FS+1d, 800, 804, 821, 823, 818, 473, 456 | 100% |  |
| 828 | 1.4.1.4.1.10 | **CIT Interval 6 Preparation** | 45d | 2023-11-20 A | 2024-01-19 A |  | 100% |  |
| 829 | 1.4.1.4.1.10.1 | **PIT Test Completion Report (incl. evidence)** | 31d | 2023-12-01 A | 2024-01-12 A |  | 100% |  |
| 830 |  | Submit draft PIT Test Completion Report (incl. evidence) and submit to Programme for assurance | 1d | 2023-12-01 A | 2023-12-01 A |  | 100% | must start on 2023-12-01 |
| 831 |  | Finalise PIT Test Completion Report (incl. evidence) | 25d | 2023-12-04 A | 2024-01-05 A | 830 | 100% |  |
| 832 |  | PP PIT Completion Report (excl. Migration/Reverse Migration) submitted to Programme for assurance CIT Interval 6 | 0d | 2024-01-05 A | 2024-01-05 A | 831, 79, 95, 275, 280, 283 | 100% |  |
| 833 |  | PP Final PIT Completion Reports assured by SI | 5d | 2024-01-08 A | 2024-01-12 A | 832 | 100% |  |
| 834 | 1.4.1.4.1.10.2 | **Environments (SIT A)** | 30d | 2023-11-24 A | 2024-01-05 A |  | 100% |  |
| 835 |  | Programme Participants Ready to Start Connectivity Proving | 0d | 2023-11-24 A | 2023-11-24 A |  | 100% | start no earlier than 2023-11-24 |
| 836 |  | SIT Participants' SIT A environments ready to start connectivity proving CIT Interval 6 | 0d | 2023-11-24 A | 2023-11-24 A | 835 | 100% |  |
| 837 |  | Internal Connectivity Proving Phase | 10d | 2023-11-27 A | 2023-12-08 A | 836FS+1d | 100% |  |
| 838 |  | Internal Connectivity Proving Phase Complete | 0d | 2023-12-08 A | 2023-12-08 A | 837 | 100% |  |
| 839 |  | DIP Onboarding Activity (1. PKI Officers and Certificates, 2. Set-up Validation, 3. End Point Creation, 4. Controlled Smoke Test ) | 5d | 2023-12-04 A | 2023-12-08 A | 836FS+6d | 100% |  |
| 840 |  | DIP Onboarding Complete | 0d | 2023-12-08 A | 2023-12-08 A | 839 | 100% |  |

| ID | WBS | Task | Duration | Start | Finish | Predecessors | Complete | Constraint |
| --- | --- | --- | --- | --- | --- | --- | --- | --- |
| 841 |  | PPs register PKI Officers and Request PKI Certificates Complete - Interval 6 | 0d | 2023-12-08 A | 2023-12-08 A | 840 | 100% | start no earlier than 2023-12-08 |
| 842 |  | PP Code Deployment | 0d | 2024-01-05 A | 2024-01-05 A |  | 100% | start no earlier than 2024-01-05 |
| 843 | 1.4.1.4.1.10.3 | **Test Data (SIT A) Interval 6** | 25d | 2023-11-20 A | 2023-12-22 A |  | 100% |  |
| 844 |  | Run data allocation | 10d | 2023-11-20 A | 2023-12-01 A | 814SS | 100% |  |
| 845 |  | Cleanse and populate data post cut | 1d | 2023-12-04 A | 2023-12-04 A | 844 | 100% |  |
| 846 |  | Transmit data sets to PPs | 1d | 2023-12-05 A | 2023-12-05 A | 845 | 100% |  |
| 847 |  | PP - Load test data to test environments | 8d | 2023-12-06 A | 2023-12-15 A | 846 | 100% |  |
| 848 |  | PP Check data integrity on test environment | 5d | 2023-12-18 A | 2023-12-22 A | 847 | 100% |  |
| 849 |  | PP submit self-declaration to Programme to confirm loading & verification of test data | 0d | 2023-12-22 A | 2023-12-22 A | 848FF | 100% |  |
| 850 |  | Test Data (SIT A) Interval 6 Complete | 0d | 2023-12-22 A | 2023-12-22 A | 849 | 100% |  |
| 851 | 1.4.1.4.1.10.4 | **Other Preparation** | 31d | 2023-12-04 A | 2024-01-15 A |  | 100% |  |
| 852 |  | Onboarding of Test Participants to Test Management Tool (Azure DevOps) | 31d | 2023-12-04 A | 2024-01-15 A |  | 100% | start no earlier than 2023-12-04 |
| 853 |  | Test Management Tool onboarding | 31d | 2023-12-04 A | 2024-01-15 A |  | 100% | start no earlier than 2023-12-04 |
| 854 | 1.4.1.4.1.10.5 | **SIT Component Integration Test Readiness Report** | 25d | 2023-11-20 A | 2023-12-22 A |  | 100% |  |
| 855 |  | PP submit Test Readiness Report to Programme for assurance | 0d | 2023-12-08 A | 2023-12-08 A | 647 | 100% |  |
| 856 |  | SI assure Test Participants' Test Readiness Reports | 5d | 2023-12-11 A | 2023-12-15 A | 855FF+5d | 100% |  |
| 857 |  | SI develop Overarching SIT Component Integration Test Readiness Report | 20d | 2023-11-20 A | 2023-12-15 A | 856FF | 100% |  |
| 858 |  | Artefact review (via TMAG) and updates | 5d | 2023-12-18 A | 2023-12-22 A | 857 | 100% |  |
| 859 |  | SIT Component Integration Testing 6 Preparation Complete (incl. approval of SI SIT Component Integration Test Readiness Report) | 0d | 2024-01-19 A | 2024-01-19 A | 858FS+1d, 832, 836, 853, 855, 850, 301, 490 | 100% |  |
| 860 | 1.4.1.4.2 | **SIT Functional Preparation** | 595d? | 2022-10-31 A | 2025-02-07 A |  | 100% |  |
| 861 |  | Environment Approach and Plan - SIT Functional | 1d? | 2023-11-20 A | 2023-11-20 A |  | 100% | start no earlier than 2023-11-20 |
| 862 | 1.4.1.4.2.2 | **Test Approach & Plan** | 208d | 2022-10-31 A | 2023-08-16 A |  | 100% |  |
| 863 |  | Develop document with SITWG | 179d | 2022-10-31 A | 2023-07-06 A |  | 100% | finish no earlier than 2023-07-06 |
| 864 |  | Industry Consultation | 10d | 2023-07-07 A | 2023-07-20 A | 863 | 100% |  |
| 865 |  | Artefact review (via TMAG) and updates | 19d | 2023-07-21 A | 2023-08-16 A | 864 | 100% | finish no earlier than 2023-08-03 |
| 866 |  | SIT Functional Test Approach & Plan approved | 0d | 2023-08-16 A | 2023-08-16 A |  | 100% | finish no earlier than 2023-08-16 |
| 867 | 1.4.1.4.2.3 | **Test Data Approach & Plan** | 29d | 2023-07-07 A | 2023-08-16 A |  | 100% |  |
| 868 |  | Industry Consultation | 10d | 2023-07-07 A | 2023-07-20 A | 864SS | 100% |  |
| 869 |  | Artefact review (via TMAG) and updates | 19d | 2023-07-21 A | 2023-08-16 A | 868 | 100% |  |
| 870 |  | SIT Functional Testing Test Data Approach & Plan approved | 0d | 2023-08-16 A | 2023-08-16 A | 869 | 100% |  |
| 871 | 1.4.1.4.2.4 | **Test scenarios** | 298d | 2023-01-02 A | 2024-02-21 A |  | 100% |  |
| 872 |  | Development of test scenarios | 85d | 2023-01-02 A | 2023-04-28 A | 863SS+45d | 100% |  |
| 873 |  | Review test scenarios with SIT Working Group | 65d | 2023-08-17 A | 2023-11-15 A | 872FS+78d | 100% |  |
| 874 |  | SIT Functional Testing Test scenarios (themes 1-5) approved | 0d | 2023-12-08 A | 2023-12-08 A | 873FS+17d | 100% |  |
| 875 |  | SIT Functional Testing Test scenarios (themes 6,7,9) approved | 0d | 2024-01-17 A | 2024-01-17 A | 874FS+28d | 100% |  |
| 876 |  | SIT Functional Testing Test scenarios (theme 8) approved | 0d | 2024-02-21 A | 2024-02-21 A | 875FS+25d | 100% |  |
| 877 | 1.4.1.4.2.5 | **Test cases** | 465d? | 2023-05-01 A | 2025-02-07 A |  | 100% |  |
| 878 | 1.4.1.4.2.5.1 | **SI Test cases** | 213d | 2023-05-01 A | 2024-02-21 A |  | 100% |  |
| 879 |  | Development of Test cases | 150d | 2023-05-01 A | 2023-11-24 A | 872 | 100% |  |
| 880 |  | Review Test cases with SIT Working Group | 78d | 2023-09-25 A | 2024-01-10 A | 879SS+105d | 100% |  |
| 881 |  | SIT Functional Testing Test Cases (themes 1-5) approved | 0d | 2024-01-17 A | 2024-01-17 A | 880FS+5d | 100% |  |
| 882 |  | SIT Functional Testing Test cases (themes 6,7,9) approved | 0d | 2024-01-17 A | 2024-01-17 A | 881 | 100% |  |
| 883 |  | SIT Functional Testing Test cases (theme 8) approved | 0d | 2024-02-21 A | 2024-02-21 A | 882FS+25d | 100% |  |
| 884 | 1.4.1.4.2.5.2 | **SIT Functional Programme RTTM** | 74d? | 2024-07-29 A | 2024-11-07 A |  | 100% |  |
| 885 | 1.4.1.4.2.5.2.1 | **RTTM Development** | 30d? | 2024-07-29 A | 2024-09-06 A |  | 100% |  |
| 886 |  | Development of Manual SIT Functional RTTM | 30d? | 2024-07-29 A | 2024-09-06 A |  | 100% | start no earlier than 2024-07-29 |
| 887 |  | Manual SIT Functional RTTM Complete | 0d? | 2024-09-06 A | 2024-09-06 A | 886 | 100% | start no earlier than 2024-07-29 |
| 888 | 1.4.1.4.2.5.2.2 | **Gap analysis** | 54d? | 2024-08-26 A | 2024-11-07 A |  | 100% |  |
| 889 |  | Identify gaps in test case coverage following RTTM review | 20d? | 2024-08-26 A | 2024-09-20 A |  | 100% |  |
| 890 |  | Address gaps in test case coverage following RTTM review | 25d | 2024-09-09 A | 2024-10-11 A | 889SS+10d | 100% |  |
| 891 |  | Gap analysis complete | 0d | 2024-10-11 A | 2024-10-11 A | 890 | 100% |  |
| 892 |  | Test Script updates identified | 1d? | 2024-10-14 A | 2024-10-14 A | 891 | 100% |  |
| 893 |  | Test Scripts updates | 1d | 2024-10-15 A | 2024-10-15 A | 892 | 100% |  |
| 894 |  | RTTM Updated Additional Static RTTM WBS items | 10d | 2024-10-14 A | 2024-10-25 A | 892FS-1d | 100% |  |
| 895 |  | Removal of de-scoped TCs from the RTTMs | 5d | 2024-10-21 A | 2024-10-25 A | 894FS-5d | 100% |  |
| 896 |  | Update and stabilisation of all TC ADO IDs | 14d | 2024-10-21 A | 2024-11-07 A | 894FS-5d | 100% |  |
| 897 |  | Addition and integration of Role tags to reqs in the Role RTTMs | 5d | 2024-10-21 A | 2024-10-25 A | 894FS-5d | 100% |  |
| 898 |  | Update of the RTTM All sheet (porting of the individual RTTMs) | 7d | 2024-10-24 A | 2024-11-01 A | 894FS-2d | 100% |  |
| 899 |  | Define Additional ADO Tags | 1d | 2024-10-23 A | 2024-10-23 A | 894FS-3d | 100% |  |
| 900 |  | Functional RTTM ready for import into ADO | 0d | 2024-11-01 A | 2024-11-01 A | 898 | 100% |  |
| 901 |  | Further Interative Deepdive on the requirements to testcase mapping | 9d | 2024-10-21 A | 2024-10-31 A | 898FS-10d | 100% |  |
| 902 |  | Internal review | 5d | 2024-10-21 A | 2024-10-25 A | 901FS-9d | 100% |  |
| 903 |  | Issue Static RTTM to Code Bodies | 1d? | 2024-10-29 A | 2024-10-29 A | 902FS+1d | 100% |  |
| 904 |  | Code Body Acceptance of RTTM | 5d | 2024-10-30 A | 2024-11-05 A | 903 | 100% |  |
| 905 | 1.4.1.4.2.5.3 | **Cycle 3 Test Evidence Capturing Approach** | 25d? | 2024-09-16 A | 2024-10-18 A |  | 100% |  |
| 906 |  | Define guiding principles and proof of concept | 10d | 2024-09-16 A | 2024-09-27 A |  | 100% | start no earlier than 2024-09-16 |
| 907 |  | Draft proposed test evidence capturing approach | 3d | 2024-09-30 A | 2024-10-02 A | 906 | 100% |  |
| 908 |  | SRO review | 5d | 2024-10-03 A | 2024-10-09 A | 907 | 100% |  |
| 909 |  | Present proposed approach | 1d? | 2024-10-11 A | 2024-10-11 A | 908FS+1d | 100% |  |
| 910 |  | Incorporate feedback | 4d | 2024-10-14 A | 2024-10-17 A | 909 | 100% |  |

| ID | WBS | Task | Duration | Start | Finish | Predecessors | Complete | Constraint |
| --- | --- | --- | --- | --- | --- | --- | --- | --- |
| 911 |  | Publish proposed approach ahead of Cycle 3 start | 1d? | 2024-10-18 A | 2024-10-18 A | 910 | 100% |  |
| 912 | 1.4.1.4.2.5.4 | **DITL Cycle 3 Pack Development** | 8d? | 2024-10-08 A | 2024-10-17 A |  | 100% |  |
| 913 |  | Programme Cycle 2 Retro | 1d? | 2024-10-08 A | 2024-10-08 A |  | 100% | start no earlier than 2024-10-08 |
| 914 |  | Post-retro DITL Changes | 3d | 2024-10-09 A | 2024-10-11 A | 913 | 100% |  |
| 915 |  | SRO Review | 2d | 2024-10-14 A | 2024-10-15 A | 914 | 100% |  |
| 916 |  | Post-SRO Review Changes | 1d? | 2024-10-16 A | 2024-10-16 A | 915 | 100% |  |
| 917 |  | Publish Cycle 3 DITL / Cycle 3 DITL Online Sessions for SIT PPs | 1d? | 2024-10-17 A | 2024-10-17 A | 916 | 100% |  |
| 918 | 1.4.1.4.2.5.5 | **Test Script Exit Points** | 85d | 2024-10-14 A | 2025-02-07 A |  | 100% |  |
| 919 |  | Implement exit points for Sprint 5 | 5d | 2024-10-14 A | 2024-10-18 A | 911FS-5d | 100% |  |
| 920 |  | Identify exit points for Sprint 6 | 5d | 2024-11-07 A | 2024-11-13 A | 1541SS | 100% |  |
| 921 |  | Identify exit points for Sprint 7 | 5d | 2024-11-08 A | 2024-11-14 A | 1542SS | 100% | start no earlier than 2024-11-08 |
| 922 |  | Identify exit points for Sprint 8 | 5d | 2024-11-18 A | 2024-11-22 A | 1543SS | 100% |  |
| 923 |  | Identify exit points for Sprint 9 | 5d | 2024-12-02 A | 2024-12-06 A | 1544SS | 100% |  |
| 924 |  | Identify exit points for Sprint 10 | 5d | 2024-12-23 A | 2024-12-27 A | 1545SS | 100% |  |
| 925 |  | Identify exit points for Sprint 11 | 5d | 2025-01-06 A | 2025-01-10 A | 1546SS | 100% |  |
| 926 |  | Identify exit points for Sprint 12 | 5d | 2025-01-20 A | 2025-01-24 A | 1547SS | 100% |  |
| 927 |  | Identify exit points for Sprint 13 | 5d | 2025-02-03 A | 2025-02-07 A | 1548SS | 100% |  |
| 928 |  | Exit point identified and evidence capture flags updated | 0d | 2025-02-07 A | 2025-02-07 A | 927 | 100% |  |
| 929 | 1.4.1.4.2.6 | **Environments (SIT-Staging)** | 10d | 2023-12-04 A | 2023-12-15 A |  | 100% |  |
| 930 | 1.4.1.4.2.6.1 | **SIT Functional pre-requisites** | 10d | 2023-12-04 A | 2023-12-15 A |  | 100% |  |
| 931 | 1.4.1.4.2.6.1.1 | **DCC** | 10d | 2023-12-04 A | 2023-12-15 A |  | 100% |  |
| 932 | 1.4.1.4.2.6.1.1.1 | **CSS** | 10d | 2023-12-04 A | 2023-12-15 A |  | 100% |  |
| 933 |  | SIT participants have requested DCC CSS PKI certificates for access to UIT-B environment | 10d | 2023-12-04 A | 2023-12-15 A |  | 100% | start no earlier than 2023-12-04 |
| 934 |  | SIT participants have received DCC CSS PKI certificates for UIT-B environment | 0d | 2023-12-15 A | 2023-12-15 A | 933 | 100% |  |
| 935 | 1.4.1.4.2.6.1.1.2 | **DSP** | 10d | 2023-12-04 A | 2023-12-15 A |  | 100% |  |
| 936 |  | SIT participants have requested DCC DSP PKI certificates for access to UIT-B environment | 10d | 2023-12-04 A | 2023-12-15 A |  | 100% | start no earlier than 2023-12-04 |
| 937 |  | SIT participants have received DCC DSP PKI certificates for UIT-B environment | 0d | 2023-12-15 A | 2023-12-15 A | 936 | 100% |  |
| 938 | 1.4.1.4.2.7 | **Stand up SIT A Environment** | 25d | 2024-02-05 A | 2024-03-08 A |  | 100% |  |
| 939 | 1.4.1.4.2.7.1 | **SIT Functional Connectivity Proving** | 15d | 2024-02-12 A | 2024-03-01 A |  | 100% |  |
| 940 |  | SIT Functional Connectivity Proving Period | 15d | 2024-02-12 A | 2024-03-01 A |  | 100% | start no earlier than 2024-01-08 |
| 941 |  | SIT Functional Connectivity Proving Complete | 0d | 2024-03-01 A | 2024-03-01 A | 940 | 100% | start no earlier than 2024-03-01 |
| 942 | 1.4.1.4.2.7.2 | **PP Environments (SIT A)** | 25d | 2024-02-05 A | 2024-03-08 A |  | 100% |  |
| 943 |  | Deployment of MHHS solution code to SIT A environments | 25d | 2024-02-05 A | 2024-03-08 A |  | 100% | start no earlier than 2024-02-05 |
| 944 | 1.4.1.4.2.7.3 | **SI Environments (SIT A)** | 25d | 2024-02-05 A | 2024-03-08 A |  | 100% |  |
| 945 |  | Coordinate deployment of MHHS solution code to SIT Participants' SIT A environments | 25d | 2024-02-05 A | 2024-03-08 A | 943SS | 100% |  |
| 946 | 1.4.1.4.2.8 | **Test data (SIT A)** | 221d? | 2023-12-18 A | 2024-10-21 A |  | 100% |  |
| 947 | 1.4.1.4.2.8.1 | **Cycle 1 Test data (SIT A)** | 55d | 2023-12-18 A | 2024-03-01 A |  | 100% |  |
| 948 |  | Prepare, Generate and Allocate Test Data | 28d | 2023-12-18 A | 2024-01-24 A | 679, 687 | 100% | start no earlier than 2023-12-11 |
| 949 |  | Transmit Data Sets to PPs | 4d | 2024-01-26 A | 2024-01-31 A | 948FS+1d | 100% |  |
| 950 |  | PP's Iterative load and data integrity check | 22d | 2024-02-01 A | 2024-03-01 A | 949 | 100% |  |
| 951 |  | Cycle 1 - PP's confirmation that test data is ready for SIT Functional | 0d | 2024-03-01 A | 2024-03-01 A | 950 | 100% |  |
| 952 | 1.4.1.4.2.8.2 | **Cycle 2 Test data (inc. Settlement Data) (SIT A)** | 57d | 2024-03-28 A | 2024-06-14 A |  | 100% |  |
| 953 |  | Prepare, Generate and Allocate Test Data | 31d | 2024-03-28 A | 2024-05-09 A | 951FS+18d | 100% |  |
| 954 |  | Transmit Data Sets to PPs | 3d | 2024-05-10 A | 2024-05-14 A | 953 | 100% |  |
| 955 |  | PP's Iterative load and data integrity check | 13d | 2024-05-15 A | 2024-05-31 A | 954 | 100% |  |
| 956 |  | Cycle 2 - PP's confirmation that test data is ready for SIT Functional | 0d | 2024-06-14 A | 2024-06-14 A | 955FS+10d | 100% |  |
| 957 | 1.4.1.4.2.8.3 | **Cycle 3 Test data (SIT A) (2)** | 71d? | 2024-07-15 A | 2024-10-21 A |  | 100% |  |
| 958 |  | Cycle 3 data requirments analysis - check Cycle 2 data for gaps Check blocked test cases | 10d? | 2024-07-15 A | 2024-07-26 A |  | 100% | finish no earlier than 2024-07-26 |
| 959 |  | Provide DCC with MPANS for deletion secure file with password | 1d? | 2024-08-12 A | 2024-08-12 A |  | 100% |  |
| 960 |  | Receive MPANS from DCC to exclude | 1d? | 2024-08-09 A | 2024-08-09 A |  | 100% |  |
| 961 |  | Exclude MPANS from allocation | 1d | 2024-08-16 A | 2024-08-16 A |  | 100% |  |
| 962 |  | Allocate Cycle 3 MPANS | 16d? | 2024-08-06 A | 2024-08-27 A |  | 100% |  |
| 963 |  | Generate Cycle 3 Data | 2d? | 2024-08-27 A | 2024-08-28 A |  | 100% |  |
| 964 |  | Check data prior to sending to DCC | 5d? | 2024-08-22 A | 2024-08-28 A |  | 100% |  |
| 965 |  | Share Cycle 3 MPAN data with DCC | 1d? | 2024-08-29 A | 2024-08-29 A |  | 100% |  |
| 966 |  | DCC - load data and create registration Id's for Cycle 3 data | 13d? | 2024-08-27 A | 2024-09-12 A |  | 100% |  |
| 967 |  | Add registration ID's to Cycle 3 Data | 2d? | 2024-09-12 A | 2024-09-13 A |  | 100% |  |
| 968 |  | Share subset of data with St Cls for data load | 2d? | 2024-09-12 A | 2024-09-13 A |  | 100% |  |
| 969 |  | St Clements to run test with Subset of data - MPRS business process checks including Import/Export MPANS | 5d? | 2024-09-16 A | 2024-09-20 A |  | 100% |  |
| 970 |  | Send Cycle 3 data to partcipants for early sight of data | 3d? | 2024-09-25 A | 2024-09-27 A |  | 100% |  |
| 971 |  | St Clements MPRS data load bulk files for Cycle 3 | 15d? | 2024-09-23 A | 2024-10-11 A |  | 100% |  |
| 972 |  | New MPAN creation and load through DCC and St Clements | 1d? | 2024-10-11 A | 2024-10-11 A |  | 100% | start no earlier than 2024-10-11 |
| 973 |  | Share files with PP's and central parties | 1d | 2024-10-11 A | 2024-10-11 A |  | 100% | start no earlier than 2024-10-11 |
| 974 |  | Avanade to load data | 6d | 2024-10-14 A | 2024-10-21 A |  | 100% | start no earlier than 2024-10-14 |
| 975 |  | Helix to load data | 6d | 2024-10-14 A | 2024-10-21 A |  | 100% | start no earlier than 2024-10-14 |
| 976 |  | PP's and central parties to load all Cycle 3 data | 6d | 2024-10-14 A | 2024-10-21 A |  | 100% | start no earlier than 2024-10-14 |
| 977 |  | All parties to finalise data load | 1d? | 2024-10-21 A | 2024-10-21 A |  | 100% | start no earlier than 2024-10-21 |
| 978 | 1.4.1.4.2.9 | **SIT Functional Test Readiness Report** | 45d | 2024-01-01 A | 2024-03-01 A |  | 100% |  |
| 979 | 1.4.1.4.2.9.1 | **PP SIT Functional Test Readiness Report** | 44d | 2024-01-01 A | 2024-02-29 A |  | 100% |  |
| 980 |  | Develop draft Test Readiness Report and submit to Programme for assurance | 21d | 2024-01-01 A | 2024-01-29 A |  | 100% | start no earlier than 2024-01-01 |

| ID | WBS | Task | Duration | Start | Finish | Predecessors | Complete | Constraint |
| --- | --- | --- | --- | --- | --- | --- | --- | --- |
| 981 |  | Placing Reliance Stage 2 Review | 34d | 2024-01-15 A | 2024-02-29 A | 980SS+10d | 100% |  |
| 982 |  | Finalise Test Readiness Report and submit to Programme for assurance | 9d | 2024-01-30 A | 2024-02-09 A | 980 | 100% |  |
| 983 | 1.4.1.4.2.9.2 | **SI SIT Functional Test Readiness Report** | 40d | 2024-01-01 A | 2024-02-23 A |  | 100% |  |
| 984 |  | Assure Test Participants' Test Readiness Reports | 35d | 2024-01-01 A | 2024-02-16 A | 980SS, 982FF+5d | 100% |  |
| 985 |  | Develop Overarching SIT Functional Test Readiness Report | 20d | 2024-01-22 A | 2024-02-16 A | 984FF | 100% |  |
| 986 |  | Artefact review (via TMAG) and updates | 5d | 2024-02-19 A | 2024-02-23 A | 985 | 100% |  |
| 987 |  | SIT Functional Testing Preparation Complete | 0d | 2024-03-01 A | 2024-03-01 A | 986FF+5d, 866, 370, 981, 874, 881, 951 | 100% |  |
| 988 | 1.4.1.4.3 | **SIT Migration Testing Preparation** | 595d? | 2022-10-31 A | 2025-02-07 A |  | 100% |  |
| 989 | 1.4.1.4.3.1 | **Test Approach & Plan** | 75d | 2023-09-07 A | 2023-12-20 A |  | 100% |  |
| 990 |  | Develop document with SITWG | 32d | 2023-09-07 A | 2023-10-20 A | 2618 | 100% | finish no earlier than 2023-10-11 |
| 991 |  | Draft document review with Code Bodies | 8d | 2023-10-23 A | 2023-11-01 A | 990 | 100% |  |
| 992 |  | Industry Consultation | 10d | 2023-11-02 A | 2023-11-15 A | 991 | 100% |  |
| 993 |  | Artefact review (via TMAG) and updates | 25d | 2023-11-16 A | 2023-12-20 A | 992 | 100% |  |
| 994 |  | SIT Migration Testing Test Approach & Plan approved | 0d | 2023-12-20 A | 2023-12-20 A | 993 | 100% | finish no earlier than 2023-12-20 |
| 995 | 1.4.1.4.3.2 | **Test Data Approach & Plan** | 35d | 2023-11-02 A | 2023-12-20 A |  | 100% |  |
| 996 |  | Industry Consultation | 10d | 2023-11-02 A | 2023-11-15 A | 992SS | 100% |  |
| 997 |  | Artefact review (via TMAG) and updates | 25d | 2023-11-16 A | 2023-12-20 A | 996 | 100% |  |
| 998 |  | SIT Migration Test Data Test Approach & Plan approved | 0d | 2023-12-20 A | 2023-12-20 A | 997 | 100% |  |
| 999 | 1.4.1.4.3.3 | **Test scenarios & Test Cases** | 297d? | 2023-12-21 A | 2025-02-07 A |  | 100% |  |
| 1000 | 1.4.1.4.3.3.1 | **Theme 1** | 65d | 2023-12-21 A | 2024-03-20 A |  | 100% |  |
| 1001 |  | Develop Test Scenarios & Test Cases | 25d | 2023-12-21 A | 2024-01-24 A | 994 | 100% |  |
| 1002 |  | Industry Review Workshop | 1d | 2024-01-25 A | 2024-01-25 A | 1001 | 100% |  |
| 1003 |  | Industry Consultation Review | 6d | 2024-02-05 A | 2024-02-12 A | 1002FS+6d | 100% |  |
| 1004 |  | Review with SIT Working Group | 5d | 2024-02-29 A | 2024-03-06 A | 1003FS+12d | 100% |  |
| 1005 |  | SIT Migration Test scenarios & Test Cases Approved - Theme 1 | 0d | 2024-03-20 A | 2024-03-20 A | 1004FS+10d | 100% |  |
| 1006 | 1.4.1.4.3.3.2 | **Theme 2** | 85d | 2023-12-21 A | 2024-04-17 A |  | 100% |  |
| 1007 |  | Develop Test Scenarios & Test Cases | 40d | 2023-12-21 A | 2024-02-14 A | 994 | 100% |  |
| 1008 |  | Industry Review Workshop | 1d | 2024-02-15 A | 2024-02-15 A | 1007 | 100% |  |
| 1009 |  | Industry Consultation Review | 6d | 2024-02-26 A | 2024-03-04 A | 1008FS+6d | 100% |  |
| 1010 |  | Review with SIT Working Group | 5d | 2024-03-28 A | 2024-04-03 A | 1009FS+17d | 100% |  |
| 1011 |  | SIT Migration Test scenarios & Test Cases Approved - Theme 2 | 0d | 2024-04-17 A | 2024-04-17 A | 1010FS+10d | 100% |  |
| 1012 | 1.4.1.4.3.3.3 | **Theme 3** | 85d | 2023-12-21 A | 2024-04-17 A |  | 100% |  |
| 1013 |  | Develop Test Scenarios & Test Cases | 55d | 2023-12-21 A | 2024-03-06 A | 994 | 100% |  |
| 1014 |  | Industry Review Workshop | 1d | 2024-03-07 A | 2024-03-07 A | 1013 | 100% |  |
| 1015 |  | Industry Consultation Review | 6d | 2024-03-13 A | 2024-03-20 A | 1014FS+3d | 100% |  |
| 1016 |  | Review with SIT Working Group | 5d | 2024-03-28 A | 2024-04-03 A | 1015FS+5d | 100% |  |
| 1017 |  | SIT Migration Test scenarios & Test Cases Approved - Theme 3 | 0d | 2024-04-17 A | 2024-04-17 A | 1016FS+10d | 100% |  |
| 1018 | 1.4.1.4.3.3.4 | **RTTM Development** | 17d | 2024-08-29 A | 2024-09-20 A |  | 100% |  |
| 1019 |  | Develop Manual SIT Migration RTTM | 17d | 2024-08-29 A | 2024-09-20 A |  | 100% | start no earlier than 2024-08-29 |
| 1020 |  | Manual SIT Migration RTTM Complete | 0d | 2024-09-20 A | 2024-09-20 A | 1019 | 100% |  |
| 1021 | 1.4.1.4.3.3.5 | **Gap analysis** | 107d? | 2024-09-12 A | 2025-02-07 A |  | 100% |  |
| 1022 |  | Identify gaps in test case coverage following RTTM review. | 12d | 2024-09-12 A | 2024-09-27 A | 1019SS+10d | 100% |  |
| 1023 |  | Address gaps in test case coverage following RTTM review. | 17d | 2024-09-19 A | 2024-10-11 A | 1022SS+5d | 100% |  |
| 1024 |  | Gap analysis complete | 0d? | 2024-10-11 A | 2024-10-11 A | 1023 | 100% |  |
| 1025 |  | Test Script updates identified | 1d? | 2024-10-14 A | 2024-10-14 A | 1024 | 100% |  |
| 1026 |  | Test Scripts updates | 16d? | 2024-10-14 A | 2024-11-04 A | 1025FS-1d | 100% |  |
| 1027 |  | RTTM Updated | 1d? | 2024-10-29 A | 2024-10-29 A | 1026FS-5d | 100% |  |
| 1028 |  | Removal of de-scoped TCs from the RTTMs | 2d | 2024-10-31 A | 2024-11-01 A | 1026FS-3d | 100% |  |
| 1029 |  | Update and stabilisation of all TC ADO IDs | 2d | 2024-10-31 A | 2024-11-01 A | 1026FS-3d | 100% |  |
| 1030 |  | Addition and integration of Role tags to reqs in the Role RTTMs | 3d | 2024-10-30 A | 2024-11-01 A | 1026FS-4d | 100% |  |
| 1031 |  | Update of the RTTM All sheet (porting of the individual RTTMs) | 2d | 2024-10-31 A | 2024-11-01 A | 1026FS-3d | 100% |  |
| 1032 |  | ADO IDs corrected | 1d? | 2024-11-04 A | 2024-11-04 A | 1031 | 100% | start no earlier than 2024-10-16 |
| 1033 |  | Migration RTTM ready for import into ADO | 0d | 2024-11-04 A | 2024-11-04 A | 1032 | 100% |  |
| 1034 |  | Issue Static RTTM to Code Bodies | 1d? | 2024-11-05 A | 2024-11-05 A | 1033 | 100% |  |
| 1035 |  | Implement Code Bodies feedback on RTTM | 6d | 2024-11-06 A | 2024-11-13 A | 1034 | 100% |  |
| 1036 |  | Code Body Acceptance of RTTM | 0d | 2024-11-13 A | 2024-11-13 A | 1034, 1035 | 100% |  |
| 1037 | 1.4.1.4.3.3.5.16 | **ADO Clean-up** | 17d? | 2024-10-24 | 2024-11-15 A |  | 100% |  |
| 1038 |  | Theme alignment | 1d? | 2024-10-28 A | 2024-10-28 A |  | 100% | start no earlier than 2024-10-28 |
| 1039 |  | Understand Additional suffix Fields in ADO as defined by Kevin | 1d? | 2024-10-25 A | 2024-10-25 A |  | 100% | finish no earlier than 2024-10-25 |
| 1040 |  | Correct Missing Test Case References | 1d? | 2024-10-28 A | 2024-10-28 A |  | 100% | start no earlier than 2024-10-28 |
| 1041 |  | Load Functional RTTMs into ADO | 1d? | 2024-10-28 A | 2024-10-28 A |  | 100% | start no earlier than 2024-10-28 |
| 1042 |  | Load Migration RTTMs into ADO | 1d? | 2024-11-06 A | 2024-11-06 A |  | 100% | start no earlier than 2024-11-06 |
| 1043 |  | Confirm Missing fields in ADO are resolved | 1d? | 2024-11-07 A | 2024-11-07 A |  | 100% | finish no earlier than 2024-11-07 |
| 1044 |  | Reload Functional RTTM into ADO | 1d? | 2024-11-07 A | 2024-11-07 A |  | 100% | start no earlier than 2024-11-07 |
| 1045 | 1.4.1.4.3.3.5.16.8 | **ADO Design Documentation** | 10d? | 2024-11-04 | 2024-11-15 A |  | 100% |  |
| 1046 |  | Produce ADO high Level Design and Data Model | 1d? | 2024-11-15 A | 2024-11-15 A |  | 100% | finish no earlier than 2024-11-15 |
| 1047 |  | Produce Report derivation document | 1d? | 2024-11-15 A | 2024-11-15 A |  | 100% | finish no earlier than 2024-11-15 |
| 1048 | 1.4.1.4.3.3.5.17 | **Test Case Rationalisation (Functional + Migration)** | 67d | 2024-11-07 A | 2025-02-07 A |  | 100% |  |
| 1049 |  | Internal preliminary rationalisation workshop 1 | 1d | 2024-11-07 A | 2024-11-07 A | 1034FS+1d | 100% |  |
| 1050 |  | Baseline RTTMs | 0d | 2024-11-13 A | 2024-11-13 A | 1036, 904 | 100% |  |

| ID | WBS | Task | Duration | Start | Finish | Predecessors | Complete | Total float | Constraint |
| --- | --- | --- | --- | --- | --- | --- | --- | --- | --- |
| 1051 |  | Baseline test cases | 0d | 2024-11-13 A | 2024-11-13 A | 1036 | 100% |  |  |
| 1052 |  | Produce requirements / test case analysis doc | 1d | 2024-11-14 A | 2024-11-14 A | 1051 | 100% |  |  |
| 1053 |  | Internal finalisation rationalisation workshop 2 | 13d | 2024-11-15 A | 2024-12-03 A | 1052 | 100% |  |  |
| 1054 |  | SRO walkthrough | 1d | 2024-12-04 A | 2024-12-04 A | 1053 | 100% |  |  |
| 1055 |  | Code Bodies walkthrough | 1d | 2024-12-04 A | 2024-12-04 A | 1053 | 100% |  |  |
| 1056 |  | Send invites to PPs for walkthrough | 1d | 2024-12-04 A | 2024-12-04 A | 1055FS-1d | 100% |  |  |
| 1057 |  | PP walkthrough | 1d | 2024-12-17 A | 2024-12-17 A | 1056FS+8d | 100% |  |  |
| 1058 |  | Update requirements / test case analysis doc | 29d | 2024-12-05 A | 2025-01-14 A | 1056 | 100% |  |  |
| 1059 |  | SITWG Paper Day | 0d | 2025-01-14 A | 2025-01-14 A | 1058 | 100% |  |  |
| 1060 |  | SITWG recommendation on requirements / test case analysis doc | 0d | 2025-01-21 A | 2025-01-21 A | 1059FS+5d | 100% |  |  |
| 1061 |  | Issue to SITAG / SITAG paper day | 0d | 2025-01-22 A | 2025-01-22 A | 1060FS+1d | 100% |  |  |
| 1062 |  | Prepare ADO update | 6d | 2025-01-22 A | 2025-01-29 A | 1060 | 100% |  |  |
| 1063 |  | Sign off by SITAG | 0d | 2025-01-29 A | 2025-01-29 A | 1061FS+5d | 100% |  |  |
| 1064 |  | Update ADO | 7d | 2025-01-30 A | 2025-02-07 A | 1063 | 100% |  |  |
| 1065 |  | Update all ADO reporting | 7d | 2025-01-30 A | 2025-02-07 A | 1063 | 100% |  |  |
| 1066 |  | Update test cases | 7d | 2025-01-30 A | 2025-02-07 A | 1063 | 100% |  |  |
| 1067 |  | Update RTTM | 7d | 2025-01-30 A | 2025-02-07 A | 1063 | 100% |  |  |
| 1068 |  | Update master test case spreadsheet | 7d | 2025-01-30 A | 2025-02-07 A | 1063 | 100% |  |  |
| 1069 |  | Test Case Rationalisation complete | 0d | 2025-02-07 A | 2025-02-07 A | 1064, 1065, 1063, 1066, 1067, 1068 | 100% |  |  |
| 1070 | 1.4.1.4.3.4 | **Environments (SIT B)** | 435d | 2022-10-31 A | 2024-06-28 A |  | 100% |  |  |
| 1071 | 1.4.1.4.3.4.1 | **PP Environments (SIT B)** | 41d | 2024-05-03 A | 2024-06-28 A |  | 100% |  |  |
| 1072 |  | PP Environments available | 0d | 2024-05-03 A | 2024-05-03 A | 541 | 100% |  | start no earlier than 2024-05-03 |
| 1073 |  | PP Onboarding / Smoke test | 35d | 2024-05-13 A | 2024-06-28 A | 1072FS+6d | 100% |  |  |
| 1074 |  | DTN Connectivity Proving Complete | 5d | 2024-06-10 A | 2024-06-14 A | 1072FS+26d | 100% |  |  |
| 1075 |  | PP Code Deployment | 0d | 2024-06-14 A | 2024-06-14 A | 1074 | 100% |  |  |
| 1076 | 1.4.1.4.3.4.2 | **SI Environments (SIT B)** | 425d | 2022-10-31 A | 2024-06-14 A |  | 100% |  |  |
| 1077 |  | Coordinate SIT Participants' SIT B environment preparation | 420d | 2022-10-31 A | 2024-06-07 A |  | 100% |  |  |
| 1078 |  | Assure PPs' self-declaration of environment preparation complete (incl. security certificates and security compliance) | 0d | 2024-06-07 A | 2024-06-07 A | 1077 | 100% |  |  |
| 1079 |  | SIT Participants' SIT B environments ready to start connectivity proving (incl. certificates and security compliance) | 0d | 2024-06-05 A | 2024-06-05 A | 1072FS+24d | 100% |  |  |
| 1080 |  | Coordinate SIT Participants' SIT B environment connectivity proving | 2d | 2024-06-06 A | 2024-06-07 A | 1079 | 100% |  |  |
| 1081 |  | Coordinate deployment of MHHS solution code to SIT Participants' SIT B environments | 0d | 2024-06-14 A | 2024-06-14 A | 1075 | 100% |  |  |
| 1082 | 1.4.1.4.3.5 | **SIT Migration Test Readiness Report** | 44d | 2024-04-02 A | 2024-05-31 A |  | 100% |  |  |
| 1083 | 1.4.1.4.3.5.1 | **PP SIT Migration Test Readiness Report** | 44d | 2024-04-02 A | 2024-05-31 A |  | 100% |  |  |
| 1084 |  | Develop draft Test Readiness Report and submit to Programme for assurance | 20d | 2024-04-02 A | 2024-04-29 A |  | 100% |  | start no earlier than 2024-04-02 |
| 1085 |  | Placing Reliance Stage 2 Review | 35d | 2024-04-15 A | 2024-05-31 A | 1084SS+9d | 100% |  |  |
| 1086 |  | Finalise Test Readiness Report and submit to Programme for assurance | 10d | 2024-04-30 A | 2024-05-13 A | 1084 | 100% |  |  |
| 1087 | 1.4.1.4.3.5.2 | **SI SIT Migration Test Readiness Report** | 40d | 2024-04-02 A | 2024-05-27 A |  | 100% |  |  |
| 1088 |  | Assure Test Participants' Test Readiness Reports | 35d | 2024-04-02 A | 2024-05-20 A | 1084SS, 1086FF+5d | 100% |  |  |
| 1089 |  | Develop Overarching SIT Migration Test Readiness Report | 20d | 2024-04-23 A | 2024-05-20 A | 1088FF | 100% |  |  |
| 1090 |  | Artefact review (via SITAG) and updates | 5d | 2024-05-21 A | 2024-05-27 A | 1089 | 100% |  |  |
| 1091 |  | SIT Migration Testing Preparation Complete | 0d | 2024-06-03 A | 2024-06-03 A | 1090FF+5d, 994, 387, 1085, 1005, 1011, 1017 | 100% |  |  |
| 1092 | 1.4.1.4.4 | **SIT Non-Functional Preparation** | 347d? | 2023-11-30 A | 2025-03-28 |  | 93% | 714d |  |
| 1093 | 1.4.1.4.4.1 | **Test Approach & Plan** | 120d | 2023-11-30 A | 2024-05-15 A |  | 100% |  |  |
| 1094 |  | Develop document with SITWG | 67d | 2023-11-30 A | 2024-03-01 A |  | 100% |  | must start on 2023-11-30 |
| 1095 |  | Draft document review with Code Bodies | 10d | 2024-03-04 A | 2024-03-15 A | 1094 | 100% |  |  |
| 1096 |  | Industry Consultation | 10d | 2024-03-18 A | 2024-03-29 A | 1095 | 100% |  |  |
| 1097 |  | Industry Assurance Review | 5d | 2024-04-11 A | 2024-04-17 A | 1096FS+8d | 100% |  |  |
| 1098 |  | SIT Non-Functional Testing Test Approach & Plan approved | 0d | 2024-05-15 A | 2024-05-15 A | 1097FS+20d | 100% |  |  |
| 1099 | 1.4.1.4.4.2 | **Test Data Approach & Plan** | 41d | 2024-03-20 A | 2024-05-15 A |  | 100% |  |  |
| 1100 |  | Industry Consultation | 14d | 2024-03-20 A | 2024-04-08 A | 1096SS+2d | 100% |  |  |
| 1101 |  | Artefact review (via SITAG) and updates | 27d | 2024-04-09 A | 2024-05-15 A | 1100 | 100% |  |  |
| 1102 |  | SIT Non-Functional Testing Test Data Approach & Plan approved | 0d | 2024-05-15 A | 2024-05-15 A | 1098FF, 1101 | 100% |  |  |
| 1103 | 1.4.1.4.4.3 | **Test scenarios & Test Cases** | 98d? | 2024-03-04 A | 2024-07-17 |  | 100% |  |  |
| 1104 | 1.4.1.4.4.3.1 | **Theme 1** | 78d | 2024-03-04 A | 2024-06-19 A |  | 100% |  |  |
| 1105 |  | Develop Test Scenarios & Test Cases | 33d | 2024-03-04 A | 2024-04-17 A | 1094 | 100% |  |  |
| 1106 |  | Industry Review Workshop | 1d | 2024-04-18 A | 2024-04-18 A | 1105 | 100% |  |  |
| 1107 |  | Industry Consultation Review | 7d | 2024-05-02 A | 2024-05-10 A | 1106FS+9d | 100% |  |  |
| 1108 |  | Review with NFT Working Group | 5d | 2024-05-31 A | 2024-06-06 A | 1107FS+14d | 100% |  |  |
| 1109 |  | SIT NFT Scenarios & Test Cases Approved - Theme 1 | 0d | 2024-06-19 A | 2024-06-19 A | 1108FS+9d | 100% |  |  |
| 1110 | 1.4.1.4.4.3.2 | **Theme 2** | 98d | 2024-03-04 A | 2024-07-17 A |  | 100% |  |  |
| 1111 |  | Develop Test Scenarios & Test Cases | 53d | 2024-03-04 A | 2024-05-15 A | 1094 | 100% |  |  |
| 1112 |  | Industry Review Workshop | 1d | 2024-05-16 A | 2024-05-16 A | 1111 | 100% |  |  |
| 1113 |  | Industry Consultation Review | 7d | 2024-05-20 A | 2024-05-28 A | 1112FS+1d | 100% |  |  |
| 1114 |  | Review with NFT Working Group | 5d | 2024-06-28 A | 2024-07-04 A | 1113FS+22d | 100% |  |  |
| 1115 |  | SIT NFT Scenarios & Test Cases Approved - Theme 2 | 0d | 2024-07-17 A | 2024-07-17 A | 1114FS+9d | 100% |  |  |
| 1116 | 1.4.1.4.4.3.3 | **Theme 3** | 98d? | 2024-03-04 A | 2024-07-17 |  | 100% |  |  |
| 1117 |  | Develop Test Scenarios & Test Cases | 63d | 2024-03-04 A | 2024-05-29 A | 1094 | 100% |  |  |
| 1118 |  | Industry Review Workshop | 1d | 2024-05-30 A | 2024-05-30 A | 1117 | 100% |  |  |
| 1119 |  | Industry Consultation Review | 6d | 2024-06-10 A | 2024-06-17 A | 1118FS+6d | 100% |  |  |
| 1120 |  | Review with NFT Working Group | 5d | 2024-06-28 A | 2024-07-04 A | 1119FS+8d | 100% |  |  |

| ID | WBS | Task | Duration | Start | Finish | Predecessors | Complete | Total float | Constraint |
| --- | --- | --- | --- | --- | --- | --- | --- | --- | --- |
| 1121 |  | SIT NFT Scenarios & Test Cases Approved - Theme 3 | 0d | 2024-09-18 A | 2024-09-18 A | 1120FS+9d | 100% |  | start no earlier than 2024-09-18 |
| 1122 | 1.4.1.4.4.4 | **SIT NFT Programme RTTM** | 45d | 2024-09-18 A | 2024-11-19 A |  | 100% |  |  |
| 1123 |  | Develop Manual SIT NFT RTTM | 30d | 2024-09-18 A | 2024-10-29 A | 1121 | 100% |  |  |
| 1124 |  | LDP peer review | 10d | 2024-10-30 A | 2024-11-12 A | 1123 | 100% |  |  |
| 1125 |  | Review with SRO | 5d | 2024-11-13 A | 2024-11-19 A | 1124 | 100% |  |  |
| 1126 |  | DIP Manager / Code Bodies / Full SRO to review | 5d | 2024-11-13 A | 2024-11-19 A | 1124 | 100% |  |  |
| 1127 |  | DIP Manager / Code Bodies / Full SRO acceptance of RTTM | 0d | 2024-11-19 A | 2024-11-19 A | 1126 | 100% |  |  |
| 1128 |  | Manual SIT NFT RTTM Complete | 0d | 2024-11-19 A | 2024-11-19 A | 1125, 1126 | 100% |  |  |
| 1129 | 1.4.1.4.4.5 | **NFT (Theme 1, 2 and 3) DITL** | 18d | 2025-02-03 A | 2025-02-26 |  | 99% | 736d |  |
| 1130 |  | DITL Development | 10d | 2025-02-03 A | 2025-02-14 A |  | 100% |  | start no earlier than 2025-02-03 |
| 1131 |  | SRO Review | 5d | 2025-02-17 A | 2025-02-21 A | 1130 | 100% |  |  |
| 1132 |  | Post-SRO Review Changes | 3d | 2025-02-24 A | 2025-02-26 A | 1131 | 100% |  |  |
| 1133 |  | Programme DITL walkthrough with PPs on Theme 1, 2 and 3 | 0d | 2025-02-26 | 2025-02-26 | 1132 |  | 736d |  |
| 1134 | 1.4.1.4.4.6 | **NFT Performance Tool Theme 1 Setup** | 268d? | 2024-03-04 A | 2025-03-12 A |  | 100% |  |  |
| 1135 |  | Theme 1 injection tool initial POC | 85d? | 2024-03-04 A | 2024-06-28 A |  | 100% |  |  |
| 1136 |  | Theme 1 injection tool configuration and validation against DIP SIM (IR7.1) | 38d | 2024-07-01 A | 2024-08-21 A | 1135 | 100% |  |  |
| 1137 |  | Theme 1 injection tool configuration and validation against DIP SIM (IR8.1) | 29d | 2024-08-22 A | 2024-10-01 A | 1136 | 100% |  |  |
| 1138 |  | Theme 1 injection tool configuration and validation againast UIT DIP (IR8.1) | 11d | 2024-10-02 A | 2024-10-16 A | 1137 | 100% |  |  |
| 1139 |  | Theme 1 injection tool configuration and validation against SIT-B DIP (IR8.4) | 3d? | 2025-03-10 A | 2025-03-12 A | 1585FS+10d | 100% |  |  |
| 1140 | 1.4.1.4.4.7 | **Environments (SIT B)** | 134d | 2024-08-27 A | 2025-02-28 |  |  | 20d |  |
| 1141 | 1.4.1.4.4.7.1 | **PP Environments (SIT B)** | 0d | 2024-08-27 A | 2024-08-27 A |  | 100% |  |  |
| 1142 |  | Deployment of MHHS solution code to SIT B environments | 0d | 2024-08-27 A | 2024-08-27 A |  | 100% |  | start no earlier than 2024-08-27 |
| 1143 | 1.4.1.4.4.7.2 | **SI Environments (SIT B)** | 0d | 2024-08-27 A | 2024-08-27 A |  | 100% |  |  |
| 1144 |  | Coordinate deployment of MHHS solution code to SIT Participants' SIT B environments | 0d | 2024-08-27 A | 2024-08-27 A | 1142SS | 100% |  |  |
| 1145 | 1.4.1.4.4.7.3 | **Helix and Avanade Environments Upscale** | 5d | 2025-02-24 | 2025-02-28 |  |  | 20d |  |
| 1146 |  | Environment Uplift Window | 5d | 2025-02-24 | 2025-02-28 | 1585 |  | 20d |  |
| 1147 | 1.4.1.4.4.8 | **SIT Non-Functional Execution Model** | 42d | 2025-01-20 A | 2025-03-18 |  | 99% | 722d |  |
| 1148 | 1.4.1.4.4.8.1 | **Theme 1** | 22d | 2025-01-20 A | 2025-02-18 |  | 99% | 742d |  |
| 1149 |  | Develop execution model Theme 1 | 3d | 2025-01-20 A | 2025-01-22 A |  | 100% |  | start no earlier than 2025-01-20 |
| 1150 |  | SRO provide feedback | 5d | 2025-01-23 A | 2025-01-29 A | 1149 | 100% |  |  |
| 1151 |  | Address SRO feedback on execution model | 2d | 2025-01-30 A | 2025-01-31 A | 1150 | 100% |  |  |
| 1152 |  | Finalise execution model | 3d | 2025-02-03 A | 2025-02-05 A | 1151 | 100% |  |  |
| 1153 |  | NFTWG paper day | 0d | 2025-02-11 A | 2025-02-11 A | 1152FS+4d | 100% |  |  |
| 1154 |  | NFTWG update on execution model | 0d | 2025-02-18 | 2025-02-18 | 1153FS+5d |  | 742d |  |
| 1155 | 1.4.1.4.4.8.2 | **Theme 2 & 3** | 42d | 2025-01-20 A | 2025-03-18 |  | 99% | 722d |  |
| 1156 |  | Develop execution model Theme 2 & 3 | 3d | 2025-01-20 A | 2025-01-22 A |  | 100% |  | start no earlier than 2025-01-20 |
| 1157 |  | SRO provide feedback | 5d | 2025-01-23 A | 2025-01-29 A | 1156 | 100% |  |  |
| 1158 |  | Address SRO feedback on execution model | 2d | 2025-01-30 A | 2025-01-31 A | 1157 | 100% |  |  |
| 1159 |  | Finalise execution model | 3d | 2025-02-03 A | 2025-02-05 A | 1158 | 100% |  |  |
| 1160 |  | NFTWG paper day | 0d | 2025-03-11 | 2025-03-11 | 1159FS+24d |  | 722d |  |
| 1161 |  | NFTWG update on execution model | 0d | 2025-03-18 | 2025-03-18 | 1160FS+5d |  | 722d |  |
| 1162 | 1.4.1.4.4.9 | **SIT Non-Functional Progress reporting** | 17d | 2025-01-23 A | 2025-02-14 |  | 6% | 125d |  |
| 1163 |  | Determine reporting methodology | 2d | 2025-01-23 A | 2025-01-24 | 1149, 1156 | 50% | 125d |  |
| 1164 |  | Implement reporting | 15d | 2025-01-27 | 2025-02-14 | 1163, 866, 404, 1109, 1115, 1121 |  | 125d |  |
| 1165 | 1.4.1.4.4.10 | **SIT Non-Functional Test Readiness Report** | 48d | 2025-01-21 A | 2025-03-28 |  | 49% | 715d |  |
| 1166 | 1.4.1.4.4.10.1 | **SIT Non-Functional Theme 1 Overarching Test Readiness Report** | 29d | 2025-01-21 A | 2025-02-28 |  | 73% | 734d |  |
| 1167 |  | Develop Overarching SIT Non-Functional Theme 1 Overarching Test Readiness Report | 11d | 2025-01-21 A | 2025-02-04 A | 404 | 100% |  | finish no earlier than 2025-02-04 |
| 1168 |  | SRO review | 5d | 2025-02-05 A | 2025-02-11 A | 1167 | 100% |  | finish no earlier than 2025-02-10 |
| 1169 |  | NFTWG paper day | 0d | 2025-02-11 A | 2025-02-11 A | 1168 | 100% |  | finish no earlier than 2025-02-11 |
| 1170 |  | NFTWG review the Non-Functional Theme 1 Overarching Test Readiness Report | 0d | 2025-02-18 | 2025-02-18 | 1169FS+5d |  | 736d |  |
| 1171 |  | Update Non-Functional Theme 1 Overarching Test Readiness Report following SRO / NFTWG feedback | 6d | 2025-02-19 | 2025-02-26 | 1168, 1170 |  | 736d | finish no earlier than 2025-02-26 |
| 1172 |  | FTIG Recommendation | 0d | 2025-02-21 | 2025-02-21 | 1170FS+3d |  | 739d |  |
| 1173 |  | eSITAG paper day | 0d | 2025-02-26 | 2025-02-26 | 1171 |  | 736d | finish no earlier than 2025-02-21 |
| 1174 |  | eSITAG approve Non-Functional Theme 1 Overarching Test Readiness Report | 0d | 2025-02-28 | 2025-02-28 | 1420 |  | 1d |  |
| 1175 | 1.4.1.4.4.10.2 | **SIT Non-Functional Overarching Test Readiness Report Theme 2 & 3** | 28d | 2025-02-18 A | 2025-03-28 |  | 25% | 715d |  |
| 1176 |  | Develop Overarching SIT Non-Functional Overarching Test Readiness Report Theme 2 & 3 | 11d | 2025-02-18 A | 2025-03-04 |  | 50% | 732d | finish no earlier than 2025-03-04 |
| 1177 |  | SRO review | 5d | 2025-03-05 | 2025-03-11 | 1176SS |  | 57d | start no earlier than 2025-03-05 |
| 1178 |  | NFTWG paper day | 0d | 2025-03-11 | 2025-03-11 | 1177 |  | 57d | finish no earlier than 2025-03-11 |
| 1179 |  | NFTWG review the Non-Functional Overarching Test Readiness Report Theme 2 & 3 | 0d | 2025-03-18 | 2025-03-18 | 1178FS+5d |  | 57d | finish no earlier than 2025-03-18 |
| 1180 |  | Update Non-Functional Overarching Test Readiness Report Theme 2 & 3 following SRO / NFTWG feedback | 6d | 2025-03-19 | 2025-03-26 | 1177, 1179 |  | 57d |  |
| 1181 |  | FTIG Recommendation | 0d | 2025-03-21 | 2025-03-21 | 1179FS+3d |  | 60d |  |
| 1182 |  | eSITAG paper day | 0d | 2025-03-26 | 2025-03-26 | 1180, 1181 |  | 57d | start no earlier than 2025-03-21 |
| 1183 |  | eSITAG approve Non-Functional Overarching Test Readiness Report Theme 2 & 3 | 0d | 2025-03-28 | 2025-03-28 | 1182, 1421FS-1d, 1422 |  | 56d |  |
| 1184 |  | SIT Non-Functional Testing Preparation Complete Theme 1 | 0d | 2025-02-28 | 2025-02-28 | 1420 |  | 734d | start no earlier than 2025-02-28 |
| 1185 |  | SIT Non-Functional Testing Preparation Complete Theme 2 & 3 | 0d | 2025-03-28 | 2025-03-28 | 405FS+5d, 1421, 1422 |  | 714d |  |
| 1186 | 1.4.1.4.5 | **SIT Operational Preparation** | 630d? | 2022-10-31 A | 2025-03-28 |  | 91% | 714d |  |
| 1187 | 1.4.1.4.5.1 | **Test Approach & Plan** | 75d | 2024-02-01 A | 2024-05-15 A |  | 100% |  |  |
| 1188 |  | Develop document with SITWG | 25d | 2024-02-01 A | 2024-03-06 A |  | 100% |  | must start on 2024-02-01 |
| 1189 |  | Draft document review with Code Bodies | 4d | 2024-03-21 A | 2024-03-26 A | 1188FS+10d | 100% |  |  |
| 1190 |  | Industry Consultation | 10d | 2024-03-27 A | 2024-04-09 A | 1189 | 100% |  |  |

| ID | WBS | Task | Duration | Start | Finish | Predecessors | Complete | Constraint |
| --- | --- | --- | --- | --- | --- | --- | --- | --- |
| 1191 |  | Artefact review (via SITAG) and updates | 26d | 2024-04-10 A | 2024-05-15 A | 1190 | 100% |  |
| 1192 |  | SIT Operational Testing Test Approach & Plan approved | 0d | 2024-05-15 A | 2024-05-15 A | 1191 | 100% |  |
| 1193 | 1.4.1.4.5.2 | **Test Data Approach & Plan** | 36d | 2024-03-27 A | 2024-05-15 A |  | 100% |  |
| 1194 |  | Industry Consultation | 10d | 2024-03-27 A | 2024-04-09 A | 1190SS | 100% |  |
| 1195 |  | Artefact review (via SITAG) and updates | 26d | 2024-04-10 A | 2024-05-15 A | 1194 | 100% |  |
| 1196 |  | SIT Operational Testing Test Data Approach & Plan approved | 0d | 2024-05-15 A | 2024-05-15 A | 1195 | 100% |  |
| 1197 | 1.4.1.4.5.3 | **Theme 1 & 2 Test Cases Approved** | 108d | 2024-04-10 A | 2024-09-06 A |  | 100% |  |
| 1198 | 1.4.1.4.5.3.1 | **Theme 1** | 108d | 2024-04-10 A | 2024-09-06 A |  | 100% |  |
| 1199 |  | Develop Test Scenarios & Test Cases | 53d | 2024-04-10 A | 2024-06-21 A | 1190 | 100% |  |
| 1200 |  | Industry Review Workshop | 1d | 2024-06-24 A | 2024-06-24 A | 1199 | 100% |  |
| 1201 |  | Industry Consultation Review | 6d | 2024-07-02 A | 2024-07-09 A | 1200FS+17d | 100% |  |
| 1202 |  | Review with SIT Working Group | 5d | 2024-08-19 A | 2024-08-23 A | 1201FS+16d | 100% |  |
| 1203 |  | SIT Operational Scenarios & Test Cases Approved - Theme 1 | 0d | 2024-09-06 A | 2024-09-06 A | 1202FS+10d | 100% | start no earlier than 2024-09-06 |
| 1204 | 1.4.1.4.5.3.2 | **Theme 2** | 107d | 2024-04-10 A | 2024-09-06 A |  | 100% |  |
| 1205 |  | Develop Test Scenarios & Test Cases | 53d | 2024-04-10 A | 2024-06-21 A | 1190 | 100% | finish no earlier than 2024-06-21 |
| 1206 |  | Industry Review Workshop | 1d | 2024-06-24 A | 2024-06-24 A | 1205 | 100% |  |
| 1207 |  | Industry Consultation Review | 6d | 2024-07-02 A | 2024-07-09 A | 1206FS+7d | 100% |  |
| 1208 |  | Review with SIT Working Group | 5d | 2024-08-19 A | 2024-08-23 A | 1207FS+11d | 100% |  |
| 1209 |  | SIT Operational Scenarios & Test Cases Approved - Theme 2 | 0d | 2024-09-06 A | 2024-09-06 A | 1208FS+10d | 100% |  |
| 1210 | 1.4.1.4.5.4 | **Environments (SIT B)** | 0d | 2024-10-07 A | 2024-10-07 A |  | 100% |  |
| 1211 | 1.4.1.4.5.4.1 | **PP Environments (SIT B)** | 0d | 2024-10-07 A | 2024-10-07 A |  | 100% |  |
| 1212 |  | Deployment of MHHS solution code to SIT B environments | 0d | 2024-10-07 A | 2024-10-07 A | 141 | 100% | start no earlier than 2024-08-27 |
| 1213 | 1.4.1.4.5.4.2 | **SI Environments (SIT B)** | 0d | 2024-10-07 A | 2024-10-07 A |  | 100% |  |
| 1214 |  | Coordinate deployment of MHHS solution code to SIT Participants' SIT B environments | 0d | 2024-10-07 A | 2024-10-07 A | 1212SS | 100% |  |
| 1215 | 1.4.1.4.5.5 | **SIT Operations Manual** | 590d? | 2022-10-31 | 2025-01-31 A |  | 100% |  |
| 1216 | 1.4.1.4.5.5.1 | **Version 1 SIT Operations Manual** | 35d | 2024-10-07 A | 2024-11-22 A |  | 100% |  |
| 1217 |  | Creation of SIT Operations Manual Template | 8d | 2024-10-07 A | 2024-10-16 A |  | 100% | start no earlier than 2024-10-07 |
| 1218 |  | November TORWG Paper Day | 0d | 2024-11-07 A | 2024-11-07 A | 1217FS+16d | 100% |  |
| 1219 |  | November TORWG (Timeline and Next Steps for SIT Operations Manual) | 0d | 2024-11-14 A | 2024-11-14 A | 1218FS+5d | 100% |  |
| 1220 |  | SIT Operations Manual Version 1 Shared with MHHSP | 0d | 2024-11-11 A | 2024-11-11 A | 1217FS+18d | 100% |  |
| 1221 |  | MHHSP provide feedback on SIT Operations Manual Version 1 | 9d | 2024-11-12 A | 2024-11-22 A | 1220 | 100% |  |
| 1222 |  | SIT Operations Manual Version 1 Shared with Programme Participants | 0d | 2024-11-13 A | 2024-11-13 A | 1217FS+20d | 100% |  |
| 1223 |  | PPs provide feedback on SIT Operations Manual Version 1 | 7d | 2024-11-14 A | 2024-11-22 A | 1222 | 100% |  |
| 1224 |  | Programme Participants and MHHSP Feedback and Actions Received (SIT Ops Manual Version 1) | 0d | 2024-11-22 A | 2024-11-22 A | 1223, 1221 | 100% |  |
| 1225 | 1.4.1.4.5.5.2 | **Version 2 SIT Operations Manual** | 27d | 2024-11-12 A | 2024-12-18 A |  | 100% |  |
| 1226 |  | Version 2 SIT Operations Manual (Composition) | 12d | 2024-11-12 A | 2024-11-27 A | 1218FS+2d | 100% |  |
| 1227 |  | Version 2 SIT Operations Manual Completed | 0d | 2024-11-27 A | 2024-11-27 A | 1226 | 100% |  |
| 1228 |  | Version 2 SIT Operations Manual Shared with MHHSP & PPs for TORWG (Consultation Starts) | 0d | 2024-11-27 A | 2024-11-27 A | 1227 | 100% |  |
| 1229 |  | Version 2 SIT Ops Manual - PP Consultation (Iterative Feedback Process) | 10d | 2024-11-28 A | 2024-12-11 A | 1228 | 100% |  |
| 1230 |  | Version 2 SIT Ops Manual - PP Consultation Completed | 0d | 2024-12-11 A | 2024-12-11 A | 1229 | 100% |  |
| 1231 |  | December TORWG Paper Day | 0d | 2024-12-04 A | 2024-12-04 A | 1226FS+5d | 100% |  |
| 1232 |  | December TORWG (Initial Feedback, Common Themes and Comments) | 0d | 2024-12-11 A | 2024-12-11 A | 1231FS+5d | 100% |  |
| 1233 |  | December Extraordinary TORWG Paper Day | 0d | 2024-12-11 A | 2024-12-11 A | 1230 | 100% |  |
| 1234 |  | Publication of key themes from consultation to eTORWG | 2d | 2024-12-12 A | 2024-12-13 A | 1233 | 100% |  |
| 1235 |  | December Extraordinary TORWG (Summary of Version 2 Feedback and Response Approach Shared with PPs) | 0d | 2024-12-18 A | 2024-12-18 A | 1234FS+3d | 100% |  |
| 1236 | 1.4.1.4.5.5.3 | **Version 3 (Final) SIT Operations Manual** | 44d | 2024-11-28 A | 2025-01-28 A |  | 100% |  |
| 1237 |  | Update SIT Operations Manual (Final) Version 3 (with Comments Received From Version 2) [Pre-Christmas Furlough] | 17d | 2024-11-28 A | 2024-12-20 A | 1227, 185FF | 100% |  |
| 1238 |  | Update SIT Operations Manual (Final) Version 3 (with Comments Received From Version 2) [Post-Christmas Furlough] | 5d | 2025-01-02 A | 2025-01-08 A | 1237FS+8d | 100% |  |
| 1239 |  | SIT Operations Manual (Final) Version 3 Completed | 0d | 2025-01-08 A | 2025-01-08 A | 1238 | 100% |  |
| 1240 |  | January TORWG Paper Day | 0d | 2025-01-08 A | 2025-01-08 A | 1239 | 100% |  |
| 1241 |  | January TORWG (SIT Operations Manual Agreement) [Assurance Meeting] | 0d | 2025-01-15 A | 2025-01-15 A | 1240FS+5d | 100% |  |
| 1242 |  | January MCAG Paper Day (Final SIT Operations Manual Submitted) | 0d | 2025-01-21 A | 2025-01-21 A | 1241FS+4d | 100% |  |
| 1243 |  | January MCAG (Final SIT Operations Manual Endorsement) [Advisory Group Sign-off] | 0d | 2025-01-28 A | 2025-01-28 A | 1242FS+5d | 100% |  |
| 1244 | 1.4.1.4.5.5.4 | **Elexon / Helix Service Now Test Prep** | 119d? | 2024-08-01 A | 2025-01-14 A |  | 100% |  |
| 1245 | 1.4.1.4.5.5.4.1 | **Incident Management Build** | 75d? | 2024-08-05 A | 2024-11-15 A |  | 100% |  |
| 1246 |  | Build | 40d | 2024-08-05 A | 2024-09-27 A |  | 100% | finish no earlier than 2024-09-27 |
| 1247 |  | Test | 15d | 2024-09-30 A | 2024-10-18 A | 1246 | 100% | finish no earlier than 2024-10-18 |
| 1248 |  | Deploy | 20d | 2024-10-21 A | 2024-11-15 A | 1247 | 100% | finish no earlier than 2024-11-15 |
| 1249 |  | Incident Management Build & Configuration Complete | 0d | 2024-11-15 A | 2024-11-15 A | 1248 | 100% |  |
| 1250 | 1.4.1.4.5.5.4.2 | **Major Incident Management Build & Configuration** | 0d? | 2024-11-15 | 2024-11-15 |  | 100% |  |
| 1251 |  | Build | 40d | 2024-10-02 A | 2024-11-26 A |  | 100% | finish no earlier than 2024-11-26 |
| 1252 |  | Test | 15d | 2024-11-27 A | 2024-12-17 A | 1251 | 100% | finish no earlier than 2024-12-17 |
| 1253 |  | Deploy | 20d | 2024-12-18 A | 2025-01-14 A | 1252 | 100% | finish no earlier than 2025-01-14 |
| 1254 |  | Major Incident Management Build & Configuration Complete | 0d | 2025-01-14 A | 2025-01-14 A | 1253 | 100% |  |
| 1255 | 1.4.1.4.5.5.4.3 | **Knowledge Management Build & Configuration** | 75d? | 2024-10-02 A | 2025-01-14 A |  | 100% |  |
| 1256 |  | Build | 40d | 2024-10-02 A | 2024-11-26 A |  | 100% | finish no earlier than 2024-11-26 |
| 1257 |  | Test | 15d | 2024-11-27 A | 2024-12-17 A | 1256 | 100% | finish no earlier than 2024-12-17 |
| 1258 |  | Deploy | 20d | 2024-12-18 A | 2025-01-14 A | 1257 | 100% | finish no earlier than 2025-01-14 |
| 1259 |  | Knowledge Management Build & Configuration Complete | 0d | 2025-01-14 A | 2025-01-14 A | 1258 | 100% |  |
| 1260 | 1.4.1.4.5.5.4.4 | **Problem Management Build & Configuration** | 1d? | 2024-08-01 | 2024-08-01 |  | 100% |  |

| ID | WBS | Task | Duration | Start | Finish | Predecessors | Complete | Total float | Constraint |
| --- | --- | --- | --- | --- | --- | --- | --- | --- | --- |
| 1261 |  | Build | 40d | 2024-10-02 A | 2024-11-26 A |  | 100% |  | finish no earlier than 2024-11-26 |
| 1262 |  | Test | 15d | 2024-11-27 A | 2024-12-17 A | 1261 | 100% |  | finish no earlier than 2024-12-17 |
| 1263 |  | Deploy | 20d | 2024-12-18 A | 2025-01-14 A | 1262 | 100% |  | finish no earlier than 2025-01-14 |
| 1264 |  | Problem Management Build & Configuration Complete | 0d | 2025-01-14 A | 2025-01-14 A | 1263 | 100% |  | start no earlier than 2025-01-14 |
| 1265 | 1.4.1.4.5.5.4.5 | **Change Management Build & Configuration** | 75d? | 2024-10-02 A | 2025-01-14 A |  | 100% |  |  |
| 1266 |  | Build | 40d | 2024-10-02 A | 2024-11-26 A |  | 100% |  | finish no earlier than 2024-11-26 |
| 1267 |  | Test | 15d | 2024-11-27 A | 2024-12-17 A | 1266 | 100% |  | finish no earlier than 2024-12-17 |
| 1268 |  | Deploy | 20d | 2024-12-18 A | 2025-01-14 A | 1267 | 100% |  | finish no earlier than 2025-01-14 |
| 1269 |  | Change Management Build & Configuration Complete | 0d | 2025-01-14 A | 2025-01-14 A | 1268 | 100% |  | start no earlier than 2025-01-14 |
| 1270 | 1.4.1.4.5.5.4.6 | **Service Catalogue Management Build & Configuration** | 75d? | 2024-10-02 A | 2025-01-14 A |  | 100% |  |  |
| 1271 |  | Build | 40d | 2024-10-02 A | 2024-11-26 A |  | 100% |  | finish no earlier than 2024-11-26 |
| 1272 |  | Test | 15d | 2024-11-27 A | 2024-12-17 A | 1271 | 100% |  | finish no earlier than 2024-12-17 |
| 1273 |  | Deploy | 20d | 2024-12-18 A | 2025-01-14 A | 1272 | 100% |  | finish no earlier than 2025-01-14 |
| 1274 |  | Service Catalogue Management Build & Configuration Complete | 0d | 2025-01-14 A | 2025-01-14 A | 1273 | 100% |  | start no earlier than 2025-01-14 |
| 1275 |  | ServiceNow SIT Ops Available | 0d? | 2025-01-14 A | 2025-01-14 A | 1249, 1254, 1259, 1264, 1269, 1274 | 100% |  | start no earlier than 2024-09-09 |
| 1276 | 1.4.1.4.5.5.4.8 | **Helix Service Management Documentation (Service Design Pack)** | 115d | 2024-08-01 A | 2025-01-08 A |  | 100% |  |  |
| 1277 |  | Document Drafting | 95d | 2024-08-01 A | 2024-12-11 A |  | 100% |  | finish no earlier than 2024-12-11 |
| 1278 |  | Internal Elexon Review | 3d | 2025-01-06 A | 2025-01-08 A | 1277 | 100% |  | finish no earlier than 2024-12-16 |
| 1279 |  | Elexon Service Panel Sign off | 0d | 2025-01-08 A | 2025-01-08 A | 1278 | 100% |  | start no earlier than 2024-12-20 |
| 1280 | 1.4.1.4.5.5.5 | **Incident Management Support** | 1d? | 2022-10-31 | 2022-10-31 |  | 100% |  |  |
| 1281 |  | Identify Relevant Stakeholders to Support Incident Management Process | 10d | 2024-12-02 A | 2024-12-13 A |  | 100% |  | start no earlier than 2024-12-02 |
| 1282 |  | Schedule Time to Upskill Stakeholders | 5d | 2024-12-16 A | 2024-12-20 A | 1281 | 100% |  |  |
| 1283 |  | Helix Stakeholders Attendance at MHHS Defect Triage Meetings [Meeting Dates to be Confirmed] | 10d | 2025-01-06 A | 2025-01-17 A | 1282FS+10d | 100% |  |  |
| 1284 |  | SIT Service Readiness (Elexon & Helix) Completed | 0d | 2025-01-17 A | 2025-01-17 A | 1283 | 100% |  |  |
| 1285 | 1.4.1.4.5.5.7 | **SIT Service Readiness (External Parties)** | 85d | 2024-10-07 A | 2025-01-31 A |  | 100% |  |  |
| 1286 | 1.4.1.4.5.5.7.1 | **Helix Engagement & Comms** | 71d | 2024-10-07 A | 2025-01-13 A |  | 100% |  |  |
| 1287 |  | Engagement Execution | 71d | 2024-10-07 A | 2025-01-13 A |  | 100% |  | finish no earlier than 2025-01-13 |
| 1288 |  | Information Gathering | 32d | 2024-11-29 A | 2025-01-13 A |  | 100% |  | finish no earlier than 2025-01-13 |
| 1289 |  | SIT Participants Preparation | 9d | 2024-11-28 A | 2024-12-10 A |  | 100% |  | start no earlier than 2024-11-28 |
| 1290 |  | SIT Service Readiness (External Parties) Completed | 0d | 2025-01-31 A | 2025-01-31 A | 1287FS+9d, 1288, 1289, 1307 | 100% |  |  |
| 1291 | 1.4.1.4.5.5.8 | **ServiceNow Support Portal Onboarding (Helix Suppliers & SIT Participants)** | 78d? | 2024-10-02 A | 2025-01-17 |  | 100% |  |  |
| 1292 | 1.4.1.4.5.5.8.1 | **ServiceNow Portal Preparation and Planning** | 40d? | 2024-10-02 A | 2024-11-26 A |  | 100% |  |  |
| 1293 |  | Define Supplier Requirements | 30d? | 2024-10-02 A | 2024-11-12 A |  | 100% |  | start no earlier than 2024-10-02 |
| 1294 |  | Determine Supplier ServiceNow modules | 10d? | 2024-11-13 A | 2024-11-26 A | 1293 | 100% |  | finish no earlier than 2024-11-26 |
| 1295 |  | Review compliance requirements, including data privacy and access limitations. | 10d? | 2024-11-13 A | 2024-11-26 A | 1293 | 100% |  | finish no earlier than 2024-11-26 |
| 1296 |  | Conduct a security assessment to ensure the supplier complies with organisational policies. | 10d? | 2024-11-13 A | 2024-11-26 A | 1293 | 100% |  | finish no earlier than 2024-11-26 |
| 1297 | 1.4.1.4.5.5.8.2 | **ServiceNow Portal System Configuration** | 48d? | 2024-11-27 A | 2025-01-31 A |  | 100% |  |  |
| 1298 |  | Create Supplier User Accounts | 48d | 2024-11-27 A | 2025-01-31 A | 1296 | 100% |  | finish no earlier than 2025-01-31 |
| 1299 |  | Assign appropriate access based on the supplier’s needs and security requirements (e.g., read-only access, submit requests, etc.). | 25d? | 2024-12-30 A | 2025-01-31 A | 1298FF | 100% |  | finish no earlier than 2024-12-24 |
| 1300 |  | Configure Access Controls | 25d? | 2024-12-30 A | 2025-01-31 A | 1299FF | 100% |  | finish no earlier than 2025-01-07 |
| 1301 | 1.4.1.4.5.5.8.3 | **ServiceNow Portal Training and Documentation** | 20d? | 2025-01-06 A | 2025-01-31 A |  | 100% |  |  |
| 1302 |  | Provide Training to the Supplier | 1d | 2025-01-31 A | 2025-01-31 A |  | 100% |  | finish no earlier than 2025-01-31 |
| 1303 |  | Create Supplier Training Documentation | 20d | 2025-01-06 A | 2025-01-31 A |  | 100% |  | finish no earlier than 2025-01-31 |
| 1304 | 1.4.1.4.5.5.8.4 | **ServiceNow Portal Testing and Validation** | 18d | 2025-01-08 | 2025-01-31 A |  | 100% |  |  |
| 1305 |  | Conduct User Acceptance Testing (UAT) | 1d | 2025-01-31 A | 2025-01-31 A | 1302SS | 100% |  | finish no earlier than 2025-01-17 |
| 1306 |  | Validate Access and Security Controls | 4d | 2025-01-28 A | 2025-01-31 A |  | 100% |  | finish no earlier than 2025-01-31 |
| 1307 |  | ServiceNow Support Portal Onboarding (Helix Suppliers& SIT Participants) Completed | 0d | 2025-01-31 A | 2025-01-31 A | 1296, 1300, 1303, 1306, 1302 | 100% |  | start no earlier than 2025-01-17 |
| 1308 |  | Stage 1 - Helix SIT Operational Readiness Completed | 0d | 2025-01-31 A | 2025-01-31 A | 1290, 1275, 1243 | 100% |  | start no earlier than 2025-01-31 |
| 1309 | 1.4.1.4.5.6 | **Theme 3 Test Cases Approved** | 246d? | 2024-04-10 A | 2025-03-19 |  | 93% | 721d |  |
| 1310 | 1.4.1.4.5.6.1 | **Theme 3 (Batch 2)** | 64d | 2024-09-19 A | 2024-12-18 A |  | 100% |  |  |
| 1311 |  | Conclude BCDR Scope with SRO, Code Bodies and DIP Manager | 22d | 2024-09-19 A | 2024-10-18 A |  | 100% |  | start no earlier than 2024-09-19 |
| 1312 |  | Develop BDCR Test Scenarios & Test Cases (Batch 2) | 10d | 2024-10-14 A | 2024-10-25 A | 1311 | 100% |  |  |
| 1313 |  | Develop DIP Test Scenarios and Test Cases (Batch 2) | 27d | 2024-09-19 A | 2024-10-25 A |  | 100% |  | start no earlier than 2024-09-19 |
| 1314 |  | SRO Review | 5d | 2024-10-28 A | 2024-11-01 A | 1313 | 100% |  | start no earlier than 2024-10-28 |
| 1315 |  | Industry Consultation (Batch 2) | 10d | 2024-11-11 A | 2024-11-22 A | 1314 | 100% |  |  |
| 1316 |  | Review Feedback and Update | 4d | 2024-11-25 A | 2024-11-28 A | 1315 | 100% |  |  |
| 1317 |  | SITWG paper day | 0d | 2024-11-28 A | 2024-11-28 A | 1316 | 100% |  |  |
| 1318 |  | Review with SIT WG (Batch 2) | 5d | 2024-11-29 A | 2024-12-05 A | 1317 | 100% |  |  |
| 1319 |  | SITWG endorse Theme 3 (Batch 2) | 0d | 2024-12-05 A | 2024-12-05 A | 1318 | 100% |  |  |
| 1320 |  | SITAG paper day | 0d | 2024-12-11 A | 2024-12-11 A | 1319FS+4d | 100% |  |  |
| 1321 |  | SITAG approve Theme 3 (Batch 2) | 0d | 2024-12-18 A | 2024-12-18 A | 1320FS+5d | 100% |  |  |
| 1322 | 1.4.1.4.5.6.2 | **Theme 3 (Batch 1)** | 181d? | 2024-04-10 A | 2024-12-18 A |  | 100% |  |  |
| 1323 |  | Develop Test Scenarios & Test Cases (Batch 1) | 78d | 2024-04-10 A | 2024-07-26 A | 1190 | 100% |  |  |
| 1324 |  | Conclude Industry Consultation (Batch 1) | 11d | 2024-09-05 A | 2024-09-19 A |  | 100% |  | start no earlier than 2024-09-05 |
| 1325 |  | Review Feedback and Update | 5d | 2024-09-20 A | 2024-09-26 A | 1324 | 100% |  |  |
| 1326 |  | Draft Test Cases from Feedback and LLSD | 15d? | 2024-09-30 A | 2024-10-18 A | 1325FS+1d, 1348 | 100% |  |  |
| 1327 |  | SRO Review | 5d? | 2024-10-21 A | 2024-10-25 A | 1326 | 100% |  |  |
| 1328 |  | Industry Consultation | 10d? | 2024-10-28 A | 2024-11-08 A | 1327 | 100% |  |  |
| 1329 |  | Review Feedback and Update | 10d | 2024-11-11 A | 2024-11-22 A | 1328 | 100% |  |  |
| 1330 |  | SITWG paper day | 0d | 2024-11-28 A | 2024-11-28 A | 1329FS+4d | 100% |  |  |

| ID | WBS | Task | Duration | Start | Finish | Predecessors | Complete | Total float | Constraint |
| --- | --- | --- | --- | --- | --- | --- | --- | --- | --- |
| 1331 |  | Review with SITWG (Batch 1) | 5d | 2024-11-29 A | 2024-12-05 A | 1330 | 100% |  |  |
| 1332 |  | SITWG endorse Theme 3 (Batch 1) | 0d | 2024-12-05 A | 2024-12-05 A | 1331 | 100% |  |  |
| 1333 |  | SITAG paper day | 0d | 2024-12-11 A | 2024-12-11 A | 1332FS+4d | 100% |  |  |
| 1334 |  | SITAG approve Theme 3 (Batch 1) | 0d | 2024-12-18 A | 2024-12-18 A | 1333FS+5d | 100% |  |  |
| 1335 |  | SIT Operational Scenarios & Test Cases Approved - Theme 3 (Batch 1 + 2) | 0d | 2024-12-18 A | 2024-12-18 A | 1348, 1321, 1334 | 100% |  |  |
| 1336 | 1.4.1.4.5.6.3 | **Theme 3 (Batch 2) Supplementary** | 33d | 2025-02-03 A | 2025-03-19 |  | 24% | 721d |  |
| 1337 |  | Conclude DIP Onboarding / Offboarding Scope with DIP Manager | 5d | 2025-02-03 A | 2025-02-07 A |  | 100% |  | start no earlier than 2025-02-03 |
| 1338 |  | Develop DIP Onboarding / Offboarding Test Scenarios & Test Cases (Batch 2) Supplementary | 2d | 2025-02-10 A | 2025-02-11 | 1337 | 25% | 721d |  |
| 1339 |  | SRO Review | 5d | 2025-02-12 | 2025-02-18 | 1338 |  | 721d |  |
| 1340 |  | Industry Consultation (Batch 2) Supplementary | 10d | 2025-02-19 | 2025-03-04 | 1339 |  | 721d |  |
| 1341 |  | SITWG Paper Day | 0d | 2025-02-27 | 2025-02-27 | 1340SS+7d, 1339FS+7d |  | 726d |  |
| 1342 |  | Review Feedback and Update | 1d | 2025-03-05 | 2025-03-05 | 1340 |  | 721d |  |
| 1343 |  | SITWG endorse Theme 3 (Batch 2) Supplementary | 0d | 2025-03-06 | 2025-03-06 | 1340, 1341, 1342FS+1d |  | 721d |  |
| 1344 |  | SITAG paper day | 0d | 2025-03-12 | 2025-03-12 | 1343FS+4d |  | 721d |  |
| 1345 |  | SITAG approve Theme 3 (Batch 2) Supplementary | 0d | 2025-03-19 | 2025-03-19 | 1344FS+5d |  | 721d |  |
| 1346 | 1.4.1.4.5.7 | **Helix SDD and LLSD Development and Approval** | 1d | 2024-09-27 A | 2024-09-30 A |  | 100% |  |  |
| 1347 |  | Development | 0d | 2024-09-27 A | 2024-09-27 A |  | 100% |  | start no earlier than 2024-09-27 |
| 1348 |  | Approval | 0d | 2024-09-30 A | 2024-09-30 A |  | 100% |  | start no earlier than 2024-09-30 |
| 1349 | 1.4.1.4.5.8 | **SIT Operational Programme RTTM (Theme 3 (Batch 1))** | 35d | 2024-12-09 A | 2025-01-24 A |  | 100% |  |  |
| 1350 |  | Develop SIT Operational Theme 3 (Batch 1) RTTM | 25d | 2024-12-09 A | 2025-01-10 A | 1335FF | 100% |  |  |
| 1351 |  | SRO review of SIT Operational Theme 3 (Batch 1) RTTM | 5d | 2025-01-13 A | 2025-01-17 A | 1350 | 100% |  |  |
| 1352 |  | DIP Manager / Code Bodies / Full SRO to review | 5d | 2025-01-20 A | 2025-01-24 A | 1351 | 100% |  |  |
| 1353 |  | DIP Manager / Code Bodies / Full SRO acceptance of Theme 3 (Batch 1) Operational RTTM | 0d | 2025-01-24 A | 2025-01-24 A | 1352 | 100% |  |  |
| 1354 |  | SIT Operational Theme 3 (Batch 1) RTTM Complete | 0d | 2025-01-24 A | 2025-01-24 A | 1350, 1353 | 100% |  |  |
| 1355 | 1.4.1.4.5.9 | **SIT Operational Programme RTTM (Theme 1, 2 & 3 (Batch 2))** | 45d | 2025-01-06 A | 2025-03-07 |  | 50% | 729d |  |
| 1356 |  | Develop SIT Operational (Theme 1, 2 & 3 (Batch 2)) RTTM | 25d | 2025-01-06 A | 2025-02-07 |  | 90% | 729d | start no earlier than 2025-01-06 |
| 1357 |  | SRO review of SIT Operational (Theme 1, 2 & 3 (Batch 2)) RTTM | 5d | 2025-02-10 | 2025-02-14 | 1356 |  | 729d |  |
| 1358 |  | DIP Manager / Code Bodies / Full SRO to review | 5d | 2025-02-17 | 2025-02-21 | 1357 |  | 729d |  |
| 1359 |  | Incorporate feedback | 5d | 2025-02-24 | 2025-02-28 | 1358 |  | 729d |  |
| 1360 |  | Reissued to DIP Manager / Code Bodies / SRO for review | 5d | 2025-03-03 | 2025-03-07 | 1359 |  | 729d |  |
| 1361 |  | DIP Manager / Code Bodies / SRO acceptance of (Theme 1, 2 & 3 (Batch 2)) Operational RTTM | 0d | 2025-03-07 | 2025-03-07 | 1360 |  | 729d |  |
| 1362 |  | SIT Operational (Theme 1, 2 & 3 (Batch 2)) RTTM Complete | 0d | 2025-03-07 | 2025-03-07 | 1361 |  | 729d |  |
| 1363 | 1.4.1.4.5.10 | **SIT Operational Theme 3 (Batch 1) DITL** | 17d | 2025-01-06 A | 2025-01-28 A |  | 100% |  |  |
| 1364 |  | DITL + Familiarisation session development | 8d | 2025-01-06 A | 2025-01-15 A |  | 100% |  | start no earlier than 2025-01-06 |
| 1365 |  | SRO Review | 5d | 2025-01-16 A | 2025-01-22 A | 1364 | 100% |  |  |
| 1366 |  | Post-SRO Review Changes | 2d | 2025-01-23 A | 2025-01-24 A | 1365 | 100% |  |  |
| 1367 |  | Familiarisation session Service Management test case schedule + mapping | 0d | 2025-01-24 A | 2025-01-24 A | 1366 | 100% |  |  |
| 1368 |  | Publish Cycle 3 DITL / Cycle 3 DITL Online Sessions for SIT PPs | 0d | 2025-01-28 A | 2025-01-28 A | 1367FS+2d | 100% |  |  |
| 1369 | 1.4.1.4.5.11 | **SIT Operational Theme 1, 2 & 3 (Batch 2) DITL** | 23d | 2025-02-24 | 2025-03-26 |  |  | 716d |  |
| 1370 |  | DITL + Familiarisation session development | 15d | 2025-02-24 | 2025-03-14 |  |  | 716d | start no earlier than 2025-02-24 |
| 1371 |  | SRO Review | 5d | 2025-03-17 | 2025-03-21 | 1370 |  | 716d |  |
| 1372 |  | Post-SRO Review Changes | 3d | 2025-03-24 | 2025-03-26 | 1371 |  | 716d |  |
| 1373 |  | Familiarisation session Service Management test case schedule + mapping | 0d | 2025-03-26 | 2025-03-26 | 1372 |  | 716d |  |
| 1374 |  | Publish Cycle 3 DITL / Cycle 3 DITL Online Sessions for SIT PPs | 0d | 2025-03-26 | 2025-03-26 | 1373 |  | 716d |  |
| 1375 | 1.4.1.4.5.12 | **SIT Operational Defect Management** | 15d? | 2025-01-06 A | 2025-01-24 A |  | 100% |  |  |
| 1376 |  | Develop defect management approach | 10d? | 2025-01-06 A | 2025-01-17 A |  | 100% |  | start no earlier than 2025-01-06 |
| 1377 |  | Defect management approach agreed | 5d? | 2025-01-20 A | 2025-01-24 A | 1376 | 100% |  |  |
| 1378 | 1.4.1.4.5.13 | **SIT Operational Execution Model** | 43d? | 2024-08-05 | 2024-10-02 |  | 77% |  |  |
| 1379 | 1.4.1.4.5.13.1 | **Theme 3 (Batch 1)** | 27d | 2024-08-05 | 2024-09-10 |  | 100% |  |  |
| 1380 |  | Develop execution model Theme 3 (Batch 1) | 3d | 2024-12-16 A | 2024-12-18 A | 1335FF | 100% |  |  |
| 1381 |  | SRO provide feedback | 14d | 2024-12-19 A | 2025-01-07 A | 1380 | 100% |  |  |
| 1382 |  | Address SRO feedback on execution model | 2d | 2025-01-08 A | 2025-01-09 A | 1381 | 100% |  |  |
| 1383 |  | Finalise execution model | 3d | 2025-01-10 A | 2025-01-14 A | 1382 | 100% |  |  |
| 1384 |  | SITWG paper day | 0d | 2025-01-14 A | 2025-01-14 A | 1383 | 100% |  |  |
| 1385 |  | SITWG update on execution model | 0d | 2025-01-21 A | 2025-01-21 A | 1384FS+5d | 100% |  |  |
| 1386 | 1.4.1.4.5.13.2 | **Theme 1, 2 and 3 (Batch 2)** | 23d | 2024-08-05 | 2024-09-04 |  | 31% |  |  |
| 1387 |  | Develop execution model Theme 1, 2 and 3 (Batch 2) | 10d | 2025-02-03 A | 2025-02-14 | 1335 | 75% | 730d | start no earlier than 2025-02-03 |
| 1388 |  | SRO provide feedback | 5d | 2025-02-17 | 2025-02-21 | 1387 |  | 730d | finish no earlier than 2025-01-21 |
| 1389 |  | Address SRO feedback on execution model | 5d | 2025-02-17 | 2025-02-21 | 1388FF |  | 730d |  |
| 1390 |  | Finalise execution model | 4d | 2025-02-24 | 2025-02-27 | 1389 |  | 730d |  |
| 1391 |  | SITWG paper day | 0d | 2025-02-27 | 2025-02-27 | 1390 |  | 730d |  |
| 1392 |  | SITWG update on execution model | 0d | 2025-03-06 | 2025-03-06 | 1391FS+5d |  | 730d | finish no earlier than 2025-03-06 |
| 1393 | 1.4.1.4.5.13.3 | **SIT Operational Theme 3 (Batch 1) progress reporting** | 29d? | 2024-12-19 A | 2025-01-28 |  | 100% |  |  |
| 1394 |  | Determine reporting methodology | 2d? | 2024-12-19 A | 2024-12-20 A |  | 100% |  |  |
| 1395 |  | Implement reporting | 25d | 2024-12-23 A | 2025-01-24 A | 1394 | 100% |  |  |
| 1396 | 1.4.1.4.5.14 | **SIT Operational Overarching Test Readiness Reports** | 33d? | 2024-08-05 | 2024-09-18 |  | 57% |  |  |
| 1397 | 1.4.1.4.5.14.1 | **SI SIT Operational Theme 3 (Batch 1) Overarching Test Readiness Report** | 31d? | 2024-12-18 A | 2025-01-29 A |  | 100% |  |  |
| 1398 |  | Develop Overarching SIT Operational Theme 3 (Batch 1) Overarching Test Readiness Report | 20d | 2024-12-18 A | 2025-01-14 A | 421FF | 100% |  | finish no earlier than 2025-01-14 |
| 1399 |  | SRO review | 5d | 2025-01-08 A | 2025-01-14 A | 1398FF | 100% |  | finish no earlier than 2025-01-13 |
| 1400 |  | SITWG Paper day | 0d | 2025-01-14 A | 2025-01-14 A | 1399 | 100% |  | finish no earlier than 2025-01-14 |

| ID | WBS | Task | Duration | Start | Finish | Predecessors | Complete | Total float | Constraint |
| --- | --- | --- | --- | --- | --- | --- | --- | --- | --- |
| 1401 |  | SITWG review the Operational Theme 3 (Batch 1) Overarching Test Readiness Report | 0d | 2025-01-21 A | 2025-01-21 A | 1400FS+5d | 100% |  | finish no earlier than 2025-01-21 |
| 1402 |  | Update Operational Theme 3 (Batch 1) Overarching Test Readiness Report following SRO / SITWG feedback | 1d | 2025-01-22 A | 2025-01-22 A | 1401 | 100% |  | start no earlier than 2025-01-22 |
| 1403 |  | SITAG paper day | 0d | 2025-01-22 A | 2025-01-22 A | 1402 | 100% |  | finish no earlier than 2025-01-22 |
| 1404 |  | FTIG recommendation | 0d | 2025-01-24 A | 2025-01-24 A | 1402FS+2d | 100% |  |  |
| 1405 |  | Republish Operational Theme 3 (Batch 1) Overarching Test Readiness Report with latest data and evidence | 1d? | 2025-01-27 A | 2025-01-27 A | 1403FS+2d | 100% |  |  |
| 1406 |  | SITAG approve Theme 3 (Batch 1) Test Readiness Report | 0d | 2025-01-29 A | 2025-01-29 A | 1403FS+5d, 1243, 1405 | 100% |  | finish no earlier than 2025-01-29 |
| 1407 | 1.4.1.4.5.14.2 | **SI SIT Operational Theme 1, 2 and 3 (Batch 2) Overarching Test Readiness Report** | 45d | 2025-01-27 A | 2025-03-28 |  | 26% | 714d |  |
| 1408 |  | Develop Overarching SIT Operational Theme 1, 2 and 3 (Batch 2) Overarching Test Readiness Report | 20d | 2025-01-27 A | 2025-02-21 | 404FS+25d | 50% | 734d | start no earlier than 2025-01-20 |
| 1409 |  | SRO review | 5d | 2025-02-24 | 2025-02-28 | 1408 |  | 734d |  |
| 1410 |  | SITWG Paper day | 0d | 2025-02-27 | 2025-02-27 |  |  | 735d | finish no earlier than 2025-02-27 |
| 1411 |  | SITWG review the Operational Theme 1, 2 and 3 (Batch 2) Overarching Test Readiness Report | 0d | 2025-03-06 | 2025-03-06 | 1410SS+5d |  | 25d |  |
| 1412 |  | Update Operational Theme 1, 2 and 3 (Batch 2) Overarching Test Readiness Report following SRO feedback | 13d | 2025-03-07 | 2025-03-25 | 1411 |  | 717d | start no earlier than 2025-03-07 |
| 1413 |  | FTIG recommendation | 0d | 2025-03-21 | 2025-03-21 | 1411FS+11d |  | 25d |  |
| 1414 |  | eSITAG paper day | 0d | 2025-03-26 | 2025-03-26 | 1412 |  | 716d | finish no earlier than 2025-03-26 |
| 1415 |  | eSITAG approve Operational Theme 1, 2 and 3 (Batch 2) Overarching Test Readiness Report | 0d | 2025-03-28 | 2025-03-28 | 1413, 1423, 1424 |  | 20d |  |
| 1416 |  | SIT Operational Theme 3 (Batch 1) Testing Preparation Complete | 0d | 2025-01-31 A | 2025-01-31 A | 1406, 1307 | 100% |  |  |
| 1417 |  | SIT Operational Theme 1, 2, 3 (Batch 2) Testing Preparation Complete | 0d | 2025-03-28 | 2025-03-28 | 422, 1203, 1209, 1335, 1415 |  | 21d | finish no earlier than 2024-10-04 |
| 1418 | 1.4.1.4.5.17 | **Test Data - Non-Functional and Operational (SIT B)** | 25d? | 2025-02-24 | 2025-03-28 |  |  | 1d |  |
| 1419 | 1.4.1.4.5.17.1 | **Data Load** | 25d? | 2025-02-24 | 2025-03-28 |  |  | 1d |  |
| 1420 |  | Non-Functional Theme 1 (Avenade) Data Load | 5d? | 2025-02-24 | 2025-02-28 | 1585 |  | 1d |  |
| 1421 |  | Non-Functional Theme 2 & 3 (Helix, Avenade & PPs) Data Load | 5d | 2025-03-24 | 2025-03-28 | 1671 |  | 1d |  |
| 1422 |  | Non-Functional Themes 2 & 3 (LDSO's and DCC) Data Load | 15d | 2025-03-03 | 2025-03-21 | 1146 |  | 60d |  |
| 1423 |  | Operational Themes 1, 2 & 3 (Batch 2) (LDSO's and DCC) Data Load | 20d? | 2025-03-03 | 2025-03-28 | 1146 |  | 20d | start no earlier than 2025-01-06 |
| 1424 |  | Operational Themes 1, 2 & 3 (Batch 2) (Helix, Avenade & PPs) Data Load | 5d | 2025-03-24 | 2025-03-28 | 1671 |  | 20d |  |
| 1425 |  | Non-Functional and Operational Test Data Preparation Complete | 0d | 2025-03-28 | 2025-03-28 | 1424 |  | 714d |  |
| 1426 | 1.4.1.4.6 | **Regression Test Preparation** | 2d? | 2024-11-18 A | 2024-11-19 |  | 47% |  |  |
| 1427 | 1.4.1.4.6.1 | **Regression Test Approach** | 10d | 2024-11-18 A | 2024-11-29 |  | 97% |  |  |
| 1428 |  | Develop approach doc | 45d | 2024-11-18 A | 2025-01-17 A |  | 100% |  | start no earlier than 2024-09-16 |
| 1429 |  | SRO / LDP review of approach doc | 5d | 2025-01-20 A | 2025-01-24 A | 1428 | 100% |  |  |
| 1430 |  | Incorporate SRO feedback into approach doc | 5d | 2025-01-20 A | 2025-01-24 A | 1429FF | 100% |  |  |
| 1431 |  | Industry review of approach | 10d | 2025-01-27 A | 2025-02-07 A | 1430 | 100% |  |  |
| 1432 |  | Updates to approach doc on back of industry feedback | 2d | 2025-02-10 A | 2025-02-11 | 1431 | 80% | 11d |  |
| 1433 |  | eSITWG paper day | 0d | 2025-02-11 | 2025-02-11 | 1432 |  | 11d |  |
| 1434 |  | eSITWG Recommendation | 0d | 2025-02-18 | 2025-02-18 | 1433FS+5d |  | 735d | start no earlier than 2025-01-20 |
| 1435 |  | Incorporate eSITWG feedback into approach doc | 2d | 2025-02-19 | 2025-02-20 | 1434 |  | 735d |  |
| 1436 |  | eSITAG paper day | 0d | 2025-02-20 | 2025-02-20 | 1435 |  | 735d |  |
| 1437 |  | eSITAG (inc SRO) Approval | 0d | 2025-02-28 | 2025-02-28 | 1436FS+5d |  | 734d | finish no earlier than 2025-02-28 |
| 1438 |  | SIT Regression Testing Approach and Plan Approval | 0d | 2025-02-28 | 2025-02-28 | 1437 |  | 734d |  |
| 1439 | 1.4.1.4.6.2 | **Regression Test Suite** | 46d | 2025-02-12 | 2025-04-16 |  |  | 11d |  |
| 1440 |  | Build Regression Test Suite | 13d | 2025-02-12 | 2025-02-28 | 1433 |  | 11d |  |
| 1441 |  | SITWG paper day | 1d | 2025-02-27 | 2025-02-27 | 1440SS |  | 12d | start no earlier than 2025-02-27 |
| 1442 |  | SITWG provides feedback on regression suite approach | 0d | 2025-03-06 | 2025-03-06 | 1441FS+5d |  | 12d |  |
| 1443 |  | LDP walkthrough of Regression Test Suite | 1d | 2025-02-28 | 2025-02-28 | 1440FF |  | 734d |  |
| 1444 |  | SRO Review of regression suite doc | 5d | 2025-03-03 | 2025-03-07 | 1440 |  | 11d |  |
| 1445 |  | Incorporate SRO feedback into regression suite doc | 5d | 2025-03-03 | 2025-03-07 | 1444SS, 1442FF |  | 11d |  |
| 1446 |  | Industry review of Regression Test Suite | 10d | 2025-03-10 | 2025-03-21 | 1445 |  | 11d |  |
| 1447 |  | Incorporate Industry feedback into regression suite doc | 4d | 2025-03-24 | 2025-03-27 | 1446 |  | 11d |  |
| 1448 |  | SITWG paper day | 0d | 2025-03-27 | 2025-03-27 | 1447 |  | 11d |  |
| 1449 |  | SITWG endorses regression suite doc | 0d | 2025-04-03 | 2025-04-03 | 1448FS+5d |  | 11d | finish no earlier than 2025-04-03 |
| 1450 |  | Incorporate SITWG feedback into regression suite doc | 1d | 2025-04-04 | 2025-04-04 | 1449 |  | 11d |  |
| 1451 |  | eSITAG paper day | 0d | 2025-04-09 | 2025-04-09 | 1450 |  | 8d | finish no earlier than 2025-04-09 |
| 1452 |  | eSITAG (inc SRO) Approval of regression suite doc | 0d | 2025-04-16 | 2025-04-16 | 1451FS+5d |  | 8d | finish no earlier than 2025-04-16 |
| 1453 |  | SIT Regression Approval | 0d | 2025-04-16 | 2025-04-16 | 1452 |  | 8d |  |
| 1454 | 1.4.1.4.6.3 | **Regression Test Data Load Window (SIT Functional and Migration) - SIT A** | 1d? | 2025-04-28 | 2025-04-29 |  |  |  |  |
| 1455 |  | Data Load preparation activities | 20d | 2025-03-31 | 2025-04-25 | 1421 |  | 1d | start no earlier than 2025-03-17 |
| 1456 |  | Regression Test Data Load Start | 0d | 2025-04-28 | 2025-04-28 | 1652, 1553FS+1d, 1656FS+1d, 1455, 1453 |  | 0d |  |
| 1457 |  | Regression Test Data Load Window | 14d | 2025-04-29 | 2025-05-16 | 1456 |  | 0d | start no earlier than 2025-04-28 |
| 1458 | 1.4.1.4.7 | **Single Instance ADO** | 32d? | 2024-08-21 A | 2024-10-03 |  | 98% | 840d |  |
| 1459 | 1.4.1.4.7.1 | **Single ADO Project for all Cohorts - Implementation and Test Phase** | 30d? | 2024-08-21 A | 2024-10-01 A |  | 100% |  |  |
| 1460 |  | Create test plans and suites in master project | 2d? | 2024-08-21 A | 2024-08-22 A |  | 100% |  | finish no earlier than 2024-08-22 |
| 1461 |  | Create area paths / iterations | 2d? | 2024-08-21 A | 2024-08-22 A |  | 100% |  | finish no earlier than 2024-08-22 |
| 1462 |  | Create IAM roles | 2d? | 2024-08-21 A | 2024-08-22 A |  | 100% |  | finish no earlier than 2024-08-22 |
| 1463 |  | Add users to roles | 1d? | 2024-08-23 A | 2024-08-23 A |  | 100% |  | start no earlier than 2024-08-23 |
| 1464 | 1.4.1.4.7.1.5 | **Testing permissions** | 2d? | 2024-08-27 A | 2024-08-28 A |  | 100% |  |  |
| 1465 |  | Adding tests | 2d? | 2024-08-27 A | 2024-08-28 A |  | 100% |  | finish no earlier than 2024-08-28 |
| 1466 |  | Deleting tests | 2d? | 2024-08-27 A | 2024-08-28 A |  | 100% |  | finish no earlier than 2024-08-28 |
| 1467 |  | Adding tests to incorrect Cohort | 2d? | 2024-08-27 A | 2024-08-28 A |  | 100% |  | finish no earlier than 2024-08-28 |
| 1468 |  | Add / delete defects | 2d? | 2024-08-27 A | 2024-08-28 A |  | 100% |  | finish no earlier than 2024-08-28 |
| 1469 |  | Migrate defects from cohort project to master - Option 2 | 3d | 2024-09-23 A | 2024-09-25 A |  | 100% |  | start no earlier than 2024-09-23 |
| 1470 |  | Testing Permissions - Evidence attachment security | 10d? | 2024-09-18 A | 2024-10-01 A |  | 100% |  | finish no earlier than 2024-10-01 |

| ID | WBS | Task | Duration | Start | Finish | Predecessors | Complete | Total float | Constraint |
| --- | --- | --- | --- | --- | --- | --- | --- | --- | --- |
| 1471 | 1.4.1.4.7.2 | **ADO Dashboard Updates** | 20d? | 2024-09-03 A | 2024-09-30 A |  | 100% |  |  |
| 1472 |  | Update reporting dashboards in ADO | 3d | 2024-09-03 A | 2024-09-05 A |  | 100% |  | start no earlier than 2024-09-03 |
| 1473 |  | Review dashboards with SI LDP leads | 16d | 2024-09-06 A | 2024-09-27 A |  | 100% |  | start no earlier than 2024-09-06 |
| 1474 |  | Review dashboards with SRO | 16d | 2024-09-09 A | 2024-09-30 A |  | 100% |  | start no earlier than 2024-09-09 |
| 1475 |  | Update dashboards following review | 2d | 2024-09-12 A | 2024-09-13 A |  | 100% |  | start no earlier than 2024-09-12 |
| 1476 |  | Document changes to dashboard creation process | 4d | 2024-09-16 A | 2024-09-19 A |  | 100% |  | start no earlier than 2024-09-16 |
| 1477 |  | Update SIT Dashboards for Sprints 4.1 & 4.2 across all Cohorts | 1d? | 2024-09-03 A | 2024-09-03 A |  | 100% |  | start no earlier than 2024-09-03 |
| 1478 | 1.4.1.4.7.3 | **Reporting Changes - PowerBI & QIP** | 23d? | 2024-08-23 A | 2024-09-24 |  | 70% | 847d |  |
| 1479 |  | Design, Create and ETL ADO Entities into PowerBI Data Model | 1d? | 2024-08-23 A | 2024-08-23 A |  | 100% |  | start no earlier than 2024-08-23 |
| 1480 |  | Determine Relationships between ADO Entities & Attributes | 1d? | 2024-08-27 A | 2024-08-27 A |  | 100% |  | start no earlier than 2024-08-27 |
| 1481 |  | Create Relevant Dax Measures | 1d? | 2024-08-28 A | 2024-08-28 A |  | 100% |  | start no earlier than 2024-08-28 |
| 1482 |  | Design & Build Visualisations (Graphs) | 1d? | 2024-08-29 A | 2024-08-29 A |  | 100% |  | start no earlier than 2024-08-29 |
| 1483 |  | Implement Filters | 1d? | 2024-09-23 A | 2024-09-23 A |  | 100% |  | start no earlier than 2024-09-23 |
| 1484 |  | Check Data Quality & Integrity | 1d? | 2024-09-24 A | 2024-09-24 A |  | 100% |  | start no earlier than 2024-09-24 |
| 1485 |  | Performance Optimisation | 1d? | 2024-09-24 A | 2024-09-24 A |  | 100% |  | start no earlier than 2024-09-24 |
| 1486 |  | Publish (QIP) | 1d? | 2024-09-04 | 2024-09-04 |  |  | 861d | start no earlier than 2024-09-04 |
| 1487 |  | Review & UAT | 1d? | 2024-09-05 | 2024-09-05 |  |  | 860d | start no earlier than 2024-09-05 |
| 1488 |  | QIP Training Material & User Guides | 1d? | 2024-09-10 | 2024-09-10 |  |  | 857d | start no earlier than 2024-09-10 |
| 1489 | 1.4.1.4.7.4 | **Reporting Changes - Daily Excel Extract & PDF** | 2d | 2024-09-05 A | 2024-09-06 A |  | 100% |  |  |
| 1490 |  | Excel Daily Report changes (Refer to above) | 2d | 2024-09-05 A | 2024-09-06 A |  | 100% |  | start no earlier than 2024-09-05 |
| 1491 |  | PDF Daily Report changes (Refer to Above) | 2d | 2024-09-05 A | 2024-09-06 A |  | 100% |  | start no earlier than 2024-09-05 |
| 1492 | 1.4.1.4.7.5 | **Documentation Updates** | 23d? | 2024-09-02 A | 2024-10-02 A |  | 100% |  |  |
| 1493 |  | Changes to onboarding process (security) | 10d | 2024-09-02 A | 2024-09-13 A |  | 100% |  | start no earlier than 2024-09-02 |
| 1494 |  | Update the documents on loading tests into ADO? | 10d | 2024-09-02 A | 2024-09-13 A |  | 100% |  | start no earlier than 2024-09-02 |
| 1495 |  | Update ADO Training material | 10d | 2024-09-02 A | 2024-09-13 A |  | 100% |  | start no earlier than 2024-09-02 |
| 1496 |  | Update ADO User Guide | 10d | 2024-09-02 A | 2024-09-13 A |  | 100% |  | start no earlier than 2024-09-02 |
| 1497 |  | Update ADO Configuration document | 10d | 2024-09-02 A | 2024-09-13 A |  | 100% |  | start no earlier than 2024-09-02 |
| 1498 |  | Update ADO Training Material and User Guide following SRO review | 1d? | 2024-10-02 A | 2024-10-02 A |  | 100% |  | start no earlier than 2024-10-02 |
| 1499 | 1.4.1.4.7.6 | **ADO Changes - Review Stage** | 19d? | 2024-09-09 A | 2024-10-03 A |  | 100% |  |  |
| 1500 |  | Review implementation with SI LDP leads | 1d? | 2024-09-27 A | 2024-09-27 A |  | 100% |  | start no earlier than 2024-09-27 |
| 1501 |  | Review implementation with SRO | 1d? | 2024-09-30 A | 2024-09-30 A |  | 100% |  | start no earlier than 2024-09-30 |
| 1502 |  | LDP Review - ADO User Guide, Training Materials | 5d | 2024-09-09 A | 2024-09-13 A |  | 100% |  | start no earlier than 2024-09-09 |
| 1503 |  | SRO Review - ADO User Guide, Training Materials | 1d? | 2024-09-30 A | 2024-09-30 A |  | 100% |  | start no earlier than 2024-09-30 |
| 1504 |  | LDP Review - Config doc | 1d? | 2024-09-30 A | 2024-09-30 A |  | 100% |  | start no earlier than 2024-09-30 |
| 1505 |  | SRO Review - Config doc | 1d? | 2024-09-30 A | 2024-09-30 A |  | 100% |  | start no earlier than 2024-09-30 |
| 1506 |  | SRO Sign-off of all changes | 1d? | 2024-10-03 A | 2024-10-03 A |  | 100% |  | start no earlier than 2024-10-03 |
| 1507 | 1.4.1.4.7.7 | **Azure DevOps Changes - Final Implementation** | 1d? | 2024-10-03 A | 2024-10-03 A |  | 100% |  |  |
| 1508 |  | Final task rollout | 1d? | 2024-10-03 A | 2024-10-03 A |  | 100% |  | start no earlier than 2024-10-03 |
| 1509 |  | ADO Training Drop-in Session ahead of Cycle 3 | 1d? | 2024-10-03 A | 2024-10-03 A |  | 100% |  | start no earlier than 2024-10-03 |
| 1510 | 1.4.2 | **SIT Execution** | 544d? | 2023-10-30 A | 2025-11-27 |  | 43% | 540d |  |
| 1511 |  | System Integration Testing Start (M9) | 0d | 2023-10-30 A | 2023-10-30 A | 704FS+5d, 618 | 100% |  | must start on 2023-10-30 |
| 1512 | 1.4.2.2 | **SIT Component Integration Testing** | 96d | 2023-10-30 A | 2024-03-11 A |  | 100% |  |  |
| 1513 |  | SIT Component Integration Testing Start | 0d | 2023-10-30 A | 2023-10-30 A | 1511 | 100% |  |  |
| 1514 |  | Component Integration Testing Interval 1 Start | 0d | 2023-10-30 A | 2023-10-30 A | 704SS+1d, 625, 629, 633, 114 | 100% |  |  |
| 1515 |  | Component Integration Testing Interval 2 Start | 0d | 2023-11-13 A | 2023-11-13 A | 731SS+5d, 625, 633, 629, 114 | 100% |  |  |
| 1516 |  | Component Integration Testing Interval 3 Start | 0d | 2023-11-27 A | 2023-11-27 A | 763SS+5d, 625, 629, 633, 114 | 100% |  |  |
| 1517 |  | Component Integration Testing Interval 4 Start | 0d | 2023-12-11 A | 2023-12-11 A | 795SS+5d, 625, 629, 633, 114 | 100% |  |  |
| 1518 |  | Component Integration Testing Interval 5 Start | 0d | 2024-01-15 A | 2024-01-15 A | 827SS+5d, 625, 629, 633, 114 | 100% |  |  |
| 1519 |  | Component Integration Testing Interval 6 Start | 0d | 2024-01-29 A | 2024-01-29 A | 625, 629, 633, 859, 114, 671 | 100% |  | must start on 2024-01-29 |
| 1520 |  | SIT Component Integration Testing Execution | 85d | 2023-10-30 A | 2024-02-23 A | 1514SS | 100% |  | must start on 2023-10-30 |
| 1521 |  | SIT Component Integration Testing End (incl. confirmation that PPs have submitted their Test Completion Reports to Programme for assurance) | 0d | 2024-02-23 A | 2024-02-23 A | 1520FF | 100% |  | finish no earlier than 2024-02-23 |
| 1522 |  | Assurance of PPs Test Completion Reports | 30d | 2024-01-22 A | 2024-03-01 A | 1521FF+5d | 100% |  |  |
| 1523 | 1.4.2.2.11 | **SIT CI Test Completion Report** | 18d | 2024-02-07 A | 2024-03-01 A |  | 100% |  |  |
| 1524 |  | Develop document | 13d | 2024-02-07 A | 2024-02-23 A | 1521FF | 100% |  |  |
| 1525 |  | Review & agree document | 5d | 2024-02-26 A | 2024-03-01 A | 1524, 1522FF | 100% |  |  |
| 1526 |  | SIT Component Integration Testing Test Completion Report Approved | 0d | 2024-03-11 A | 2024-03-11 A | 1525FS+6d | 100% |  |  |
| 1527 | 1.4.2.3 | **SIT - Minimum Viable Cohort (MVC)** | 380d? | 2024-03-11 A | 2025-08-22 |  | 45% | 609d |  |
| 1528 | 1.4.2.3.1 | **SIT Functional Testing (MVC)** | 375d? | 2024-03-11 A | 2025-08-15 |  | 55% | 614d |  |
| 1529 |  | SIT Functional Testing Start | 0d | 2024-03-11 A | 2024-03-11 A | 1526, 987FS+5d, 866, 874, 875, 876, 883 | 100% |  |  |
| 1530 | 1.4.2.3.1.2 | **SIT Functional Testing Execution (Minimum Viable Cohort)** | 296d? | 2024-03-11 A | 2025-04-28 |  | 81% | 693d |  |
| 1531 | 1.4.2.3.1.2.1 | **Cycle 1 (Full Cycle)** | 70d | 2024-03-11 A | 2024-06-14 A |  | 100% |  |  |
| 1532 |  | Test Execution | 55d | 2024-03-11 A | 2024-05-24 A | 1529SS-1d, 951 | 100% |  |  |
| 1533 |  | Defect resolution, assurance, review, data & environments maintenance | 15d | 2024-05-27 A | 2024-06-14 A | 1532 | 100% |  |  |
| 1534 | 1.4.2.3.1.2.2 | **Cycle 2 (Defect retests and targeted regression testing)** | 80d | 2024-06-17 A | 2024-10-04 A |  | 100% |  |  |
| 1535 |  | Test Execution | 70d | 2024-06-17 A | 2024-09-20 A | 1533, 956 | 100% |  |  |
| 1536 |  | Defect resolution, assurance, review, data & environments maintenance | 10d | 2024-09-23 A | 2024-10-04 A | 1535 | 100% |  |  |
| 1537 | 1.4.2.3.1.2.3 | **SIT Functional Testing back-up progress risk-assessment** | 7d? | 2024-10-07 A | 2024-10-15 A |  | 100% |  |  |
| 1538 |  | Back-up risk-assessment of SIT Functional progress to assess whether Qualification Execution can start early | 1d? | 2024-10-07 A | 2024-10-07 A | 1536 | 100% |  |  |
| 1539 |  | Back-up SITAG decision on early Qualification Testing Execution start | 1d? | 2024-10-15 A | 2024-10-15 A | 1538FS+5d | 100% |  |  |
| 1540 | 1.4.2.3.1.2.4 | **Cycle 3 (Defect retests and targeted regression testing)** | 105d? | 2024-10-21 A | 2025-03-14 |  | 60% |  |  |

| ID | WBS | Task | Duration | Start | Finish | Predecessors | Complete | Total float | Constraint |
| --- | --- | --- | --- | --- | --- | --- | --- | --- | --- |
| 1541 |  | Sprint 5 | 10d? | 2024-10-21 A | 2024-11-01 A | 140SS-1d | 100% |  |  |
| 1542 |  | Sprint 6 | 10d? | 2024-11-04 A | 2024-11-15 A | 1541 | 100% |  |  |
| 1543 |  | Sprint 7 | 10d? | 2024-11-18 A | 2024-11-29 A | 1542 | 100% |  |  |
| 1544 |  | Sprint 8 | 15d? | 2024-12-02 A | 2024-12-20 A | 1543 | 100% |  |  |
| 1545 |  | Christmas downtime | 10d? | 2024-12-23 A | 2025-01-03 A | 1544 | 100% |  |  |
| 1546 |  | Sprint 9 | 10d? | 2025-01-06 A | 2025-01-17 A | 1545 | 100% |  |  |
| 1547 |  | Sprint 10 | 10d? | 2025-01-20 A | 2025-01-31 A | 1546 | 100% |  |  |
| 1548 |  | Sprint 11 | 10d? | 2025-02-03 A | 2025-02-14 | 1547 | 70% | 0d |  |
| 1549 |  | Sprint 12 | 10d? | 2025-02-17 | 2025-02-28 | 1548 |  | 0d |  |
| 1550 |  | Sprint 13 (RTTM Gap Analysis + CR056) | 10d? | 2025-03-03 | 2025-03-14 | 1549 |  | 0d |  |
| 1551 |  | Sprint 14 (RTTM Gap Analysis + CR056) | 10d? | 2025-03-17 | 2025-03-28 | 1550 |  | 0d |  |
| 1552 |  | Sprint 15 (Contingency 1) | 10d? | 2025-03-31 | 2025-04-11 | 1551 |  | 0d |  |
| 1553 |  | Sprint 16 (Contingency 2) | 10d? | 2025-04-14 | 2025-04-25 | 1552 |  | 0d |  |
| 1554 |  | SIT Functional Cycle 3 Complete | 1d? | 2025-04-28 | 2025-04-28 | 1553 |  | 693d |  |
| 1555 | 1.4.2.3.1.3 | **SIT Scope Traceability** | 38d | 2025-01-27 A | 2025-03-19 |  | 33% | 721d |  |
| 1556 |  | Draft Scope Tracability document | 10d | 2025-01-27 A | 2025-02-07 A |  | 100% |  | start no earlier than 2025-01-27 |
| 1557 |  | LDP review | 2d | 2025-02-10 A | 2025-02-11 A | 1556 | 100% |  |  |
| 1558 |  | SRO review | 5d | 2025-02-12 | 2025-02-18 | 1557 |  | 721d |  |
| 1559 |  | Updates to reflect SRO feedback | 5d | 2025-02-12 | 2025-02-18 | 1558FF |  | 721d |  |
| 1560 |  | Industry Review | 10d | 2025-02-19 | 2025-03-04 | 1559 |  | 732d |  |
| 1561 |  | SITWG paper day | 0d | 2025-02-27 | 2025-02-27 | 1559FS+7d |  | 721d |  |
| 1562 |  | SITWG recommends Scope Tracability document | 0d | 2025-03-06 | 2025-03-06 | 1561FS+5d |  | 721d |  |
| 1563 |  | Update document to reflect industry consultation views | 4d | 2025-03-07 | 2025-03-12 | 1562 |  | 721d |  |
| 1564 |  | SITAG paper day | 0d | 2025-03-12 | 2025-03-12 | 1563 |  | 721d |  |
| 1565 |  | SITAG approve SIT Scope Traceability document | 0d | 2025-03-19 | 2025-03-19 | 1564FS+5d |  | 721d |  |
| 1566 |  | SIT Scope Traceability Approved | 0d | 2025-03-19 | 2025-03-19 | 1565 |  | 721d |  |
| 1567 | 1.4.2.3.1.4 | **SIT Functional Settlement Testing** | 230d? | 2024-06-17 | 2025-05-02 |  | 31% |  |  |
| 1568 |  | SIT-B Settlement Testing Cycle 2 | 70d | 2025-03-10 | 2025-06-13 | 1585FS+10d |  | 659d | start no earlier than 2024-06-17 |
| 1569 | 1.4.2.3.1.4.2 | **SIT-B Settlement Testing Cycle 3** | 100d? | 2024-10-07 A | 2025-02-21 |  | 88% | 1d |  |
| 1570 |  | Sprint 5 | 20d? | 2024-10-07 A | 2024-11-01 A | 1214 | 100% |  |  |
| 1571 |  | Sprint 5 Review (Flexibility Window Checkpoint) | 0d | 2024-11-04 A | 2024-11-04 A | 1570SS+21d | 100% |  |  |
| 1572 |  | Sprint 6 | 10d? | 2024-11-04 A | 2024-11-15 A | 1570 | 100% |  |  |
| 1573 |  | Sprint 6 Review (Pre Christmas Contingency Decision Point) | 0d | 2024-11-18 A | 2024-11-18 A | 1572SS+11d | 100% |  |  |
| 1574 |  | Sprint 7 | 10d? | 2024-11-18 A | 2024-11-29 A | 1572 | 100% |  |  |
| 1575 |  | Sprint 7 Review (Post Christmas Contingency Decision Point) | 0d | 2024-12-02 A | 2024-12-02 A | 1574SS+11d | 100% |  |  |
| 1576 |  | Sprint 8 | 15d | 2024-12-02 A | 2024-12-20 A | 1574 | 100% |  |  |
| 1577 |  | Post-Christmas Stabilisation | 5d | 2025-01-06 A | 2025-01-10 A | 1576FS+10d | 100% |  |  |
| 1578 |  | Sprint 9 | 10d | 2025-01-06 A | 2025-01-17 A | 1576FS+10d | 100% |  |  |
| 1579 |  | Sprint 9 Review | 0d | 2025-01-20 A | 2025-01-20 A | 1578FS+1d | 100% |  |  |
| 1580 |  | Sprint 10 | 10d | 2025-01-20 A | 2025-01-31 A | 1578 | 100% |  |  |
| 1581 |  | Sprint 10 Review | 0d | 2025-02-03 A | 2025-02-03 A | 1580FS+1d | 100% |  |  |
| 1582 |  | Sprint 11 | 10d | 2025-02-03 A | 2025-02-14 | 1580 | 33% | 1d |  |
| 1583 |  | Sprint 11 Review | 0d | 2025-02-14 | 2025-02-14 | 1582 |  | 1d |  |
| 1584 |  | Sprint 12 | 5d | 2025-02-17 | 2025-02-21 | 1583 |  | 1d |  |
| 1585 |  | End of Settlement Testing Cycle 3 | 0d | 2025-02-21 | 2025-02-21 | 1584 |  | 1d |  |
| 1586 |  | SIT-A CoS Settlement Testing | 20d? | 2025-05-19 | 2025-06-13 | 1457 |  | 0d |  |
| 1587 | 1.4.2.3.1.4.4 | **SIT Functional MVC Regression Testing (code freeze)** | 40d? | 2025-06-16 | 2025-08-08 |  |  | 0d |  |
| 1588 |  | Regression Test Execution Start | 1d | 2025-06-16 | 2025-06-16 | 1457, 1586 |  | 658d |  |
| 1589 |  | Regression Sprint 1 | 10d? | 2025-06-16 | 2025-06-27 | 1586, 1451 |  | 0d |  |
| 1590 |  | Regression Sprint 2 | 15d | 2025-06-30 | 2025-07-18 | 1589 |  | 0d |  |
| 1591 |  | Regression Sprint 3 | 15d | 2025-07-21 | 2025-08-08 | 1590 |  | 0d |  |
| 1592 |  | SIT Functional Testing End (Minimum Viable Cohort) (incl. confirmation that PPs have submitted their Test Completion Reports to Programme for assurance) | 0d | 2025-08-08 | 2025-08-08 | 1591 |  | 0d | start no earlier than 2025-03-14 |
| 1593 |  | Assurance of PPs Test Completion Reports | 25d | 2025-07-14 | 2025-08-15 | 1592FF+5d |  | 0d |  |
| 1594 | 1.4.2.3.1.4.7 | **SIT Functional Test Completion Report (Minimum Viable Cohort)** | 20d | 2025-07-21 | 2025-08-15 |  |  | 0d |  |
| 1595 |  | Develop document | 15d | 2025-07-21 | 2025-08-08 | 1592FF |  | 0d |  |
| 1596 |  | Review & agree document | 5d | 2025-08-11 | 2025-08-15 | 1595, 1593FF |  | 0d |  |
| 1597 |  | SIT Functional Testing Test Completion Report (Minimum Viable Cohort) Approved | 0d | 2025-08-15 | 2025-08-15 | 1596FF |  | 0d |  |
| 1598 | 1.4.2.3.2 | **Helix E2E Settlement Assurance Testing (SAT)** | 229d? | 2024-08-19 A | 2025-07-03 |  | 45% | 645d |  |
| 1599 |  | Programme agreement into Settlement Testing | 1d? | 2025-02-07 | 2025-02-07 |  |  | 749d | start no earlier than 2025-02-07 |
| 1600 |  | Helix E2E Settlement Testing Execution | 65d | 2025-03-10 | 2025-06-06 | 1569FS+10d |  | 664d |  |
| 1601 |  | Helix E2E Settlement Testing Execution Complete | 0d | 2025-06-06 | 2025-06-06 | 1600 |  | 664d |  |
| 1602 |  | MHHSP Helix E2E Testing Assurance | 65d | 2025-03-10 | 2025-06-06 | 1569FS+10d |  | 664d |  |
| 1603 |  | MHHSP Helix E2E Testing Assurance Complete | 0d | 2025-06-06 | 2025-06-06 | 1602 |  | 664d |  |
| 1604 | 1.4.2.3.2.6 | **Test design** | 125d | 2024-09-02 A | 2025-02-21 |  | 42% | 739d |  |
| 1605 |  | SAT tests (Review and finalise) | 95d | 2024-09-02 A | 2025-01-10 A |  | 100% |  | start no earlier than 2024-09-02 |
| 1606 |  | Test Automation and Supporting Tools | 80d | 2024-11-04 | 2025-02-21 |  |  | 739d | start no earlier than 2024-11-04 |
| 1607 |  | SAT tests batch 3 | 50d | 2024-12-16 | 2025-02-21 |  |  | 739d | start no earlier than 2024-12-16 |
| 1608 | 1.4.2.3.2.7 | **Data and environment** | 120d? | 2024-08-19 A | 2025-01-31 A |  | 100% |  |  |
| 1609 |  | Data and environment requirements | 55d | 2024-08-19 A | 2024-11-01 A |  | 100% |  | start no earlier than 2024-08-19 |
| 1610 |  | Data sourcing | 95d | 2024-09-02 A | 2025-01-10 A |  | 100% |  | start no earlier than 2024-09-02 |

| ID | WBS | Task | Duration | Start | Finish | Predecessors | Complete | Total float | Constraint |
| --- | --- | --- | --- | --- | --- | --- | --- | --- | --- |
| 1611 |  | Environment data check | 15d? | 2025-01-13 A | 2025-01-31 A | 1610 | 100% |  |  |
| 1612 | 1.4.2.3.2.8 | **Execution** | 169d | 2024-11-11 A | 2025-07-03 |  | 31% | 645d |  |
| 1613 |  | Trial test runs | 50d | 2024-11-11 A | 2025-01-17 A |  | 100% |  | start no earlier than 2024-11-11 |
| 1614 |  | Test planning prioritisation | 14d | 2025-01-20 A | 2025-02-06 A | 1613 | 100% |  |  |
| 1615 |  | Programme agreement to start SAT testing | 0d | 2025-02-06 | 2025-02-06 | 1614 |  | 645d |  |
| 1616 |  | SAT Testing Start | 0d | 2025-02-06 | 2025-02-06 | 1615 |  | 645d |  |
| 1617 |  | SAT first run | 39d | 2025-02-07 | 2025-04-02 | 1616 |  | 645d |  |
| 1618 |  | First run complete | 0d | 2025-04-02 | 2025-04-02 | 1617 |  | 645d |  |
| 1619 |  | SAT test second run | 30d | 2025-04-03 | 2025-05-14 | 1618 |  | 645d |  |
| 1620 |  | Second run complete | 0d | 2025-05-14 | 2025-05-14 | 1619 |  | 645d |  |
| 1621 | 1.4.2.3.2.8.9 | **Contingency test time** | 70d | 2025-03-06 | 2025-06-11 |  |  | 661d |  |
| 1622 |  | Demand Disconnection Event (DDE) | 20d | 2025-05-15 | 2025-06-11 | 1620 |  | 645d |  |
| 1623 |  | Trading Disputes | 20d | 2025-05-15 | 2025-06-11 | 1620 |  | 645d |  |
| 1624 | 1.4.2.3.2.8.9.3 | **NESO** | 70d | 2025-03-06 | 2025-06-11 |  |  | 661d |  |
| 1625 |  | P210 Test files to NESO | 0d | 2025-03-06 | 2025-03-06 |  |  | 731d | start no earlier than 2025-03-06 |
| 1626 |  | NESO | 20d | 2025-05-15 | 2025-06-11 | 1620 |  | 645d |  |
| 1627 |  | Estimated all SAT tests completed | 0d | 2025-06-11 | 2025-06-11 | 1622, 1623, 1626 |  | 645d |  |
| 1628 |  | Test Completion Report Drafting | 11d | 2025-06-12 | 2025-06-26 | 1627 |  | 645d |  |
| 1629 |  | Test Completion Report/Recommendation | 0d | 2025-06-26 | 2025-06-26 | 1628 |  | 645d |  |
| 1630 |  | SAT is signed off by the SAA Value Stream Lead / Head of Product (SAT complete) | 0d | 2025-07-03 | 2025-07-03 | 1629FS+5d |  | 645d |  |
| 1631 | 1.4.2.3.3 | **SIT Migration Testing (MVC)** | 380d? | 2024-03-11 A | 2025-08-22 |  | 64% | 609d |  |
| 1632 |  | SIT Migration Testing Start | 0d? | 2024-03-11 A | 2024-03-11 A |  | 100% |  | start no earlier than 2024-03-11 |
| 1633 | 1.4.2.3.3.2 | **SIT Migration Testing Execution (Minimum Viable Cohort)** | 380d? | 2024-03-11 A | 2025-08-22 |  | 64% | 609d |  |
| 1634 | 1.4.2.3.3.2.1 | **Cycle 1 (Full Cycle)** | 70d? | 2024-03-11 A | 2024-06-14 A |  | 100% |  |  |
| 1635 |  | Test Execution | 55d? | 2024-03-11 A | 2024-05-24 A |  | 100% |  | start no earlier than 2024-03-11 |
| 1636 |  | Defect resolution, assurance, review, data& environments maintenance | 15d? | 2024-05-27 A | 2024-06-14 A |  | 100% |  | finish no earlier than 2024-06-14 |
| 1637 | 1.4.2.3.3.2.2 | **Cycle 2 (Defect retests and targeted regression testing)** | 80d? | 2024-03-11 | 2024-06-28 |  | 100% |  |  |
| 1638 |  | Test Execution | 70d? | 2024-06-17 A | 2024-09-20 A | 1636 | 100% |  | start no earlier than 2024-06-17 |
| 1639 |  | Defect resolution, assurance, review, data & environments maintenance | 10d? | 2024-09-23 A | 2024-10-04 A | 1638 | 100% |  | finish no earlier than 2024-10-04 |
| 1640 | 1.4.2.3.3.2.3 | **SIT Migration Testing back-up progress risk-assessment** | 70d? | 2024-06-17 | 2024-09-20 |  | 100% |  |  |
| 1641 |  | Back-up risk-assessment of SIT Migration progress to assess whether Qualification Execution can start early | 15d? | 2024-10-07 A | 2024-10-25 A | 1639 | 100% |  | finish no earlier than 2024-10-04 |
| 1642 |  | Back-up SITAG decision on early Qualification Testing Execution start | 0d? | 2024-11-01 A | 2024-11-01 A | 1641FS+5d | 100% |  |  |
| 1643 | 1.4.2.3.3.2.4 | **Cycle 3 (Defect retests and targeted regression testing)** | 135d? | 2024-10-21 A | 2025-04-25 |  | 61% | 694d |  |
| 1644 |  | Sprint 5 | 10d | 2024-10-21 A | 2024-11-01 A | 140FS-1d | 100% |  | start no earlier than 2024-10-21 |
| 1645 |  | Sprint 6 | 10d | 2024-11-04 A | 2024-11-15 A | 1644 | 100% |  | start no earlier than 2024-11-04 |
| 1646 |  | Sprint 7 | 10d | 2024-11-18 A | 2024-11-29 A | 1645 | 100% |  |  |
| 1647 |  | Sprint 8 | 15d | 2024-12-02 A | 2024-12-20 A | 1646 | 100% |  | finish no earlier than 2024-11-15 |
| 1648 |  | Christmas downtime | 10d | 2024-12-23 A | 2025-01-03 A | 1647 | 100% |  | finish no earlier than 2024-11-29 |
| 1649 |  | Sprint 9 | 10d | 2025-01-06 A | 2025-01-17 A | 1648 | 100% |  | finish no earlier than 2024-12-20 |
| 1650 |  | Sprint 10 | 10d | 2025-01-20 A | 2025-01-31 A | 1649 | 100% |  | finish no earlier than 2025-01-03 |
| 1651 |  | Sprint 11 | 10d | 2025-02-03 A | 2025-02-14 | 1650 | 70% | 0d | finish no earlier than 2025-01-17 |
| 1652 |  | Sprint 12 | 10d | 2025-02-17 | 2025-02-28 | 1651 |  | 0d | finish no earlier than 2025-01-31 |
| 1653 |  | Sprint 13 | 10d | 2025-03-03 | 2025-03-14 | 1652 |  | 0d |  |
| 1654 |  | Sprint 14 (RTTM Gap Analysis + CR056) | 10d? | 2025-03-17 | 2025-03-28 | 1653 |  | 0d |  |
| 1655 |  | Sprint 15 (Contingency 1) | 10d? | 2025-03-31 | 2025-04-11 | 1654 |  | 0d |  |
| 1656 |  | Sprint 16 (Contingency 2) | 10d? | 2025-04-14 | 2025-04-25 | 1655 |  | 0d |  |
| 1657 |  | SIT Migration Cycle 3 Complete | 0d | 2025-04-25 | 2025-04-25 | 1656 |  | 694d |  |
| 1658 | 1.4.2.3.3.2.5 | **SIT Migration MVC Regression Testing (code freeze)** | 35d? | 2025-06-16 | 2025-08-01 |  |  | 609d |  |
| 1659 |  | Regression Sprint 1 | 10d? | 2025-06-16 | 2025-06-27 | 1586 |  | 609d |  |
| 1660 |  | Regression Sprint 2 | 10d? | 2025-06-30 | 2025-07-11 | 1659 |  | 609d |  |
| 1661 |  | Regression Sprint 3 | 15d? | 2025-07-14 | 2025-08-01 | 1660 |  | 609d |  |
| 1662 |  | SIT Migration Testing End (Minimum Viable Cohort) (incl. confirmation that PPs have submitted their Test Completion Reports to Programme for assurance) | 0d | 2025-08-01 | 2025-08-01 | 1661 |  | 609d | start no earlier than 2025-06-20 |
| 1663 | 1.4.2.3.3.2.6 | **SIT Migration Test Completion Report (Minimum Viable Cohort)** | 25d | 2025-07-14 | 2025-08-15 | 1091, 994, 998, 1005, 1011, 1017 |  | 609d |  |
| 1664 |  | Develop document | 15d | 2025-07-14 | 2025-08-01 | 1662FF |  | 609d |  |
| 1665 |  | Review & agree document | 5d | 2025-08-04 | 2025-08-08 | 1664 |  | 609d |  |
| 1666 |  | SIT Migration Testing Test Completion Report (Minimum Viable Cohort) Approved | 0d | 2025-08-15 | 2025-08-15 | 1665FS+5d |  | 609d |  |
| 1667 |  | SIT Migration Testing End (Minimum Viable Cohort) (incl. confirmation that PPs have submitted their Test Completion Reports to Programme for assurance) | 0d | 2025-08-15 | 2025-08-15 | 1664FF, 1666 |  | 609d | start no earlier than 2025-03-14 |
| 1668 |  | Assurance of PPs Test Completion Reports | 30d | 2025-07-14 | 2025-08-22 | 1667FF+5d |  | 609d |  |
| 1669 | 1.4.2.3.4 | **SIT Non-Functional Testing (all SIT PPs)** | 69d? | 2025-03-03 | 2025-06-05 |  |  | 1d |  |
| 1670 |  | Theme 1 (Helix and DIP Volume Testing) Start | 0d? | 2025-03-03 | 2025-03-03 | 1174FS+1d, 1420 |  | 1d | finish no earlier than 2025-01-13 |
| 1671 |  | Theme 1 (Helix and DIP Volume Testing) Execution | 15d? | 2025-03-03 | 2025-03-21 | 1670FS-1d |  | 1d | start no earlier than 2025-01-13 |
| 1672 |  | Theme 2 SIT Non-Functional Testing Start | 0d | 2025-03-28 | 2025-03-28 | 1535, 1098, 1102, 1109, 1115, 1121, 1585, 1183FS+1d, 1422, 1164 |  | 95d |  |
| 1673 |  | Theme 2 SIT Non-Functional Testing Execution | 40d | 2025-03-28 | 2025-05-22 | 1672SS-1d |  | 56d |  |
| 1674 |  | Theme 3 SIT Non-Functional Testing Start | 1d? | 2025-03-28 | 2025-03-28 | 1183, 1422 |  | 56d |  |
| 1675 |  | Theme 3 SIT Non-Functional Testing Execution | 40d? | 2025-03-28 | 2025-05-22 | 1674SS |  | 56d |  |
| 1676 |  | SIT Non-Functional Testing End (all SIT PPs) (incl. confirmation that PPs have submitted their Test Completion Reports to Programme for assurance) | 0d | 2025-05-23 | 2025-05-23 | 1673FF, 1675FF |  | 56d | start no earlier than 2025-05-23 |
| 1677 |  | Assurance of PPs Test Completion Reports | 20d | 2025-05-02 | 2025-05-29 | 1676FF+5d |  | 56d |  |
| 1678 | 1.4.2.3.4.9 | **SIT Non-Functional Testing Test Completion Report (all SIT PPs)** | 20d | 2025-05-02 | 2025-05-29 |  |  | 56d |  |
| 1679 |  | Develop document | 15d | 2025-05-02 | 2025-05-23 | 1676FF |  | 56d |  |
| 1680 |  | Review & agree document | 5d | 2025-05-23 | 2025-05-29 | 1679, 1677FF |  | 56d |  |

| ID | WBS | Task | Duration | Start | Finish | Predecessors | Complete | Total float | Constraint |
| --- | --- | --- | --- | --- | --- | --- | --- | --- | --- |
| 1681 |  | SIT Non-Functional Testing Test Completion Report (all SIT PPs) Approved | 0d | 2025-06-05 | 2025-06-05 | 1680FF+5d |  | 56d |  |
| 1682 | 1.4.2.3.5 | **SIT Operational Testing (all SIT PPs)** | 125d? | 2025-02-03 A | 2025-07-25 |  | 3% | 20d |  |
| 1683 | 1.4.2.3.5.1 | **Non-SIT B Testing** | 25d? | 2025-02-03 A | 2025-03-07 |  | 15% | 110d |  |
| 1684 |  | SIT Operational Testing Start (Theme 3 - Batch 1 (Service Management)) | 0d? | 2025-02-03 A | 2025-02-03 A | 1335, 1275, 1276 | 100% |  | start no earlier than 2025-02-03 |
| 1685 |  | SIT Operational Testing Execution Window (Theme 3 - Batch 1 (Service Management)) | 25d? | 2025-02-03 A | 2025-03-07 | 1684 | 15% | 110d | start no earlier than 2025-01-06 |
| 1686 | 1.4.2.3.5.2 | **SIT B Testing** | 70d? | 2025-03-31 | 2025-07-04 |  |  | 20d |  |
| 1687 |  | SIT Operational Testing Start (SIT B) | 0d | 2025-03-31 | 2025-03-31 | 1417, 1192, 1196, 1203, 1209, 1335, 1415FS+1d, 1423, 1424 |  | 20d |  |
| 1688 |  | SIT Operational Testing Execution Theme 3 Batch 2 | 25d? | 2025-03-31 | 2025-05-02 | 1687FS-1d, 1321 |  | 20d |  |
| 1689 |  | SIT Operational Testing Execution Theme 1 | 25d? | 2025-05-05 | 2025-06-06 | 1688 |  | 20d |  |
| 1690 |  | SIT Operational Testing Execution Theme 2 | 20d? | 2025-06-09 | 2025-07-04 | 1689 |  | 20d |  |
| 1691 |  | SIT Operational Testing End (all SIT PPs) (incl. confirmation that PPs have submitted their Test Completion Reports to Programme for assurance) | 0d | 2025-07-11 | 2025-07-11 | 1690FS+5d, 1685 |  | 20d |  |
| 1692 |  | Assurance of PPs Test Completion Reports | 30d | 2025-06-09 | 2025-07-18 | 1691FF+5d |  | 20d |  |
| 1693 | 1.4.2.3.5.5 | **SIT Operational Testing Test Completion Report (all SIT PPs)** | 20d | 2025-06-23 | 2025-07-18 |  |  | 20d |  |
| 1694 |  | Develop document | 15d | 2025-06-23 | 2025-07-11 | 1691FF |  | 20d |  |
| 1695 |  | Review & agree document | 5d | 2025-07-14 | 2025-07-18 | 1694, 1692FF |  | 20d |  |
| 1696 |  | SIT Operational Testing Test Completion Report (all SIT PPs) Approved | 0d | 2025-07-25 | 2025-07-25 | 1695FF+5d |  | 20d |  |
| 1697 | 1.4.2.3.6 | **SIT MVC Test Exit Report** | 20d | 2025-07-21 | 2025-08-15 |  |  | 614d |  |
| 1698 |  | Develop document | 15d | 2025-07-21 | 2025-08-08 | 1595FF |  | 614d |  |
| 1699 |  | Review & agree document | 5d | 2025-08-11 | 2025-08-15 | 1698 |  | 614d |  |
| 1700 |  | SIT Minimum Viable Cohort Complete (SIT Minimum Viable Cohort Test Exit Report Approved) | 0d | 2025-08-22 | 2025-08-22 | 1526, 1597FS+5d, 1681, 1696 |  | 0d |  |
| 1701 | 1.4.2.4 | **SIT (non-MVC)** | 119d? | 2025-06-16 | 2025-11-27 |  |  | 0d |  |
| 1702 | 1.4.2.4.1 | **SIT Functional Testing (non-MVC)** | 110d? | 2025-06-16 | 2025-11-14 |  |  | 0d |  |
| 1703 | 1.4.2.4.1.1 | **SIT Functional Testing Execution (non-MVC)** | 95d? | 2025-06-16 | 2025-10-24 |  |  | 0d |  |
| 1704 |  | Test Execution (Cycle 3 Completion and Regression Testing) | 95d? | 2025-06-16 | 2025-10-24 | 1586 |  | 0d |  |
| 1705 |  | SIT Functional Testing End (non-MVC) (incl. confirmation that PPs have submitted their Test Completion Reports to Programme for assurance) | 0d | 2025-10-24 | 2025-10-24 | 1704FF |  | 0d |  |
| 1706 |  | Assurance of PPs Test Completion Reports | 5d | 2025-11-03 | 2025-11-07 | 1705FS+5d |  | 0d |  |
| 1707 | 1.4.2.4.1.3 | **SIT Functional Testing Test Completion Report (non-MVC)** | 25d | 2025-10-06 | 2025-11-07 |  |  | 0d |  |
| 1708 |  | Develop document | 15d | 2025-10-06 | 2025-10-24 | 1705FF |  | 5d |  |
| 1709 |  | Review & agree document | 5d | 2025-11-03 | 2025-11-07 | 1708, 1706FF |  | 0d |  |
| 1710 |  | SIT Functional Testing Test Completion Report (non-MVC) Approved | 0d | 2025-11-14 | 2025-11-14 | 1709FF+5d |  | 0d |  |
| 1711 | 1.4.2.4.2 | **SIT Migration Testing (non-MVC)** | 110d | 2025-06-16 | 2025-11-14 |  |  | 0d |  |
| 1712 |  | Test Execution (Cycle 3 Completion and Regression Testing) | 95d | 2025-06-16 | 2025-10-24 | 1586 |  | 0d |  |
| 1713 |  | SIT Migration Testing End (non-MVC) (incl. confirmation that PPs have submitted their Test Completion Reports to Programme for assurance) | 0d | 2025-10-24 | 2025-10-24 | 1712FF |  | 0d |  |
| 1714 |  | Assurance of PPs Test Completion Reports | 5d | 2025-11-03 | 2025-11-07 | 1713FS+5d |  | 0d |  |
| 1715 | 1.4.2.4.2.4 | **SIT Migration Testing Test Completion Report (non-MVC)** | 25d | 2025-10-06 | 2025-11-07 |  |  | 0d |  |
| 1716 |  | Develop document | 15d | 2025-10-06 | 2025-10-24 | 1713FF |  | 5d |  |
| 1717 |  | Review & agree document | 5d | 2025-11-03 | 2025-11-07 | 1716, 1714FF |  | 0d |  |
| 1718 |  | SIT Migration Testing Test Completion Report (non-MVC Approved) | 0d | 2025-11-14 | 2025-11-14 | 1717FF+5d |  | 0d |  |
| 1719 | 1.4.2.4.3 | **SIT non-MVC Test Exit Report** | 20d | 2025-10-27 | 2025-11-21 |  |  | 0d |  |
| 1720 |  | Develop document | 15d | 2025-10-27 | 2025-11-14 | 1710FF, 1718FF |  | 0d |  |
| 1721 |  | Review & agree document | 5d | 2025-11-17 | 2025-11-21 | 1720 |  | 0d |  |
| 1722 |  | SIT non-MVC Complete | 0d | 2025-11-27 | 2025-11-27 | 1721FS+4d, 1710, 1718 |  | 0d |  |
| 1723 | 1.4.3 | **UIT Environment Preparation** | 680d? | 2022-10-31 A | 2025-06-06 |  | 51% | 664d |  |
| 1724 | 1.4.3.1 | **Test Artefact Development** | 556d? | 2023-03-01 A | 2025-04-16 |  | 51% | 701d |  |
| 1725 | 1.4.3.1.1 | **E2E Sandbox Guidance** | 539d? | 2023-03-01 A | 2025-03-24 |  | 71% | 718d |  |
| 1726 |  | Develop document | 83d | 2023-03-01 A | 2023-06-23 A |  | 100% |  | start no earlier than 2023-03-01 |
| 1727 |  | Artefact review (via SITAG) and updates | 25d | 2023-06-26 A | 2023-07-28 A | 1726 | 100% |  |  |
| 1728 |  | E2E Sandbox Guidance approved | 0d | 2024-07-18 A | 2024-07-18 A | 1727FF+5d | 100% |  | start no earlier than 2024-07-18 |
| 1729 |  | Update E2E Sandbox guidance to reflect CR55 | 29d | 2025-01-13 | 2025-02-20 |  |  | 718d | start no earlier than 2025-01-13 |
| 1730 |  | Internal SI review | 5d | 2025-02-21 | 2025-02-27 | 1729 |  | 718d |  |
| 1731 |  | SRO / Code Bodies review | 5d | 2025-02-28 | 2025-03-06 | 1730 |  | 718d |  |
| 1732 |  | Submit version to QWG | 3d | 2025-03-07 | 2025-03-11 | 1731 |  | 718d |  |
| 1733 |  | Artefact Approval (via QWG) | 0d | 2025-03-11 | 2025-03-11 | 1732 |  | 718d |  |
| 1734 |  | Final Document updates post QWG review | 1d | 2025-03-13 | 2025-03-13 | 1733FS+1d |  | 718d |  |
| 1735 |  | Submit final version to QAG | 1d? | 2025-03-17 | 2025-03-17 | 1734FS+1d |  | 718d |  |
| 1736 |  | E2E Sandbox guidance update approved | 1d? | 2025-03-24 | 2025-03-24 | 1735FS+4d |  | 718d |  |
| 1737 | 1.4.3.1.2 | **E2E Sandbox Test Data Approach & Plan** | 68d | 2025-01-13 | 2025-04-16 |  |  | 701d |  |
| 1738 |  | Develop document | 27d | 2025-01-13 | 2025-02-18 | 1726SS+199d |  | 701d | start no earlier than 2025-01-13 |
| 1739 |  | Internal SI review and updates | 5d | 2025-02-19 | 2025-02-25 | 1738 |  | 701d |  |
| 1740 |  | SRO / Code Bodies review | 5d | 2025-02-26 | 2025-03-04 | 1739 |  | 701d |  |
| 1741 |  | Submit proposed version to QWG | 0d | 2025-03-04 | 2025-03-04 | 1740 |  | 701d |  |
| 1742 |  | Discuss document at QWG | 0d | 2025-03-11 | 2025-03-11 | 1741FS+5d |  | 701d |  |
| 1743 |  | Final updates prior to consultation | 4d | 2025-03-12 | 2025-03-17 | 1742 |  | 701d |  |
| 1744 |  | Industry Consultation for E2E Sandbox Test Data Approach and Plan document | 10d | 2025-03-18 | 2025-03-31 | 1743 |  | 701d |  |
| 1745 |  | Document updates post Industry Consultation | 3d | 2025-04-01 | 2025-04-03 | 1744 |  | 701d | finish no earlier than 2024-04-22 |
| 1746 |  | Submit Proposed Version to QWG | 3d | 2025-04-04 | 2025-04-08 | 1745 |  | 701d |  |
| 1747 |  | Artefact Approval (via QWG) | 0d | 2025-04-08 | 2025-04-08 | 1746 |  | 701d |  |
| 1748 |  | Final Document updates post QWG review | 0d | 2025-04-09 | 2025-04-09 | 1747FS+1d |  | 701d | start no earlier than 2024-05-01 |
| 1749 |  | Submit final version to QAG | 0d | 2025-04-10 | 2025-04-10 | 1748FS+1d |  | 701d | start no earlier than 2024-05-02 |
| 1750 |  | E2E Sandbox Test Data Approach and Plan | 0d | 2025-04-16 | 2025-04-16 | 1749FS+4d |  | 701d | start no earlier than 2024-05-09 |

| ID | WBS | Task | Duration | Start | Finish | Predecessors | Complete | Total float | Constraint |
| --- | --- | --- | --- | --- | --- | --- | --- | --- | --- |
| 1751 | 1.4.3.2 | **UIT Stub Specification and Delivery** | 260d | 2023-12-04 A | 2024-11-29 A |  | 100% |  |  |
| 1752 | 1.4.3.2.1 | **Qualification Test Stubs** | 260d | 2023-12-04 A | 2024-11-29 A |  | 100% |  |  |
| 1753 |  | Specify | 44d | 2023-12-04 A | 2024-02-01 A | 545FS+13d | 100% |  |  |
| 1754 |  | Build & Test | 141d | 2024-02-02 A | 2024-08-16 A | 1753 | 100% |  |  |
| 1755 |  | Prepare for release | 75d | 2024-08-19 A | 2024-11-29 A | 1754 | 100% |  |  |
| 1756 |  | Non-SIT LDSO Test Harness Released | 0d | 2024-11-29 A | 2024-11-29 A | 1755 | 100% |  |  |
| 1757 | 1.4.3.3 | **Environments (UIT)** | 680d | 2022-10-31 A | 2025-06-06 |  | 50% | 664d |  |
| 1758 | 1.4.3.3.1 | **Central Party (Avanade) Environments (UIT)** | 488d | 2022-11-16 A | 2024-09-27 A |  | 100% |  |  |
| 1759 |  | Central Party (Avandae) environment preparation (incl. security certificates and security compliance) | 447d | 2022-11-16 A | 2024-08-01 A | 541 | 100% |  |  |
| 1760 |  | Submit self-declaration of environment preparation complete (incl. security certificates and security compliance) to Programme for assurance | 447d | 2022-11-16 A | 2024-08-01 A | 1759SS | 100% |  |  |
| 1761 |  | Central Party (Avanade) UIT environment connectivity proving | 25d | 2024-08-26 A | 2024-09-27 A | 1773 | 100% |  |  |
| 1762 |  | Deployment of MHHS solution code to UIT environments | 2d | 2024-07-29 A | 2024-07-30 A |  | 100% |  | start no earlier than 2024-07-29 |
| 1763 |  | Central Party (Avanade) UIT environment Regression Testing | 1d | 2024-07-31 A | 2024-07-31 A | 1762 | 100% |  |  |
| 1764 | 1.4.3.3.2 | **E2E Sandbox Participants (UIT)** | 680d | 2022-10-31 | 2025-06-06 |  |  | 0d |  |
| 1765 |  | E2E Sandbox Participants environment preparation (incl. security certificates and security compliance) | 660d | 2022-10-31 | 2025-05-09 |  |  | 0d | must finish on 2025-05-09 |
| 1766 |  | Submit self-declaration of environment preparation complete (incl. security certificates and security compliance) to Programme for assurance | 660d | 2022-10-31 | 2025-05-09 |  |  | 664d |  |
| 1767 |  | E2E Sandbox Participants UIT environment connectivity proving | 20d | 2025-05-12 | 2025-06-06 | 1766 |  | 664d |  |
| 1768 |  | Deployment of MHHS solution code to UIT environments | 10d | 2025-05-26 | 2025-06-06 | 1767FF |  | 664d |  |
| 1769 |  | Coordinate E2E Sandbox Participants' UIT environment preparation (for E2E Sandbox Testing Start) | 463d | 2022-10-31 | 2024-08-07 | 1765SS |  | 881d |  |
| 1770 | 1.4.3.3.3 | **SI Environments (UIT)** | 489d | 2022-11-16 A | 2024-09-30 |  | 99% | 843d |  |
| 1771 |  | Coordinate Central Parties' UIT environment preparation | 447d | 2022-11-16 A | 2024-08-01 A | 1759SS | 100% |  |  |
| 1772 |  | Assure Central Parties' self-declaration of environment preparation complete (incl. security certificates and security compliance) | 463d | 2022-11-16 A | 2024-08-23 | 1760SS | 97% | 869d |  |
| 1773 |  | Central Parties' UIT environments ready to start connectivity proving (incl. certificates and security compliance) | 0d | 2024-08-23 A | 2024-08-23 A | 1756 | 100% |  |  |
| 1774 |  | Coordinate Central Parties' UIT environment connectivity proving | 26d | 2024-08-26 A | 2024-09-30 A | 1761SS | 100% |  |  |
| 1775 |  | Coordinate deployment of MHHS solution code to Central Parties' UIT environments | 2d | 2024-07-29 A | 2024-07-30 A | 1762SS | 100% |  |  |
| 1776 |  | Coordinate Central Parties' UIT environment Regression Testing | 1d | 2024-07-31 | 2024-07-31 | 1775 |  | 886d |  |
| 1777 | 1.4.3.4 | **Test Data** | 30d | 2024-08-26 | 2024-10-04 |  |  | 819d |  |
| 1778 | 1.4.3.4.1 | **Central Parties (for E2E Sandbox & Qualification)** | 30d | 2024-08-26 | 2024-10-04 |  |  | 819d |  |
| 1779 |  | Central Parties' UIT environment test data loading & verification (& data cleansing, if required) | 30d | 2024-08-26 | 2024-10-04 |  |  | 819d | start no earlier than 2024-08-26 |
| 1780 |  | Submit self-declaration to Programme to confirm loading & verification of test data | 30d | 2024-08-26 | 2024-10-04 | 1779SS |  | 819d |  |
| 1781 | 1.4.3.4.2 | **E2E Sandbox Participants** | 30d | 2024-08-26 | 2024-10-04 |  |  | 839d |  |
| 1782 |  | UIT environment test data loading and verification (and data cleansing, if required) (for E2E Sandbox Testing Start) | 30d | 2024-08-26 | 2024-10-04 | 1779FF |  | 839d |  |
| 1783 | 1.4.3.4.3 | **SI Test Data** | 30d | 2024-08-26 | 2024-10-04 |  |  | 839d |  |
| 1784 |  | Coordinate Central Parties' UIT environment test data loading and verification (and data cleansing, if required) | 30d | 2024-08-26 | 2024-10-04 | 1779SS |  | 839d |  |
| 1785 |  | Assure evidence of Central Parties' UIT environment test data load and verification | 30d | 2024-08-26 | 2024-10-04 | 1780SS |  | 839d |  |
| 1786 |  | Coordinate E2E Sandbox Participants' UIT environment test data loading and verification (and data cleansing, if required) (for E2E Sandbox Testing Start) | 30d | 2024-08-26 | 2024-10-04 | 1782SS |  | 839d |  |
| 1787 | 1.4.3.5 | **Other Preparation** | 496d | 2022-10-31 A | 2024-09-23 |  | 59% | 848d |  |
| 1788 | 1.4.3.5.1 | **SI Other Preparation** | 66d | 2022-10-31 | 2023-01-30 |  |  | 1278d |  |
| 1789 |  | Onboarding of UIT E2E Sandbox Participants to Test Management Tool for E2E Sandbox Testing Start (onboarding of participants will be ongoing hereafter) | 66d | 2022-10-31 | 2023-01-30 |  |  | 1278d |  |
| 1790 | 1.4.3.5.2 | **Other Preparation (for Central Parties & E2E Sandbox Participants)** | 484d | 2022-11-16 A | 2024-09-23 |  | 67% | 848d |  |
| 1791 |  | Test Management Tool onboarding for E2E Sandbox Testing Start (onboarding will be ongoing hereafter) | 66d | 2024-05-02 | 2024-08-01 | 1789SS |  | 885d | start no earlier than 2024-05-02 |
| 1792 |  | Other Preparation (incl. test execution planning) | 484d | 2022-11-16 A | 2024-09-23 | 1759SS, 1765SS | 76% | 848d |  |
| 1793 | 1.4.3.6 | **UIT E2E Sandbox Test Readiness Report** | 114d | 2024-08-26 | 2025-01-31 |  |  | 750d |  |
| 1794 | 1.4.3.6.1 | **Central Parties E2E Sandbox Test Readiness Report** | 30d | 2024-08-26 | 2024-10-04 |  |  | 819d |  |
| 1795 |  | Develop draft Test Readiness Report and submit to Programme for assurance | 20d | 2024-08-26 | 2024-09-20 | 1780FF-10d |  | 819d |  |
| 1796 |  | Finalise Test Readiness Report and submit to Programme for assurance | 10d | 2024-09-23 | 2024-10-04 | 1780FF |  | 819d |  |
| 1797 | 1.4.3.6.2 | **SI E2E Sandbox Test Readiness Report** | 40d | 2024-08-26 | 2024-10-18 |  |  | 819d |  |
| 1798 |  | Assure Central Parties' E2E Sandbox Test Readiness Reports | 35d | 2024-08-26 | 2024-10-11 | 1795SS, 1796FF+5d |  | 819d |  |
| 1799 |  | Develop Overarching E2E Sandbox Test Readiness Report | 20d | 2024-09-16 | 2024-10-11 | 1798FF |  | 819d |  |
| 1800 |  | Artefact review (via SITAG) and updates | 5d | 2024-10-14 | 2024-10-18 | 1799 |  | 819d |  |
| 1801 |  | UIT E2E Sandbox Preparation Complete | 0d | 2025-01-31 | 2025-01-31 | 1800FS+5d |  | 750d | start no earlier than 2025-01-31 |
| 1802 | 1.4.4 | **Sandbox Testing Execution (UIT)** | 260d | 2025-09-01 | 2026-08-28 |  |  | 344d |  |
| 1803 |  | Sandbox Testing Start (UIT) | 0d | 2025-09-01 | 2025-09-01 | 1700, 2255FS+5d, 1801 |  | 603d | start no earlier than 2025-02-10 |
| 1804 |  | Sandbox Testing Execution (UIT) | 260d | 2025-09-01 | 2026-08-28 | 1803SS-1d |  | 344d | start no earlier than 2024-11-04 |
| 1805 |  | Sandbox Testing End (UIT) | 0d | 2026-08-28 | 2026-08-28 | 1804 |  | 344d |  |
| 1806 | 1.4.5 | **SIT PPs Early Sandbox Testing Execution (SIT-A)** | 56d | 2025-08-08 | 2025-10-24 |  |  | 564d |  |
| 1807 |  | SIT PPs E2E Sandbox Testing Start | 0d | 2025-08-08 | 2025-08-08 | 1801FS+5d, 1591 |  | 619d | start no earlier than 2025-02-10 |
| 1808 |  | SIT PPs E2E Sandbox Testing Execution | 56d | 2025-08-08 | 2025-10-24 | 1807SS-1d |  | 564d | start no earlier than 2024-11-04 |
| 1809 | 1.4.6 | **System Integration Testing - Tier 1 Milestones** | 823d? | 2022-10-31 A | 2025-12-24 |  | 20% | 521d |  |
| 1810 | 1.4.6.1 | **M10 Checkpoint** | 633d? | 2022-10-31 A | 2025-04-02 |  | 20% | 711d |  |
| 1811 | 1.4.6.1.1 | **M10 Readiness** | 50d? | 2025-01-06 A | 2025-03-14 |  | 58% | 724d |  |
| 1812 |  | Define guiding principles and approach | 15d? | 2025-01-06 A | 2025-01-24 A |  | 100% |  | start no earlier than 2025-01-06 |
| 1813 |  | Engage IPA | 10d | 2025-01-13 A | 2025-01-24 A |  | 100% |  | start no earlier than 2025-01-13 |
| 1814 |  | Mobilise Get to Go-Live Group | 10d | 2025-01-27 A | 2025-02-07 A | 1812, 1813 | 100% |  |  |
| 1815 |  | Progress against the M10 Readiness Criteria | 25d? | 2025-02-10 | 2025-03-14 | 1814 |  | 724d |  |
| 1816 | 1.4.6.1.2 | **Downstream milestone feasibility assessment** | 50d? | 2025-01-06 | 2025-03-14 |  |  | 711d |  |
| 1817 |  | Define guiding principles and approach to addressing points 1 - 3 | 20d? | 2025-01-06 | 2025-01-31 |  |  | 721d | start no earlier than 2025-01-06 |
| 1818 |  | Assess capacity within migration envelopes (Point 1 - Bringing M15 forwards) | 20d | 2025-01-20 | 2025-02-14 | 1817FF |  | 711d | start no earlier than 2025-01-20 |
| 1819 |  | Review M16 process (Point 3 - Bringing M16 forwards) | 25d? | 2025-01-20 | 2025-02-21 | 1817FF |  | 711d | start no earlier than 2025-01-20 |
| 1820 |  | Develop M16 process review findings | 10d | 2025-02-24 | 2025-03-07 | 1819 |  | 711d |  |

| ID | WBS | Task | Duration | Start | Finish | Predecessors | Complete | Total float | Constraint |
| --- | --- | --- | --- | --- | --- | --- | --- | --- | --- |
| 1821 |  | Agree M16 process review findings with Code Bodies | 5d | 2025-03-10 | 2025-03-14 | 1820 |  | 711d |  |
| 1822 |  | Agree M16 process review findings with PAB | 5d | 2025-03-10 | 2025-03-14 | 1820 |  | 711d |  |
| 1823 |  | Run PPIR with impacted parties (Point 2 - Bringing M14 forwards) | 10d | 2025-03-03 | 2025-03-14 | 1818FS+10d |  | 711d |  |
| 1824 | 1.4.6.1.3 | **Checkpoint governance** | 633d? | 2022-10-31 | 2025-04-02 |  |  | 711d |  |
| 1825 |  | PSG Updated on progress | 0d | 2025-03-05 | 2025-03-05 |  |  | 732d | start no earlier than 2025-03-05 |
| 1826 |  | Review final M10 Readiness outputs with IPA | 5d | 2025-03-17 | 2025-03-21 | 1821, 1822, 1823 |  | 719d |  |
| 1827 |  | Review final M10 Readiness outputs with Ofgem | 8d | 2025-03-17 | 2025-03-26 | 1821, 1822, 1823 |  | 711d |  |
| 1828 |  | QAG paper day | 1d? | 2022-10-31 | 2022-10-31 |  |  | 1343d |  |
| 1829 |  | QAG recommend M10 Checkpoint | 1d? | 2022-10-31 | 2022-10-31 |  |  | 1343d |  |
| 1830 |  | MCAG paper day | 1d? | 2022-10-31 | 2022-10-31 |  |  | 1343d |  |
| 1831 |  | MCAG recommend M10 Checkpoint | 1d? | 2022-10-31 | 2022-10-31 |  |  | 1343d |  |
| 1832 |  | PSG paper day | 0d | 2025-03-26 | 2025-03-26 | 1827 |  | 711d |  |
| 1833 |  | PSG M10 Checkpoint Meeting | 0d | 2025-04-02 | 2025-04-02 | 1832FS+5d |  | 711d |  |
| 1834 |  | M10 Checkpoint complete | 0d | 2025-04-02 | 2025-04-02 | 1835FS-126d, 1833 |  | 711d |  |
| 1835 |  | Central systems ready for migrating MPANs (M10) | 0d | 2025-09-24 | 2025-09-24 | 1700FS+20d, 3063, 2737FS+2d, 2734, 2749, 2716, 2720 |  | 0d |  |
| 1836 |  | Central systems ready for migrating MPANs (M10*) - Late Exit | 0d | 2025-12-24 | 2025-12-24 | 1835FS+65d |  | 521d |  |
| 1837 | 1.4.7 | **External Programme Dependency Management** | 174d | 2022-10-31 A | 2023-06-30 A |  | 100% |  |  |
| 1838 | 1.4.7.1 | **BSC CP1558** | 173d | 2022-10-31 A | 2023-06-29 A |  | 100% |  |  |
| 1839 |  | Monitor progress to implementation date | 173d | 2022-10-31 A | 2023-06-28 A |  | 100% |  |  |
| 1840 |  | BSC CP1558 Implementation Date | 0d | 2023-06-29 A | 2023-06-29 A | 1839 | 100% |  | must start on 2023-06-29 |
| 1841 | 1.4.7.2 | **REC CP R0032** | 174d | 2022-10-31 A | 2023-06-30 A |  | 100% |  |  |
| 1842 |  | Monitor progress to implementation date | 174d | 2022-10-31 A | 2023-06-29 A |  | 100% |  |  |
| 1843 |  | REC CP R0032 Implementation Date | 0d | 2023-06-30 A | 2023-06-30 A | 1842 | 100% |  | must start on 2023-06-30 |
| 1844 | 1.4.7.3 | **REC CP R0044** | 173d | 2022-10-31 A | 2023-06-29 A |  | 100% |  |  |
| 1845 |  | Monitor progress to implementation date | 173d | 2022-10-31 A | 2023-06-28 A |  | 100% |  |  |
| 1846 |  | REC CP R0044 Implementation Date | 0d | 2023-06-29 A | 2023-06-29 A | 1845 | 100% |  | must start on 2023-06-29 |
| 1847 | 1.5 | **NON SIT LDSO QUALIFICATION** | 489d? | 2023-11-07 A | 2025-09-19 |  | 70% | 589d |  |
| 1848 | 1.5.1 | **Approach Planning** | 208d | 2023-11-07 A | 2024-08-22 A |  | 100% |  |  |
| 1849 |  | Develop Draft Testing Approach & Plan | 61d | 2023-11-07 A | 2024-01-30 A |  | 100% |  | start no earlier than 2023-11-07 |
| 1850 |  | Draft Testing Approach & Plan Issued to LDSO for Review | 1d | 2024-01-31 A | 2024-01-31 A | 1849 | 100% |  |  |
| 1851 |  | LDSO Review Complete | 10d | 2024-02-01 A | 2024-02-14 A | 1850 | 100% |  |  |
| 1852 |  | Update Following LDSO Review | 14d | 2024-02-15 A | 2024-03-05 A | 1851 | 100% |  |  |
| 1853 |  | QWG Review of Approach & Plan | 1d | 2024-03-12 A | 2024-03-12 A | 1852FS+4d | 100% |  |  |
| 1854 |  | QAG Approval for Approach & Plan | 0d | 2024-03-21 A | 2024-03-21 A | 1853FS+7d | 100% |  |  |
| 1855 |  | Confirmation of Participants for Non-SIT LDSO Qualification Testing | 0d | 2024-03-21 A | 2024-03-21 A | 1854 | 100% |  |  |
| 1856 |  | Update to Annex 1 for internal review (NF, Not Operational) | 15d | 2024-03-18 A | 2024-04-05 A | 1095 | 100% |  |  |
| 1857 |  | Non-Functional, Operational & Migration Approaches Socialised with Code Bodies & LDSO & Feedback Actioned | 86d | 2024-04-08 A | 2024-08-05 A | 1856 | 100% |  |  |
| 1858 |  | QWG Review Operational, Non-Functional & Migration Annexes of Approach & Plan | 1d | 2024-08-13 A | 2024-08-13 A | 1857FS+5d | 100% |  |  |
| 1859 |  | Update Following QWG Review | 6d | 2024-08-14 A | 2024-08-21 A | 1858 | 100% |  |  |
| 1860 |  | QAG Approval for Operational, Non-Functional & Migration Annexes of Approach & Plan | 0d | 2024-08-22 A | 2024-08-22 A | 1859FS+1d, 1855, 1098 | 100% |  |  |
| 1861 | 1.5.2 | **Functional Test Cases & Scenarios** | 58d | 2024-01-30 A | 2024-04-18 A |  | 100% |  |  |
| 1862 | 1.5.2.1 | **Functional Test Cases & Scenarios Batch 1** | 8d | 2024-01-30 A | 2024-02-08 A |  | 100% |  |  |
| 1863 |  | Walkthrough Test Cases & Scenarios Batch 1 with Code Bodies | 1d | 2024-01-30 A | 2024-01-30 A | 1849SS+60d | 100% |  |  |
| 1864 |  | Walkthrough Test Cases & Scenarios Batch 1 with LDSO | 1d | 2024-02-01 A | 2024-02-01 A | 1863 | 100% |  |  |
| 1865 |  | Action Feedback on Test Cases & Scenarios Batch 1 | 5d | 2024-02-02 A | 2024-02-08 A | 1864 | 100% |  |  |
| 1866 | 1.5.2.2 | **Functional Test Cases & Scenarios Batch 2** | 14d | 2024-02-20 A | 2024-03-08 A |  | 100% |  |  |
| 1867 |  | Walkthrough Test Cases & Scenarios Batch 2 with Code Bodies | 1d | 2024-02-20 A | 2024-02-20 A | 1849SS+75d | 100% |  |  |
| 1868 |  | Walkthrough Test Cases & Scenarios Batch 2 with LDSO | 1d | 2024-03-01 A | 2024-03-01 A | 1867FS+7d | 100% |  |  |
| 1869 |  | Action Feedback on Test Cases & Scenarios Batch 2 | 5d | 2024-03-04 A | 2024-03-08 A | 1868 | 100% |  |  |
| 1870 | 1.5.2.3 | **Functional Test Cases & Scenarios Batch 3** | 13d | 2024-03-20 A | 2024-04-05 A |  | 100% |  |  |
| 1871 |  | Walkthrough Test Cases & Scenarios Batch 3 with Code Bodies | 1d | 2024-03-20 A | 2024-03-20 A | 1849SS+96d | 100% |  |  |
| 1872 |  | Walkthrough Test Cases & Scenarios Batch 3 with LDSO | 1d | 2024-03-28 A | 2024-03-28 A | 1871FS+5d | 100% |  |  |
| 1873 |  | Action Feedback on Test Cases & Scenarios Batch 3 | 6d | 2024-03-29 A | 2024-04-05 A | 1872 | 100% |  |  |
| 1874 |  | Test Cases & Scenarios Batch 1-3 Discussion at QWG | 1d | 2024-04-09 A | 2024-04-09 A | 1865, 1869, 1873FS+1d | 100% |  |  |
| 1875 |  | Action QWG Feedback on Test Cases & Scenarios Batch 1-3 | 2d | 2024-04-10 A | 2024-04-11 A | 1874 | 100% |  |  |
| 1876 |  | Batch 1-3 Non-SIT LDSO QT Functional Test Scenarios and Test Cases approved | 0d | 2024-04-18 A | 2024-04-18 A | 1875FS+5d | 100% |  |  |
| 1877 | 1.5.3 | **Test Execution Schedule** | 161d | 2024-04-19 A | 2024-11-29 A |  | 100% |  |  |
| 1878 |  | Draft Test Delivery Schedule for Functional and Operational Testing | 20d | 2024-04-19 A | 2024-05-16 A | 1876 | 100% |  |  |
| 1879 |  | Socialise Test Delivery Schedule with Code Bodies & LDSO for Review & Action Feedback | 37d | 2024-05-17 A | 2024-07-08 A | 1878 | 100% |  |  |
| 1880 |  | Agree Test Execution Timetable Format at QWG, Including Anonymisation Requirements | 1d | 2024-07-09 A | 2024-07-09 A | 1879 | 100% |  |  |
| 1881 |  | Action QWG Feedback | 3d | 2024-07-10 A | 2024-07-12 A | 1880 | 100% |  |  |
| 1882 |  | Agree Test Execution Timetable Format at QAG, Including Anonymisation Requirements | 0d | 2024-07-18 A | 2024-07-18 A | 1881FS+4d | 100% |  |  |
| 1883 |  | Qualification Testing for Non-SIT LDSOs (Functional, Migration, NFT, Operational) Test Execution Schedule Complete | 0d | 2024-11-29 A | 2024-11-29 A | 1860 | 100% |  | finish no earlier than 2024-11-29 |
| 1884 | 1.5.4 | **Functional, Non-Functional, Operational & Migration Test Scenarios & Cases** | 110d | 2024-03-22 A | 2024-08-22 A |  | 100% |  |  |
| 1885 |  | Test Scenarios & Cases - Functional - Drafted, Reviewed | 14d | 2024-04-01 A | 2024-04-18 A | 1854 | 100% |  |  |
| 1886 |  | Test Scenarios & Cases- Functional - Approved at QAG | 0d | 2024-04-18 A | 2024-04-18 A | 1885 | 100% |  |  |
| 1887 |  | Test Scenarios & Cases - Non-Functional - Drafted, Reviewed | 110d | 2024-03-22 A | 2024-08-22 A | 1854, 1115FF | 100% |  |  |
| 1888 |  | Test Scenarios & Cases - Non-Functional - Approved at QAG | 0d | 2024-08-22 A | 2024-08-22 A | 1887 | 100% |  |  |
| 1889 |  | Test Scenarios & Cases - Migration - Drafted, Reviewed | 45d | 2024-03-22 A | 2024-05-23 A | 1854 | 100% |  |  |
| 1890 |  | Test Scenarios & Cases - Migration - Approved at QAG | 0d | 2024-05-23 A | 2024-05-23 A | 1889 | 100% |  |  |

| ID | WBS | Task | Duration | Start | Finish | Predecessors | Complete | Total float | Constraint |
| --- | --- | --- | --- | --- | --- | --- | --- | --- | --- |
| 1891 |  | Test Scenarios & Cases - Operational - Drafted, Reviewed | 59d | 2024-06-03 A | 2024-08-22 A | 1854FS+51d | 100% |  |  |
| 1892 |  | Test Scenarios & Cases - Operational - Approved at QAG | 0d | 2024-08-22 A | 2024-08-22 A | 1891, 1115FF | 100% |  |  |
| 1893 | 1.5.5 | **Test Data** | 345d | 2024-01-22 A | 2025-05-16 |  | 65% | 679d |  |
| 1894 |  | Test Data Plan Drafted & Reviewed | 89d | 2024-01-22 A | 2024-05-23 A | 1849 | 100% |  |  |
| 1895 |  | Non-SIT LDSO QT Test Data Plan Approved by QAG | 0d | 2024-05-23 A | 2024-05-23 A | 1894 | 100% |  |  |
| 1896 |  | Develop Test Data Matrices | 10d | 2024-05-24 A | 2024-06-06 A | 1895 | 100% |  |  |
| 1897 |  | Test Data Cut | 17d | 2024-05-24 A | 2024-06-17 A | 1895 | 100% |  |  |
| 1898 |  | Test Data Cut Complete | 0d | 2024-06-17 A | 2024-06-17 A | 1897, 1896 | 100% |  |  |
| 1899 |  | Test Data Reviewed by the Programme | 39d | 2024-06-18 A | 2024-08-09 A | 1898 | 100% |  |  |
| 1900 |  | Test Data Loaded | 85d | 2024-08-12 A | 2024-12-06 | 1899 | 90% | 679d |  |
| 1901 |  | Test Data Signed Off | 0d | 2024-12-06 | 2024-12-06 | 1900 |  | 679d |  |
| 1902 |  | Test Execution Data Support | 115d | 2024-12-09 | 2025-05-16 | 1901 |  | 679d |  |
| 1903 | 1.5.6 | **Tooling** | 148d | 2024-01-31 A | 2024-08-23 A |  | 100% |  |  |
| 1904 |  | Design Approach & Set-Up ADO Tool for Test & Defect Management Tool | 53d | 2024-01-31 A | 2024-04-12 A | 1849 | 100% |  |  |
| 1905 |  | Develop Training Requirements & Materials Inc. Day in the Life | 87d | 2024-04-15 A | 2024-08-13 A | 1904 | 100% |  |  |
| 1906 |  | ADO Launch complete | 1d | 2024-08-23 A | 2024-08-23 A | 1905, 1886, 1890, 1892 | 100% |  |  |
| 1907 | 1.5.7 | **Pre-Integration Testing** | 263d | 2024-01-31 A | 2025-01-31 |  | 84% | 754d |  |
| 1908 |  | PIT Guidance & Templates & Approach & Plans Developed | 106d | 2024-02-05 A | 2024-07-01 A | 1849FS+3d | 100% |  |  |
| 1909 |  | PIT Test Approach & Plan Deadline for Submission for Non-SIT LDSO​ QT | 0d | 2024-07-01 A | 2024-07-01 A | 1908 | 100% |  |  |
| 1910 |  | Develop and agree PIT Test Scenarios | 20d | 2024-07-02 A | 2024-07-29 A | 1909 | 100% |  |  |
| 1911 |  | PIT Execution (Functional and Migration) | 45d | 2024-09-30 A | 2024-11-29 A | 1910 | 100% |  | start no earlier than 2024-09-30 |
| 1912 |  | PIT Execution (Non-Functional and Operational) | 95d | 2024-09-23 A | 2025-01-31 | 1910 | 22% | 754d | finish no earlier than 2025-01-31 |
| 1913 |  | Non-SIT LDSO Participants have submitted functional PIT Test Completion Report & evidence for QT Entry​ | 0d | 2024-11-29 | 2024-11-29 | 1911 |  | 799d |  |
| 1914 |  | Non-SIT LDSO Participants have submitted non-functional PIT Test Completion Report | 0d | 2025-01-31 | 2025-01-31 | 1912 |  | 754d |  |
| 1915 | 1.5.7.8 | **Placing Reliance - Code Body & LDSO Functional and Migration** | 147d | 2024-01-31 A | 2024-08-22 A |  | 100% |  |  |
| 1916 |  | Placing Reliance Submitted & Reviewed | 21d | 2024-01-31 A | 2024-02-28 A | 1849 | 100% |  |  |
| 1917 |  | Define & Agree QT Testing for Each LDSO | 22d | 2024-02-29 A | 2024-03-29 A | 1916 | 100% |  |  |
| 1918 |  | Develop Test Scope & Reliance Submissions | 20d | 2024-04-01 A | 2024-04-26 A | 1917 | 100% |  |  |
| 1919 |  | Review and Consultation | 84d | 2024-04-29 A | 2024-08-22 A | 1918, 1860FF | 100% |  |  |
| 1920 | 1.5.7.9 | **Placing Reliance - Code Body & LDSO Non Functional and Operational** | 49d | 2024-06-17 A | 2024-08-22 A |  | 100% |  |  |
| 1921 |  | Placing Reliance Submitted & Reviewed | 32d | 2024-06-17 A | 2024-07-30 A | 1858FF-10d | 100% |  |  |
| 1922 |  | Review and Consultation | 17d | 2024-07-31 A | 2024-08-22 A | 1921 | 100% |  |  |
| 1923 |  | PP Test Scope Presented at QAG | 0d | 2024-08-22 A | 2024-08-22 A | 1922, 1919 | 100% |  |  |
| 1924 | 1.5.8 | **LDSO Test Readiness Reporting** | 71d | 2024-04-19 A | 2024-07-26 A |  | 100% |  |  |
| 1925 |  | Interim Test Readiness Report & Plan Developed & Reviewed | 71d | 2024-04-19 A | 2024-07-26 A | 1876 | 100% |  |  |
| 1926 |  | Test Plan Submission to MHHS Programme For Review | 0d | 2024-07-26 A | 2024-07-26 A | 1925 | 100% |  |  |
| 1927 | 1.5.9 | **Test Environment** | 163d | 2024-04-17 A | 2024-11-29 A |  | 100% |  |  |
| 1928 |  | Define Test Harness Requirements and Sign-Off with SRO | 13d | 2024-04-17 A | 2024-05-03 A | 546 | 100% |  |  |
| 1929 |  | Central System (DIP Env & Helix Test Harness) Test Environment DBT | 163d | 2024-04-17 A | 2024-11-29 A | 546 | 100% |  | finish no earlier than 2024-11-29 |
| 1930 |  | Coordinate LDSO Environment Preparation | 101d | 2024-07-12 A | 2024-11-29 A | 1929FF | 100% |  |  |
| 1931 |  | DIP available for Onboarding | 1d | 2024-08-01 A | 2024-08-01 A |  | 100% |  | start no earlier than 2024-08-01 |
| 1932 |  | Qualification Testing for Non-SIT LDSOs Participants' environments) Ready to start DIP onboarding (incl. certificates and security compliance) | 0d | 2024-08-05 A | 2024-08-05 A | 1931FS+2d | 100% |  |  |
| 1933 |  | LDSO Test Environments Connection Confirmed to UIT Environment | 0d | 2024-11-29 A | 2024-11-29 A | 1932FS+32d, 1930 | 100% |  |  |
| 1934 | 1.5.10 | **Test Readiness** | 124d | 2024-07-02 A | 2024-12-20 |  | 90% | 784d |  |
| 1935 |  | Preparation for Interim Test Readiness Report | 19d | 2024-07-02 A | 2024-07-26 A | 1909 | 100% |  |  |
| 1936 |  | Interim Test Readiness Report Submission to MHHS Programme for Review | 0d | 2024-07-26 A | 2024-07-26 A | 1935 | 100% |  |  |
| 1937 |  | LDSO Update Readiness Report & Final Assurance by Programme | 99d | 2024-07-29 A | 2024-12-12 | 1936 | 95% | 10d |  |
| 1938 |  | Final Test Readiness Report Submitted to MHHS Programme | 1d | 2024-12-13 | 2024-12-13 | 1937 |  | 789d |  |
| 1939 |  | Final Programme Assurance of LDSO Test Readiness | 6d | 2024-12-13 | 2024-12-20 | 1937 |  | 10d |  |
| 1940 |  | Qualification Testing for Non-SIT LDSOs (Functional, Migration, NFT, Operational) Programme Test Readiness confirmed | 0d | 2024-12-20 A | 2024-12-20 A | 1938FS+5d, 1913, 1886, 1888, 1890, 1928 | 100% |  |  |
| 1941 |  | Qualification Testing for Non-SIT LDSOs (Functional, Migration, NFT, Operational) Test Readiness Confirmed (Final Test Readiness Review for LDSO) | 0d | 2024-12-20 A | 2024-12-20 | 1937, 1939 | 90% | 10d |  |
| 1942 | 1.5.11 | **Test Window** | 165d? | 2025-01-06 A | 2025-08-22 |  | 23% | 609d |  |
| 1943 | 1.5.11.1 | **All Non-SIT LDSOs Qualification Testing** | 94d | 2025-01-06 A | 2025-05-16 | 1941, 1933 | 26% | 1d |  |
| 1944 |  | Non-SIT LDSO QT Test Execution Starts | 0d | 2025-01-06 A | 2025-01-06 A | 1941FS+11d | 100% |  | start no earlier than 2024-11-01 |
| 1945 |  | LDSO Alpha | 86d | 2025-01-06 A | 2025-05-05 | 1944FS-1d | 12% | 9d |  |
| 1946 |  | LDSO Bravo | 59d | 2025-01-06 A | 2025-03-27 | 1944FS-1d | 5% | 36d |  |
| 1947 |  | LDSO Charlie | 88d | 2025-01-06 A | 2025-05-07 | 1944FS-1d | 30% | 7d |  |
| 1948 |  | LDSO Delta | 83d | 2025-01-06 A | 2025-04-30 | 1944FS-1d | 15% | 12d |  |
| 1949 |  | LDSO Echo | 69d | 2025-01-06 A | 2025-04-10 | 1944FS-1d | 57% | 26d |  |
| 1950 |  | LDSO Foxtrot | 44d | 2025-01-20 | 2025-03-20 | 1944FS+9d |  | 41d |  |
| 1951 |  | LDSO Golf | 66d | 2025-01-06 A | 2025-04-07 | 1944FS-1d | 47% | 29d |  |
| 1952 |  | LDSO Hotel | 45d | 2025-01-06 A | 2025-03-07 | 1944FS-1d | 37% | 50d |  |
| 1953 |  | LDSO India | 86d | 2025-01-06 A | 2025-05-05 | 1944FS-1d | 25% | 9d |  |
| 1954 |  | Qualification Testing for Non-SIT LDSOs (Functional, Migration, NFT, Operational) 1 End | 0d | 2025-05-16 | 2025-05-16 | 1945, 1946, 1947, 1948, 1949, 1950, 1951, 1952, 1953 |  | 1d | start no earlier than 2025-05-16 |
| 1955 |  | Potential for non-SIT LDSO QT Regression for Qualification | 70d? | 2025-05-19 | 2025-08-22 | 1954FS+1d |  | 609d |  |
| 1956 | 1.5.12 | **Test Result Assurance** | 29d | 2025-04-21 | 2025-05-29 |  |  | 44d |  |
| 1957 |  | LDSOs Develop & Submit Test Report (QT Test Completion Report) | 19d | 2025-04-21 | 2025-05-16 | 1954FF |  | 44d |  |
| 1958 |  | Test Reports Reviewed By MHHS & Code Bodies & Finalised | 10d | 2025-05-16 | 2025-05-29 | 1957 |  | 650d |  |
| 1959 |  | Non-SIT LDSOs submission deadline for their QT Test Completion Report to MHHS Programme | 0d | 2025-05-29 | 2025-05-29 | 1958, 1943 |  | 650d |  |
| 1960 | 1.5.13 | **Non-SIT LDSO Qualification Closure** | 20d | 2025-08-25 | 2025-09-19 |  |  | 589d |  |

| ID | WBS | Task | Duration | Start | Finish | Predecessors | Complete | Total float | Constraint |
| --- | --- | --- | --- | --- | --- | --- | --- | --- | --- |
| 1961 |  | Non-SIT LDSO Qualification Learned Captured | 15d | 2025-08-25 | 2025-09-12 | 1959, 2052 |  | 589d |  |
| 1962 |  | Non-SIT LDSO Qualification Closure Down | 5d | 2025-09-15 | 2025-09-19 | 1961 |  | 589d |  |
| 1963 | 1.6 | **S & A QUALIFICATION** | 843d? | 2023-11-07 A | 2027-01-28 |  | 59% | 235d |  |
| 1964 | 1.6.1 | **MHHS Qualification - Qualification Deliverables** | 509d | 2023-11-07 A | 2025-10-17 |  | 95% | 0d |  |
| 1965 | 1.6.1.1 | **BSC & REC Assessment Criteria** | 463d | 2023-11-07 A | 2025-08-14 A |  | 100% |  |  |
| 1966 |  | Draft BSC Assessment Criteria (Functional) | 21d | 2023-11-07 A | 2023-12-05 A |  | 100% |  | finish no earlier than 2023-12-05 |
| 1967 |  | BSC PAB Review | 1d | 2023-12-14 A | 2023-12-14 A |  | 100% |  | start no earlier than 2023-12-14 |
| 1968 |  | Update BSC Assessment Criteria (Functional, Non-Functional, Migration) | 30d | 2024-02-07 A | 2024-03-19 A |  | 100% |  | finish no earlier than 2024-03-19 |
| 1969 |  | REC & BSC PAB Approval | 3d | 2024-03-26 A | 2024-03-28 A |  | 100% |  | start no earlier than 2024-03-28 |
| 1970 |  | Update BSC Assessment Criteria (Functional, Non-Functional, Migration, Operational) | 20d | 2024-07-24 A | 2024-08-20 A |  | 100% |  |  |
| 1971 |  | Assessment Criteria (Functional, Non-Functional, Migration, Operational) Approved by REC PAB and BSC PAB | 250d | 2024-08-29 A | 2025-08-14 A | 1970FS+7d | 100% |  | start no earlier than 2023-09-15 |
| 1972 | 1.6.1.2 | **Qualification Approach and Plan** | 194d | 2023-12-04 A | 2024-08-29 A |  | 100% |  |  |
| 1973 | 1.6.1.2.1 | **Qualification Approach and Plan v2** | 84d | 2023-12-04 A | 2024-03-28 A |  | 100% |  |  |
| 1974 |  | Draft Qualification Approach and Plan v2 | 30d | 2023-12-04 A | 2024-01-12 A |  | 100% |  | finish no earlier than 2024-01-12 |
| 1975 |  | Internal Review (Code Bodies and MHHSP) for Qualification Approach and Plan V2 | 10d | 2024-01-15 A | 2024-01-26 A | 1974 | 100% |  | finish no earlier than 2024-01-26 |
| 1976 |  | Industry consultation for Qualification Approach and Plan v2 | 11d | 2024-01-31 A | 2024-02-14 A | 1975 | 100% |  | start no earlier than 2024-01-31 |
| 1977 |  | Update Qualification Approach and Plan v2 post industry consultation | 10d | 2024-02-15 A | 2024-02-28 A | 1976 | 100% |  |  |
| 1978 |  | QWG Endorsement of Qualification Approach and Plan v2 | 1d | 2024-03-12 A | 2024-03-12 A |  | 100% |  | start no earlier than 2024-03-12 |
| 1979 |  | QAG Approval of Qualification Approach and Plan v2 | 1d | 2024-03-21 A | 2024-03-21 A |  | 100% |  | start no earlier than 2024-03-21 |
| 1980 |  | BSC and REC PAB Approval of Qualification Approach and Plan v2 | 3d | 2024-03-26 A | 2024-03-28 A |  | 100% |  | finish no earlier than 2024-03-28 |
| 1981 |  | Functional Testing elements of Qualification Approach & Plan v2 approvement by REC PAB and BSC PAB | 0d | 2024-03-28 A | 2024-03-28 A | 1980 | 100% |  |  |
| 1982 |  | Migration Testing elements of Qualification Approach & Plan v2 appoved by REC PAB and BSC PAB | 0d | 2024-03-28 A | 2024-03-28 A | 1980 | 100% |  |  |
| 1983 | 1.6.1.2.2 | **Qualification Approach and Plan v3** | 84d | 2024-05-06 A | 2024-08-29 A |  | 100% |  |  |
| 1984 |  | Draft Qualification Approach and Plan v3 | 35d | 2024-05-06 A | 2024-06-21 A | 1098 | 100% |  | finish no earlier than 2024-05-17 |
| 1985 |  | Internal Review (Code Bodies and MHHSP) of Qualification Approach and Plan v3 | 10d | 2024-06-24 A | 2024-07-05 A | 1984 | 100% |  |  |
| 1986 |  | Industry consultation for Qualification Approach and Plan v3 | 10d | 2024-07-08 A | 2024-07-19 A | 1985 | 100% |  |  |
| 1987 |  | Update Qualification Approach and Plan v3 Post-Consultation | 10d | 2024-07-22 A | 2024-08-02 A | 1986 | 100% |  |  |
| 1988 |  | QWG Endorsement of Qualification Approach and Plan v3 | 1d | 2024-08-13 A | 2024-08-13 A | 1987FS+6d | 100% |  |  |
| 1989 |  | QAG Approval of Qualification Approach and Plan v3 | 0d | 2024-08-22 A | 2024-08-22 A | 1988FS+7d | 100% |  |  |
| 1990 |  | BSC and REC PAB Approval of Qualification Approach and Plan v3 | 3d | 2024-08-27 A | 2024-08-29 A | 1989FS+2d | 100% |  |  |
| 1991 |  | Non-Functional Testing elements of Qualification Approach and Plan v3 approved by REC PAB and BSC PAB | 0d | 2024-08-29 A | 2024-08-29 A | 1990 | 100% |  |  |
| 1992 | 1.6.1.3 | **Qualification Assessment Document** | 476d | 2023-12-22 A | 2025-10-17 |  | 87% | 0d |  |
| 1993 | 1.6.1.3.1 | **Qualification Assessment Document v1** | 70d | 2023-12-22 A | 2024-03-28 A |  | 100% |  |  |
| 1994 |  | Draft Qualification Assessment Document v1 | 30d | 2023-12-22 A | 2024-02-01 A |  | 100% |  | finish no earlier than 2024-02-01 |
| 1995 |  | Internal Review (Code Bodies and MHHSP) of Qualification Assessment Document v1 | 10d | 2024-02-01 A | 2024-02-14 A |  | 100% |  | finish no earlier than 2024-02-14 |
| 1996 |  | Industry consultation for Qualification Assessment Document v1 | 11d | 2024-02-16 A | 2024-03-01 A |  | 100% |  | start no earlier than 2024-02-16 |
| 1997 |  | Update Post-Consultation for Qualification Assessment Document v1 | 10d | 2024-03-04 A | 2024-03-15 A | 1996 | 100% |  |  |
| 1998 |  | BSC and REC PAB Approval of Qualification Assessment Document v1 | 3d | 2024-03-26 A | 2024-03-28 A |  | 100% |  | start no earlier than 2024-03-26 |
| 1999 |  | Qualification Assessment Document v1 approved by REC PAB and BSC PAB | 0d | 2024-03-28 A | 2024-03-28 A | 1998 | 100% |  |  |
| 2000 | 1.6.1.3.2 | **Qualification Assessment Document v3** | 110d | 2024-03-29 A | 2024-08-29 A |  | 100% |  |  |
| 2001 |  | Draft Qualification Assessment Document V1.1 | 26d | 2024-03-29 A | 2024-05-03 A | 1999 | 100% |  |  |
| 2002 |  | Industry Consultation for Qualification Assessment Document V1.1 | 12d | 2024-05-06 A | 2024-05-21 A | 2001 | 100% |  |  |
| 2003 |  | Draft Qualification Assessment Document v3 | 6d | 2024-06-14 A | 2024-06-21 A | 1206, 2002 | 100% |  |  |
| 2004 |  | Internal Review (Code Bodies and MHHSP) of Qualification Assessment Document v3 | 10d | 2024-06-24 A | 2024-07-05 A | 2003 | 100% |  |  |
| 2005 |  | Industry consultation for Qualification Assessment Document v3 | 10d | 2024-07-08 A | 2024-07-19 A | 2004 | 100% |  |  |
| 2006 |  | Update Post-Consultation for Qualification Assessment Document v3 | 10d | 2024-07-22 A | 2024-08-02 A | 2005 | 100% |  |  |
| 2007 |  | QWG Endorsement of Qualification Assessment Document v3 | 1d | 2024-08-13 A | 2024-08-13 A | 2006FS+6d | 100% |  |  |
| 2008 |  | QAG Endorsement of Qualification Assessment Document v3 | 1d | 2024-08-22 A | 2024-08-22 A | 2007FS+6d | 100% |  |  |
| 2009 |  | BSC and REC PAB Approval of Qualification Assessment Document v3 | 3d | 2024-08-27 A | 2024-08-29 A | 2008FS+2d | 100% |  |  |
| 2010 |  | Qualification Assessment Document v3 approved by REC PAB and BSC PAB | 0d | 2024-08-29 A | 2024-08-29 A | 2009 | 100% |  |  |
| 2011 | 1.6.1.3.3 | **Qualification Assessment Document Portal** | 445d | 2024-02-05 A | 2025-10-17 |  | 77% | 0d |  |
| 2012 |  | Design Completion | 30d | 2024-02-05 A | 2024-03-15 A |  | 100% |  | finish no earlier than 2024-03-15 |
| 2013 |  | Qualification Assessment Document Portal Build | 30d | 2024-03-18 A | 2024-04-26 A | 2012 | 100% |  |  |
| 2014 |  | Qualification Assessment Document Internal Testing | 20d | 2024-04-29 A | 2024-05-24 A | 2013 | 100% |  |  |
| 2015 |  | Qualification Assessment Document Portal Training and Onboarding Material Creation | 20d | 2024-05-27 A | 2024-06-21 A | 2014 | 100% |  |  |
| 2016 |  | Qualification Assessment Document Portal Webinar (Date TBC) | 1d | 2024-06-18 A | 2024-06-18 A |  | 100% |  | start no earlier than 2024-06-18 |
| 2017 |  | SIT Participant QAD Application Creation in Portal | 10d | 2024-12-09 A | 2024-12-20 A | 2015FS+120d | 100% |  |  |
| 2018 |  | Non-SIT LDSO Participant QAD Application Creation in Portal | 10d | 2024-12-09 A | 2024-12-20 A | 2015FS+120d | 100% |  |  |
| 2019 |  | QT Wave 1 Participant QAD Application Creation in Portal | 10d | 2025-04-21 | 2025-05-02 | 2015FS+215d |  | 1d |  |
| 2020 |  | QT Wave 2 Participant QAD Application Creation in Portal | 10d | 2025-05-26 | 2025-06-06 | 2015FS+240d |  | 0d |  |
| 2021 |  | QT Wave 3 Participant QAD Application Creation in Portal | 10d | 2025-07-28 | 2025-08-08 | 2015FS+285d |  | 0d |  |
| 2022 |  | QT Wave 4 Participant QAD Application Creation in Portal | 10d | 2025-10-06 | 2025-10-17 | 2015FS+335d |  | 0d |  |
| 2023 |  | Update to Qualification Assessment Document Portal post QAD V3 | 10d | 2024-08-30 A | 2024-09-12 A | 2010 | 100% |  |  |
| 2024 |  | Update to Qualification Assessment Document Portal post QAD V3 Complete | 0d | 2024-09-12 A | 2024-09-12 A | 2023 | 100% |  |  |
| 2025 | 1.6.2 | **MHHS Qualification - SIT Participants** | 249d | 2025-01-06 A | 2025-12-18 |  | 9% | 0d |  |
| 2026 |  | Initial QAD Submission Window opens | 0d | 2025-01-06 A | 2025-01-06 A | 2017FS+10d | 100% |  | start no earlier than 2025-01-06 |
| 2027 |  | SIT Participants submit Initial QAD | 30d | 2025-01-06 A | 2025-02-14 |  | 65% | 55d | start no earlier than 2025-01-06 |
| 2028 |  | Code Bodies review Initial QAD | 36d | 2025-02-14 | 2025-04-04 | 2027FS-1d |  | 55d |  |
| 2029 |  | Completion of Code Bodies review of Initial QAD | 0d | 2025-04-04 | 2025-04-04 | 2028 |  | 55d |  |
| 2030 | 1.6.2.5 | **MHHS Qualification - SIT MVC Participants** | 114d | 2025-04-07 | 2025-09-11 |  |  | 0d |  |

| ID | WBS | Task | Duration | Start | Finish | Predecessors | Complete | Total float | Constraint |
| --- | --- | --- | --- | --- | --- | --- | --- | --- | --- |
| 2031 |  | Final QAD Submission Window (MVC) opens | 0d | 2025-04-07 | 2025-04-07 | 2028, 2024, 2029FS+1d |  | 55d |  |
| 2032 |  | SIT MVC Participants submit Final QAD (exc Test Reports) | 25d | 2025-04-07 | 2025-05-09 | 2031FS-1d |  | 55d |  |
| 2033 |  | Completion of Code Bodies review of Final QAD (MVC) | 20d | 2025-05-12 | 2025-06-06 | 2032 |  | 55d |  |
| 2034 |  | QAD Sign Off Deadline (MVC) + Test Reports | 0d | 2025-08-22 | 2025-08-22 | 1700, 2033, 1691 |  | 0d | start no earlier than 2025-07-11 |
| 2035 |  | REC Code Manager / BSC PAB Approval of Qualification (MVC) | 0d | 2025-09-11 | 2025-09-11 | 2034FS+14d |  | 0d |  |
| 2036 | 1.6.2.6 | **MHHS Qualification - SIT Non-MVC Participants** | 154d | 2025-05-19 | 2025-12-18 |  |  | 0d |  |
| 2037 |  | Final QAD Submission Window (Non-MVC) opens | 0d | 2025-05-19 | 2025-05-19 | 2029FS+31d |  | 109d |  |
| 2038 |  | SIT Non-MVC Participants submit Final QAD | 90d | 2025-05-19 | 2025-09-19 | 2037SS-1d |  | 20d |  |
| 2039 |  | Completion of Code Bodies review of Final QAD (Non-MVC) | 25d | 2025-09-22 | 2025-10-24 | 2038 |  | 20d |  |
| 2040 |  | QAD Sign Off Deadline (Non-MVC) | 1d | 2025-11-28 | 2025-11-28 | 2039FS+4d, 1722 |  | 0d |  |
| 2041 |  | REC Code Manager / BSC PAB Approval of Qualification (Non-MVC) | 0d | 2025-12-18 | 2025-12-18 | 2040FS+14d |  | 0d |  |
| 2042 | 1.6.3 | **MHHS Qualification - Non-SIT LDSO** | 178d | 2025-01-06 A | 2025-09-10 |  | 18% | 4d |  |
| 2043 |  | Initial QAD Submission window opens | 0d | 2025-01-06 A | 2025-01-06 A | 2018FS+11d | 100% |  |  |
| 2044 |  | Non-SIT LDSO Participants submit initial QAD | 30d | 2025-01-06 A | 2025-02-14 |  | 65% | 53d | start no earlier than 2025-01-06 |
| 2045 |  | Non-SIT LDSO QT Participants have submitted their initial QAD | 0d | 2025-02-14 | 2025-02-14 | 2044 |  | 53d |  |
| 2046 |  | Code Bodies review of Non-SIT LDSO participants Initial QAD | 35d | 2025-02-17 | 2025-04-04 | 2045 |  | 53d |  |
| 2047 |  | Completion of Code Bodies review of Initial QAD | 0d | 2025-04-04 | 2025-04-04 | 2046 |  | 53d |  |
| 2048 |  | Final QAD Submission window opens | 0d | 2025-04-07 | 2025-04-07 | 2047FS+1d |  | 53d |  |
| 2049 |  | Non-SIT LDSO Participants submit Final QAD | 25d | 2025-04-21 | 2025-05-23 | 1957SS, 2048SS |  | 44d |  |
| 2050 |  | Non-SIT LDSO QT Participants have submitted their final QAD | 0d | 2025-05-23 | 2025-05-23 | 2049 |  | 44d |  |
| 2051 |  | Completion of Code Bodies review of the Final QAD | 20d | 2025-05-26 | 2025-06-20 | 2050 |  | 44d |  |
| 2052 |  | QAD Sign Off Deadline (Non-SIT LDSOs) | 0d | 2025-08-22 | 2025-08-22 | 2051FS+5d, 1700, 1954 |  | 4d |  |
| 2053 |  | BSC PAB & REC Manager approval of Qualification for Non-SIT LDSOs | 0d | 2025-09-10 | 2025-09-10 | 2052FS+13d |  | 4d |  |
| 2054 | 1.6.4 | **MHHS Qualification - Qualification Waves** | 814d? | 2023-12-18 A | 2027-01-28 |  | 56% | 235d |  |
| 2055 | 1.6.4.1 | **Qualification Wave Prep** | 560d? | 2023-12-18 A | 2026-02-06 |  | 91% | 489d |  |
| 2056 | 1.6.4.1.1 | **Non-SIT Supplier and Agent Test Approach and Plan** | 119d | 2023-12-18 A | 2024-05-30 A |  | 100% |  |  |
| 2057 |  | Draft Non-SIT S&A Test Approach and Plan | 50d | 2023-12-18 A | 2024-02-23 A |  | 100% |  | finish no earlier than 2024-02-23 |
| 2058 |  | Internal Review of Non-SIT S&A Test Approach and Plan (Code Bodies and MHHSP) | 10d | 2024-02-26 A | 2024-03-08 A | 2057 | 100% |  |  |
| 2059 |  | Issue Non-SIT S&A Test Approach and Plan for Consultation | 15d | 2024-03-18 A | 2024-04-05 A | 2058 | 100% |  | start no earlier than 2024-03-18 |
| 2060 |  | Update Non-SIT S&A Test Approach and Plan Post-Consultation | 10d | 2024-04-08 A | 2024-04-19 A | 2059 | 100% |  |  |
| 2061 |  | QWG Endorsement of Non-SIT S&A Test Approach and Plan | 1d | 2024-05-14 A | 2024-05-14 A |  | 100% |  | finish no earlier than 2024-05-14 |
| 2062 |  | QAG Approval of Non-SIT S&A Test Approach and Plan | 0d | 2024-05-23 A | 2024-05-23 A | 2061FS+7d | 100% |  |  |
| 2063 |  | BSC & REC PAB Approval of Non-SIT S&A Test Approach and Plan | 0d | 2024-05-30 A | 2024-05-30 A | 2062FS+5d | 100% |  |  |
| 2064 | 1.6.4.1.2 | **QT Test Data Approach and Plan** | 64d | 2024-04-19 A | 2024-07-18 A |  | 100% |  |  |
| 2065 |  | QT Test Data Approach agreed as part of the Non-SIT Supplier and Agent Test Approach and Plan | 0d | 2024-04-19 A | 2024-04-19 A | 2060 | 100% |  |  |
| 2066 |  | Draft Test Data Approach and Plan for QT | 10d | 2024-05-06 A | 2024-05-17 A | 2065 | 100% |  |  |
| 2067 |  | Internal Review (Code Bodies and MHHSP) of QT Test Data Approach and Plan | 15d | 2024-05-20 A | 2024-06-07 A | 2066 | 100% |  |  |
| 2068 |  | Issue QT Test Data Approach and Plan for Industry Consultation | 10d | 2024-06-10 A | 2024-06-21 A | 2067 | 100% |  |  |
| 2069 |  | Update QT Test Approach and Plan Post Industry Consultation | 5d | 2024-06-24 A | 2024-06-28 A | 2068 | 100% |  |  |
| 2070 |  | QWG Endorsement of Test Data Approach and Plan | 1d | 2024-07-09 A | 2024-07-09 A | 2069FS+6d | 100% |  |  |
| 2071 |  | QAG Approval of QT Test Data Approach and Plan | 0d | 2024-07-18 A | 2024-07-18 A | 2070FS+7d | 100% |  |  |
| 2072 | 1.6.4.1.3 | **QT Functional Test Scenarios and Test Cases** | 59d | 2024-03-04 A | 2024-05-23 A |  | 100% |  |  |
| 2073 |  | Draft Test Scenarios and Test Case list - Batch 1 | 10d | 2024-03-04 A | 2024-03-15 A |  | 100% |  | finish no earlier than 2024-03-15 |
| 2074 |  | Issue Batch 1 for Consultation | 15d | 2024-03-18 A | 2024-04-05 A | 2073 | 100% |  | start no earlier than 2024-03-18 |
| 2075 |  | Gap analysis against QT Requirements | 8d | 2024-03-18 A | 2024-03-27 A | 2073 | 100% |  |  |
| 2076 |  | Update Test Scenarios and Test Case list - Batch 2 | 6d | 2024-03-28 A | 2024-04-04 A | 2075 | 100% |  |  |
| 2077 |  | Issue Batch 2 for consultation | 10d | 2024-04-05 A | 2024-04-18 A | 2076 | 100% |  |  |
| 2078 |  | Update Batch 2 post consultation | 10d | 2024-04-19 A | 2024-05-02 A | 2077 | 100% |  |  |
| 2079 |  | QWG Endorsement of Batch 1 and 2 | 1d | 2024-05-14 A | 2024-05-14 A |  | 100% |  | finish no earlier than 2024-05-14 |
| 2080 |  | QAG Approval of QT Functional Test Scenarios and Test Cases Batches 1 and 2 | 0d | 2024-05-23 A | 2024-05-23 A | 2079FS+7d | 100% |  |  |
| 2081 | 1.6.4.1.4 | **QT Migration Test Scenarios and Test Cases** | 54d | 2024-05-06 A | 2024-07-18 A |  | 100% |  |  |
| 2082 |  | Draft Test Scenarios and Test Case list - Batch 1 | 20d | 2024-05-06 A | 2024-05-31 A | 1017FS+12d | 100% |  |  |
| 2083 |  | Issue Batch 1 for Consultation | 10d | 2024-06-03 A | 2024-06-14 A | 2082 | 100% |  |  |
| 2084 |  | Update Batch 1 Post Consultation | 10d | 2024-06-17 A | 2024-06-28 A | 2083 | 100% |  |  |
| 2085 |  | QWG Endorsement of Batch 1 | 0d | 2024-07-09 A | 2024-07-09 A | 2084FS+7d | 100% |  |  |
| 2086 |  | QAG Approval of QT Migration Test Scenarios and Test Cases Batches 1 | 0d | 2024-07-18 A | 2024-07-18 A | 2085FS+7d | 100% |  |  |
| 2087 | 1.6.4.1.5 | **QT Functional (inc NF and Operational) Test Scenarios and Test Cases** | 77d | 2024-11-05 A | 2025-02-20 A |  | 100% |  |  |
| 2088 |  | Draft Test Scenarios and Test Case list - Batch 3 | 20d | 2024-11-05 A | 2024-12-02 A | 904FS-1d | 100% |  |  |
| 2089 |  | Issue Batch 3 for Consultation | 10d | 2024-12-03 A | 2024-12-16 A | 2088 | 100% |  |  |
| 2090 |  | Update Batch 3 Post Consultation | 20d | 2024-12-17 A | 2025-01-13 A | 2089 | 100% |  |  |
| 2091 |  | QWG Endorsement of Batch 3 | 0d | 2025-02-11 A | 2025-02-11 A | 2090FS+21d | 100% |  |  |
| 2092 |  | QAG Approval of QT Functional Test Scenarios and Test Cases Batches 3 | 0d | 2025-02-20 A | 2025-02-20 A | 2091FS+6d | 100% |  | start no earlier than 2025-02-20 |
| 2093 | 1.6.4.1.6 | **Qualification Testing Framework (Test Stubs and Supporting UI)** | 530d? | 2024-01-29 A | 2026-02-06 |  | 90% | 489d |  |
| 2094 |  | Proof of Concept for QTF Completion | 45d | 2024-01-29 A | 2024-03-29 A |  | 100% |  | finish no earlier than 2024-03-29 |
| 2095 |  | Discovery and Mobilisation | 25d | 2024-04-01 A | 2024-05-03 A | 2094 | 100% |  | finish no earlier than 2024-05-03 |
| 2096 | 1.6.4.1.6.3 | **Agile DBT of Qualification Testing Framework** | 83d | 2024-04-24 A | 2024-08-16 A |  | 100% |  |  |
| 2097 | 1.6.4.1.6.3.1 | **User Interface (UI)** | 48d | 2024-04-24 A | 2024-06-28 A |  | 100% |  |  |
| 2098 |  | UI Wireframe | 48d | 2024-04-24 A | 2024-06-28 A |  | 100% |  | finish no earlier than 2024-06-28 |
| 2099 |  | UI Standards | 35d | 2024-05-13 A | 2024-06-28 A | 2098FS+13d | 100% |  | finish no earlier than 2024-06-28 |
| 2100 |  | Elexon Branding Sylesheet | 2d | 2024-05-17 A | 2024-05-20 A | 2099FS+10d | 100% |  | finish no earlier than 2024-05-20 |

| ID | WBS | Task | Duration | Start | Finish | Predecessors | Complete | Total float | Constraint |
| --- | --- | --- | --- | --- | --- | --- | --- | --- | --- |
| 2101 |  | Elexon Branding QTF Logo | 2d | 2024-05-31 A | 2024-06-03 A | 2100FS+20d | 100% |  | finish no earlier than 2024-06-03 |
| 2102 | 1.6.4.1.6.3.2 | **Design, Build, Test** | 70d | 2024-05-13 A | 2024-08-16 A |  | 100% |  |  |
| 2103 |  | Core UI Screens | 60d | 2024-05-13 A | 2024-08-02 A | 2099SS | 100% |  | finish no earlier than 2024-08-02 |
| 2104 |  | Tooling (Trigger Files / Template Generators) | 70d | 2024-05-13 A | 2024-08-16 A | 2098SS+13d | 100% |  | finish no earlier than 2024-08-16 |
| 2105 |  | Database Schema | 50d | 2024-05-13 A | 2024-07-19 A | 2098SS+13d | 100% |  | finish no earlier than 2024-07-19 |
| 2106 |  | Core API's | 60d | 2024-05-13 A | 2024-08-02 A | 2098SS+13d | 100% |  | finish no earlier than 2024-08-02 |
| 2107 |  | QTF Test Cases DBT Refinement, Execution and Results Validation, Defect Management, Error Handling | 77d | 2024-11-05 A | 2025-02-20 | 2092FF, 2086FF, 2088SS | 80% | 722d |  |
| 2108 | 1.6.4.1.6.5 | **Environments** | 339d | 2024-04-15 A | 2025-07-31 |  | 98% | 625d |  |
| 2109 | 1.6.4.1.6.5.1 | **Azure Devops** | 173d | 2024-04-15 A | 2024-12-11 A |  | 100% |  |  |
| 2110 | 1.6.4.1.6.5.1.1 | **QFT ADO Development Instance** | 15d | 2024-04-15 A | 2024-05-03 A |  | 100% |  |  |
| 2111 |  | Elexon Instance Setup for QTF Build | 5d | 2024-04-15 A | 2024-04-19 A | 2095SS+10d | 100% |  | finish no earlier than 2024-04-19 |
| 2112 |  | Configuration and User Access | 10d | 2024-04-22 A | 2024-05-03 A | 2111 | 100% |  | finish no earlier than 2024-05-03 |
| 2113 | 1.6.4.1.6.5.1.2 | **MHHSP ADO Instance** | 102d | 2024-07-23 A | 2024-12-11 A |  | 100% |  |  |
| 2114 |  | MHHSP Instance Setup for QTF Production | 29d | 2024-07-23 A | 2024-08-30 A | 2120SS+41d | 100% |  | finish no earlier than 2024-08-30 |
| 2115 |  | Configuration and User Access | 73d | 2024-09-02 A | 2024-12-11 A | 2114 | 100% |  | finish no earlier than 2024-09-27 |
| 2116 | 1.6.4.1.6.5.2 | **Temporary Development Environment** | 35d | 2024-04-15 A | 2024-05-31 A |  | 100% |  |  |
| 2117 |  | Design | 15d | 2024-04-15 A | 2024-05-03 A | 2095SS+10d | 100% |  | finish no earlier than 2024-05-03 |
| 2118 |  | Build and Deployment | 20d | 2024-05-06 A | 2024-05-31 A | 2112, 2117 | 100% |  | finish no earlier than 2024-05-31 |
| 2119 | 1.6.4.1.6.5.3 | **Dev, Test & Prod Environment Requirements + Design** | 135d | 2024-05-27 A | 2024-11-29 A |  | 100% |  |  |
| 2120 |  | Design (including Security Review) | 135d | 2024-05-27 A | 2024-11-29 A | 2095FS+15d | 100% |  | finish no earlier than 2024-08-30 |
| 2121 |  | Hub Development Dev/Test | 20d | 2024-06-10 A | 2024-07-05 A | 2120SS+10d | 100% |  |  |
| 2122 |  | Hub Deployment | 20d | 2024-06-10 A | 2024-07-05 A | 2120FS+10d, 2121 | 100% |  | finish no earlier than 2024-07-05 |
| 2123 |  | Development Envn. Deployment | 53.8d | 2024-07-08 A | 2024-09-19 A | 2122 | 100% |  | finish no earlier than 2024-08-30 |
| 2124 |  | Test Envn. Deployment | 10d | 2024-09-19 A | 2024-10-03 A | 2123 | 100% |  | finish no earlier than 2024-09-13 |
| 2125 |  | Production Envn. Deployment | 25d | 2024-10-03 A | 2024-11-07 A | 2124 | 100% |  | finish no earlier than 2024-10-18 |
| 2126 | 1.6.4.1.6.5.4 | **QTF Deployment into Production** | 19d | 2025-02-20 | 2025-03-18 |  |  | 722d |  |
| 2127 |  | App Deployment | 5d | 2025-02-20 | 2025-02-26 | 2107, 2125 |  | 722d | start no earlier than 2025-02-03 |
| 2128 |  | Smoke Test | 2d | 2025-02-27 | 2025-02-28 | 2127 |  | 722d | finish no earlier than 2025-02-04 |
| 2129 |  | PEN Test | 2d | 2025-03-03 | 2025-03-04 | 2128 |  | 722d | finish no earlier than 2025-02-06 |
| 2130 |  | Regression Test | 10d | 2025-03-05 | 2025-03-18 | 2129 |  | 722d | finish no earlier than 2025-02-20 |
| 2131 | 1.6.4.1.6.5.5 | **DIP Onboarding (UIT)** | 101d | 2024-07-26 A | 2024-12-13 A |  | 100% |  |  |
| 2132 |  | DIP Simulator | 15d | 2024-07-26 A | 2024-08-15 A |  | 100% |  | finish no earlier than 2024-08-15 |
| 2133 |  | DIP (UIT) Instance available for Onboarding | 1d | 2024-08-05 A | 2024-08-05 A |  | 100% |  | start no earlier than 2024-08-05 |
| 2134 |  | DIP (UIT) Portal | 1d | 2024-09-03 A | 2024-09-03 A | 2133 | 100% |  | start no earlier than 2024-09-03 |
| 2135 |  | DIP (UIT) Onboarding for Development (incl. certificates and security compliance) | 39d | 2024-08-06 A | 2024-09-27 A | 2133 | 100% |  | finish no earlier than 2024-09-27 |
| 2136 |  | DIP (UIT) Onboarding for Development Connection Confirmed | 1d | 2024-09-30 A | 2024-09-30 A | 2135 | 100% |  | start no earlier than 2024-09-30 |
| 2137 |  | DIP (UIT) Onboarding for Test (incl. certificates and security compliance) | 5d | 2024-10-01 A | 2024-10-07 A | 2136 | 100% |  | finish no earlier than 2024-10-07 |
| 2138 |  | DIP (UIT) Onboarding for Test Connection Confirmed | 1d | 2024-10-08 A | 2024-10-08 A | 2137 | 100% |  | start no earlier than 2024-10-08 |
| 2139 |  | DIP (UIT) Onboarding for Prod (incl. certificates and security compliance) | 5d | 2024-10-09 A | 2024-10-15 A | 2138 | 100% |  | finish no earlier than 2024-10-15 |
| 2140 |  | DIP (UIT) Onboarding for Prod Connection Confirmed | 1d | 2024-10-16 A | 2024-10-16 A | 2139 | 100% |  | start no earlier than 2024-10-16 |
| 2141 |  | DIP UIT Test Stubs | 32d | 2024-10-31 A | 2024-12-13 A | 2136, 2138, 2140 | 100% |  | start no earlier than 2024-10-31 |
| 2142 | 1.6.4.1.6.5.6 | **DTN Onboarding** | 115d | 2024-05-20 A | 2024-10-25 A |  | 100% |  |  |
| 2143 |  | DTN Request Raised for Onboarding | 25d | 2024-05-20 A | 2024-06-21 A |  | 100% |  | start no earlier than 2024-05-20 |
| 2144 |  | Setup, configuration of New Host and Test Flags | 5d | 2024-06-24 A | 2024-06-28 A | 2143 | 100% |  | start no earlier than 2024-06-24 |
| 2145 |  | New VPN Connection (Test) | 30d | 2024-08-05 A | 2024-09-13 A | 2144 | 100% |  | start no earlier than 2024-08-05 |
| 2146 |  | New VPN Connection (Prod) | 30d | 2024-09-16 A | 2024-10-25 A | 2145 | 100% |  | finish no earlier than 2024-10-25 |
| 2147 |  | DTN Test Stubs | 10d | 2024-09-16 A | 2024-09-27 A | 2145 | 100% |  | start no earlier than 2024-09-16 |
| 2148 | 1.6.4.1.6.5.7 | **Generate Tooling** | 334d | 2024-04-22 A | 2025-07-31 |  | 100% |  |  |
| 2149 |  | MPAN Core Generator | 25d | 2024-04-22 A | 2024-05-24 A |  | 100% |  | finish no earlier than 2024-05-24 |
| 2150 |  | MPAN File Generator | 55d | 2024-05-27 A | 2024-08-09 A | 2149 | 100% |  | finish no earlier than 2024-08-09 |
| 2151 |  | MPAN Template Loader | 32d | 2024-08-12 A | 2024-09-24 A | 2150 | 100% |  | finish no earlier than 2024-09-24 |
| 2152 |  | ADO Extract (QTC) From SIT | 30d | 2024-05-06 A | 2024-06-14 A |  | 100% |  | finish no earlier than 2024-06-14 |
| 2153 |  | Populate QT ADO | 40d | 2024-06-17 A | 2024-08-09 A | 2152 | 100% |  | finish no earlier than 2024-08-09 |
| 2154 |  | Create QTC Spreadsheets | 20d | 2024-06-03 A | 2024-06-28 A | 2152 | 100% |  | finish no earlier than 2024-06-28 |
| 2155 |  | Upload QTC Spreadsheets to QTF | 20d | 2024-07-01 A | 2024-07-26 A | 2154 | 100% |  | finish no earlier than 2024-07-26 |
| 2156 |  | Create QTC Set / Master QTC Loader | 40d | 2024-07-22 A | 2024-09-13 A | 2155 | 100% |  | finish no earlier than 2024-09-13 |
| 2157 | 1.6.4.1.6.5.8 | **Test Data** | 15d | 2024-06-10 A | 2024-06-28 A |  | 100% |  |  |
| 2158 |  | Sample MPAN Data + Attributes from Suppliers | 15d | 2024-06-10 A | 2024-06-28 A |  | 100% |  | finish no earlier than 2024-06-28 |
| 2159 | 1.6.4.1.6.6 | **MPANs, DIP Messages, Settlement, Consumption, Reference** | 423d? | 2024-05-27 A | 2026-01-07 |  | 77% |  |  |
| 2160 |  | Create MPAN Data | 55d | 2024-05-27 A | 2024-08-09 A | 2149 | 100% |  | finish no earlier than 2024-08-09 |
| 2161 |  | Create message templates (DIP, CSS, DTN) | 40d | 2024-06-03 A | 2024-07-26 A |  | 100% |  | finish no earlier than 2024-07-26 |
| 2162 |  | Create Consumption Data Templates | 20d | 2024-09-16 A | 2024-10-11 A |  | 100% |  | finish no earlier than 2024-10-11 |
| 2163 |  | Load Consumption Data | 25d | 2024-11-11 A | 2024-12-13 A | 2162FS+20d | 100% |  |  |
| 2164 |  | Create Load Shape and Load Shape Total Templates | 20d | 2024-09-16 A | 2024-10-11 A |  | 100% |  | finish no earlier than 2024-10-11 |
| 2165 |  | Load Shape and Load Shape Total Data | 25d | 2024-11-11 A | 2024-12-13 A | 2164FS+20d | 100% |  |  |
| 2166 |  | Create Settlement Report Templates | 20d | 2024-09-16 A | 2024-10-11 A |  | 100% |  | finish no earlier than 2024-10-11 |
| 2167 |  | Load Settlement Report Data | 25d | 2024-11-11 A | 2024-12-13 A | 2166FS+20d | 100% |  |  |
| 2168 |  | Market Domain Data (MDD) For Legacy Systems | 25d | 2024-07-29 A | 2024-08-30 A |  | 100% |  | finish no earlier than 2024-08-30 |
| 2169 | 1.6.4.1.6.6.10 | **Industry Standing Data (ISD)** | 71d? | 2024-07-26 A | 2024-11-01 A |  | 100% |  |  |
| 2170 |  | Dependant on Receiving ISD Agreed Source Data from Helix | 1d | 2024-07-26 A | 2024-07-26 A |  | 100% |  | start no earlier than 2024-07-26 |

| ID | WBS | Task | Duration | Start | Finish | Predecessors | Complete | Total float | Constraint |
| --- | --- | --- | --- | --- | --- | --- | --- | --- | --- |
| 2171 |  | Helix Dev Environment migration | 6d | 2024-07-29 A | 2024-08-05 A | 2170 | 100% |  | finish no earlier than 2024-08-05 |
| 2172 |  | STGi (UK) migration | 5d | 2024-09-09 A | 2024-09-13 A | 2170 | 100% |  | finish no earlier than 2024-09-13 |
| 2173 |  | Maintenance window between cycle 2 and 3 | 1d | 2024-09-20 A | 2024-09-20 A | 2170 | 100% |  | finish no earlier than 2024-09-20 |
| 2174 |  | First View of Migrated ISD Data | 5d | 2024-09-23 A | 2024-09-27 A | 2173 | 100% |  | finish no earlier than 2024-09-27 |
| 2175 |  | Second View of Migrated ISD Data (HXT1 (SIT B) migration) | 5d | 2024-09-23 A | 2024-09-27 A | 2173 | 100% |  | finish no earlier than 2024-09-27 |
| 2176 |  | Final Cycle 3 Migrated ISD Data | 5d | 2024-10-07 A | 2024-10-11 A | 2174 | 100% |  | finish no earlier than 2024-10-11 |
| 2177 |  | Create ISD Template inc. DIP ID | 35d? | 2024-09-16 A | 2024-11-01 A | 2173 | 100% |  | finish no earlier than 2024-11-01 |
| 2178 |  | Publish Qualification ISD | 10d? | 2024-10-14 A | 2024-10-25 A | 2176, 2173 | 100% |  | finish no earlier than 2024-10-25 |
| 2179 | 1.6.4.1.6.6.11 | **BETA Testing 1 - Test Data** | 27d | 2024-11-01 A | 2024-12-09 |  | 100% |  |  |
| 2180 |  | Provide Example MPAN File | 3d | 2024-11-01 A | 2024-11-05 A | 2223SS | 100% |  | finish no earlier than 2024-11-05 |
| 2181 |  | Load Example MPAN File | 6d | 2024-11-06 A | 2024-11-13 A | 2180 | 100% |  | finish no earlier than 2024-11-13 |
| 2182 |  | Industry Standing Data (ISD) | 6d | 2024-11-06 A | 2024-11-13 A | 2223SS+3d | 100% |  | finish no earlier than 2024-11-13 |
| 2183 |  | Market Domain Data (MDD) | 6d | 2024-11-06 A | 2024-11-13 A | 2223SS+3d | 100% |  | finish no earlier than 2024-11-13 |
| 2184 |  | Load ISD / MDD Data | 1d | 2024-12-06 A | 2024-12-06 A | 2182FS+16d, 2183FS+11d | 100% |  | start no earlier than 2024-11-14 |
| 2185 |  | Create QTC sets and Test MPANs via QTF | 1d | 2024-12-06 A | 2024-12-06 A | 2181FS+16d | 100% |  | start no earlier than 2024-11-14 |
| 2186 |  | Create QTC sets in ADO via QTF | 1d | 2024-12-06 A | 2024-12-06 A | 2185SS | 100% |  | start no earlier than 2024-11-14 |
| 2187 |  | Provide Test MPANs (Suppliers only) allocated to specfic QTC's | 1d | 2024-12-06 A | 2024-12-06 A | 2184SS | 100% |  | start no earlier than 2024-11-14 |
| 2188 |  | Load Test MPANs | 1d | 2024-12-09 A | 2024-12-09 A | 2187 | 100% |  | start no earlier than 2024-11-15 |
| 2189 | 1.6.4.1.6.6.11.10 | **BETA Testing 2 - Test Data** | 11d | 2025-01-08 A | 2025-01-22 A |  | 100% |  |  |
| 2190 |  | Provide Example MPAN File | 3d | 2025-01-08 A | 2025-01-10 A | 2224SS | 100% |  | start no earlier than 2025-01-08 |
| 2191 |  | Load Example MPAN File | 6d | 2025-01-13 A | 2025-01-20 A | 2190 | 100% |  | start no earlier than 2025-01-13 |
| 2192 |  | Industry Standing Data (ISD) | 6d | 2025-01-08 A | 2025-01-15 A | 2178, 2224SS | 100% |  | start no earlier than 2025-01-08 |
| 2193 |  | Market Domain Data (MDD) | 6d | 2025-01-08 A | 2025-01-15 A | 2162, 2224SS | 100% |  | start no earlier than 2025-01-08 |
| 2194 |  | Load ISD / MDD Data | 1d | 2025-01-16 A | 2025-01-16 A | 2192, 2193, 2224SS | 100% |  | start no earlier than 2025-01-16 |
| 2195 |  | Create QTC sets and Test MPANs via QTF | 1d | 2025-01-21 A | 2025-01-21 A | 2191 | 100% |  | start no earlier than 2025-01-21 |
| 2196 |  | Create QTC sets in ADO via QTF | 1d | 2025-01-21 A | 2025-01-21 A | 2195SS | 100% |  | start no earlier than 2025-01-21 |
| 2197 |  | Provide Test MPANs (Suppliers only) allocated to specfic QTC's | 1d | 2025-01-21 A | 2025-01-21 A | 2195SS | 100% |  | start no earlier than 2025-01-21 |
| 2198 |  | Load Test MPANs | 1d | 2025-01-22 A | 2025-01-22 A | 2197 | 100% |  | start no earlier than 2025-01-22 |
| 2199 | 1.6.4.1.6.6.12 | **Wave 1 Test Data** | 46d | 2025-05-12 | 2025-07-15 | 2185SS |  |  |  |
| 2200 |  | Test Data Request + Templates Completed | 5d | 2025-06-02 | 2025-06-06 | 2184SS |  | 21d | start no earlier than 2025-06-02 |
| 2201 |  | Test Data Generated | 5d | 2025-06-09 | 2025-06-13 | 2187, 2200 |  | 21d | finish no earlier than 2025-06-03 |
| 2202 |  | Test Data Loaded into QP Systems | 15d | 2025-06-16 | 2025-07-04 | 2201 |  | 21d | finish no earlier than 2025-06-17 |
| 2203 |  | Test Data Loaded into QTF + ADO | 15d | 2025-07-07 | 2025-07-25 | 2201, 2202 |  | 21d | finish no earlier than 2025-06-17 |
| 2204 | 1.6.4.1.6.6.13 | **Wave 2 Test Data** | 42d | 2025-07-07 | 2025-09-03 |  |  |  |  |
| 2205 |  | Test Data Request + Templates Completed | 5d | 2025-07-28 | 2025-08-01 |  |  | 21d | start no earlier than 2025-07-28 |
| 2206 |  | Test Data Generated | 5d | 2025-08-04 | 2025-08-08 | 2205 |  | 21d | finish no earlier than 2025-07-29 |
| 2207 |  | Test Data Loaded into QP Systems | 15d | 2025-08-11 | 2025-08-29 | 2206 |  | 21d | finish no earlier than 2025-08-12 |
| 2208 |  | Test Data Loaded into QTF + ADO | 15d | 2025-09-01 | 2025-09-19 | 2206, 2207 |  | 21d | finish no earlier than 2025-08-12 |
| 2209 | 1.6.4.1.6.6.14 | **Wave 3 Test Data** | 45d | 2025-09-08 | 2025-11-10 |  |  |  |  |
| 2210 |  | Test Data Request + Templates Completed | 5d | 2025-10-20 | 2025-10-24 |  |  | 21d | start no earlier than 2025-10-20 |
| 2211 |  | Test Data Generated | 5d | 2025-10-27 | 2025-10-31 | 2210 |  | 21d | finish no earlier than 2025-09-29 |
| 2212 |  | Test Data Loaded into QP Systems | 15d | 2025-11-03 | 2025-11-21 | 2211 |  | 21d | finish no earlier than 2025-10-13 |
| 2213 |  | Test Data Loaded into QTF + ADO | 15d | 2025-11-24 | 2025-12-12 | 2211, 2212 |  | 21d | finish no earlier than 2025-10-13 |
| 2214 | 1.6.4.1.6.6.15 | **Wave 4 Test Data** | 45d | 2025-11-06 | 2026-01-08 |  |  |  |  |
| 2215 |  | Test Data Request + Templates Completed | 5d | 2025-12-15 | 2025-12-19 |  |  | 21d | start no earlier than 2025-12-15 |
| 2216 |  | Test Data Generated | 5d | 2025-12-22 | 2025-12-26 | 2215 |  | 21d | finish no earlier than 2025-11-27 |
| 2217 |  | Test Data Loaded into QP Systems | 15d | 2025-12-29 | 2026-01-16 | 2216 |  | 21d | finish no earlier than 2025-12-11 |
| 2218 |  | Test Data Loaded into QTF + ADO | 15d | 2026-01-19 | 2026-02-06 | 2216, 2217 |  | 21d | finish no earlier than 2025-12-11 |
| 2219 | 1.6.4.1.6.6.16 | **Governance** | 195d | 2024-07-01 A | 2025-03-28 |  | 89% | 714d |  |
| 2220 |  | Onboarding Strategy and Develop Training Requirements & Materials Inc. Day in the Life | 120d | 2024-07-01 A | 2024-12-13 A | 2098 | 100% |  | finish no earlier than 2024-12-13 |
| 2221 |  | Design Approach & Set-Up ADO Tool for Test & Defect Management Tool | 20d | 2024-07-01 A | 2024-07-26 A | 2220SS | 100% |  |  |
| 2222 |  | Knowledge Transfer, Training, Demonstrations, Documentation, Governance | 78d | 2024-08-30 A | 2024-12-17 A | 2220SS+44d | 100% |  |  |
| 2223 |  | BETA Testing | 33d | 2024-11-01 A | 2024-12-17 A |  | 100% |  | finish no earlier than 2024-12-17 |
| 2224 |  | BETA Testing 2 | 58d | 2025-01-08 A | 2025-03-28 | 2223 | 40% | 714d | start no earlier than 2025-01-08 |
| 2225 |  | Qualification Testing Framework Readiness Confirmed | 0d | 2025-03-28 | 2025-03-28 | 2224 |  | 714d | start no earlier than 2025-03-28 |
| 2226 |  | Qualification Testing Wave Readiness Confirmed | 0d | 2025-08-21 | 2025-08-21 | 2254FS-2d |  | 611d | finish no earlier than 2025-05-30 |
| 2227 | 1.6.4.1.7 | **Wave Allocation** | 129d | 2024-01-02 A | 2024-06-28 A |  | 100% |  |  |
| 2228 |  | Draft Pre-Qualification Submission (PQS) document | 20d | 2024-01-02 A | 2024-01-29 A |  | 100% |  | finish no earlier than 2024-01-26 |
| 2229 |  | Publish PQS document | 1d | 2024-01-31 A | 2024-01-31 A |  | 100% |  | start no earlier than 2024-01-31 |
| 2230 |  | PQS Submission window | 60d | 2024-02-05 A | 2024-04-26 A |  | 100% |  | start no earlier than 2024-02-05 |
| 2231 |  | Pre-Qualification Submission and PIT Test Plan Deadline for Submission​ | 0d | 2024-04-26 A | 2024-04-26 A | 2230 | 100% |  |  |
| 2232 |  | PQS Review by Code Bodies | 25d | 2024-04-29 A | 2024-05-31 A | 2230, 2231 | 100% |  |  |
| 2233 |  | Draft Wave Allocations | 15d | 2024-06-03 A | 2024-06-21 A | 2232 | 100% |  |  |
| 2234 |  | Confirmation of participant Qualification Wave allocation | 0d | 2024-06-28 A | 2024-06-28 A | 2233FS+5d | 100% |  |  |
| 2235 | 1.6.4.2 | **Qualification Wave 1** | 248d | 2025-05-05 | 2026-04-15 |  |  | 0d |  |
| 2236 | 1.6.4.2.1 | **Qualification Wave 1 QAD Prep** | 80d | 2025-05-05 | 2025-08-22 |  |  | 1d |  |
| 2237 |  | Initial QAD Submission window opens | 0d | 2025-05-05 | 2025-05-05 | 2234, 2019FS+1d |  | 1d | start no earlier than 2025-03-24 |
| 2238 |  | Qualification Wave 1 Participants Submit Initial QAD | 50d | 2025-05-05 | 2025-07-11 | 2237FS-1d |  | 1d |  |
| 2239 |  | Qualification Wave 1 Participants have submitted their initial QAD | 0d | 2025-07-14 | 2025-07-14 | 2238FS+1d |  | 1d |  |
| 2240 |  | Code Bodies review of Wave 1 Participants Initial QAD | 30d | 2025-07-14 | 2025-08-22 | 2238FS-1d, 2239FS-1d |  | 1d |  |

| ID | WBS | Task | Duration | Start | Finish | Predecessors | Total float | Constraint |
| --- | --- | --- | --- | --- | --- | --- | --- | --- |
| 2241 |  | Completion of Code Bodies review of Initial QAD | 0d | 2025-08-22 | 2025-08-22 | 2240 | 1d |  |
| 2242 | 1.6.4.2.2 | **Qualification Wave 1 Test Prep** | 60d | 2025-05-26 | 2025-08-15 |  | 6d |  |
| 2243 |  | Confirmation from Qualification Wave 1 Participants that DIP onboarding has commenced | 0d | 2025-05-26 | 2025-05-26 |  | 26d | start no earlier than 2025-05-26 |
| 2244 |  | Qualification Wave 1 Participants DIP Onboarding Window | 35d | 2025-05-26 | 2025-07-11 | 2243 | 26d |  |
| 2245 |  | Confirmation from Qualification Wave 1 Participants that DIP onboarding has completed | 0d | 2025-07-11 | 2025-07-11 | 2244 | 26d |  |
| 2246 |  | Qualification Wave 1 Participants' to provide status of PIT completion and submit QT Test Plan | 0d | 2025-06-13 | 2025-06-13 |  | 32d | start no earlier than 2025-06-13 |
| 2247 |  | Review of Participants' PIT Status and QT Test Plan | 15d | 2025-06-13 | 2025-07-03 | 2246 | 32d |  |
| 2248 |  | Qualification Test Plans for Wave 1 Participants approved | 0d | 2025-07-03 | 2025-07-03 | 2247 | 32d |  |
| 2249 |  | Qualification Wave 1 Participants have submitted PIT Test Completion Report and evidence for QT Entry | 0d | 2025-07-14 | 2025-07-14 |  | 1d | start no earlier than 2025-07-14 |
| 2250 |  | Review of Participants PIT Test Completion Report | 25d | 2025-07-14 | 2025-08-15 | 2249 | 1d |  |
| 2251 |  | Onboarding to QTF & ADO | 25d | 2025-07-14 | 2025-08-15 | 2250SS | 6d |  |
| 2252 | 1.6.4.2.3 | **Qualification Wave 1 QT Execution** | 105d | 2025-08-18 | 2026-01-09 |  | 1d |  |
| 2253 |  | Review Entry Criteria Evidence for each Wave 1 Participant | 5d | 2025-08-18 | 2025-08-22 | 2241FF, 2245, 2248, 2250 | 1d |  |
| 2254 |  | Qualification Wave 1 Participant Test Readiness Confirmed | 0d | 2025-08-22 | 2025-08-22 | 2240, 2241, 2253FF | 1d |  |
| 2255 |  | Qualification Wave 1 QT Execution Start | 0d | 2025-08-25 | 2025-08-25 | 2254, 2251, 1597FS+6d, 2203 | 0d | start no earlier than 2025-07-14 |
| 2256 |  | Qualification Wave 1 QT Execution Window | 100d | 2025-08-25 | 2026-01-09 | 2255FS-1d | 5d |  |
| 2257 |  | Qualification Wave 1 QT Projected Execution End | 0d | 2026-01-09 | 2026-01-09 | 2256 | 5d |  |
| 2258 | 1.6.4.2.4 | **Qualification Wave 1 Exit** | 168d | 2025-08-25 | 2026-04-15 |  | 0d |  |
| 2259 |  | Final QAD Submission window opens | 0d | 2025-08-25 | 2025-08-25 | 2255 | 0d |  |
| 2260 |  | Qualification Wave 1 Participants submit their Final QAD | 105d | 2025-08-25 | 2026-01-16 | 2259FS-1d | 0d |  |
| 2261 |  | Qualification Wave 1 Participants have submitted their final QAD | 0d | 2026-01-16 | 2026-01-16 | 2260, 2257 | 0d |  |
| 2262 |  | Completion of Code Bodies review of Final QAD | 35d | 2026-01-19 | 2026-03-06 | 2260, 2261 | 0d |  |
| 2263 |  | QAD Sign Off deadline | 1d | 2026-03-20 | 2026-03-20 | 2262FS+9d | 0d |  |
| 2264 |  | Qualification Wave 1 Participants Qualification approved by BSC PAB and REC Manager | 0d | 2026-04-15 | 2026-04-15 | 2263FS+18d | 0d |  |
| 2265 | 1.6.4.3 | **Qualification Wave 2** | 254d | 2025-06-09 | 2026-05-28 |  | 0d |  |
| 2266 | 1.6.4.3.1 | **Qualification Wave 2 QAD Prep** | 95d | 2025-06-09 | 2025-10-17 |  | 0d |  |
| 2267 |  | Initial QAD Submission window opens | 0d | 2025-06-09 | 2025-06-09 | 2020FS+1d | 0d |  |
| 2268 |  | Qualification Wave 2 Participants Submit Initial QAD | 70d | 2025-06-09 | 2025-09-12 | 2267FS-1d | 0d |  |
| 2269 |  | Qualification Wave 2 Participants have submitted their initial QAD | 0d | 2025-09-12 | 2025-09-12 | 2268 | 0d |  |
| 2270 |  | Code Bodies review of Wave 2 Participants' Initial QAD | 25d | 2025-09-15 | 2025-10-17 | 2269 | 0d |  |
| 2271 |  | Completion of Code Bodies review of Initial QAD | 0d | 2025-10-17 | 2025-10-17 | 2270 | 0d |  |
| 2272 | 1.6.4.3.2 | **Qualification Wave 2 Test Prep** | 60d | 2025-07-21 | 2025-10-10 |  | 6d |  |
| 2273 |  | Confirmation from Qualification Wave 2 Participants that DIP Onboarding has commenced | 0d | 2025-07-21 | 2025-07-21 |  | 25d | start no earlier than 2025-07-21 |
| 2274 |  | Qualification Wave 2 Participants DIP Onboarding Window | 35d | 2025-07-21 | 2025-09-05 | 2273 | 25d |  |
| 2275 |  | Confirmation from Qualificiation Wave 2 Participants that DIP onboarding has completed | 0d | 2025-09-05 | 2025-09-05 | 2274 | 25d |  |
| 2276 |  | Qualification Wave 2 Participants' to provide status of PIT completion and submit QT Test Plan | 0d | 2025-08-18 | 2025-08-18 |  | 25d | start no earlier than 2025-08-18 |
| 2277 |  | Review of Participants' PIT Status and QT Test Plan | 15d | 2025-08-18 | 2025-09-05 | 2276 | 25d | start no earlier than 2025-07-07 |
| 2278 |  | Qualification Test Plans for Wave 2 Participants approved | 0d | 2025-09-05 | 2025-09-05 | 2277 | 25d | start no earlier than 2025-07-25 |
| 2279 |  | Qualification Wave 2 Participants have submitted PIT Test Completion Report and evidence for QT entry | 0d | 2025-09-08 | 2025-09-08 |  | 0d | start no earlier than 2025-09-08 |
| 2280 |  | Review of Participants' PIT Test Completion Report | 25d | 2025-09-08 | 2025-10-10 | 2279 | 0d |  |
| 2281 |  | Onboarding to QTF & ADO | 25d | 2025-09-08 | 2025-10-10 | 2280SS | 6d |  |
| 2282 | 1.6.4.3.3 | **Qualification Wave 2 QT Execution** | 100d | 2025-10-13 | 2026-02-27 |  | 0d |  |
| 2283 |  | Review Entry Criteria Evidence for each Wave 2 Participant | 5d | 2025-10-13 | 2025-10-17 | 2271FF, 2275, 2278, 2280 | 0d |  |
| 2284 |  | Qualification Wave 2 Participant Test Readiness Confirmed | 0d | 2025-10-17 | 2025-10-17 | 2283, 2271 | 0d |  |
| 2285 |  | Qualification Wave 2 Execution Start | 0d | 2025-10-20 | 2025-10-20 | 2284FS+1d, 2281, 2208 | 0d |  |
| 2286 |  | Qualification Wave 2 QT Execution Window | 95d | 2025-10-20 | 2026-02-27 | 2285SS-1d | 5d |  |
| 2287 |  | Qualfication Wave 2 QT Execution End | 0d | 2026-02-27 | 2026-02-27 | 2286 | 5d |  |
| 2288 | 1.6.4.3.4 | **Qualification Wave 2 Exit** | 159d | 2025-10-20 | 2026-05-28 |  | 0d |  |
| 2289 |  | Final QAD Submission window opens | 0d | 2025-10-20 | 2025-10-20 | 2285 | 0d |  |
| 2290 |  | Qualification Wave 2 Participants submit their Final QAD | 100d | 2025-10-20 | 2026-03-06 | 2289FS-1d | 0d |  |
| 2291 |  | Qualification Wave 2 Participants have submitted their final QAD | 0d | 2026-03-06 | 2026-03-06 | 2290, 2287 | 0d |  |
| 2292 |  | Completion of Code Bodies review of Final QAD | 26d | 2026-03-09 | 2026-04-13 | 2291 | 0d |  |
| 2293 |  | QAD Sign Off deadline | 1d | 2026-04-20 | 2026-04-20 | 2292FS+4d | 0d |  |
| 2294 |  | Qualification Wave 2 Participants Qualification approved by BSC PAB and REC Manager | 0d | 2026-05-28 | 2026-05-28 | 2293FS+28d | 0d |  |
| 2295 | 1.6.4.4 | **Qualification Wave 3** | 254d | 2025-08-11 | 2026-07-30 |  | 0d |  |
| 2296 | 1.6.4.4.1 | **Qualification Wave 3 QAD Prep** | 95d | 2025-08-11 | 2025-12-19 |  | 0d |  |
| 2297 |  | Initial QAD Submission window opens | 0d | 2025-08-11 | 2025-08-11 | 2021FS+1d | 0d |  |
| 2298 |  | Qualification Wave 3 Participants Submit Initial QAD | 65d | 2025-08-11 | 2025-11-07 | 2297FS-1d | 0d |  |
| 2299 |  | Qualification Wave 3 Participants have submitted their initial QAD | 0d | 2025-11-07 | 2025-11-07 | 2298 | 0d |  |
| 2300 |  | Code Bodies review of Wave 3 Participants' Initial QAD | 30d | 2025-11-10 | 2025-12-19 | 2299 | 0d |  |
| 2301 |  | Completion of Code Bodies review of Initial QAD | 0d | 2025-12-19 | 2025-12-19 | 2300 | 0d |  |
| 2302 | 1.6.4.4.2 | **Qualification Wave 3 Test Prep** | 65d | 2025-09-15 | 2025-12-12 |  | 30d |  |
| 2303 |  | Confirmation from Qualification Wave 3 Participants that DIP Onboarding has commenced | 0d | 2025-09-15 | 2025-09-15 |  | 30d | start no earlier than 2025-09-15 |
| 2304 |  | Qualification Wave 3 Participants DIP Onboarding window | 35d | 2025-09-15 | 2025-10-31 | 2303 | 30d | start no earlier than 2025-08-04 |
| 2305 |  | Confirmation from Qualification Wave 3 Participants that DIP onboarding has completed | 0d | 2025-10-31 | 2025-10-31 | 2304 | 30d | start no earlier than 2025-09-22 |
| 2306 |  | Qualification Wave 3 Participants' to provide status of PIT completion and submit QT Test Plan | 0d | 2025-10-20 | 2025-10-20 |  | 554d | start no earlier than 2025-10-20 |
| 2307 |  | Review of Participants' PIT Status and QT Test Plan | 15d | 2025-10-20 | 2025-11-07 | 2306 | 554d | start no earlier than 2025-09-08 |
| 2308 |  | Qualification Test Plans for Wave 3 Participants approved | 0d | 2025-11-07 | 2025-11-07 | 2307 | 554d | start no earlier than 2025-09-26 |
| 2309 |  | Qualification Wave 3 Participants have submitted PIT Test Completion Report and evidence for QT Entry | 0d | 2025-11-10 | 2025-11-10 |  | 0d | start no earlier than 2025-11-10 |
| 2310 |  | Review of Participants' PIT Test Completion Report | 25d | 2025-11-10 | 2025-12-12 | 2309 | 0d | start no earlier than 2025-09-29 |

| ID | WBS | Task | Duration | Start | Finish | Predecessors | Complete | Total float | Constraint |
| --- | --- | --- | --- | --- | --- | --- | --- | --- | --- |
| 2311 |  | Onboarding to QTF & ADO | 25d | 2025-11-10 | 2025-12-12 | 2310SS |  | 0d | finish no earlier than 2025-10-31 |
| 2312 | 1.6.4.4.3 | **Qualification Wave 3 QT Execution** | 102d | 2025-11-03 | 2026-03-24 |  |  |  |  |
| 2313 |  | Review Entry Criteria Evidence for each Wave 3 Participant | 5d | 2025-12-15 | 2025-12-19 | 2305, 2301FF, 2311 |  | 0d | start no earlier than 2025-11-03 |
| 2314 |  | Qualification Wave 3 Participant Test Readiness confirmed | 0d | 2025-12-19 | 2025-12-19 | 2305, 2313 |  | 0d |  |
| 2315 |  | Qualification Wave 3 Execution Start | 0d | 2026-01-12 | 2026-01-12 | 2314FS+16d, 2311FS+1d, 2213 |  | 0d | start no earlier than 2025-11-03 |
| 2316 |  | Qualification Wave 3 QT Execution Window | 90d | 2026-01-12 | 2026-05-15 | 2313, 2315FS-1d |  | 5d |  |
| 2317 |  | Qualification Wave 3 Projected Execution End | 0d | 2026-05-15 | 2026-05-15 | 2316 |  | 5d |  |
| 2318 | 1.6.4.4.4 | **Qualification Wave 3 Exit** | 144d | 2026-01-12 | 2026-07-30 |  |  | 0d |  |
| 2319 |  | Final QAD Submission window opens | 0d | 2026-01-12 | 2026-01-12 | 2315 |  | 0d |  |
| 2320 |  | Qualification Wave 3 Participants submit their Final QAD | 95d | 2026-01-12 | 2026-05-22 | 2319FS-1d |  | 0d |  |
| 2321 |  | Qualification Wave 3 Participants have submitted their Final QAD | 0d | 2026-05-22 | 2026-05-22 | 2320, 2317 |  | 0d |  |
| 2322 |  | Completion of Code Bodies review of Final QAD | 20d | 2026-05-25 | 2026-06-19 | 2321 |  | 0d |  |
| 2323 |  | QAD Sign Off deadline | 1d | 2026-06-26 | 2026-06-26 | 2322FS+4d |  | 0d |  |
| 2324 |  | Qualification Wave 3 Participants Qualification approved by BSC PAB and REC Manager | 0d | 2026-07-30 | 2026-07-30 | 2323FS+24d |  | 0d |  |
| 2325 | 1.6.4.5 | **Qualification Wave 4** | 526d | 2025-01-23 | 2027-01-28 |  |  | 192d |  |
| 2326 | 1.6.4.5.1 | **Qualification Wave 4 QAD Prep** | 95d | 2025-10-20 | 2026-02-27 |  |  | 0d |  |
| 2327 |  | Initial QAD Submission window opens | 0d | 2025-10-20 | 2025-10-20 | 2022FS+1d |  | 0d |  |
| 2328 |  | Qualification Wave 4 Participants Submit Initial QAD | 65d | 2025-10-20 | 2026-01-16 | 2327FS-1d |  | 0d |  |
| 2329 |  | Qualification Wave 4 Participants have submitted their Initial QAD | 0d | 2026-01-16 | 2026-01-16 | 2328 |  | 0d |  |
| 2330 |  | Code Bodies review of Wave 4 Participants' Initial QAD | 30d | 2026-01-19 | 2026-02-27 | 2329 |  | 0d |  |
| 2331 |  | Completion of Code Bodies review of Initial QAD | 0d | 2026-02-27 | 2026-02-27 | 2330 |  | 0d |  |
| 2332 | 1.6.4.5.2 | **Qualification Wave 4 Test Prep** | 75d | 2025-11-03 | 2026-02-13 |  |  | 16d |  |
| 2333 |  | Confirmation from Qualification 4 Participants that DIP Onboarding has commenced | 0d | 2025-11-03 | 2025-11-03 |  |  | 50d | start no earlier than 2025-11-03 |
| 2334 |  | Qualification Wave 4 Participants DIP Onboarding Window | 35d | 2025-11-03 | 2025-12-19 | 2333 |  | 50d |  |
| 2335 |  | Confirmation from Qualification Wave 4 Participants that DIP onboarding has completed | 0d | 2025-12-19 | 2025-12-19 | 2334 |  | 50d |  |
| 2336 |  | Qualification Wave 4 Participants' to provide status of PIT completion and submit QT Test Plan | 0d | 2025-12-08 | 2025-12-08 |  |  | 16d | start no earlier than 2025-12-08 |
| 2337 |  | Review of Participants' PIT Status and QT Test Plan | 25d | 2025-12-08 | 2026-01-09 | 2336 |  | 16d |  |
| 2338 |  | Qualification Test Plans for Qualification Wave 4 Participants approved | 0d | 2026-01-09 | 2026-01-09 | 2337 |  | 16d |  |
| 2339 |  | Qualification Wave 4 Participants have submitted PIT Test Completion Report and evidence for QT entry | 0d | 2026-01-09 | 2026-01-09 | 2338 |  | 16d |  |
| 2340 |  | Review of Participants' PIT Test Completion Report | 25d | 2026-01-12 | 2026-02-13 | 2339 |  | 16d |  |
| 2341 |  | Onboarding to QTF & ADO | 25d | 2026-01-12 | 2026-02-13 | 2340SS |  | 16d | start no earlier than 2025-11-24 |
| 2342 | 1.6.4.5.3 | **Qualification Wave 4 QT Execution** | 100d | 2026-03-02 | 2026-07-17 |  |  | 0d |  |
| 2343 |  | Review Entry Criteria Evidence for each Wave 4 Participant | 5d | 2026-03-02 | 2026-03-06 | 2331FF+5d, 2335 |  | 0d |  |
| 2344 |  | Qualification Wave 4 Participant Test Readiness Confirmed | 0d | 2026-03-06 | 2026-03-06 | 2335, 2343 |  | 0d |  |
| 2345 |  | Qualification Wave 4 QT Execution Start | 0d | 2026-03-09 | 2026-03-09 | 2344FS+1d, 2341, 2218 |  | 0d | start no earlier than 2026-01-07 |
| 2346 |  | Qualification Wave 4 QT Execution Window | 95d | 2026-03-09 | 2026-07-17 | 2345FS-1d, 2343 |  | 5d |  |
| 2347 |  | Qualification Wave 4 Projected Execution End | 0d | 2026-07-17 | 2026-07-17 | 2346 |  | 5d |  |
| 2348 | 1.6.4.5.4 | **Qualification Wave 4 Exit** | 144d | 2026-03-09 | 2026-09-24 |  |  | 0d |  |
| 2349 |  | Final QAD Submission window opens | 0d | 2026-03-09 | 2026-03-09 | 2345 |  | 0d |  |
| 2350 |  | Qualification Wave 4 Participants submit their Final QAD | 100d | 2026-03-09 | 2026-07-24 | 2349FS-1d |  | 0d |  |
| 2351 |  | Qualification Wave 4 Participants have submitted their Final QAD | 0d | 2026-07-24 | 2026-07-24 | 2350, 2347 |  | 0d |  |
| 2352 |  | Completion of Code Bodies review of Final QAD | 20d | 2026-07-27 | 2026-08-21 | 2351 |  | 0d |  |
| 2353 |  | QAD Sign Off deadline | 1d | 2026-08-28 | 2026-08-28 | 2352FS+4d |  | 0d |  |
| 2354 |  | Qualification Wave 4 Participants Qualification approved by BSC PAB and REC Manager | 0d | 2026-09-24 | 2026-09-24 | 2353FS+19d |  | 0d |  |
| 2355 | 1.6.4.5.5 | **Qualification Tier 1 Milestone** | 66d | 2026-10-28 | 2027-01-28 |  |  | 235d |  |
| 2356 |  | All suppliers must be able to access MPANs under the new TOM (M14) | 0d | 2026-10-28 | 2026-10-28 | 2354FS+24d |  | 235d | start no earlier than 2026-03-12 |
| 2357 |  | All suppliers must be able to access MPANs under the new TOM (M14*) - Late Exit | 0d | 2027-01-28 | 2027-01-28 | 2356FS+66d |  | 235d |  |
| 2358 | 1.6.4.5.6 | **PAB dates** | 235d | 2025-01-23 | 2025-12-18 |  |  | 526d |  |
| 2359 |  | PAB288 | 0d | 2025-01-23 | 2025-01-23 |  |  | 761d | start no earlier than 2025-01-23 |
| 2360 |  | PAB289 | 2d | 2025-02-26 | 2025-02-27 |  |  | 735d | start no earlier than 2025-02-26 |
| 2361 |  | PAB290 | 0d | 2025-03-12 | 2025-03-12 |  |  | 727d | start no earlier than 2025-03-12 |
| 2362 |  | PAB291 | 0d | 2025-03-27 | 2025-03-27 |  |  | 716d | start no earlier than 2025-03-27 |
| 2363 |  | PAB292 | 0d | 2025-04-09 | 2025-04-09 |  |  | 707d | start no earlier than 2025-04-09 |
| 2364 |  | PAB293 | 0d | 2025-04-24 | 2025-04-24 |  |  | 696d | start no earlier than 2025-04-24 |
| 2365 |  | PAB294 | 0d | 2025-05-14 | 2025-05-14 |  |  | 682d | start no earlier than 2025-05-14 |
| 2366 |  | PAB295 | 0d | 2025-05-29 | 2025-05-29 |  |  | 671d | start no earlier than 2025-05-29 |
| 2367 |  | PAB296 | 0d | 2025-06-11 | 2025-06-11 |  |  | 662d | start no earlier than 2025-06-11 |
| 2368 |  | PAB297 | 0d | 2025-06-26 | 2025-06-26 |  |  | 651d | start no earlier than 2025-06-26 |
| 2369 |  | PAB298 | 0d | 2025-07-16 | 2025-07-16 |  |  | 637d | start no earlier than 2025-07-16 |
| 2370 |  | PAB299 | 0d | 2025-07-31 | 2025-07-31 |  |  | 626d | start no earlier than 2025-07-31 |
| 2371 |  | PAB300 | 0d | 2025-08-13 | 2025-08-13 |  |  | 617d | start no earlier than 2025-08-13 |
| 2372 |  | PAB301 | 0d | 2025-08-28 | 2025-08-28 |  |  | 606d | start no earlier than 2025-08-28 |
| 2373 |  | PAB302 | 0d | 2025-09-10 | 2025-09-10 |  |  | 597d | start no earlier than 2025-09-10 |
| 2374 |  | PAB303 | 0d | 2025-09-25 | 2025-09-25 |  |  | 586d | start no earlier than 2025-09-25 |
| 2375 |  | PAB304 | 0d | 2025-10-15 | 2025-10-15 |  |  | 572d | start no earlier than 2025-10-15 |
| 2376 |  | PAB305 | 0d | 2025-10-30 | 2025-10-30 |  |  | 561d | start no earlier than 2025-10-30 |
| 2377 |  | PAB306 | 0d | 2025-11-12 | 2025-11-12 |  |  | 552d | start no earlier than 2025-11-12 |
| 2378 |  | PAB307 | 0d | 2025-11-27 | 2025-11-27 |  |  | 541d | start no earlier than 2025-11-27 |
| 2379 |  | PAB308 | 0d | 2025-12-18 | 2025-12-18 |  |  | 526d | start no earlier than 2025-12-18 |
| 2380 | 1.7 | **REGULATORY** | 823d | 2022-10-31 A | 2025-12-24 |  | 99% | 521d |  |

| ID | WBS | Task | Duration | Start | Finish | Predecessors | Complete | Constraint |
| --- | --- | --- | --- | --- | --- | --- | --- | --- |
| 2381 | 1.7.1 | **Baseline MHHS Code Changes** | 475d | 2022-10-31 A | 2024-08-23 A |  | 100% |  |
| 2382 | 1.7.1.1 | **Preparation and planning** | 35d | 2022-10-31 A | 2022-12-16 A |  | 100% |  |
| 2383 |  | Impact assessment of Programme design on codes to determine required changes | 20d | 2022-10-31 A | 2022-11-25 A | 47 | 100% |  |
| 2384 |  | Become 'code draft ready' | 35d | 2022-10-31 A | 2022-12-16 A |  | 100% |  |
| 2385 |  | Soft start drafting where possible | 35d | 2022-10-31 A | 2022-12-16 A |  | 100% |  |
| 2386 | 1.7.1.2 | **Code drafting** | 443d | 2022-12-12 A | 2024-08-21 A |  | 100% |  |
| 2387 | 1.7.1.2.1 | **Data Services (BSC driven)** | 118d | 2022-12-12 A | 2023-05-24 A |  | 100% |  |
| 2388 |  | Pre Code Drafting activities | 5d | 2022-12-12 A | 2022-12-16 A |  | 100% | start no earlier than 2022-12-12 |
| 2389 |  | Code and subsidiary document drafting takes place offline | 19d | 2023-01-03 A | 2023-01-27 A | 2388FS+11d | 100% |  |
| 2390 |  | Internal review and cross-checking of drafting across code drafters | 11d | 2023-01-30 A | 2023-02-13 A | 2389 | 100% |  |
| 2391 |  | External industry review via consultation | 20d | 2023-02-14 A | 2023-03-13 A | 2390 | 100% |  |
| 2392 |  | Triage and action comments | 19d | 2023-03-10 A | 2023-04-05 A | 2391FS-2d | 100% |  |
| 2393 |  | CDWG review | 30d | 2023-04-06 A | 2023-05-17 A | 2392 | 100% |  |
| 2394 |  | CCAG review | 5d | 2023-05-18 A | 2023-05-24 A | 2393 | 100% |  |
| 2395 |  | Code drafting for Data Services topic area approved | 0d | 2023-05-24 A | 2023-05-24 A | 2394 | 100% |  |
| 2396 | 1.7.1.2.2 | **Metering (REC driven)** | 118d | 2022-12-12 A | 2023-05-24 A |  | 100% |  |
| 2397 |  | Pre Code Drafting activities | 5d | 2022-12-12 A | 2022-12-16 A | 2388SS | 100% |  |
| 2398 |  | Code and subsidiary document drafting takes place offline | 19d | 2023-01-03 A | 2023-01-27 A | 2397FS+11d | 100% |  |
| 2399 |  | Internal review and cross-checking of drafting across code drafters | 11d | 2023-01-30 A | 2023-02-13 A | 2398 | 100% |  |
| 2400 |  | External industry review via consultation | 20d | 2023-02-14 A | 2023-03-13 A | 2399 | 100% |  |
| 2401 |  | Triage and action comments | 19d | 2023-03-10 A | 2023-04-05 A | 2400FS-2d | 100% |  |
| 2402 |  | CDWG review | 30d | 2023-04-06 A | 2023-05-17 A | 2401 | 100% |  |
| 2403 |  | CCAG review | 5d | 2023-05-18 A | 2023-05-24 A | 2402 | 100% |  |
| 2404 |  | Code drafting for Metering topic area approved | 0d | 2023-05-24 A | 2023-05-24 A | 2403 | 100% |  |
| 2405 | 1.7.1.2.3 | **BSC Central Services (BSC driven)** | 156d | 2023-02-22 A | 2023-09-27 A |  | 100% |  |
| 2406 |  | Pre Code Drafting activities | 5d | 2023-02-22 A | 2023-02-28 A | 2407SS-5d | 100% |  |
| 2407 |  | Code Drafting (offline) | 80d | 2023-03-01 A | 2023-06-20 A | 2391SS | 100% | must start on 2023-03-01 |
| 2408 |  | Internal review and cross-checking of drafting across code drafters | 70d | 2023-03-15 A | 2023-06-20 A | 2407SS+10d | 100% |  |
| 2409 |  | External industry review via consultation | 15d | 2023-06-21 A | 2023-07-11 A | 2408 | 100% |  |
| 2410 |  | Triage and action comments | 19d | 2023-07-10 A | 2023-08-03 A | 2409FS-2d | 100% |  |
| 2411 |  | CDWG review | 28d | 2023-08-04 A | 2023-09-12 A | 2410 | 100% |  |
| 2412 |  | CCAG review | 11d | 2023-09-13 A | 2023-09-27 A | 2411 | 100% |  |
| 2413 |  | Code drafting for BSC Central Services topic area approved | 0d | 2023-09-27 A | 2023-09-27 A | 2412 | 100% |  |
| 2414 | 1.7.1.2.4 | **Registration (BSC & REC driven)** | 131d | 2023-02-22 A | 2023-08-23 A |  | 100% |  |
| 2415 |  | Pre Code Drafting activities | 5d | 2023-02-22 A | 2023-02-28 A | 2416SS-5d | 100% |  |
| 2416 |  | Code Drafting (offline) | 65d | 2023-03-01 A | 2023-05-30 A | 2390, 2399 | 100% | must start on 2023-03-01 |
| 2417 |  | Internal review and cross-checking of drafting across code drafters | 55d | 2023-03-15 A | 2023-05-30 A | 2416SS+10d | 100% |  |
| 2418 |  | External industry review via consultation | 15d | 2023-05-31 A | 2023-06-20 A | 2417 | 100% |  |
| 2419 |  | Triage and action comments | 19d | 2023-06-19 A | 2023-07-13 A | 2418FS-2d | 100% |  |
| 2420 |  | CDWG review | 18d | 2023-07-14 A | 2023-08-08 A | 2419 | 100% |  |
| 2421 |  | CCAG review | 11d | 2023-08-09 A | 2023-08-23 A | 2420 | 100% |  |
| 2422 |  | Code drafting for Registration topic area approved | 0d | 2023-08-23 A | 2023-08-23 A | 2421 | 100% |  |
| 2423 | 1.7.1.2.5 | **Governance and Qualification (BSC & REC driven)** | 130d | 2023-05-25 A | 2023-11-22 A |  | 100% |  |
| 2424 |  | Pre Code Drafting activities | 5d | 2023-05-25 A | 2023-05-31 A | 2425SS-5d | 100% |  |
| 2425 |  | Code Drafting (offline) | 55d | 2023-06-01 A | 2023-08-16 A | 2418SS+1d | 100% |  |
| 2426 |  | Internal review and cross-checking of drafting across code drafters | 45d | 2023-06-15 A | 2023-08-16 A | 2425SS+10d | 100% |  |
| 2427 |  | External industry review via consultation | 15d | 2023-08-18 A | 2023-09-07 A | 2426FS+1d | 100% |  |
| 2428 |  | Triage and action comments | 19d | 2023-09-06 A | 2023-10-02 A | 2427FS-2d | 100% |  |
| 2429 |  | CDWG review | 31d | 2023-10-03 A | 2023-11-14 A | 2428 | 100% |  |
| 2430 |  | CCAG review | 6d | 2023-11-15 A | 2023-11-22 A | 2429 | 100% |  |
| 2431 |  | Code drafting for Governance and Qualification topic areas approved | 0d | 2023-11-22 A | 2023-11-22 A | 2430 | 100% |  |
| 2432 | 1.7.1.2.6 | **Interfaces / Data Specification (REC driven)** | 174d | 2023-05-25 A | 2024-01-23 A |  | 100% |  |
| 2433 |  | Pre Code Drafting activities | 5d | 2023-05-25 A | 2023-05-31 A | 2434SS-5d | 100% |  |
| 2434 |  | Code Drafting (offline) | 94d | 2023-06-01 A | 2023-10-10 A | 2418SS+1d | 100% |  |
| 2435 |  | Internal review and cross-checking of drafting across code drafters | 84d | 2023-06-15 A | 2023-10-10 A | 2434SS+10d | 100% |  |
| 2436 |  | External industry review via consultation | 15d | 2023-10-11 A | 2023-10-31 A | 2435 | 100% |  |
| 2437 |  | Triage and action comments | 20d | 2023-10-30 A | 2023-11-24 A | 2436FS-2d | 100% |  |
| 2438 |  | CDWG review | 37d | 2023-11-27 A | 2024-01-16 A | 2437 | 100% |  |
| 2439 |  | CCAG review | 5d | 2024-01-17 A | 2024-01-23 A | 2438 | 100% |  |
| 2440 |  | Code drafting for Interfaces / Data Specification topic areas approved | 0d | 2024-01-23 A | 2024-01-23 A | 2439 | 100% |  |
| 2441 | 1.7.1.2.7 | **Migration (BSC & REC driven)** | 130d | 2023-05-25 A | 2023-11-22 A |  | 100% |  |
| 2442 |  | Pre Code Drafting activities | 5d | 2023-05-25 A | 2023-05-31 A | 2443SS-5d | 100% |  |
| 2443 |  | Code Drafting (offline) | 55d | 2023-06-01 A | 2023-08-16 A | 2418SS+1d | 100% |  |
| 2444 |  | Internal review and cross-checking of drafting across code drafters | 45d | 2023-06-15 A | 2023-08-16 A | 2443SS+10d | 100% |  |
| 2445 |  | External industry review via consultation | 15d | 2023-08-18 A | 2023-09-07 A | 2444FS+1d | 100% |  |
| 2446 |  | Triage and action comments | 19d | 2023-09-06 A | 2023-10-02 A | 2445FS-2d | 100% |  |
| 2447 |  | CDWG review | 31d | 2023-10-03 A | 2023-11-14 A | 2446 | 100% |  |
| 2448 |  | CCAG review | 6d | 2023-11-15 A | 2023-11-22 A | 2447 | 100% |  |
| 2449 |  | Code drafting for Migration topic area approved | 0d | 2023-11-22 A | 2023-11-22 A | 2448 | 100% |  |
| 2450 | 1.7.1.2.8 | **Consequential Code Change** | 109d | 2023-10-11 A | 2024-03-11 A |  | 100% |  |

| ID | WBS | Task | Duration | Start | Finish | Predecessors | Complete | Total float | Constraint |
| --- | --- | --- | --- | --- | --- | --- | --- | --- | --- |
| 2451 |  | External industry review via consultation - drop 1 (DCUSA) | 15d | 2023-10-11 A | 2023-10-31 A | 2457SS | 100% |  |  |
| 2452 |  | External industry review via consultation - drop 2 (Elexon) | 16d | 2024-02-19 A | 2024-03-11 A | 2467SS | 100% |  | start no earlier than 2024-02-19 |
| 2453 | 1.7.1.2.9 | **Transition Text (all codes)** | 118d | 2023-08-11 A | 2024-01-23 A |  | 100% |  |  |
| 2454 |  | Pre Code Drafting activities | 8d | 2023-08-11 A | 2023-08-22 A | 2455SS-5d | 100% |  |  |
| 2455 |  | Code Drafting (offline) | 38d | 2023-08-18 A | 2023-10-10 A | 2445SS | 100% |  |  |
| 2456 |  | Internal review and cross-checking of drafting across code drafters | 28d | 2023-09-01 A | 2023-10-10 A | 2455SS+10d | 100% |  |  |
| 2457 |  | External industry review via consultation | 15d | 2023-10-11 A | 2023-10-31 A | 2456 | 100% |  |  |
| 2458 |  | Triage and action comments | 20d | 2023-10-30 A | 2023-11-24 A | 2457FS-2d | 100% |  |  |
| 2459 |  | CDWG review | 37d | 2023-11-27 A | 2024-01-16 A | 2458 | 100% |  |  |
| 2460 |  | CCAG review | 5d | 2024-01-17 A | 2024-01-23 A | 2459 | 100% |  |  |
| 2461 |  | Code drafting for Transition Text topic area approved | 0d | 2024-01-23 A | 2024-01-23 A | 2460 | 100% |  |  |
| 2462 | 1.7.1.2.10 | **Final Code Drafting (mop-up) (all codes)** | 199d | 2023-08-18 A | 2024-05-22 A |  | 100% |  |  |
| 2463 |  | Forward look and confirm remaining plan | 15d | 2023-08-18 A | 2023-09-07 A | 2455SS | 100% |  |  |
| 2464 |  | Identify remaining or additional areas of code (e.g. consequential change requirements) to be completed | 15d | 2023-08-18 A | 2023-09-07 A | 2463SS | 100% |  |  |
| 2465 |  | Code Drafting (offline) Interim Consultation (1) | 60d | 2023-09-08 A | 2023-11-30 A | 2464 | 100% |  |  |
| 2466 |  | Internal review and cross-checking of drafting across code drafters Interim Consultation (1) | 50d | 2023-09-22 A | 2023-11-30 A | 2465SS+10d | 100% |  |  |
| 2467 |  | External industry review via consultation Interim Consultation (1) | 23d | 2023-12-01 A | 2024-01-02 A | 2466 | 100% |  |  |
| 2468 |  | Code Drafting (offline) Final Consultation (2) | 55d | 2023-12-01 A | 2024-02-15 A | 2466 | 100% |  |  |
| 2469 |  | Internal review and cross-checking of drafting across code drafters Final Consultation (2) | 45d | 2023-12-15 A | 2024-02-15 A | 2468SS+10d | 100% |  |  |
| 2470 |  | External industry review via consultation Final Consultation (2) | 16d | 2024-02-19 A | 2024-03-11 A | 2469FS+1d | 100% |  |  |
| 2471 |  | Triage and action comments | 18d | 2024-03-11 A | 2024-04-03 A | 2470FS-1d | 100% |  |  |
| 2472 |  | CDWG review | 29d | 2024-04-04 A | 2024-05-14 A | 2471 | 100% |  |  |
| 2473 |  | CCAG review | 6d | 2024-05-15 A | 2024-05-22 A | 2472 | 100% |  |  |
| 2474 |  | Final code drafting (mop-up) approved | 0d | 2024-05-22 A | 2024-05-22 A | 2473 | 100% |  |  |
| 2475 | 1.7.1.2.11 | **Final code review, consistency check and approval** | 100d | 2024-04-04 A | 2024-08-21 A |  | 100% |  |  |
| 2476 |  | Gap analysis of final code against design artefacts (reverse process to code drafting) | 38d | 2024-04-04 A | 2024-05-27 A | 2472SS | 100% |  |  |
| 2477 |  | Outputs of gap analysis actioned offline | 11d | 2024-05-28 A | 2024-06-11 A | 2476 | 100% |  |  |
| 2478 |  | Final documentation collated for final consultation | 8d | 2024-06-12 A | 2024-06-21 A | 2477 | 100% |  |  |
| 2479 |  | External industry review via consultation | 15d | 2024-06-24 A | 2024-07-12 A | 2478 | 100% |  |  |
| 2480 |  | Triage and action comments | 10d | 2024-07-15 A | 2024-07-26 A | 2479 | 100% |  |  |
| 2481 |  | Final CDWG review | 8d | 2024-08-02 A | 2024-08-13 A | 2480FS+4d | 100% |  |  |
| 2482 |  | Final CCAG review | 6d | 2024-08-14 A | 2024-08-21 A | 2481 | 100% |  |  |
| 2483 |  | CCAG recommend final code to PSG for baselining | 0d | 2024-08-21 A | 2024-08-21 A | 2482 | 100% |  |  |
| 2484 |  | Code changes baselined (M6) | 0d | 2024-08-23 A | 2024-08-23 A | 2482FS+2d, 2474, 2461, 2449, 2440, 2431, 2422, 2413, 2404, 2395 | 100% |  |  |
| 2485 | 1.7.2 | **Ofgem preparation and enactment of SCR powers** | 225d | 2024-02-05 A | 2024-12-13 A |  | 100% |  |  |
| 2486 | 1.7.2.1 | **Preparation and enactment of SCR Powers** | 223d | 2024-02-05 A | 2024-12-11 A |  | 100% |  |  |
| 2487 |  | Ofgem to keep Ofgem legal informed of process followed and nature of Code drafting to ensure that prepared for SCR go/no go decision | 101d | 2024-02-05 A | 2024-06-24 A | 2488SF | 100% |  |  |
| 2488 |  | OFGEM Legal to review Code Artefacts deliver policy intent and process followed and confirm that SCR powers are appropriate to use rather than SMAP - SCR go/no go | 14d | 2024-06-24 A | 2024-07-11 A | 2479SS | 100% |  |  |
| 2489 |  | Code Bodies to draft MOD proposal forms | 20d | 2024-07-12 A | 2024-08-08 A | 2488 | 100% |  |  |
| 2490 |  | Ofgem discuss and agree code mod timetable with code bodies (and MHHSP in relation to the dates for expected decisions) | 20d | 2024-07-12 A | 2024-08-08 A | 2488 | 100% |  |  |
| 2491 |  | Ofgem to publish each Direction to each code body specifying the timetable for each modification | 1d | 2024-08-28 A | 2024-08-28 A | 2490FS+13d | 100% |  |  |
| 2492 |  | Formally submit (by separate email) Modification Proposal Forms and legal texts to each code body | 1d | 2024-08-28 A | 2024-08-28 A | 2490FS+13d | 100% |  |  |
| 2493 |  | Each Code Body publishes and issues Modification Proposal Forms | 3d | 2024-08-29 A | 2024-09-02 A | 2492, 2491 | 100% |  |  |
| 2494 |  | Each Code Body sends Modification Proposal Forms to Panel to approve Mod to go to consultation | 10d | 2024-09-03 A | 2024-09-16 A | 2493 | 100% |  |  |
| 2495 |  | Modification Proposal approved by Panel for Consultation | 1d | 2024-09-17 A | 2024-09-17 A | 2494 | 100% |  |  |
| 2496 |  | Draft Modification Report issued for consultation | 1d | 2024-09-18 A | 2024-09-18 A | 2495 | 100% |  |  |
| 2497 |  | Consultation Close-out for representations | 15d | 2024-09-19 A | 2024-10-09 A | 2496 | 100% |  |  |
| 2498 |  | Each Code Body reviews consultation response and drafts Modification Report | 10d | 2024-10-10 A | 2024-10-23 A | 2497 | 100% |  |  |
| 2499 |  | Final Modification Report sent to Panel for decision with recommendation to approve | 1d | 2024-10-24 A | 2024-10-24 A | 2498 | 100% |  |  |
| 2500 |  | Modification Panel decision | 1d | 2024-11-07 A | 2024-11-07 A | 2499FS+9d | 100% |  |  |
| 2501 |  | Code Bodies Submit Final Modification/Change Reports | 1d | 2024-11-08 A | 2024-11-08 A | 2500 | 100% |  |  |
| 2502 |  | Ofgem Reviews Final Modification/Change Reports | 10d | 2024-11-11 A | 2024-11-22 A | 2501 | 100% |  |  |
| 2503 |  | Ofgem Drafts Decision/Direction Letters | 17d | 2024-11-18 A | 2024-12-10 A | 2502SS+5d | 100% |  |  |
| 2504 |  | Ofgem Internally Signs Off the Decision/Direction Letters and Sends Them to the Code Bodies | 1d | 2024-12-11 A | 2024-12-11 A | 2503 | 100% |  |  |
| 2505 |  | Ofgem decisions on M6 baselined code modification proposals (M7) | 0d | 2024-12-11 A | 2024-12-11 A | 2484, 2504 | 100% |  |  |
| 2506 |  | Ofgem Publishes the Decisions/Directions | 2d | 2024-12-12 A | 2024-12-13 A | 2505 | 100% |  |  |
| 2507 | 1.7.3 | **Deliver MHHS Code Changes** | 292d | 2024-11-12 A | 2025-12-24 |  | 93% | 521d |  |
| 2508 | 1.7.3.1 | **Releases** | 292d | 2024-11-12 A | 2025-12-24 |  | 93% | 521d |  |
| 2509 |  | Impacted codes make resourcing provisions and prepare to implement new Code via internal code body change processes | 78d | 2024-11-12 A | 2025-02-27 A |  | 100% |  | start no earlier than 2024-11-12 |
| 2510 | 1.7.3.1.2 | **Main Code Release** | 71d | 2025-09-17 | 2025-12-24 |  |  | 521d |  |
| 2511 |  | Release preparation (e.g. preparing release documentation) | 6d | 2025-09-17 | 2025-09-24 | 2512SF |  | 586d |  |
| 2512 |  | Implement new code on day of code release | 0d | 2025-09-24 | 2025-09-24 | 2513SF |  | 586d |  |
| 2513 |  | Code changes delivered (M8) | 0d | 2025-09-24 | 2025-09-24 | 2505, 2484, 1835SS |  | 521d |  |
| 2514 |  | Code changes delivered (M8*) late exit | 0d | 2025-12-24 | 2025-12-24 | 2513FS+65d |  | 521d |  |
| 2515 | 1.7.4 | **External Programme Dependency Management** | 38d | 2023-12-01 A | 2024-01-24 A |  | 100% |  |  |
| 2516 | 1.7.4.1 | **DCP397** | 38d | 2023-12-01 A | 2024-01-24 A |  | 100% |  |  |
| 2517 |  | Ensure DCP397 drafting included in mop-up code drafting activity (link to mop-up) | 20d | 2023-12-01 A | 2023-12-28 A | 2468SS, 2465SS | 100% |  |  |
| 2518 |  | Implementation of DCP397 | 0d | 2024-01-24 A | 2024-01-24 A |  | 100% |  | start no earlier than 2024-01-24 |
| 2519 | 1.8 | **MIGRATION** | 1246d? | 2022-10-31 A | 2027-08-09 |  | 36% | 98d |  |
| 2520 | 1.8.1 | **Regulatory Governance** | 198d | 2024-04-01 A | 2025-01-01 |  | 47% | 776d |  |

| ID | WBS | Task | Duration | Start | Finish | Predecessors | Complete | Total float | Constraint |
| --- | --- | --- | --- | --- | --- | --- | --- | --- | --- |
| 2521 |  | Incentive Mods Created | 110d | 2024-04-01 A | 2024-08-30 |  | 85% | 776d | start no earlier than 2024-04-01 |
| 2522 |  | Incentives Implemented | 88d | 2024-09-02 | 2025-01-01 | 2521 |  | 776d | start no earlier than 2024-07-02 |
| 2523 | 1.8.2 | **Migration Framework Agreed and Implemented** | 324d? | 2024-02-01 A | 2025-04-29 |  | 84% | 692d |  |
| 2524 | 1.8.2.1 | **Consultation 1 - Schedule** | 70d | 2024-02-01 A | 2024-05-08 A |  | 100% |  |  |
| 2525 |  | Prepare Artefacts for Consultation | 33d | 2024-02-01 A | 2024-03-18 A |  | 100% |  |  |
| 2526 |  | Industry Consultation | 16d | 2024-03-18 A | 2024-04-08 A |  | 100% |  |  |
| 2527 |  | Triage and Action Comments | 10d | 2024-04-08 A | 2024-04-19 A |  | 100% |  |  |
| 2528 |  | Industry Assurance Review | 6d | 2024-04-19 A | 2024-04-26 A |  | 100% |  |  |
| 2529 |  | MWG Recommendation | 1d | 2024-04-26 A | 2024-04-26 A |  | 100% |  |  |
| 2530 |  | MCAG Interim Approval Artefacts | 1d | 2024-05-08 A | 2024-05-08 A |  | 100% |  |  |
| 2531 | 1.8.2.2 | **Consultation 2 - Control** | 79d | 2024-04-08 A | 2024-07-25 A |  | 100% |  |  |
| 2532 |  | Prepare Artefacts for Consultation | 49d | 2024-04-08 A | 2024-06-13 A |  | 100% |  |  |
| 2533 |  | Industry Consultation | 11d | 2024-06-14 A | 2024-06-28 A | 2532 | 100% |  |  |
| 2534 |  | Triage and Action Comments | 9d | 2024-07-01 A | 2024-07-11 A | 2533 | 100% |  |  |
| 2535 |  | Industry Assurance Review | 5d | 2024-07-12 A | 2024-07-18 A | 2534 | 100% |  |  |
| 2536 |  | MWG Recommendation | 0d | 2024-07-18 A | 2024-07-18 A | 2535 | 100% |  |  |
| 2537 |  | Consultation 2 - Control - MCAG Approval of Interim Artefacts | 0d | 2024-07-25 A | 2024-07-25 A | 2536FS+5d | 100% |  |  |
| 2538 | 1.8.2.3 | **Consultation 3 - Parameters** | 71d | 2024-11-18 A | 2025-02-25 |  | 99% | 691d |  |
| 2539 |  | Prepare Artefacts for Consultation | 24d | 2024-11-18 A | 2024-12-19 A |  | 100% |  |  |
| 2540 |  | Industry Consultation | 21d | 2024-12-20 A | 2025-01-17 A | 2539 | 100% |  |  |
| 2541 |  | Triage Response | 10d | 2025-01-20 A | 2025-01-31 A | 2540 | 100% |  |  |
| 2542 |  | MWG paper day | 0d | 2025-02-06 A | 2025-02-06 A | 2541 | 100% |  | start no earlier than 2025-02-06 |
| 2543 |  | MWG Recommendation | 0d | 2025-02-13 | 2025-02-13 | 2542FS+6d |  | 695d |  |
| 2544 |  | MCAG Paper Day | 0d | 2025-02-18 | 2025-02-18 | 2543FS+3d |  | 695d |  |
| 2545 |  | MCAG Approval of Consultation 3 | 0d | 2025-02-25 | 2025-02-25 | 2543, 2544 |  | 691d | start no earlier than 2025-02-25 |
| 2546 | 1.8.2.4 | **Consultation 4** | 72d? | 2025-01-20 A | 2025-04-29 |  | 28% | 692d |  |
| 2547 |  | Agree Consultation 4 Plan | 15d | 2025-01-20 A | 2025-02-07 A |  | 100% |  |  |
| 2548 |  | Book MWG | 0d | 2025-02-07 A | 2025-02-07 A | 2547 | 100% |  |  |
| 2549 |  | Prepare Consultation 4 content | 9d | 2025-02-10 | 2025-02-20 | 2548 |  | 692d |  |
| 2550 |  | MWG paper day | 0d | 2025-02-20 | 2025-02-20 | 2549 |  | 735d |  |
| 2551 |  | MWG recommend Consultation 4 content go for industry consultation | 0d | 2025-02-27 | 2025-02-27 | 2550FS+5d |  | 735d |  |
| 2552 |  | Industry Consultation | 10d? | 2025-02-21 | 2025-03-06 | 2549 |  | 692d |  |
| 2553 |  | Comment responses by PPs | 10d? | 2025-03-07 | 2025-03-20 | 2552 |  | 692d |  |
| 2554 |  | Respond to comments and issue artefacts | 10d? | 2025-03-21 | 2025-04-03 | 2553 |  | 692d |  |
| 2555 |  | Assurance meeting | 0d | 2025-04-10 | 2025-04-10 | 2554FS+5d |  | 692d |  |
| 2556 |  | MCAG paper day | 0d | 2025-04-22 | 2025-04-22 | 2555FS+8d |  | 692d |  |
| 2557 |  | MCAG Approval of Consultation 4 | 0d | 2025-04-29 | 2025-04-29 | 2556FS+5d |  | 692d |  |
| 2558 |  | Framework Baselined at MCAG | 0d | 2025-04-29 | 2025-04-29 | 2557 |  | 692d |  |
| 2559 | 1.8.3 | **Migration Schedule Agreed and Maintained** | 560d? | 2022-10-31 A | 2024-12-20 |  | 99% | 784d |  |
| 2560 |  | Schedule Production | 125d? | 2024-07-01 A | 2024-12-20 A |  | 100% |  | start no earlier than 2024-11-18 |
| 2561 |  | Schedule Production Complete | 0d | 2024-12-20 A | 2024-12-20 A | 2560 | 100% |  |  |
| 2562 |  | Confirm Supplier Migration start dates, MPID groups (SIT & NonSIT) | 1d? | 2022-10-31 | 2022-10-31 |  |  | 1343d |  |
| 2563 | 1.8.4 | **V1.0 of Migration Schedule Baseline** | 81d | 2025-04-01 | 2025-07-22 |  |  | 632d |  |
| 2564 |  | Confirm Supplier Migration start dates, MPID groups (SIT & NonSIT) | 0d | 2025-04-01 | 2025-04-01 |  |  | 632d | start no earlier than 2025-04-01 |
| 2565 |  | V1.0 of Migration Schedule Baseline Approved at MCAG | 0d | 2025-07-22 | 2025-07-22 | 2564FS+81d |  | 632d |  |
| 2566 | 1.8.5 | **Supplier Commission 2** | 102d? | 2025-03-03 | 2025-07-22 |  |  | 632d |  |
| 2567 |  | Confirm / validate contacts for all Suppliers | 22d | 2025-03-03 | 2025-04-01 |  |  | 632d | start no earlier than 2025-03-03 |
| 2568 |  | Supplier submission issued | 0d | 2025-04-25 | 2025-04-25 | 2567FS+18d |  | 632d |  |
| 2569 |  | Supplier submission deadline | 0d | 2025-06-20 | 2025-06-20 | 2568FS+40d |  | 632d |  |
| 2570 |  | Second Supplier Submission complete | 0d | 2025-06-20 | 2025-06-20 | 2569 |  | 632d |  |
| 2571 |  | Publish and baseline Migration Schedule | 1d? | 2025-07-22 | 2025-07-22 | 2570FS+21d |  | 632d |  |
| 2572 | 1.8.6 | **Supplier Submission Support** | 29d? | 2025-04-25 | 2025-06-04 |  |  | 666d |  |
| 2573 |  | Support guides issued | 1d? | 2025-04-25 | 2025-04-25 |  |  | 666d | start no earlier than 2025-04-25 |
| 2574 |  | Envelope webinar | 0d | 2025-05-02 | 2025-05-02 | 2573FS+5d |  | 666d |  |
| 2575 |  | De-minimus webinar | 0d | 2025-05-02 | 2025-05-02 | 2574 |  | 666d |  |
| 2576 |  | Drop-in session 1 | 0d | 2025-05-14 | 2025-05-14 | 2575FS+8d |  | 666d |  |
| 2577 |  | Drop-in session 2 | 0d | 2025-05-28 | 2025-05-28 | 2576FS+10d |  | 666d |  |
| 2578 |  | Drop-in session 3 | 0d | 2025-06-04 | 2025-06-04 | 2577FS+5d |  | 666d |  |
| 2579 |  | Q+A documents from sessions published | 0d | 2025-06-04 | 2025-06-04 | 2578 |  | 666d |  |
| 2580 | 1.8.7 | **MCC Stood up** | 265d? | 2024-11-18 | 2025-11-21 |  |  |  |  |
| 2581 |  | Migration Planning Management Tool Delivery | 265d | 2024-11-18 | 2025-11-21 |  |  |  |  |
| 2582 | 1.8.7.2 | **MCC Operational** | 96d | 2025-04-18 | 2025-08-29 |  |  | 604d |  |
| 2583 | 1.8.7.2.1 | **MCC Dress Rehersal 1 - Initialise Schedule (Weekly) Drop 1, 2** | 63d | 2025-04-18 | 2025-07-15 |  |  | 637d |  |
| 2584 |  | Issue Dress Rehearsal support information to Participants | 0d | 2025-04-18 | 2025-04-18 |  |  | 637d | start no earlier than 2025-04-18 |
| 2585 |  | Kestrel Webinar 1 | 0d | 2025-04-18 | 2025-04-18 | 2584 |  | 637d |  |
| 2586 |  | Onboard and connectivity testing - Dress Rehearsal with Suppliers (All SIT and Wave 1 mandatory) | 0d | 2025-04-25 | 2025-04-25 | 2585FS+6d |  | 637d |  |
| 2587 |  | Dress rehearsal start | 0d | 2025-04-28 | 2025-04-28 | 2586FS+1d |  | 637d |  |
| 2588 |  | Test execution report (weekly) | 0d | 2025-07-15 | 2025-07-15 | 2587FS+56d |  | 637d |  |
| 2589 |  | Dress rehearsal completion report | 0d | 2025-07-15 | 2025-07-15 | 2588 |  | 637d |  |
| 2590 |  | MCC Dress Rehersal 1 - complete | 0d | 2025-07-15 | 2025-07-15 | 2589 |  | 637d |  |

| ID | WBS | Task | Duration | Start | Finish | Predecessors | Complete | Total float | Constraint |
| --- | --- | --- | --- | --- | --- | --- | --- | --- | --- |
| 2591 | 1.8.7.2.2 | **MCC Dress Rehersal 2 - complete** | 35d | 2025-07-14 | 2025-08-29 |  |  | 604d |  |
| 2592 |  | Issue Dress Rehearsal support information to Participants | 0d | 2025-07-14 | 2025-07-14 |  |  | 604d | start no earlier than 2025-07-14 |
| 2593 |  | Kestrel Webinar 2 | 0d | 2025-07-14 | 2025-07-14 | 2592 |  | 604d |  |
| 2594 |  | Onboard and connectivity testing - Dress Rehearsal with Suppliers (remaining suppliers and non-supplier PPs) | 0d | 2025-07-21 | 2025-07-21 | 2593FS+6d |  | 604d |  |
| 2595 |  | Dress rehearsal start | 0d | 2025-07-21 | 2025-07-21 | 2594 |  | 604d |  |
| 2596 |  | Test execution report (weekly) | 0d | 2025-08-29 | 2025-08-29 | 2595FS+29d |  | 604d |  |
| 2597 |  | Dress rehearsal completion report | 0d | 2025-08-29 | 2025-08-29 | 2596 |  | 604d |  |
| 2598 |  | MCC Dress Rehersal 2 - complete | 0d | 2025-08-29 | 2025-08-29 | 2597 |  | 604d |  |
| 2599 |  | MCC Operational Complete | 0d | 2025-08-29 | 2025-08-29 | 2591, 2598 |  | 604d |  |
| 2600 | 1.8.8 | **PP's Prepared for Migration** | 218d | 2024-07-01 A | 2025-04-30 |  | 23% | 691d |  |
| 2601 |  | Prep for Envelope Webinar | 26d | 2024-07-01 A | 2024-08-05 A |  | 100% |  |  |
| 2602 |  | Envelope/Submission Webinar | 1d | 2024-08-05 A | 2024-08-05 A | 2601FF | 100% |  |  |
| 2603 |  | Guides Creation | 45d | 2025-02-27 | 2025-04-30 | 2545FS+2d |  | 691d |  |
| 2604 |  | Support Channels | 45d | 2025-02-27 | 2025-04-30 | 2545FS+2d |  | 691d |  |
| 2605 | 1.8.9 | **Migration Artefact Development and Publication** | 773d | 2022-10-31 A | 2025-10-15 |  | 91% | 571d |  |
| 2606 | 1.8.9.1 | **Migration Approach** | 28d | 2022-10-31 A | 2022-12-07 A |  | 100% |  |  |
| 2607 |  | Option analysis (via MWG and PPIR) and recommendation | 23d | 2022-10-31 A | 2022-11-30 A |  | 100% |  |  |
| 2608 |  | Migration Approach approved | 0d | 2022-12-07 A | 2022-12-07 A | 2607FS+5d | 100% |  |  |
| 2609 | 1.8.9.2 | **Migration Design** | 100d | 2022-11-14 A | 2023-03-31 A |  | 100% |  |  |
| 2610 |  | Review and update existing design artefacts and socialise with participants ahead of MDSG | 10d | 2022-11-14 A | 2022-11-25 A |  | 100% |  |  |
| 2611 |  | Develop design artefacts and supporting technical documents in line with MDSG | 53d | 2022-11-30 A | 2023-02-10 A | 2610FS+2d | 100% |  |  |
| 2612 |  | Migration design artefacts issued for consultation | 0d | 2023-02-13 A | 2023-02-13 A | 2611FS+1d | 100% |  |  |
| 2613 |  | Industry consultation | 5d | 2023-02-14 A | 2023-02-20 A | 2612SS | 100% |  |  |
| 2614 |  | Review consultation feedback, address comments and update artefacts | 5d | 2023-02-21 A | 2023-02-27 A | 2613 | 100% |  |  |
| 2615 |  | Internal artefact review and comms preparation | 3d | 2023-02-28 A | 2023-03-02 A | 2614 | 100% |  |  |
| 2616 |  | Updated Migration Design artefacts issued to PPs for assurance review | 0d | 2023-03-03 A | 2023-03-03 A | 2615FS+1d | 100% |  |  |
| 2617 |  | Final Migration Design artefacts walkthrough with PPs | 0d | 2023-03-22 A | 2023-03-22 A | 2616FS+13d | 100% |  |  |
| 2618 |  | Migration Design approved | 0d | 2023-03-31 A | 2023-03-31 A | 2617FS+7d | 100% |  |  |
| 2619 | 1.8.9.3 | **Transition Design** | 186d | 2023-03-01 A | 2023-11-15 A |  | 100% |  |  |
| 2620 | 1.8.9.3.1 | **Tranche 1** | 56d | 2023-03-01 A | 2023-05-17 A |  | 100% |  |  |
| 2621 |  | Develop design artefacts and supporting technical details with participants | 50d | 2023-03-01 A | 2023-05-09 A |  | 100% |  |  |
| 2622 |  | Issue Material for DAG approval | 1d | 2023-05-10 A | 2023-05-10 A | 2621 | 100% |  |  |
| 2623 |  | Tranche 1 Transition Design approved | 0d | 2023-05-17 A | 2023-05-17 A | 2622FS+5d | 100% |  |  |
| 2624 | 1.8.9.3.2 | **Tranche 2** | 130d | 2023-05-18 A | 2023-11-15 A |  | 100% |  |  |
| 2625 |  | Develop Initial design artefacts and supporting technical details | 76d | 2023-05-18 A | 2023-08-31 A | 2623 | 100% |  |  |
| 2626 |  | Communicate Initial Design Artefacts with Industry (MTDSG) | 1d | 2023-09-01 A | 2023-09-01 A | 2625 | 100% |  |  |
| 2627 |  | Host MTDSG | 1d | 2023-09-11 A | 2023-09-11 A | 2626FS+5d | 100% |  |  |
| 2628 |  | Process MTDSG Feedback and Amend Design Artefacts | 4d | 2023-09-12 A | 2023-09-15 A | 2627 | 100% |  |  |
| 2629 |  | Communicate Amended Design Artefacts with Industry | 1d | 2023-09-15 A | 2023-09-15 A | 2628FF | 100% |  |  |
| 2630 |  | Host MTDSG | 1d | 2023-09-26 A | 2023-09-26 A | 2629FS+6d | 100% |  |  |
| 2631 |  | Make Final Amendments to Design Artefact | 5d | 2023-09-27 A | 2023-10-03 A | 2630 | 100% |  |  |
| 2632 |  | Request DAG Consultation | 1d | 2023-10-04 A | 2023-10-04 A | 2631 | 100% |  |  |
| 2633 |  | Consultation Period | 11d | 2023-10-04 A | 2023-10-18 A | 2632SS | 100% |  |  |
| 2634 |  | Action Consultation Comments | 5d | 2023-10-19 A | 2023-10-25 A | 2633 | 100% |  |  |
| 2635 |  | Post Consultation Industry Assurance | 5d | 2023-10-26 A | 2023-11-01 A | 2634 | 100% |  |  |
| 2636 |  | Request DAG Approval | 1d | 2023-11-01 A | 2023-11-01 A | 2635FF | 100% |  |  |
| 2637 |  | DAG Transition Design Approved | 1d | 2023-11-08 A | 2023-11-08 A | 2636FS+4d | 100% |  |  |
| 2638 |  | Update Transition Design Admin | 5d | 2023-11-09 A | 2023-11-15 A | 2637 | 100% |  |  |
| 2639 |  | Tranche 2 Transition Design Baselined | 0d | 2023-11-15 A | 2023-11-15 A | 2638 | 100% |  |  |
| 2640 | 1.8.9.4 | **Data Assessment Report** | 61d | 2022-12-06 A | 2023-02-28 A |  | 100% |  |  |
| 2641 |  | Develop document with MWG | 49d | 2022-12-06 A | 2023-02-10 A |  | 100% |  |  |
| 2642 |  | Artefact review (via TMAG) and updates | 25d | 2023-01-18 A | 2023-02-21 A | 2641FS-18d | 100% |  |  |
| 2643 |  | Data Assessment Report approved | 0d | 2023-02-28 A | 2023-02-28 A | 2642FS+5d | 100% |  |  |
| 2644 | 1.8.9.5 | **Migration, Cutover & Data Strategy (incl. Migration Entry Criteria)** | 102d | 2022-12-08 A | 2023-04-28 A |  | 100% |  |  |
| 2645 |  | Develop document with MWG | 67d | 2022-12-08 A | 2023-03-10 A | 2608 | 100% |  |  |
| 2646 |  | Artefact review (via TMAG) and updates | 28d | 2023-03-15 A | 2023-04-21 A | 2645FS+2d | 100% |  |  |
| 2647 |  | Migration, Cutover & Data Strategy approved | 0d | 2023-04-28 A | 2023-04-28 A | 2646FF+5d | 100% |  |  |
| 2648 | 1.8.9.6 | **Data Cleanse Plan** | 685d | 2023-03-02 A | 2025-10-15 |  | 84% | 571d |  |
| 2649 |  | Develop document with MWG | 50d | 2023-03-02 A | 2023-05-10 A |  | 100% |  |  |
| 2650 |  | Artefact review (via TMAG) and updates | 20d | 2023-05-11 A | 2023-06-07 A | 2649 | 100% |  |  |
| 2651 |  | Data Cleanse Plan approved | 0d | 2023-07-19 A | 2023-07-19 A | 2650FS+30d | 100% |  |  |
| 2652 |  | Monitor Programme Participant adherence to Data Cleanse Plan | 467d | 2023-06-15 A | 2025-03-28 | 2651 | 80% | 714d |  |
| 2653 | 1.8.9.6.5 | **MTDs** | 115d | 2024-08-16 A | 2025-01-24 A |  | 100% |  |  |
| 2654 | 1.8.9.6.5.1 | **ESME ID** | 90d | 2024-08-16 A | 2024-12-20 A |  | 100% |  |  |
| 2655 |  | DCC to extract ESME ID and share with LDSO | 0d | 2024-08-16 A | 2024-08-16 A | 2651FS+282d | 100% |  |  |
| 2656 |  | LDSO ‘full refresh’ between their Registration Service and the EES (ESME ID) | 16d | 2024-10-21 A | 2024-11-11 A | 2655FS+45d | 100% |  |  |
| 2657 |  | Suppliers complete investigation of exceptions and resolution of exceptions | 1d | 2024-12-20 A | 2024-12-20 A | 2656FS+28d | 100% |  |  |
| 2658 |  | ESME ID Complete | 0d | 2024-12-20 A | 2024-12-20 A | 2657 | 100% |  |  |
| 2659 | 1.8.9.6.5.2 | **Meter Location and Number of Displayed Register Digits** | 96d | 2024-09-13 A | 2025-01-24 A |  | 100% |  |  |
| 2660 |  | MEM to extract data and share with LDSO | 6d | 2024-09-13 A | 2024-09-20 A | 2651FS+301d | 100% |  |  |

| ID | WBS | Task | Duration | Start | Finish | Predecessors | Complete | Total float | Constraint |
| --- | --- | --- | --- | --- | --- | --- | --- | --- | --- |
| 2661 |  | LDSO ‘full refresh’ between their Registration Service and the EES (Meter Location and Number of Displayed Register Digits) | 16d | 2024-10-21 A | 2024-11-15 A | 2660FS+25d | 100% |  |  |
| 2662 |  | Suppliers complete investigation of exceptions and resolution of exceptions | 1d | 2025-01-24 A | 2025-01-24 A | 2661FS+49d | 100% |  |  |
| 2663 |  | Meter Location and Number of Displayed Register Digits Complete | 0d | 2025-01-24 A | 2025-01-24 A | 2662 | 100% |  |  |
| 2664 | 1.8.9.6.6 | **Registration Data** | 289d | 2024-09-06 A | 2025-10-15 |  | 81% | 571d |  |
| 2665 | 1.8.9.6.6.1 | **Connection Type** | 47d | 2024-09-06 A | 2024-11-11 A |  | 100% |  |  |
| 2666 |  | Automated Population of Connection Type for Measurement Classes ‘B’, ‘D’, ‘F’ & ‘G’ | 0d | 2024-10-04 A | 2024-10-04 A | 2651FS+317d | 100% |  | start no earlier than 2024-09-13 |
| 2667 |  | BAU Population of Connection Type for Site Specific LLFCs within Measurement Classes ‘C’ & ‘E’ | 0d | 2024-10-04 A | 2024-10-04 A | 2651FS+317d | 100% |  |  |
| 2668 |  | Automated Population of Connection Type for Smart Meters within Measurement Class ‘A’ | 0d | 2024-10-04 A | 2024-10-04 A | 2651FS+317d | 100% |  |  |
| 2669 |  | Population of Connection Type for Traditional and Advanced Meters within Measurement Class ‘A’ | 1d | 2024-09-06 A | 2024-09-06 A | 2651FS+296d | 100% |  |  |
| 2670 |  | Automated Population of Null Connection Type | 0d | 2024-10-04 A | 2024-10-04 A | 2651FS+317d | 100% |  |  |
| 2671 |  | Full MPAN refresh to ESS | 16d | 2024-10-21 A | 2024-11-11 A | 2651FS+327d | 100% |  |  |
| 2672 |  | Connection Type Complete | 0d | 2024-11-11 A | 2024-11-11 A | 2666, 2667, 2668, 2669, 2670, 2671 | 100% |  |  |
| 2673 | 1.8.9.6.6.2 | **Domestic Premises Indicator** | 19d | 2025-09-19 | 2025-10-15 |  |  | 571d |  |
| 2674 |  | The DCC to extract Domestic Premises Indicator from the CSS and provide a file to each LDSO and EES. | 2d | 2025-09-19 | 2025-09-22 | 1835FS-4d |  | 571d | start no earlier than 2025-08-08 |
| 2675 |  | Each LDSO notifies the DCC of any exceptions | 1d | 2025-09-23 | 2025-09-23 | 2674 |  | 571d |  |
| 2676 |  | Each LDSO and DCC completes investigation and resolution of exceptions | 1d | 2025-10-15 | 2025-10-15 | 2674FS+15d, 2675FS+15d |  | 571d |  |
| 2677 |  | Domestic Premises Indicator Complete | 0d | 2025-10-15 | 2025-10-15 | 2676 |  | 571d |  |
| 2678 | 1.8.9.6.7 | **Export / Import MPANs** | 151d | 2024-03-22 A | 2024-10-18 A |  | 100% |  |  |
| 2679 | 1.8.9.6.7.1 | **Linking of Export / Import MPANS** | 151d | 2024-03-22 A | 2024-10-18 A |  | 100% |  |  |
| 2680 |  | LDSO utilises BAU processing (DB05s) to populate each import/export association | 1d | 2024-03-22 A | 2024-03-22 A | 2651FS+176d | 100% |  |  |
| 2681 |  | Each LDSO notifies the Registered Supplier of any exceptions | 1d | 2024-04-19 A | 2024-04-19 A | 2680FS+19d | 100% |  |  |
| 2682 |  | Each Supplier completes investigation and resolution of exceptions | 1d | 2024-08-23 A | 2024-08-23 A | 2681FS+89d | 100% |  |  |
| 2683 |  | Each LDSO has linked al relevant import/export MPANS | 0d | 2024-10-18 A | 2024-10-18 A | 2682FS+40d | 100% |  |  |
| 2684 |  | Linking of Export / Import MPANS Complete | 0d | 2024-10-18 A | 2024-10-18 A | 2683 | 100% |  |  |
| 2685 |  | Pre-migration data cleanse complete | 0d | 2025-08-13 | 2025-08-13 |  |  | 617d | start no earlier than 2025-08-13 |
| 2686 | 1.8.10 | **Migration Period Planning** | 367d | 2023-07-03 A | 2024-11-26 |  | 83% | 678d |  |
| 2687 | 1.8.10.1 | **Migration Implementation Plan (incl. Migration Exit Criteria)** | 367d | 2023-07-03 A | 2024-11-26 |  | 83% | 678d |  |
| 2688 | 1.8.10.1.1 | **Migration Threshold Volumes** | 101d | 2023-07-03 A | 2023-11-20 A |  | 100% |  |  |
| 2689 |  | Threshold volumes reviewed by MWG | 54d | 2023-07-03 A | 2023-09-14 A |  | 100% |  |  |
| 2690 |  | Artefact review (via TMAG) and updates | 47d | 2023-09-15 A | 2023-11-20 A | 2689 | 100% |  |  |
| 2691 |  | Threshold volumes approved at TMAG | 0d | 2023-11-20 A | 2023-11-20 A | 2690 | 100% |  |  |
| 2692 | 1.8.10.1.2 | **Define acceptance criteria for M15** | 78d | 2023-09-04 A | 2023-12-20 A |  | 100% |  |  |
| 2693 |  | Review acceptance criteria and reporting requirements with MWG | 49d | 2023-09-04 A | 2023-11-09 A |  | 100% |  | start no earlier than 2023-09-04 |
| 2694 |  | Artefact review (via TMAG) and updates | 29d | 2023-11-10 A | 2023-12-20 A | 2693 | 100% |  | start no earlier than 2023-10-30 |
| 2695 |  | Acceptance criteria for M15 agreed at TMAG | 0d | 2023-12-20 A | 2023-12-20 A | 2694 | 100% |  | finish no earlier than 2023-11-30 |
| 2696 | 1.8.10.1.3 | **M10/M11 cut-over plan** | 119d | 2023-12-21 A | 2024-06-04 A |  | 100% |  |  |
| 2697 |  | Draft Document | 84d | 2023-12-21 A | 2024-04-16 A | 2695 | 100% |  |  |
| 2698 |  | Share Document with SRO | 1d | 2024-04-17 A | 2024-04-17 A | 2697 | 100% |  |  |
| 2699 |  | Industry Consultation | 11d | 2024-04-23 A | 2024-05-07 A | 2698FS+3d | 100% |  |  |
| 2700 |  | Assurance Meeting | 1d | 2024-05-21 A | 2024-05-21 A | 2699FS+9d | 100% |  |  |
| 2701 |  | MCAG Approval of M10/M11 Cut-over Plan | 0d | 2024-06-04 A | 2024-06-04 A | 2700FS+10d | 100% |  |  |
| 2702 | 1.8.10.1.4 | **M16 Methodology** | 85d | 2024-07-31 A | 2024-11-26 |  | 10% | 678d |  |
| 2703 |  | Draft Document | 50d | 2024-07-31 A | 2024-10-08 |  | 12% | 678d |  |
| 2704 |  | Share Document with SRO | 1d | 2024-10-09 | 2024-10-09 | 2703 |  | 678d |  |
| 2705 |  | Industry Consultation | 11d | 2024-10-15 | 2024-10-29 | 2704FS+3d |  | 678d |  |
| 2706 |  | Assurance Meeting | 1d | 2024-11-12 | 2024-11-12 | 2705FS+9d |  | 678d |  |
| 2707 |  | M16 methodology approved | 0d | 2024-11-26 | 2024-11-26 | 2706FS+10d |  | 678d |  |
| 2708 | 1.8.11 | **Preparation for Cutover to Live** | 341d | 2024-06-28 A | 2025-10-17 |  |  | 569d |  |
| 2709 | 1.8.11.1 | **Central Systems Prepare for Cutover to Live** | 326d | 2024-06-28 A | 2025-09-26 |  |  | 584d |  |
| 2710 |  | DCC (Functionality available June 2024) | 0d | 2024-06-28 A | 2024-06-28 A |  | 100% |  | start no earlier than 2024-06-28 |
| 2711 | 1.8.11.1.2 | **Development of Comms Approach and Declaration Guidance** | 79d | 2025-04-28 | 2025-08-14 |  |  | 29d |  |
| 2712 |  | Draft Cutover Comms Approach | 59d | 2025-04-28 | 2025-07-17 |  |  | 29d | start no earlier than 2025-04-28 |
| 2713 |  | Draft Cutover Comms Approach shared | 0d | 2025-07-17 | 2025-07-17 | 2712 |  | 29d |  |
| 2714 |  | Development of Implementation Group | 59d | 2025-04-28 | 2025-07-17 |  |  | 29d | start no earlier than 2025-04-28 |
| 2715 |  | Implementation Group Established | 0d | 2025-07-17 | 2025-07-17 | 2714 |  | 29d |  |
| 2716 |  | Finalised Cutover Comms Approach shared | 0d | 2025-08-14 | 2025-08-14 | 2713FS+20d, 2715FS+20d |  | 29d |  |
| 2717 | 1.8.11.1.3 | **Development of Cutover Plan requirements with Participants** | 94d | 2025-04-28 | 2025-09-04 |  |  | 14d |  |
| 2718 |  | Development of SIT Participant Cutover Plans | 59d | 2025-04-28 | 2025-07-17 |  |  | 14d | start no earlier than 2025-04-28 |
| 2719 |  | SIT Participant Cutover Plans Ready | 0d | 2025-07-17 | 2025-07-17 | 2718 |  | 14d |  |
| 2720 |  | Programme SIT Participant Cutover Plan Assurance | 35d | 2025-07-18 | 2025-09-04 | 2719 |  | 14d |  |
| 2721 | 1.8.11.1.4 | **M10/M11 Cutover Activities** | 15d | 2025-09-05 | 2025-09-26 |  |  | 7d |  |
| 2722 |  | Production DIP Portal (DIP Deployment) | 0d | 2025-09-05 | 2025-09-05 | 1700FS+10d |  | 7d |  |
| 2723 |  | Production Certificates (DIP Deployment) | 0d | 2025-09-05 | 2025-09-05 | 1700FS+10d |  | 7d |  |
| 2724 |  | Completion of the pre-M10 MHHS Data Cleanse | 0d | 2025-09-24 | 2025-09-24 | 1835 |  | 586d |  |
| 2725 |  | Market-wide Participant MHHS Supporting Functionality Ready - Confirmation from Code Bodies | 0d | 2025-09-15 | 2025-09-15 | 1835FS-8d |  | 594d |  |
| 2726 |  | Market-wide Participant MHHS Supporting Functionality Ready | 0d | 2025-09-22 | 2025-09-22 | 1835FS-3d |  | 589d |  |
| 2727 |  | Elexon Central Services Deployment | 0d | 2025-09-19 | 2025-09-19 | 2749 |  | 0d |  |
| 2728 |  | Service Management Go-Live | 0d | 2025-09-19 | 2025-09-19 | 2749 |  | 0d |  |
| 2729 |  | Data Transfer Service (DTS) New Functionality Deployment | 0d | 2025-09-19 | 2025-09-19 | 2749 |  | 0d |  |
| 2730 |  | Electricity Enquiry Service (EES) Deployment | 0d | 2025-09-19 | 2025-09-19 | 2749 |  | 0d |  |

| ID | WBS | Task | Duration | Start | Finish | Predecessors | Total float | Constraint |
| --- | --- | --- | --- | --- | --- | --- | --- | --- |
| 2731 |  | MPRS, UMSO Role, LDSO Role Operational | 0d | 2025-09-19 | 2025-09-19 | 2749 | 0d |  |
| 2732 |  | Population of Domestic Premises Indicator | 0d | 2025-09-19 | 2025-09-19 | 2749 | 0d |  |
| 2733 |  | Population of Market Segment | 0d | 2025-09-19 | 2025-09-19 | 2749 | 0d |  |
| 2734 |  | Early Life Support Implemented | 0d | 2025-09-19 | 2025-09-19 | 2749 | 3d |  |
| 2735 |  | MCC Tested and Ready to Operate | 0d | 2025-09-19 | 2025-09-19 |  | 590d | start no earlier than 2025-09-19 |
| 2736 |  | MCC Operational | 0d | 2025-09-19 | 2025-09-19 | 2735 | 590d |  |
| 2737 |  | Central Systems live and Codes designated at 00:00 | 0d | 2025-09-22 | 2025-09-22 | 2727FS+1d, 2728FS+1d, 2729FS+1d, 2730FS+1d, 2731FS+1d, 2732FS+1d, 2733FS+1d, 2710FS+1d | 0d |  |
| 2738 |  | SIT Participant Qualification - The final date by which participant qualification status can be confirmed for participants to be ready for the start of Migration at M11. | 0d | 2025-09-26 | 2025-09-26 | 1700FS+25d | 14d |  |
| 2739 | 1.8.11.2 | **Cutover Governance M10** | 11d | 2025-09-10 | 2025-09-24 |  | 3d |  |
| 2740 |  | Confirmation that Pre-migration Data Cleanse Activities have successfully taken place | 0d | 2025-09-10 | 2025-09-10 |  | 5d | start no earlier than 2025-09-10 |
| 2741 |  | Confirmation of Helix E2E Settlement Testing Complete | 0d | 2025-09-15 | 2025-09-15 |  | 2d | start no earlier than 2025-09-15 |
| 2742 |  | Confirmation of assurance of Helix E2E Settlement Testing | 0d | 2025-09-15 | 2025-09-15 |  | 2d | start no earlier than 2025-09-15 |
| 2743 |  | Confirmation of Qualification Status for SIT MVC | 0d | 2025-09-15 | 2025-09-15 |  | 2d | start no earlier than 2025-09-15 |
| 2744 |  | Confirmation of Qualification Status for Non-SIT LDSOs | 0d | 2025-09-15 | 2025-09-15 |  | 2d | start no earlier than 2025-09-15 |
| 2745 |  | Confirmation of Qualification Status of at least one Supplier and their contracted Agents | 0d | 2025-09-15 | 2025-09-15 |  | 2d | start no earlier than 2025-09-15 |
| 2746 |  | Declaration from all Central Services and LDSOs that they are in a position to move forwards | 0d | 2025-09-15 | 2025-09-15 |  | 3d | start no earlier than 2025-09-15 |
| 2747 |  | Market-wide Participant MHHS Migration Supporting Functionality is Live | 0d | 2025-09-15 | 2025-09-15 |  | 3d | start no earlier than 2025-09-15 |
| 2748 |  | TORWG (Recommendation from TORWG that the Programme should enter M10) | 0d | 2025-09-17 | 2025-09-17 | 2740FS+1d, 2743FS+1d, 2745FS+1d, 2722FS+1d, 2723FS+1d, 2912FS+1d, 2741FS+1d, 2742FS+1d, 2744FS+1d, 2746, 2747 | 0d |  |
| 2749 |  | MCAG (Confirm that the Programme can Enter M10) | 0d | 2025-09-19 | 2025-09-19 | 2748FS+2d, 2918 | 0d |  |
| 2750 |  | Self-Declaration from all Central Services and LDSOs that Cutover activities have been successfully carried out | 0d | 2025-09-22 | 2025-09-22 | 2749FS+1d | 3d |  |
| 2751 |  | Confirmation that DIP and ECS have been deployed, Service management is active, ISD has been populated | 0d | 2025-09-22 | 2025-09-22 | 2749FS+1d | 3d |  |
| 2752 |  | Self-Declarations against all M10 Data Cleanse Activities | 0d | 2025-09-22 | 2025-09-22 | 2749FS+1d | 3d |  |
| 2753 |  | IF-047 has been sent | 0d | 2025-09-22 | 2025-09-22 | 2749FS+1d | 3d |  |
| 2754 |  | Recommendation from TORWG that PSG should approve M10 | 0d | 2025-09-23 | 2025-09-23 | 2750FS+1d, 2751FS+1d, 2752FS+1d, 2753FS+1d, 2916 | 3d |  |
| 2755 |  | PSG (OFGEM and PSG to Approve That Conditions of M10 and M13 Have Been Met) | 0d | 2025-09-24 | 2025-09-24 | 2754FS+1d | 3d |  |
| 2756 | 1.8.11.3 | **Cutover Governance M11** | 16d | 2025-09-26 | 2025-10-17 |  | 3d |  |
| 2757 |  | Confirmation of Qualified Parties from Code Bodies | 11d | 2025-09-26 | 2025-10-10 | 2755FS+1d | 3d |  |
| 2758 |  | Self-Declaration that MHHS Functionality will be deployed to Production by Qualified parties | 0d | 2025-10-10 | 2025-10-10 | 2755FS+12d | 3d |  |
| 2759 |  | Production Service Activation Activities have taken place | 0d | 2025-10-10 | 2025-10-10 | 2755FS+12d | 3d |  |
| 2760 |  | TORWG (Confirmation of Qualified Parties from TORWG) | 0d | 2025-10-13 | 2025-10-13 | 2757FS+1d, 2758FS+1d, 2759FS+1d, 2738, 2913, 2917 | 3d |  |
| 2761 |  | MCAG (Provide recommendation to PSG on M11 decision) | 0d | 2025-10-15 | 2025-10-15 | 2760FS+2d | 3d |  |
| 2762 |  | PSG (OFGEM and PSG Decision to Confirm M11 and M12) | 0d | 2025-10-17 | 2025-10-17 | 2761FS+2d | 3d |  |
| 2763 | 1.8.12 | **UMS / Advanced Migration** | 402d | 2025-10-23 | 2027-05-07 |  | 0d |  |
| 2764 |  | SIT MVC UMS / Advanced Migration | 402d | 2025-10-23 | 2027-05-07 | 2918, 2874 | 0d |  |
| 2765 |  | SIT Non-MVC UMS / Advanced Migration | 355d | 2025-12-29 | 2027-05-07 | 2941 | 0d |  |
| 2766 |  | Wave 1 UMS / Advanced Migration | 256d | 2026-05-15 | 2027-05-07 | 2957 | 0d |  |
| 2767 |  | Wave 2 UMS / Advanced Migration | 223d | 2026-07-01 | 2027-05-07 | 2981FS-1d | 0d |  |
| 2768 |  | Wave 3 UMS / Advanced Migration | 191d | 2026-08-14 | 2027-05-07 | 3005 | 0d |  |
| 2769 |  | Wave 4 UMS / Advanced Migration | 141d | 2026-10-23 | 2027-05-07 | 3029FS-4d | 0d |  |
| 2770 | 1.8.13 | **Smart / Non-Smart Migration** | 524d | 2025-05-06 | 2027-05-07 |  | 122d |  |
| 2771 |  | SIT MVC Smart / Non-Smart Migration | 402d | 2025-10-23 | 2027-05-07 | 2918, 2874 | 0d |  |
| 2772 |  | SIT Non-MVC Smart / Non-Smart Migration | 355d | 2025-12-29 | 2027-05-07 | 2941 | 0d |  |
| 2773 |  | Wave 1 Smart / Non-Smart Migration | 256d | 2026-05-15 | 2027-05-07 | 2957 | 0d | start no earlier than 2025-10-03 |
| 2774 |  | Wave 2 Smart / Non-Smart Migration | 223d | 2026-07-01 | 2027-05-07 | 2981FS-1d | 0d |  |
| 2775 |  | Wave 3 Smart / Non-Smart Migration | 191d | 2026-08-14 | 2027-05-07 | 3005 | 0d |  |
| 2776 |  | Wave 4 Smart / Non-Smart Migration | 141d | 2026-10-23 | 2027-05-07 | 3029FS-4d | 0d |  |
| 2777 | 1.8.13.7 | **Migration Sprint 0** | 94d | 2025-09-25 | 2026-02-03 |  | 492d |  |
| 2778 |  | Sprint 0 Planning start date | 6d | 2025-09-25 | 2025-10-02 |  | 492d | start no earlier than 2025-09-25 |
| 2779 |  | Issue Envelope | 0d | 2025-10-02 | 2025-10-02 | 2778 | 492d |  |
| 2780 |  | Supplier Submission Deadline | 0d | 2025-10-09 | 2025-10-09 | 2779FS+5d | 492d |  |
| 2781 |  | Baseline Schedule Publication | 0d | 2025-10-16 | 2025-10-16 | 2780FS+5d | 492d |  |
| 2782 |  | Migration Sprint 0 Schedule Baselined | 0d | 2025-10-16 | 2025-10-16 | 2781 | 492d |  |
| 2783 |  | Sprint Execution Start | 0d | 2025-10-23 | 2025-10-23 | 2782FS+5d, 2918, 2874 | 492d |  |
| 2784 |  | Sprint Execution | 73d | 2025-10-24 | 2026-02-03 | 2783 | 492d |  |
| 2785 |  | Sprint Execution End | 0d | 2026-02-03 | 2026-02-03 | 2784 | 492d |  |
| 2786 | 1.8.13.8 | **Migration Sprint 1** | 60d | 2026-01-07 | 2026-03-31 |  | 452d |  |
| 2787 |  | Sprint 1 Planning start date | 6d | 2026-01-07 | 2026-01-14 |  | 452d | start no earlier than 2026-01-07 |
| 2788 |  | Issue Envelope | 0d | 2026-01-14 | 2026-01-14 | 2787 | 452d |  |
| 2789 |  | Supplier Submission Deadline | 0d | 2026-01-21 | 2026-01-21 | 2788FS+5d | 452d |  |
| 2790 |  | Baseline Schedule Publication | 0d | 2026-01-28 | 2026-01-28 | 2789FS+5d | 452d |  |
| 2791 |  | Migration Sprint 1 Schedule Baselined | 0d | 2026-01-28 | 2026-01-28 | 2790 | 452d |  |
| 2792 |  | Sprint Execution Start | 0d | 2026-02-04 | 2026-02-04 | 2791FS+5d | 452d |  |
| 2793 |  | Sprint Execution | 39d | 2026-02-05 | 2026-03-31 | 2792 | 452d |  |
| 2794 |  | Sprint Execution End | 0d | 2026-03-31 | 2026-03-31 | 2793 | 452d |  |
| 2795 | 1.8.13.9 | **Migration Sprint 2** | 65d | 2026-03-04 | 2026-06-02 |  | 407d |  |
| 2796 |  | Sprint 2 Planning start date | 6d | 2026-03-04 | 2026-03-11 |  | 407d | start no earlier than 2026-03-04 |
| 2797 |  | Issue Envelope | 0d | 2026-03-11 | 2026-03-11 | 2796 | 407d |  |
| 2798 |  | Supplier Submission Deadline | 0d | 2026-03-18 | 2026-03-18 | 2797FS+5d | 407d |  |
| 2799 |  | Baseline Schedule Publication | 0d | 2026-03-25 | 2026-03-25 | 2798FS+5d | 407d |  |
| 2800 |  | Migration Sprint 2 Schedule Baselined | 0d | 2026-03-25 | 2026-03-25 | 2799 | 407d |  |

| ID | WBS | Task | Duration | Start | Finish | Predecessors | Complete | Total float | Constraint |
| --- | --- | --- | --- | --- | --- | --- | --- | --- | --- |
| 2801 |  | Sprint Execution Start | 0d | 2026-04-01 | 2026-04-01 | 2800FS+5d |  | 407d |  |
| 2802 |  | Sprint Execution | 44d | 2026-04-02 | 2026-06-02 | 2801 |  | 407d |  |
| 2803 |  | Sprint Execution End | 0d | 2026-06-02 | 2026-06-02 | 2802 |  | 407d |  |
| 2804 | 1.8.13.10 | **Migration Sprint 3** | 65d | 2025-05-06 | 2025-08-04 |  |  | 623d |  |
| 2805 |  | Sprint 3 Planning start date | 6d | 2025-05-06 | 2025-05-13 |  |  | 623d | start no earlier than 2025-05-06 |
| 2806 |  | Issue Envelope | 0d | 2025-05-13 | 2025-05-13 | 2805 |  | 623d |  |
| 2807 |  | Supplier Submission Deadline | 0d | 2025-05-20 | 2025-05-20 | 2806FS+5d |  | 623d |  |
| 2808 |  | Baseline Schedule Publication | 0d | 2025-05-27 | 2025-05-27 | 2807FS+5d |  | 623d |  |
| 2809 |  | Migration Sprint 3 Schedule Baselined | 0d | 2025-05-27 | 2025-05-27 | 2808 |  | 623d |  |
| 2810 |  | Sprint Execution Start | 0d | 2025-06-03 | 2025-06-03 | 2809FS+5d |  | 623d |  |
| 2811 |  | Sprint Execution | 44d | 2025-06-04 | 2025-08-04 | 2810 |  | 623d |  |
| 2812 |  | Sprint Execution End | 0d | 2025-08-04 | 2025-08-04 | 2811 |  | 623d |  |
| 2813 | 1.8.13.11 | **Migration Sprint 4** | 65d | 2026-07-08 | 2026-10-06 |  |  | 317d |  |
| 2814 |  | Sprint 4 Planning start date | 6d | 2026-07-08 | 2026-07-15 |  |  | 317d | start no earlier than 2026-07-08 |
| 2815 |  | Issue Envelope | 0d | 2026-07-15 | 2026-07-15 | 2814 |  | 317d |  |
| 2816 |  | Supplier Submission Deadline | 0d | 2026-07-22 | 2026-07-22 | 2815FS+5d |  | 317d |  |
| 2817 |  | Baseline Schedule Publication | 0d | 2026-07-29 | 2026-07-29 | 2816FS+5d |  | 317d |  |
| 2818 |  | Migration Sprint 4 Schedule Baselined | 0d | 2026-07-29 | 2026-07-29 | 2817 |  | 317d |  |
| 2819 |  | Sprint Execution Start | 0d | 2026-08-05 | 2026-08-05 | 2818FS+5d |  | 317d |  |
| 2820 |  | Sprint Execution | 44d | 2026-08-06 | 2026-10-06 | 2819 |  | 317d |  |
| 2821 |  | Sprint Execution End | 0d | 2026-10-06 | 2026-10-06 | 2820 |  | 317d |  |
| 2822 | 1.8.13.12 | **Migration Sprint 5** | 60d | 2026-09-09 | 2026-12-01 |  |  | 277d |  |
| 2823 |  | Sprint 5 Planning start date | 6d | 2026-09-09 | 2026-09-16 |  |  | 277d | start no earlier than 2026-09-09 |
| 2824 |  | Issue Envelope | 0d | 2026-09-16 | 2026-09-16 | 2823 |  | 277d |  |
| 2825 |  | Supplier Submission Deadline | 0d | 2026-09-23 | 2026-09-23 | 2824FS+5d |  | 277d |  |
| 2826 |  | Baseline Schedule Publication | 0d | 2026-09-30 | 2026-09-30 | 2825FS+5d |  | 277d |  |
| 2827 |  | Migration Sprint 5 Schedule Baselined | 0d | 2026-09-30 | 2026-09-30 | 2826 |  | 277d |  |
| 2828 |  | Sprint Execution Start | 0d | 2026-10-07 | 2026-10-07 | 2827FS+5d |  | 277d |  |
| 2829 |  | Sprint Execution | 39d | 2026-10-08 | 2026-12-01 | 2828 |  | 277d |  |
| 2830 |  | Sprint Execution End | 0d | 2026-12-01 | 2026-12-01 | 2829 |  | 277d |  |
| 2831 | 1.8.13.13 | **Migration Sprint 6** | 65d | 2026-11-04 | 2027-02-02 |  |  | 232d |  |
| 2832 |  | Sprint 6 Planning start date | 6d | 2026-11-04 | 2026-11-11 |  |  | 232d | start no earlier than 2026-11-04 |
| 2833 |  | Issue Envelope | 0d | 2026-11-11 | 2026-11-11 | 2832 |  | 232d |  |
| 2834 |  | Supplier Submission Deadline | 0d | 2026-11-18 | 2026-11-18 | 2833FS+5d |  | 232d |  |
| 2835 |  | Baseline Schedule Publication | 0d | 2026-11-25 | 2026-11-25 | 2834FS+5d |  | 232d |  |
| 2836 |  | Migration Sprint 6 Schedule Baselined | 0d | 2026-11-25 | 2026-11-25 | 2835 |  | 232d |  |
| 2837 |  | Sprint Execution Start | 0d | 2026-12-02 | 2026-12-02 | 2836FS+5d |  | 232d |  |
| 2838 |  | Sprint Execution | 44d | 2026-12-03 | 2027-02-02 | 2837 |  | 232d |  |
| 2839 |  | Sprint Execution End | 0d | 2027-02-02 | 2027-02-02 | 2838 |  | 232d |  |
| 2840 | 1.8.13.14 | **Migration Sprint 7** | 65d | 2027-01-06 | 2027-04-06 |  |  | 187d |  |
| 2841 |  | Sprint 6 Planning start date | 6d | 2027-01-06 | 2027-01-13 |  |  | 187d | start no earlier than 2027-01-06 |
| 2842 |  | Issue Envelope | 0d | 2027-01-13 | 2027-01-13 | 2841 |  | 187d |  |
| 2843 |  | Supplier Submission Deadline | 0d | 2027-01-20 | 2027-01-20 | 2842FS+5d |  | 187d |  |
| 2844 |  | Baseline Schedule Publication | 0d | 2027-01-27 | 2027-01-27 | 2843FS+5d |  | 187d |  |
| 2845 |  | Migration Sprint 7 Schedule Baselined | 0d | 2027-01-27 | 2027-01-27 | 2844 |  | 187d |  |
| 2846 |  | Sprint Execution Start | 0d | 2027-02-03 | 2027-02-03 | 2845FS+5d |  | 187d |  |
| 2847 |  | Sprint Execution | 44d | 2027-02-04 | 2027-04-06 | 2846 |  | 187d |  |
| 2848 |  | Sprint Execution End | 0d | 2027-04-06 | 2027-04-06 | 2847 |  | 187d |  |
| 2849 | 1.8.13.15 | **Migration Sprint 8** | 48d | 2027-03-01 | 2027-05-05 |  |  | 0d |  |
| 2850 |  | Sprint 8 Planning start date | 6d | 2027-03-01 | 2027-03-08 |  |  | 0d | start no earlier than 2027-03-01 |
| 2851 |  | Issue Envelope | 0d | 2027-03-08 | 2027-03-08 | 2850 |  | 0d |  |
| 2852 |  | Supplier Submission Deadline | 0d | 2027-03-15 | 2027-03-15 | 2851FS+5d |  | 0d |  |
| 2853 |  | Baseline Schedule Publication | 0d | 2027-03-22 | 2027-03-22 | 2852FS+5d |  | 0d |  |
| 2854 |  | Migration Sprint 8 Schedule Baselined | 0d | 2027-03-22 | 2027-03-22 | 2853 |  | 0d |  |
| 2855 |  | Sprint Execution Start | 0d | 2027-03-29 | 2027-03-29 | 2854FS+5d |  | 0d |  |
| 2856 |  | Sprint Execution | 27d | 2027-03-30 | 2027-05-05 | 2855 |  | 0d |  |
| 2857 |  | Sprint Execution End | 0d | 2027-05-05 | 2027-05-05 | 2856 |  | 0d |  |
| 2858 | 1.8.14 | **External Programme Dependency Management** | 740d | 2022-10-31 A | 2025-08-29 |  | 66% | 604d |  |
| 2859 | 1.8.14.1 | **BSC Mod P432 & REC CP R0015** | 392d | 2022-10-31 A | 2024-04-30 A |  | 100% |  |  |
| 2860 |  | MHHSP engagement with BSCCo until Ofgem decision | 316d | 2022-10-31 A | 2024-01-15 A |  | 100% |  |  |
| 2861 |  | Monitor progress and await implementation date | 76d | 2024-01-16 A | 2024-04-30 A | 2860 | 100% |  |  |
| 2862 | 1.8.14.2 | **BSC Mod P434** | 713d | 2022-10-31 A | 2025-07-23 |  | 57% | 631d |  |
| 2863 |  | MHHSP engagement with BSCCo until Ofgem decision | 61d | 2022-10-31 A | 2023-01-23 A |  | 100% |  |  |
| 2864 |  | Monitor progress and await implementation date | 652d | 2023-01-24 A | 2025-07-23 | 2863 | 52% | 631d |  |
| 2865 | 1.8.14.3 | **Elexon System Capacity Upgrade** | 697d | 2022-10-31 A | 2025-07-01 |  | 58% | 647d |  |
| 2866 |  | Monitor progress to implementation | 697d | 2022-10-31 A | 2025-07-01 |  | 58% | 647d |  |
| 2867 |  | Implementation date | 0d | 2025-07-01 | 2025-07-01 | 2866 |  | 647d |  |
| 2868 | 1.8.14.4 | **DCC System Capacity Upgrade** | 25d | 2025-07-28 | 2025-08-29 |  |  | 604d |  |
| 2869 |  | Assurance of DCC capacity upgrade to ensure suitability to support migration | 20d | 2025-07-28 | 2025-08-22 | 1835FF-23d |  | 604d |  |
| 2870 |  | DCC Capacity Upgrade Operational | 0d | 2025-08-29 | 2025-08-29 | 2869FS+5d |  | 604d |  |

| ID | WBS | Task | Duration | Start | Finish | Predecessors | Complete | Total float | Constraint |
| --- | --- | --- | --- | --- | --- | --- | --- | --- | --- |
| 2871 | 1.8.15 | **Migration - Tier 1 Milestones** | 488d | 2025-09-24 | 2027-08-09 |  |  | 20d |  |
| 2872 |  | Load Shaping Service switched on (M13) | 0d | 2025-09-24 | 2025-09-24 | 1835 |  | 20d |  |
| 2873 |  | Load Shaping Service switched on (M13*) - Late Exit | 0d | 2025-12-24 | 2025-12-24 | 2872FS+65d |  | 521d |  |
| 2874 |  | Start of 18-month migration for UMS / Advanced (M11) | 0d | 2025-10-22 | 2025-10-22 | 2872, 2761, 2762, 2918, 1835FS+20d |  | 0d |  |
| 2875 |  | Start of 18-month migration for UMS / Advanced (M11*) - Late Exit | 0d | 2026-01-21 | 2026-01-21 | 2874FS+65d |  | 501d |  |
| 2876 |  | Start of 18-month migration for Smart / Non-smart (M12) | 0d | 2025-10-22 | 2025-10-22 | 2872, 1835FS+20d |  | 501d |  |
| 2877 |  | Start of 18-month migration for Smart / Non-smart (M12*) - Late Exit | 0d | 2026-01-21 | 2026-01-21 | 2876FS+65d |  | 501d |  |
| 2878 |  | Full transition complete (M15) | 0d | 2027-05-07 | 2027-05-07 | 2764, 2765, 2766, 2767, 2768, 2769, 2771, 2772, 2773, 2774, 2775, 2776, 2857FS+2d |  | 0d |  |
| 2879 |  | Full transition complete (M15*) - Late Exit | 0d | 2027-08-09 | 2027-08-09 | 2878FS+66d |  | 98d |  |
| 2880 | 1.9 | **BUSINESS & OPERATIONAL READINESS** | 1344d? | 2022-10-31 A | 2027-12-23 |  | 6% | 0d |  |
| 2881 | 1.9.1 | **Service Management** | 983d | 2023-09-19 A | 2027-06-24 |  | 26% | 130d |  |
| 2882 | 1.9.1.1 | **Service Management Strategy** | 116d | 2023-09-19 A | 2024-02-27 A |  | 100% |  |  |
| 2883 |  | Develop document with relevant participants (incl. review of the design baseline to ensure service management arrangements are in place across the solution architecture) | 84d | 2023-09-19 A | 2024-01-12 A |  | 100% |  | start no earlier than 2023-09-19 |
| 2884 |  | Artefact review (via relevant Advisory Group) and updates | 31d | 2024-01-15 A | 2024-02-26 A | 2883 | 100% |  |  |
| 2885 |  | Service Management Strategy approved | 0d | 2024-02-27 A | 2024-02-27 A | 2884FS+1d | 100% |  |  |
| 2886 | 1.9.1.2 | **Early Life Support Model** | 110d | 2024-02-28 A | 2024-07-30 |  | 82% | 887d |  |
| 2887 |  | Draft Document | 74d | 2024-02-28 A | 2024-06-10 | 2885 | 96% | 887d |  |
| 2888 |  | Share Document with SRO | 1d | 2024-06-11 | 2024-06-11 | 2887 |  | 887d |  |
| 2889 |  | Industry Consultation | 11d | 2024-06-18 | 2024-07-02 | 2888FS+4d |  | 887d |  |
| 2890 |  | Assurance Meeting | 1d | 2024-07-16 | 2024-07-16 | 2889FS+9d |  | 887d |  |
| 2891 |  | MCAG Approval of Early Life Support Model | 0d | 2024-07-30 | 2024-07-30 | 2890FS+10d |  | 887d |  |
| 2892 | 1.9.1.3 | **Service Management Arrangements Implementation** | 456d | 2025-09-25 | 2027-06-24 |  |  | 130d |  |
| 2893 |  | Hypercare post M10 | 80d | 2025-09-25 | 2026-01-14 | 1835 |  | 506d |  |
| 2894 |  | Monitor Elexon implementation of Service Management arrangements | 436d | 2025-10-23 | 2027-06-24 | 2764SS, 2771SS |  | 130d |  |
| 2895 | 1.9.2 | **Service Activation** | 1043d? | 2022-10-31 | 2026-10-28 |  |  | 301d |  |
| 2896 | 1.9.2.1 | **SIT MVC** | 770d? | 2022-10-31 | 2025-10-10 |  |  | 574d |  |
| 2897 | 1.9.2.1.1 | **SIT MVC Service Activation Preparation Tasks** | 20d | 2025-02-03 | 2025-02-28 |  |  | 159d |  |
| 2898 |  | Identify operational resources | 5d | 2025-02-03 | 2025-02-07 |  |  | 749d | finish no earlier than 2025-02-07 |
| 2899 |  | Define and approve operational support model | 5d | 2025-02-10 | 2025-02-14 |  |  | 744d | finish no earlier than 2025-02-14 |
| 2900 |  | Confirm SA Training completed | 10d | 2025-02-10 | 2025-02-21 |  |  | 739d | finish no earlier than 2025-02-21 |
| 2901 |  | Participant Engagement / Communications | 15d | 2025-02-10 | 2025-02-28 |  |  | 734d | finish no earlier than 2025-02-28 |
| 2902 |  | Internal Communications | 15d | 2025-02-10 | 2025-02-28 |  |  | 734d | finish no earlier than 2025-02-28 |
| 2903 |  | Validate User Access | 5d | 2025-02-17 | 2025-02-21 |  |  | 739d | finish no earlier than 2025-02-21 |
| 2904 |  | Target Systems and Environments Ready | 3d | 2025-02-20 | 2025-02-24 |  |  | 738d | finish no earlier than 2025-02-24 |
| 2905 |  | Provide opeartional resources with LWIs | 5d | 2025-02-17 | 2025-02-21 |  |  | 739d | finish no earlier than 2025-02-21 |
| 2906 |  | Business Readiness Governance Approval | 3d | 2025-02-17 | 2025-02-19 |  |  | 741d | finish no earlier than 2025-02-19 |
| 2907 |  | SIT MVC Service Activation Preparation Tasks Complete | 0d | 2025-02-28 | 2025-02-28 |  |  | 139d | finish no earlier than 2025-02-28 |
| 2908 |  | MHHSP Confirms SIT MVC PPs MHHS Enabled | 1d | 2022-10-31 | 2022-10-31 |  |  | 748d |  |
| 2909 | 1.9.2.1.3 | **SIT MVC Service Activation Implementation** | 7d? | 2025-09-12 | 2025-09-22 |  |  | 0d |  |
| 2910 |  | Add EFD to DIP | 1d | 2025-09-12 | 2025-09-12 | 2035SS, 2908, 2907 |  | 0d |  |
| 2911 |  | DIP Promoted to Production | 1d? | 2025-09-15 | 2025-09-15 | 2910 |  | 0d |  |
| 2912 |  | SIT LDSOs Create Certificates and Test Connectivity | 1d? | 2025-09-16 | 2025-09-16 | 2911 |  | 0d |  |
| 2913 |  | SIT MVC S&As Create Certificates and Test Connectivity | 1d? | 2025-09-16 | 2025-09-16 | 2911 |  | 22d |  |
| 2914 |  | Create M16 in Customer Solution | 2d | 2025-09-16 | 2025-09-17 | 2911 |  | 0d | finish no earlier than 2025-03-07 |
| 2915 |  | Publish ISD | 2d | 2025-09-18 | 2025-09-19 | 2914 |  | 0d | finish no earlier than 2025-03-07 |
| 2916 |  | SIT LDSOs to update systems with ISD | 1d? | 2025-09-22 | 2025-09-22 | 2915 |  | 4d |  |
| 2917 |  | SIT MVC S&As to update systems with ISD | 1d? | 2025-09-22 | 2025-09-22 | 2915 |  | 18d |  |
| 2918 |  | SIT MVC Service Activation Implementation Complete | 0d | 2025-09-19 | 2025-09-19 | 2915 |  | 0d | finish no earlier than 2025-03-07 |
| 2919 | 1.9.2.1.4 | **SIT MVC Service Activation Implementation MDD** | 15d | 2025-09-22 | 2025-10-10 |  |  | 574d |  |
| 2920 |  | MDD Manual Load | 7d | 2025-09-22 | 2025-09-30 | 2915 |  | 574d | finish no earlier than 2025-03-14 |
| 2921 |  | MDD Update | 8d | 2025-10-01 | 2025-10-10 | 2920 |  | 574d | finish no earlier than 2025-03-25 |
| 2922 |  | SIT MVC Service Activation Implementation MDD Complete | 0d | 2025-10-10 | 2025-10-10 | 2921 |  | 574d | finish no earlier than 2025-03-25 |
| 2923 | 1.9.2.1.5 | **SIT MVC Service Activation Hypercare** | 21d | 2025-09-12 | 2025-10-10 |  |  | 574d |  |
| 2924 |  | Service & Process Monitoring | 18d | 2025-09-12 | 2025-10-07 | 2910SS |  | 577d | finish no earlier than 2025-03-26 |
| 2925 |  | Daily Reporting | 18d | 2025-09-12 | 2025-10-07 | 2910SS |  | 577d | finish no earlier than 2025-03-26 |
| 2926 |  | Issue Management | 18d | 2025-09-12 | 2025-10-07 | 2910SS |  | 577d | finish no earlier than 2025-03-26 |
| 2927 |  | SA Hypercare Close Down Activities | 18d | 2025-09-12 | 2025-10-07 | 2910SS |  | 574d | finish no earlier than 2025-03-26 |
| 2928 |  | Handover to MHHSP | 3d | 2025-10-08 | 2025-10-10 | 2927 |  | 574d | finish no earlier than 2025-03-25 |
| 2929 |  | SIT MVC Service Activation Hypercare Complete | 0d | 2025-10-10 | 2025-10-10 | 2928 |  | 574d | finish no earlier than 2025-03-25 |
| 2930 | 1.9.2.2 | **SIT Non-MVC** | 841d? | 2022-10-31 | 2026-01-19 |  |  | 503d |  |
| 2931 | 1.9.2.2.1 | **SIT Non-MVC Service Activation Preparation Tasks** | 610d | 2022-10-31 | 2025-02-28 |  |  | 734d |  |
| 2932 |  | Helix Preparatory Activities Complete | 0d | 2025-02-28 | 2025-02-28 | 2907 |  | 734d |  |
| 2933 |  | MHHSP Confirms SIT Non-MVC PPs MHHS Enabled | 1d | 2022-10-31 | 2022-10-31 |  |  | 818d |  |
| 2934 | 1.9.2.2.2 | **SIT Non-MVC Service Activation Implementation** | 7d? | 2025-12-19 | 2025-12-29 |  |  | 0d |  |
| 2935 |  | Add EDF to DIP | 1d | 2025-12-19 | 2025-12-19 | 2041SS, 2933 |  | 0d | finish no earlier than 2025-06-04 |
| 2936 |  | DIP Promoted to Production | 1d | 2025-12-22 | 2025-12-22 | 2935 |  | 0d | finish no earlier than 2025-06-05 |
| 2937 |  | SIT non-MVC S&As Create Certificates and Test Connectivity | 1d? | 2025-12-23 | 2025-12-23 | 2936 |  | 522d |  |
| 2938 |  | Create M16 in Customer Solution | 2d | 2025-12-23 | 2025-12-24 | 2936 |  | 0d | finish no earlier than 2025-06-06 |
| 2939 |  | Publish ISD | 2d | 2025-12-25 | 2025-12-26 | 2938 |  | 0d | finish no earlier than 2025-06-06 |
| 2940 |  | SIT non-MVC S&As to update systems with ISD | 1d? | 2025-12-29 | 2025-12-29 | 2939 |  | 518d |  |

| ID | WBS | Task | Duration | Start | Finish | Predecessors | Total float | Constraint |
| --- | --- | --- | --- | --- | --- | --- | --- | --- |
| 2941 |  | SIT Non-MVC Service Activation Implementation Complete | 0d | 2025-12-26 | 2025-12-26 | 2939 | 0d | finish no earlier than 2025-06-06 |
| 2942 | 1.9.2.2.3 | **SIT Non-MVC Service Activation Implementation MDD** | 15d | 2025-12-29 | 2026-01-16 |  | 504d |  |
| 2943 |  | MDD Manual Load | 7d | 2025-12-29 | 2026-01-06 | 2939 | 504d | finish no earlier than 2025-06-13 |
| 2944 |  | MDD Update | 8d | 2026-01-07 | 2026-01-16 | 2943 | 504d | finish no earlier than 2025-06-24 |
| 2945 |  | SIT Non-MVC Service Activation Implementation MDD Complete | 0d | 2026-01-16 | 2026-01-16 | 2944 | 504d | finish no earlier than 2025-06-24 |
| 2946 | 1.9.2.2.4 | **Non-SIT MVC Service Activation Hypercare** | 22d | 2025-12-19 | 2026-01-19 |  | 503d |  |
| 2947 |  | Service& Process Monitoring | 18d | 2025-12-19 | 2026-01-13 | 2935SS | 507d | finish no earlier than 2025-06-25 |
| 2948 |  | Daily Reporting | 18d | 2025-12-19 | 2026-01-13 | 2935SS | 507d | finish no earlier than 2025-06-25 |
| 2949 |  | Issue Management | 18d | 2025-12-19 | 2026-01-13 | 2935SS | 507d | finish no earlier than 2025-06-25 |
| 2950 |  | SA Hypercare Close Down Activities | 18d | 2025-12-19 | 2026-01-13 | 2935SS | 503d | finish no earlier than 2025-06-25 |
| 2951 |  | Handover to MHHSP | 4d | 2026-01-14 | 2026-01-19 | 2950 | 503d | finish no earlier than 2025-06-26 |
| 2952 |  | Non-SIT MVC Service Activation Hypercare Complete (M) | 0d | 2026-01-19 | 2026-01-19 | 2951 | 503d | finish no earlier than 2025-06-25 |
| 2953 | 1.9.2.3 | **Wave 1** | 924d | 2022-10-31 | 2026-05-14 |  | 420d |  |
| 2954 | 1.9.2.3.1 | **SIT Non-MVC Service Activation Preparation Tasks** | 924d | 2022-10-31 | 2026-05-14 |  | 420d |  |
| 2955 |  | Helix Preparatory Activities Complete | 0d | 2022-10-31 | 2022-10-31 |  | 1344d |  |
| 2956 |  | MHHSP Confirms Wave 1 PPs MHHS Enabled | 1d | 2022-10-31 | 2022-10-31 |  | 902d |  |
| 2957 |  | Wave 1 Service Activation | 21d | 2026-04-16 | 2026-05-14 | 2264, 2956 | 0d |  |
| 2958 | 1.9.2.3.2 | **Wave 1 - Service Activation Implementation** | 171d | 2025-09-01 | 2026-04-27 |  | 433d |  |
| 2959 |  | MHHSP Enabled Confirmation | 2d | 2025-09-01 | 2025-09-02 | 2933 | 602d | finish no earlier than 2025-09-02 |
| 2960 |  | PAB Approval | 2d | 2026-04-16 | 2026-04-17 | 2264 | 439d | finish no earlier than 2025-09-02 |
| 2961 |  | Add EFD to DIP | 2d | 2026-04-16 | 2026-04-17 | 2264 | 422d | finish no earlier than 2025-09-03 |
| 2962 |  | DIP Promoted to Production | 2d | 2026-04-20 | 2026-04-21 | 2961 | 422d | finish no earlier than 2025-09-04 |
| 2963 |  | Create M16 in Customer Solution | 2d | 2026-04-22 | 2026-04-23 | 2962 | 422d | finish no earlier than 2025-09-05 |
| 2964 |  | Publish ISD | 2d | 2026-04-24 | 2026-04-27 | 2963 | 422d | finish no earlier than 2025-09-05 |
| 2965 |  | Wave 1 - Service Activation Implementation Complete (M) | 0d | 2026-04-27 | 2026-04-27 | 2964 | 433d | finish no earlier than 2025-09-05 |
| 2966 | 1.9.2.3.3 | **Wave 1 - Service Activation Implementation MDD** | 11d | 2026-04-28 | 2026-05-12 |  | 422d |  |
| 2967 |  | MDD Manual Load | 5d | 2026-04-28 | 2026-05-04 | 2964 | 422d | finish no earlier than 2025-09-10 |
| 2968 |  | MDD Update | 6d | 2026-05-05 | 2026-05-12 | 2967 | 422d | finish no earlier than 2025-09-17 |
| 2969 |  | Wave 1 - Service Activation Implementation MDD Complete (M) | 0d | 2026-05-12 | 2026-05-12 | 2968 | 422d | finish no earlier than 2025-09-17 |
| 2970 | 1.9.2.3.4 | **Wave 1 - Service Activation Hypercare** | 177d | 2025-09-01 | 2026-05-05 |  | 427d |  |
| 2971 |  | Service& Process Monitoring | 14d | 2026-04-16 | 2026-05-05 | 2961SS | 427d | finish no earlier than 2025-09-18 |
| 2972 |  | Daily Reporting | 14d | 2026-04-16 | 2026-05-05 | 2961SS | 427d | finish no earlier than 2025-09-18 |
| 2973 |  | Issue Management | 14d | 2026-04-16 | 2026-05-05 | 2961SS | 427d | finish no earlier than 2025-09-18 |
| 2974 |  | SA Hypercare Close Down Activities | 14d | 2025-09-01 | 2025-09-18 |  | 586d | finish no earlier than 2025-09-18 |
| 2975 |  | Handover to MHHSP | 4d | 2025-09-19 | 2025-09-24 | 2974 | 586d | finish no earlier than 2025-09-18 |
| 2976 |  | Non-SIT LDSO Service Activation Hypercare Complete (M) | 0d | 2025-09-24 | 2025-09-24 | 2975 | 586d |  |
| 2977 | 1.9.2.4 | **Wave 2** | 958d | 2022-10-31 | 2026-07-01 |  | 386d |  |
| 2978 | 1.9.2.4.1 | **SIT Non-MVC Service Activation Preparation Tasks** | 958d | 2022-10-31 | 2026-07-01 |  | 386d |  |
| 2979 |  | Helix Preparatory Activities Complete | 0d | 2022-10-31 | 2022-10-31 |  | 1344d |  |
| 2980 |  | MHHSP Confirms Wave 2 PPs MHHS Enabled | 1d | 2022-10-31 | 2022-10-31 |  | 933d |  |
| 2981 |  | Wave 2 Service Activation | 24d | 2026-05-29 | 2026-07-01 | 2294, 2980 | 0d |  |
| 2982 | 1.9.2.4.2 | **Wave 2 - Service Activation Implementation** | 157d | 2025-11-03 | 2026-06-09 |  | 402d |  |
| 2983 |  | MHHSP Enabled Confirmation | 2d | 2025-11-03 | 2025-11-04 |  | 557d | finish no earlier than 2025-11-04 |
| 2984 |  | PAB Approval | 2d | 2026-05-29 | 2026-06-01 | 2294 | 408d | finish no earlier than 2025-11-04 |
| 2985 |  | Add EFD to DIP | 2d | 2026-05-29 | 2026-06-01 | 2294 | 402d | finish no earlier than 2025-11-05 |
| 2986 |  | DIP Promoted to Production | 2d | 2026-06-02 | 2026-06-03 | 2985 | 402d | finish no earlier than 2025-11-06 |
| 2987 |  | Create M16 in Customer Solution | 2d | 2026-06-04 | 2026-06-05 | 2986 | 402d | finish no earlier than 2025-11-07 |
| 2988 |  | Publish ISD | 2d | 2026-06-08 | 2026-06-09 | 2987 | 402d | finish no earlier than 2025-11-07 |
| 2989 |  | Wave 2 - Service Activation Implementation Complete (M) | 0d | 2026-06-09 | 2026-06-09 | 2988 | 402d | finish no earlier than 2025-11-07 |
| 2990 | 1.9.2.4.3 | **Wave 2 - Service Activation Implementation MDD** | 10d | 2025-11-06 | 2025-11-19 |  | 546d |  |
| 2991 |  | MDD Manual Load | 5d | 2025-11-06 | 2025-11-12 |  | 551d | finish no earlier than 2025-11-12 |
| 2992 |  | MDD Update | 6d | 2025-11-12 | 2025-11-19 |  | 546d | finish no earlier than 2025-11-19 |
| 2993 |  | Wave 2 - Service Activation Implementation MDD Complete (M) | 0d | 2025-11-19 | 2025-11-19 |  | 546d | finish no earlier than 2025-11-19 |
| 2994 | 1.9.2.4.4 | **Wave 2 - Service Activation Hypercare** | 14d | 2025-11-03 | 2025-11-20 |  | 545d |  |
| 2995 |  | Service& Process Monitoring | 14d | 2025-11-03 | 2025-11-20 |  | 545d | finish no earlier than 2025-11-20 |
| 2996 |  | Daily Reporting | 14d | 2025-11-03 | 2025-11-20 |  | 545d | finish no earlier than 2025-11-20 |
| 2997 |  | Issue Management | 14d | 2025-11-03 | 2025-11-20 |  | 545d | finish no earlier than 2025-11-20 |
| 2998 |  | SA Hypercare Close Down Activities | 14d | 2025-11-03 | 2025-11-20 |  | 545d | finish no earlier than 2025-11-20 |
| 2999 |  | Handover to MHHSP | 4d | 2025-11-17 | 2025-11-20 |  | 545d | finish no earlier than 2025-11-20 |
| 3000 |  | Wave 2 - Service Activation Hypercare Complete (M) | 0d | 2025-11-19 | 2025-11-19 |  | 546d | finish no earlier than 2025-11-19 |
| 3001 | 1.9.2.5 | **Wave 3** | 989d | 2022-10-31 | 2026-08-13 |  | 355d |  |
| 3002 | 1.9.2.5.1 | **SIT Non-MVC Service Activation Preparation Tasks** | 989d | 2022-10-31 | 2026-08-13 |  | 355d |  |
| 3003 |  | Helix Preparatory Activities Complete | 0d | 2022-10-31 | 2022-10-31 |  | 1344d |  |
| 3004 |  | MHHSP Confirms Wave 3 PPs MHHS Enabled | 1d | 2022-10-31 | 2022-10-31 |  | 978d |  |
| 3005 |  | Wave 3 Service Activation | 10d | 2026-07-31 | 2026-08-13 | 2324, 3004 | 0d |  |
| 3006 | 1.9.2.5.2 | **Wave 3 - Service Activation Implementation** | 169d | 2025-12-22 | 2026-08-13 |  | 355d |  |
| 3007 |  | MHHSP Enabled Confirmation | 2d | 2025-12-22 | 2025-12-23 |  | 522d | finish no earlier than 2025-12-23 |
| 3008 |  | PAB Approval | 2d | 2026-07-31 | 2026-08-03 | 2324 | 355d | finish no earlier than 2025-12-23 |
| 3009 |  | Add EFD to DIP | 2d | 2026-08-04 | 2026-08-05 | 2324, 3008 | 355d | finish no earlier than 2025-12-24 |
| 3010 |  | DIP Promoted to Production | 2d | 2026-08-06 | 2026-08-07 | 3009 | 355d | finish no earlier than 2025-12-30 |

| ID | WBS | Task | Duration | Start | Finish | Predecessors | Total float | Constraint |
| --- | --- | --- | --- | --- | --- | --- | --- | --- |
| 3011 |  | Create M16 in Customer Solution | 2d | 2026-08-10 | 2026-08-11 | 3010 | 355d | finish no earlier than 2025-12-30 |
| 3012 |  | Publish ISD | 2d | 2026-08-12 | 2026-08-13 | 3011 | 355d | finish no earlier than 2025-12-30 |
| 3013 |  | Wave 3 - Service Activation Implementation Complete (M) | 0d | 2026-08-13 | 2026-08-13 | 3012 | 355d | finish no earlier than 2025-12-30 |
| 3014 | 1.9.2.5.3 | **Wave 3 - Service Activation Implementation MDD** | 839d | 2022-10-31 | 2026-01-15 |  | 505d |  |
| 3015 |  | MDD Manual Load | 7d | 2025-12-29 | 2026-01-06 |  | 512d | finish no earlier than 2026-01-06 |
| 3016 |  | MDD Update | 269d | 2025-01-06 | 2026-01-15 |  | 505d | finish no earlier than 2026-01-15 |
| 3017 |  | Wave 3 - Service Activation Implementation MDD Complete (M) | 0d | 2022-10-31 | 2022-10-31 |  | 1344d |  |
| 3018 | 1.9.2.5.4 | **Wave 3 - Service Activation Hypercare** | 840d | 2022-10-31 | 2026-01-16 |  | 504d |  |
| 3019 |  | Service& Process Monitoring | 20d | 2025-12-22 | 2026-01-16 |  | 504d | finish no earlier than 2026-01-16 |
| 3020 |  | Daily Reporting | 20d | 2025-12-22 | 2026-01-16 |  | 504d | finish no earlier than 2026-01-16 |
| 3021 |  | Issue Management | 20d | 2025-12-22 | 2026-01-16 |  | 504d | finish no earlier than 2026-01-16 |
| 3022 |  | SA Hypercare Close Down Activities | 20d | 2025-12-22 | 2026-01-16 |  | 504d | finish no earlier than 2026-01-16 |
| 3023 |  | Handover to MHHSP | 4d | 2026-01-12 | 2026-01-15 |  | 505d | finish no earlier than 2026-01-15 |
| 3024 |  | Wave 3 Service Activation Hypercare Complete (M) | 0d | 2022-10-31 | 2022-10-31 |  | 1344d |  |
| 3025 | 1.9.2.6 | **Wave 4** | 1043d | 2022-10-31 | 2026-10-28 |  | 301d |  |
| 3026 | 1.9.2.6.1 | **SIT Non-MVC Service Activation Preparation Tasks** | 1043d | 2022-10-31 | 2026-10-28 |  | 301d |  |
| 3027 |  | Helix Preparatory Activities Complete | 0d | 2022-10-31 | 2022-10-31 |  | 1344d |  |
| 3028 |  | MHHSP Confirms Wave 4 PPs MHHS Enabled | 1d | 2022-10-31 | 2022-10-31 |  | 1018d |  |
| 3029 |  | Wave 4 Service Activation | 24d | 2026-09-25 | 2026-10-28 | 2354, 3028 | 0d |  |
| 3030 | 1.9.2.6.2 | **Wave 4 - Service Activation Implementation** | 158d | 2026-03-02 | 2026-10-07 |  | 316d |  |
| 3031 |  | MHHSP Enabled Confirmation | 2d | 2026-03-02 | 2026-03-03 |  | 472d | finish no earlier than 2026-03-03 |
| 3032 |  | PAB Approval | 1d | 2026-09-25 | 2026-09-25 | 2354 | 316d | finish no earlier than 2025-03-03 |
| 3033 |  | Add EFD to DIP | 2d | 2026-09-28 | 2026-09-29 | 3032 | 316d | finish no earlier than 2026-03-04 |
| 3034 |  | DIP Promoted to Production | 2d | 2026-09-30 | 2026-10-01 | 3033 | 316d | finish no earlier than 2026-03-05 |
| 3035 |  | Create M16 in Customer Solution | 2d | 2026-10-02 | 2026-10-05 | 3034 | 316d | finish no earlier than 2026-03-06 |
| 3036 |  | Publish ISD | 2d | 2026-10-06 | 2026-10-07 | 3035 | 316d | finish no earlier than 2026-03-06 |
| 3037 |  | Wave 4 - Service Activation Implementation Complete (M) | 0d | 2026-10-07 | 2026-10-07 | 3036 | 316d | finish no earlier than 2026-03-06 |
| 3038 | 1.9.2.6.3 | **Wave 4 - Service Activation Implementation MDD** | 15d | 2026-03-06 | 2026-03-26 |  | 455d |  |
| 3039 |  | MDD Manual Load | 7d | 2026-03-06 | 2026-03-16 |  | 463d | finish no earlier than 2026-03-16 |
| 3040 |  | MDD Update | 9d | 2026-03-16 | 2026-03-26 |  | 455d | finish no earlier than 2026-03-26 |
| 3041 |  | Wave 4 - Service Activation Implementation MDD Complete | 0d | 2026-03-25 | 2026-03-25 |  | 456d | finish no earlier than 2026-03-25 |
| 3042 | 1.9.2.6.4 | **Wave 4 - Service Activation Hypercare** | 19d | 2026-03-02 | 2026-03-26 |  | 455d |  |
| 3043 |  | Service& Process Monitoring | 19d | 2026-03-02 | 2026-03-26 |  | 455d | finish no earlier than 2026-03-26 |
| 3044 |  | Daily Reporting | 19d | 2026-03-02 | 2026-03-26 |  | 455d | finish no earlier than 2026-03-26 |
| 3045 |  | Issue Management | 19d | 2026-03-02 | 2026-03-26 |  | 455d | finish no earlier than 2026-03-26 |
| 3046 |  | SA Hypercare Close Down Activities | 19d | 2026-03-02 | 2026-03-26 |  | 455d | finish no earlier than 2026-03-26 |
| 3047 |  | Handover to MHHSP | 4d | 2026-03-02 | 2026-03-05 |  | 470d | finish no earlier than 2026-03-05 |
| 3048 |  | Wave 4 - Service Activation Hypercare Complete (M) | 0d | 2026-03-25 | 2026-03-25 |  | 456d | finish no earlier than 2026-03-25 |
| 3049 | 1.9.2.7 | **Non-SIT LDSO** | 754d | 2022-10-31 | 2025-09-18 |  | 590d |  |
| 3050 | 1.9.2.7.1 | **Non-SIT LDSO Service Activation Data Loading** | 176d | 2024-06-07 | 2025-02-07 |  | 749d |  |
| 3051 |  | Define pre Non-SIT LDSO upfront activities | 7d | 2024-06-07 | 2024-06-17 |  | 918d | finish no earlier than 2024-06-17 |
| 3052 | 1.9.2.7.1.2 | **Execute Non-SIT LDSO Activities** | 5d | 2025-02-03 | 2025-02-07 |  | 749d |  |
| 3053 |  | Create Entity Forms in Customer Solution | 3d | 2025-02-03 | 2025-02-05 |  | 751d | finish no earlier than 2025-02-05 |
| 3054 |  | DIP - Promote to Production Environment | 3d | 2025-02-03 | 2025-02-05 |  | 751d | finish no earlier than 2025-02-05 |
| 3055 |  | DIP - Enable Technology capabilities for participants | 3d | 2025-02-03 | 2025-02-05 |  | 751d | finish no earlier than 2025-02-05 |
| 3056 |  | DIP - Add EFD to DIP | 3d | 2025-02-03 | 2025-02-05 |  | 751d | finish no earlier than 2025-02-05 |
| 3057 |  | ISD - Replicate Entity Forms from CS | 2d | 2025-02-06 | 2025-02-07 |  | 749d | finish no earlier than 2025-02-07 |
| 3058 |  | MDD - Load MHHS roles | 3d | 2025-02-03 | 2025-02-05 |  | 751d | finish no earlier than 2025-02-05 |
| 3059 |  | Non-SIT LDSO Service Activation Data Loading Completed (M) | 0d | 2025-02-07 | 2025-02-07 |  | 749d | finish no earlier than 2025-02-07 |
| 3060 | 1.9.2.7.2 | **SIT Non-MVC Service Activation Preparation Tasks** | 754d | 2022-10-31 | 2025-09-18 |  | 590d |  |
| 3061 |  | Helix Preparatory Activities Complete | 0d | 2022-10-31 | 2022-10-31 |  | 1344d |  |
| 3062 |  | MHHSP Confirms Non-SIT LDSO PPs MHHS Enabled | 1d | 2022-10-31 | 2022-10-31 |  | 751d |  |
| 3063 |  | Non-SIT LDSO Service Activation | 6d | 2025-09-11 | 2025-09-18 | 3062, 2053 | 4d |  |
| 3064 | 1.9.2.7.3 | **Non-SIT LDSO Service Activation Implementation** | 4d | 2025-02-24 | 2025-02-27 |  | 735d |  |
| 3065 |  | MHHSP Enabled Confirmation | 2d | 2025-02-24 | 2025-02-25 |  | 737d | finish no earlier than 2025-02-25 |
| 3066 |  | PAB Approval | 2d | 2025-02-24 | 2025-02-25 |  | 737d | finish no earlier than 2025-02-25 |
| 3067 |  | Add EFD to DIP | 2d | 2025-02-25 | 2025-02-26 |  | 736d | finish no earlier than 2025-02-26 |
| 3068 |  | DIP Promoted to Production | 2d | 2025-02-26 | 2025-02-27 |  | 735d | finish no earlier than 2025-02-27 |
| 3069 |  | Create M16 in Customer Solution | 2d | 2025-02-26 | 2025-02-27 |  | 735d | finish no earlier than 2025-02-27 |
| 3070 |  | Publish ISD | 2d | 2025-02-26 | 2025-02-27 |  | 735d | finish no earlier than 2025-02-27 |
| 3071 |  | Non-SIT LDSO Service Activation Implementation Completed (M) | 0d | 2025-02-27 | 2025-02-27 |  | 735d | finish no earlier than 2025-02-27 |
| 3072 | 1.9.2.7.4 | **Non-SIT LDSO Service Activation Implementation MDD** | 14d | 2025-02-27 | 2025-03-18 |  | 722d |  |
| 3073 |  | MDD Manual Load | 7d | 2025-02-27 | 2025-03-07 |  | 729d | finish no earlier than 2025-03-07 |
| 3074 |  | MDD Update | 8d | 2025-03-07 | 2025-03-18 |  | 722d | finish no earlier than 2025-03-18 |
| 3075 |  | Non-SIT LDSO Service Activation Implementation MDD Complete (M) | 0d | 2025-03-18 | 2025-03-18 |  | 722d | finish no earlier than 2025-03-18 |
| 3076 | 1.9.2.7.5 | **Non-SIT LDSO Service Activation Hypercare** | 18d | 2025-02-24 | 2025-03-19 |  | 721d |  |
| 3077 | 1.9.2.7.5.1 | **Non-SIT LDSO Service Activation Hypercare Support** | 18d | 2025-02-24 | 2025-03-19 |  | 721d |  |
| 3078 |  | Service& Process Monitoring | 18d | 2025-02-24 | 2025-03-19 |  | 721d | finish no earlier than 2025-03-19 |
| 3079 |  | Daily Reporting | 18d | 2025-02-24 | 2025-03-19 |  | 721d | finish no earlier than 2025-03-19 |
| 3080 |  | Issue Management | 18d | 2025-02-24 | 2025-03-19 |  | 721d | finish no earlier than 2025-03-19 |

| ID | WBS | Task | Duration | Start | Finish | Predecessors | Total float | Constraint |
| --- | --- | --- | --- | --- | --- | --- | --- | --- |
| 3081 |  | SA Hypercare Close Down Activities | 18d | 2025-02-24 | 2025-03-19 |  | 721d | finish no earlier than 2025-03-19 |
| 3082 |  | Handover to MHHSP | 3d | 2025-03-14 | 2025-03-18 |  | 722d | finish no earlier than 2025-03-18 |
| 3083 |  | Non-SIT LDSO Service Activation Hypercare Complete (M) | 0d | 2025-03-18 | 2025-03-18 |  | 722d | finish no earlier than 2025-03-18 |
| 3084 | 1.9.3 | **Implement Early Life Support Plan** | 55d | 2025-07-07 | 2025-09-19 |  | 589d |  |
| 3085 |  | Implement Early Life Support Plan | 55d | 2025-07-07 | 2025-09-19 |  | 589d | start no earlier than 2025-07-07 |
| 3086 | 1.9.4 | **Business Continuity and Disaster Recovery Plan** | 40d | 2025-07-31 | 2025-09-24 |  | 586d |  |
| 3087 |  | Central Parties BCDRs in Place | 20d | 2025-07-31 | 2025-08-27 | 2513FS-40d | 586d |  |
| 3088 |  | Risk Based Assurance of Cental Party BCDRs | 20d | 2025-08-28 | 2025-09-24 | 3087 | 586d |  |
| 3089 | 1.9.5 | **Training and Support Materials** | 39d | 2025-08-21 | 2025-10-14 |  | 572d |  |
| 3090 |  | Develop document | 20d | 2025-08-21 | 2025-09-17 | 2876FS-45d | 572d |  |
| 3091 |  | Document review and update | 19d | 2025-09-18 | 2025-10-14 | 3090 | 572d |  |
| 3092 |  | Training and Support Materials approved | 0d | 2025-10-14 | 2025-10-14 | 3091 | 572d |  |
| 3093 | 1.9.6 | **PP Business Change** | 129d | 2025-02-03 | 2025-07-31 |  | 625d |  |
| 3094 |  | Plan stakeholder management | 129d | 2025-02-03 | 2025-07-31 |  | 625d | start no earlier than 2025-02-03 |
| 3095 |  | Manage stakeholders | 129d | 2025-02-03 | 2025-07-31 |  | 625d | start no earlier than 2025-02-03 |
| 3096 |  | Develop & implement changes to KPIs, organisation & people management | 129d | 2025-02-03 | 2025-07-31 |  | 625d | start no earlier than 2025-02-03 |
| 3097 |  | Develop & test changes to business processes | 129d | 2025-02-03 | 2025-07-31 |  | 625d | start no earlier than 2025-02-03 |
| 3098 |  | Develop and deliver training | 129d | 2025-02-03 | 2025-07-31 |  | 625d | start no earlier than 2025-02-03 |
| 3099 |  | Programme support for PP Business Change activities | 129d | 2025-02-03 | 2025-07-31 |  | 625d | start no earlier than 2025-02-03 |
| 3100 | 1.9.7 | **Transition to New Settlement Timetable (M16)** | 566d | 2025-10-22 | 2027-12-23 |  | 0d |  |
| 3101 |  | Elexon to produce Settlement Calendar for Settlement Year 2025/2026 | 0d | 2025-10-22 | 2025-10-22 | 2874 | 5d |  |
| 3102 |  | Elexon monitor settlement data of migrated MPANs | 436d | 2025-10-23 | 2027-06-24 | 3101 | 6d |  |
| 3103 |  | M16 Checkpoint 1 | 0d | 2026-06-25 | 2026-06-25 | 3101FS+176d | 5d |  |
| 3104 |  | Confirm if M16 date retained as 07/12/2026 | 0d | 2026-07-23 | 2026-07-23 | 3103FS+20d | 5d |  |
| 3105 |  | Readiness assessment of participants' readiness to transition to new Settlement Timetable | 0d | 2026-08-20 | 2026-08-20 | 3104FS+20d | 5d |  |
| 3106 |  | Elexon to produce Settlement Calendar for Settlement Year 2026 up until day before M16 cutover | 0d | 2026-10-19 | 2026-10-19 | 3105FS+42d | 5d |  |
| 3107 |  | M16 Checkpoint 2 | 0d | 2027-04-02 | 2027-04-02 | 3106FS+119d | 5d |  |
| 3108 |  | Readiness assessment of participants' readiness to transition to new Settlement Timetable | 0d | 2027-04-19 | 2027-04-19 | 3107FS+11d | 5d |  |
| 3109 |  | Confirm M16 Date | 0d | 2027-04-30 | 2027-04-30 | 3108FS+9d | 5d |  |
| 3110 |  | Raise fast track change to ISD (November publish) | 0d | 2027-04-30 | 2027-04-30 | 3109 | 45d |  |
| 3111 | 1.9.7.11 | **M16 Approval Window** | 129d | 2027-06-25 | 2027-12-23 |  | 0d |  |
| 3112 |  | Panel approval that M16 criteria met | 0d | 2027-06-25 | 2027-06-25 | 3109FS+40d | 5d |  |
| 3113 |  | Cut over to new settlement timetable (M16) | 0d | 2027-07-02 | 2027-07-02 | 3112, 2878FS+40d, 3102, 3110, 2707 | 0d |  |
| 3114 |  | Maximum 6-month window for approval of M16 | 124d | 2027-07-05 | 2027-12-23 | 3113 | 0d |  |
| 3115 |  | Cut over to new settlement timetable (M16*) - Late Exit | 0d | 2027-12-23 | 2027-12-23 | 3114 | 0d |  |
| 3116 | 1.10 | **EARLY LIVE RUNNING** | 45d | 2027-05-10 | 2027-07-09 |  | 119d |  |
| 3117 | 1.10.1 | **Early Live Running Stabilisation Period** | 45d | 2027-05-10 | 2027-07-09 |  | 119d |  |
| 3118 |  | Manage Early Live Running stabilisation period | 45d | 2027-05-10 | 2027-07-09 | 2878 | 119d |  |
| 3119 |  | Monitor Early Live Running stabilisation period | 45d | 2027-05-10 | 2027-07-09 | 3118SS | 119d |  |
| 3120 | 1.11 | **PROGRAMME CLOSURE** | 80d | 2027-03-08 | 2027-06-25 |  | 129d |  |
| 3121 | 1.11.1 | **Handover Pack** | 80d | 2027-03-08 | 2027-06-25 |  | 129d |  |
| 3122 | 1.11.1.1 | **Draft Handover Pack (for M15)** | 40d | 2027-03-08 | 2027-04-30 |  | 169d |  |
| 3123 |  | Develop document | 20d | 2027-03-08 | 2027-04-02 | 2878FS-45d | 169d |  |
| 3124 |  | Document review and update | 20d | 2027-04-05 | 2027-04-30 | 3123 | 169d |  |
| 3125 |  | Draft Handover Pack approved | 0d | 2027-04-30 | 2027-04-30 | 3124 | 169d |  |
| 3126 | 1.11.1.2 | **Master Handover Pack (for M16)** | 40d | 2027-05-03 | 2027-06-25 |  | 129d |  |
| 3127 |  | Update document | 20d | 2027-05-03 | 2027-05-28 | 3113FS-45d | 129d |  |
| 3128 |  | Document review and update | 20d | 2027-05-31 | 2027-06-25 | 3127 | 129d |  |
| 3129 |  | Master Handover Pack approved | 0d | 2027-06-25 | 2027-06-25 | 3128 | 129d |  |
| 3130 | 1.11.2 | **Programme Lessons Learned** | 40d | 2027-03-08 | 2027-04-30 |  | 169d |  |
| 3131 |  | Develop document | 20d | 2027-03-08 | 2027-04-02 | 2878FS-45d | 169d |  |
| 3132 |  | Document review and update | 20d | 2027-04-05 | 2027-04-30 | 3131 | 169d |  |
| 3133 |  | Programme Lessons Learned document approved | 0d | 2027-04-30 | 2027-04-30 | 3132 | 169d |  |
| 3134 | 1.11.3 | **Programme Closure Report** | 40d | 2027-03-08 | 2027-04-30 |  | 169d |  |
| 3135 |  | Develop document | 20d | 2027-03-08 | 2027-04-02 | 2878FS-45d | 169d |  |
| 3136 |  | Document review and update | 20d | 2027-04-05 | 2027-04-30 | 3135 | 169d |  |
| 3137 |  | Programme Closure Report approved | 0d | 2027-04-30 | 2027-04-30 | 3136 | 169d |  |
| 3138 | 1.11.4 | **Benefit Realisation Report** | 45d | 2027-03-08 | 2027-05-07 |  | 164d |  |
| 3139 |  | Develop document | 20d | 2027-03-08 | 2027-04-02 | 2878FS-45d | 164d |  |
| 3140 |  | Document review and update | 20d | 2027-04-05 | 2027-04-30 | 3139 | 164d |  |
| 3141 |  | Benefit Realisation Report approved | 0d | 2027-05-07 | 2027-05-07 | 3140FS+5d | 164d |  |
| 3142 | 1.11.5 | **Operating Model Gap Review with recommendations** | 45d | 2027-03-08 | 2027-05-07 |  | 164d |  |
| 3143 |  | Develop document | 20d | 2027-03-08 | 2027-04-02 | 2878FS-45d | 164d |  |
| 3144 |  | Document review and update | 20d | 2027-04-05 | 2027-04-30 | 3143 | 164d |  |
| 3145 |  | Operating Model Gap Review with recommendations approved | 0d | 2027-05-07 | 2027-05-07 | 3144FS+5d | 164d |  |
| 3146 | 1.11.6 | **Post-Implementation Review** | 45d | 2027-03-08 | 2027-05-07 |  | 164d |  |
| 3147 |  | Develop document | 20d | 2027-03-08 | 2027-04-02 | 2878FS-45d | 164d |  |
| 3148 |  | Document review and update | 20d | 2027-04-05 | 2027-04-30 | 3147 | 164d |  |
| 3149 |  | Post-Implementation Review approved | 0d | 2027-05-07 | 2027-05-07 | 3148FS+5d | 164d |  |
| 3150 | 1.11.7 | **Reinforcement Guide** | 45d | 2027-03-08 | 2027-05-07 |  | 164d |  |

| ID | WBS | Task | Duration | Start | Finish | Predecessors | Complete | Total float | Constraint |
| --- | --- | --- | --- | --- | --- | --- | --- | --- | --- |
| 3151 |  | Develop document | 20d | 2027-03-08 | 2027-04-02 | 2878FS-45d |  | 164d |  |
| 3152 |  | Document review and update | 20d | 2027-04-05 | 2027-04-30 | 3151 |  | 164d |  |
| 3153 |  | Reinforcement Guide approved | 0d | 2027-05-07 | 2027-05-07 | 3152FS+5d |  | 164d |  |
| 3154 | 1.11.8 | **Material and Licenses Transfer** | 60d | 2027-04-05 | 2027-06-25 |  |  | 129d |  |
| 3155 |  | Transfer of Programme material to Elexon and perpetual licenses as appropriate | 60d | 2027-04-05 | 2027-06-25 | 3113FF-5d |  | 129d |  |
| 3156 | 1.12 | **READINESS ASSESSMENTS** | 988d | 2023-09-05 A | 2027-06-17 |  | 23% | 135d |  |
| 3157 | 1.12.1 | **Readiness Assessment 3 - Design and Build Progress Check and CP2 Check** | 60d | 2023-09-05 A | 2023-11-27 A |  | 100% |  |  |
| 3158 |  | Launch Readiness Assessment survey | 0d | 2023-09-05 A | 2023-09-05 A | 1511FS-40d | 100% |  |  |
| 3159 |  | PPs submit survey responses | 15d | 2023-09-05 A | 2023-09-25 A | 3158 | 100% |  |  |
| 3160 |  | Analyse survey responses | 15d | 2023-09-26 A | 2023-10-16 A | 3159 | 100% |  |  |
| 3161 |  | Conduct deep-dive interviews (sample of PPs) | 15d | 2023-09-26 A | 2023-10-16 A | 3159 | 100% |  |  |
| 3162 |  | Produce Readiness Assessment Reports (Overall Report & Individual Participant Reports) | 25d | 2023-10-17 A | 2023-11-20 A | 3160, 3161 | 100% |  |  |
| 3163 |  | Readiness Assessment 3 - Design & Build Checkpoint 1 - Completed (incl. Readiness Assessment Report approval) | 0d | 2023-11-27 A | 2023-11-27 A | 3162FS+5d | 100% |  |  |
| 3164 | 1.12.2 | **Readiness Assessment 5 / 6 - Start of Qualification and Participant Readiness for M10 and M11 and CP3/CP4 check** | 47d | 2025-04-28 | 2025-07-01 |  |  | 647d |  |
| 3165 |  | Launch Readiness Assessment survey | 0d | 2025-04-28 | 2025-04-28 |  |  | 647d | start no earlier than 2025-04-28 |
| 3166 |  | PPs submit survey responses | 15d | 2025-04-28 | 2025-05-16 | 3165 |  | 647d |  |
| 3167 |  | Analyse survey responses | 15d | 2025-05-19 | 2025-06-06 | 3166 |  | 647d |  |
| 3168 |  | Conduct deep-dive interviews (sample of PPs) | 15d | 2025-05-19 | 2025-06-06 | 3166 |  | 647d |  |
| 3169 |  | Produce Readiness Assessment Reports (Overall Report & Individual Participant Reports) | 15d | 2025-06-09 | 2025-06-27 | 3167, 3168 |  | 647d |  |
| 3170 |  | Readiness Assessment 5 / 6 - Start of Qualification and Participant Readiness for M10 and M11 and CP3/CP4 check (incl. Readiness Assessment Report approval) Completed | 0d | 2025-07-01 | 2025-07-01 | 3169FS+2d |  | 647d |  |
| 3171 | 1.12.3 | **Readiness Assessment 7 - Migration Checkpoint** | 49d | 2026-01-12 | 2026-03-19 |  |  | 460d |  |
| 3172 |  | Launch Readiness Assessment survey | 0d | 2026-01-12 | 2026-01-12 |  |  | 460d | start no earlier than 2026-01-12 |
| 3173 |  | PPs submit survey responses | 15d | 2026-01-12 | 2026-01-30 | 3172 |  | 460d |  |
| 3174 |  | Analyse survey responses | 15d | 2026-02-02 | 2026-02-20 | 3173 |  | 460d |  |
| 3175 |  | Conduct deep-dive interviews (sample of PPs) | 15d | 2026-02-02 | 2026-02-20 | 3173 |  | 460d |  |
| 3176 |  | Produce Readiness Assessment Reports (Overall Report & Individual Participant Reports) | 15d | 2026-02-23 | 2026-03-13 | 3174, 3175 |  | 460d |  |
| 3177 |  | Readiness Assessment 7 - Migration Checkpoint - Completed (incl. Readiness Assessment Report approval) | 0d | 2026-03-19 | 2026-03-19 | 3176FS+4d |  | 460d |  |
| 3178 | 1.12.4 | **Readiness Assessment 8 - Ready to Accept New MPANs** | 49d | 2026-08-06 | 2026-10-13 |  |  | 312d |  |
| 3179 |  | Launch Readiness Assessment survey | 0d | 2026-08-06 | 2026-08-06 | 2356FS-60d |  | 312d |  |
| 3180 |  | PPs submit survey responses | 15d | 2026-08-06 | 2026-08-26 | 3179 |  | 312d |  |
| 3181 |  | Analyse survey responses | 15d | 2026-08-27 | 2026-09-16 | 3180 |  | 312d |  |
| 3182 |  | Conduct deep-dive interviews (sample of PPs) | 15d | 2026-08-27 | 2026-09-16 | 3180 |  | 312d |  |
| 3183 |  | Produce Readiness Assessment Reports (Overall Report & Individual Participant Reports) | 15d | 2026-09-17 | 2026-10-07 | 3181, 3182 |  | 312d |  |
| 3184 |  | Readiness Assessment 8 - Ready to Accept New MPANs - Completed (incl. Readiness Assessment Report approval) | 0d | 2026-10-13 | 2026-10-13 | 3183FS+4d |  | 312d |  |
| 3185 | 1.12.5 | **Readiness Assessment 9 - Ready for New Settlement Timetable and CP5 Check** | 49d | 2027-04-12 | 2027-06-17 |  |  | 135d |  |
| 3186 |  | Launch Readiness Assessment survey | 0d | 2027-04-12 | 2027-04-12 | 3113FS-60d |  | 135d |  |
| 3187 |  | PPs submit survey responses | 15d | 2027-04-12 | 2027-04-30 | 3186 |  | 135d |  |
| 3188 |  | Analyse survey responses | 15d | 2027-05-03 | 2027-05-21 | 3187 |  | 135d |  |
| 3189 |  | Conduct deep-dive interviews (sample of PPs) | 15d | 2027-05-03 | 2027-05-21 | 3187 |  | 135d |  |
| 3190 |  | Produce Readiness Assessment Reports (Overall Report & Individual Participant Reports) | 15d | 2027-05-24 | 2027-06-11 | 3188, 3189 |  | 135d |  |
| 3191 |  | Readiness Assessment 9 - Readiness for New Settlement Timetable - Completed (incl. Readiness Assessment Report approval) | 0d | 2027-06-17 | 2027-06-17 | 3190FS+4d |  | 135d |  |
| 3192 | 1.12.6 | **Readiness Assessments - Tier 1 Milestones** | 512d | 2025-07-01 | 2027-06-17 |  |  | 135d |  |
| 3193 |  | Readiness Assessment 6 - Start of Migration - Completed (incl. Readiness Assessment Report approval) | 0d | 2025-07-01 | 2025-07-01 | 3170 |  | 647d | finish no earlier than 2025-04-04 |
| 3194 |  | Readiness Assessment 7 - Migration Checkpoint - Completed (incl. Readiness Assessment Report approval) | 0d | 2026-03-19 | 2026-03-19 | 3177 |  | 460d |  |
| 3195 |  | Readiness Assessment 8 - Ready to Accept New MPANs - Completed (incl. Readiness Assessment Report approval) | 0d | 2026-10-13 | 2026-10-13 | 3184 |  | 312d |  |
| 3196 |  | Readiness Assessment 9 - Readiness for New Settlement Timetable - Completed (incl. Readiness Assessment Report approval) | 0d | 2027-06-17 | 2027-06-17 | 3191 |  | 135d |  |
| 3197 | 1.13 | **CONTROL POINTS** | 1204d | 2022-11-10 A | 2027-06-23 |  | 51% | 132d |  |
| 3198 | 1.13.1 | **Control Point 1 - Start of System Design, Build & Test** | 20d | 2022-11-10 A | 2022-12-07 A |  | 100% |  |  |
| 3199 |  | Control Point 1 Preparation (incl. Control Point Report development and review) | 15d | 2022-11-10 A | 2022-11-30 A | 3200SS-20d | 100% |  |  |
| 3200 |  | Control Point 1 - Start of System Design, Build & Test (incl. Control Point Report approval) | 0d | 2022-12-07 A | 2022-12-07 A |  | 100% |  | must finish on 2022-12-07 |
| 3201 | 1.13.2 | **Control Point 2 - Start of Integration & Test** | 20d | 2023-10-02 A | 2023-10-30 A |  | 100% |  |  |
| 3202 |  | Control Point 2 Preparation (incl. Control Point Report development and review) | 15d | 2023-10-02 A | 2023-10-20 A | 3203SS-20d | 100% |  |  |
| 3203 |  | Control Point 2 - Start of Integration & Test (incl. Control Point Report approval) | 0d | 2023-10-30 A | 2023-10-30 A | 1511 | 100% |  |  |
| 3204 | 1.13.3 | **Control Point 3/4 - Readiness for Migration** | 20d | 2025-08-21 | 2025-09-18 |  |  | 591d |  |
| 3205 |  | Control Point 3/4 Preparation (incl. Control Point Report development and review) | 14d | 2025-08-21 | 2025-09-09 | 3206SS-20d |  | 597d |  |
| 3206 |  | Control Point 3/4 - Readiness for Migration (incl. Control Point Report approval) | 0d | 2025-09-18 | 2025-09-18 | 1835FS-5d |  | 591d |  |
| 3207 | 1.13.4 | **Control Point 5 - Cut Over to New Settlement Timetable** | 20d | 2027-05-26 | 2027-06-23 |  |  | 132d |  |
| 3208 |  | Control Point 5 Preparation (incl. Control Point Report development and review) | 15d | 2027-05-26 | 2027-06-15 | 3209SS-20d |  | 137d |  |
| 3209 |  | Control Point 5 - Cut Over to New Settlement Timetable (incl. Control Point Report approval) | 0d | 2027-06-23 | 2027-06-23 | 3113FS-8d |  | 132d |  |
| 3210 | 1.13.5 | **Control Points - Tier 1 Milestones** | 1184d | 2022-12-07 A | 2027-06-23 |  |  | 132d |  |
| 3211 |  | Control Point 1 - Start of System Design, Build & Test (incl. Control Point Report approval) | 0d | 2022-12-07 A | 2022-12-07 A | 3200SS | 100% |  |  |
| 3212 |  | Control Point 2 - Start of Integration & Test (incl. Control Point Report approval) | 0d | 2023-10-30 A | 2023-10-30 A | 3203SS | 100% |  |  |
| 3213 |  | Control Point 3/4 - Readiness for Migration (incl. Control Point Report approval) | 0d | 2025-09-18 | 2025-09-18 | 3206SS |  | 591d |  |
| 3214 |  | Control Point 5 - Cut Over to New Settlement Timetable (incl. Control Point Report approval) | 0d | 2027-06-23 | 2027-06-23 | 3209SS |  | 132d |  |
| 3215 | 1.14 | **MILESTONE RANGE CHECKPOINTS** | 1160d? | 2022-10-31 | 2027-04-12 |  |  | 184d |  |
| 3216 | 1.14.1 | **M10, M11, M12 and M13 milestone checkpoint** | 0d | 2025-07-31 | 2025-07-31 |  |  | 626d |  |
| 3217 |  | M10, M11, M12, and M13 milestone checkpoint - date approval | 0d | 2025-07-31 | 2025-07-31 | 2874FS-3mo, 2876FS-3mo, 2872FS-3mo, 1835FS-3mo |  | 626d |  |
| 3218 | 1.14.2 | **M14 milestone checkpoint** | 0d | 2026-08-06 | 2026-08-06 |  |  | 361d |  |
| 3219 |  | M14 milestone checkpoint - date approval | 0d | 2026-08-06 | 2026-08-06 | 2356FS-3mo |  | 361d |  |
| 3220 | 1.14.3 | **M15 milestone checkpoint** | 0d | 2027-02-15 | 2027-02-15 |  |  | 224d |  |

| ID | WBS | Task | Duration | Start | Finish | Predecessors | Total float |
| --- | --- | --- | --- | --- | --- | --- | --- |
| 3221 |  | M15 milestone checkpoint - date approval | 0d | 2027-02-15 | 2027-02-15 | 2878FS-3mo | 224d |
| 3222 | 1.14.4 | **M16 milestone checkpoint** | 1160d? | 2022-10-31 | 2027-04-12 |  | 184d |
| 3223 |  | M16 milestone checkpoint - date approval | 0d | 2027-04-12 | 2027-04-12 | 3113FS-3mo | 184d |

## Version 2 (data date 2025-02-26, saved 2025-03-06, file MHHS-DEL1139 - MHHS Plan v6.19.mpp)

Last finish stays 2027-12-23. Complete tasks 1545 → 1593.

Added:

| ID | Task | Duration | Start | Finish | Predecessors | Constraint |
| --- | --- | --- | --- | --- | --- | --- |
| 1440 | Build Regression Core Pack | 17d | 2025-02-12 | 2025-03-06 | 1433, 1443FF | start no earlier than 2025-02-12 |
| 1449 | Second industry review of Regression Core Pack | 5d | 2025-03-31 | 2025-04-04 | 1448 |  |
| 1451 | eSITWG paper day | 0d | 2025-04-08 | 2025-04-08 | 1450 |  |
| 1452 | eSITWG endorses regression Core Pack | 0d | 2025-04-15 | 2025-04-15 | 1451FS+5d |  |
| 1453 | Incorporate SITWG feedback into regression Core Pack | 2d | 2025-04-16 | 2025-04-17 | 1452 |  |
| 2652 | Suppliers complete Work Off plans | 105d | 2024-12-23 A | 2025-05-16 | 2651 | start no earlier than 2024-12-23 |
| 2658 | Suppliers complete Work Off plans | 123d | 2025-01-29 A | 2025-07-18 | 2657 | finish no earlier than 2025-07-18 |
| 2759 | **Migration Sprints** | 522d | 2025-05-06 | 2027-05-05 |  |  |
| 2786 | Non-SIT Participants Migration Start | 1d | 2026-05-15 | 2026-05-15 | 2942 |  |
| 2880 | **Phase 1 - Preparation** | 841d? | 2022-10-31 | 2026-01-19 |  |  |

Removed: 1448 SITWG paper day; 1449 SITWG endorses regression suite doc; 1486 Publish (QIP); 1487 Review & UAT; 1488 QIP Training Material & User Guides; 1599 Programme agreement into Settlement Testing; 1600 Helix E2E Settlement Testing Execution; 1601 Helix E2E Settlement Testing Execution Complete; 1602 MHHSP Helix E2E Testing Assurance; 1603 MHHSP Helix E2E Testing Assurance Complete; 2562 Confirm Supplier Migration start dates, MPID groups (SIT & NonSIT); 2763 UMS / Advanced Migration; 2764 SIT MVC UMS / Advanced Migration; 2765 SIT Non-MVC UMS / Advanced Migration; 2766 Wave 1 UMS / Advanced Migration; 2767 Wave 2 UMS / Advanced Migration; 2768 Wave 3 UMS / Advanced Migration; 2769 Wave 4 UMS / Advanced Migration; 2770 Smart / Non-Smart Migration; 2771 SIT MVC Smart / Non-Smart Migration; 2772 SIT Non-MVC Smart / Non-Smart Migration; 2773 Wave 1 Smart / Non-Smart Migration; 2774 Wave 2 Smart / Non-Smart Migration; 2775 Wave 3 Smart / Non-Smart Migration; 2776 Wave 4 Smart / Non-Smart Migration

Changed:

| ID | Task | Start | Finish | Duration | Complete | Total float | Predecessors | Other |
| --- | --- | --- | --- | --- | --- | --- | --- | --- |
| 1 | **PROGRAMME PLAN.** |  |  |  | 56% → 60% |  |  |  |
| 96 | **Design Artefact Releases** |  |  |  | 94% → 96% |  |  |  |
| 136 | **Interim release 8** |  |  |  | 74% → 85% |  |  |  |
| 158 | **Interim Release 8.8** | 2025-02-05 A |  |  | 0% → 40% |  |  |  |
| 159 | Update baselined artefacts | 2025-02-05 A | 2025-02-10 A |  | 0% → 100% | 726d → none |  |  |
| 160 | Interim Release 8.8 Published | 2025-02-12 A | 2025-02-12 A |  | 0% → 100% | 726d → none |  |  |
| 161 | Interim Release 8.8 Deployed to SIT by Participants | 2025-02-13 A |  |  | 0% → 25% |  |  |  |
| 439 | SIT Operational Theme 3 (Batch 1) PIT Completion Report MHHS Review Completed | 2025-01-10 A | 2025-01-10 A |  | 0% → 100% | 769d → none |  |  |
| 537 | **SYSTEMS INTEGRATION TESTING (SIT)** |  |  |  | 73% → 75% |  |  |  |
| 619 | **SIT Stage-Specific Preparation** |  |  |  | 96% → 97% |  |  |  |
| 1092 | **SIT Non-Functional Preparation** |  |  |  | 93% → 97% |  |  |  |
| 1129 | **NFT (Theme 1, 2 and 3) DITL** |  | 2025-02-26 A |  | 99% → 100% | 736d → none |  |  |
| 1133 | Programme DITL walkthrough with PPs on Theme 1, 2 and 3 | 2025-02-26 A | 2025-02-26 A |  | 0% → 100% | 736d → none |  |  |
| 1146 | Environment Uplift Window (Technical Check) |  |  |  |  | 20d → 25d |  | was named Environment Uplift Window |
| 1148 | **Theme 1** |  | 2025-02-18 A |  | 99% → 100% | 742d → none |  |  |
| 1154 | NFTWG update on execution model | 2025-02-18 A | 2025-02-18 A |  | 0% → 100% | 742d → none |  |  |
| 1162 | **SIT Non-Functional Progress reporting** |  | 2025-02-14 → 2025-02-21 A (+7d) | 17d → 22d | 6% → 100% | 125d → none |  |  |
| 1163 | Determine reporting methodology |  | 2025-01-24 A |  | 50% → 100% | 125d → none |  |  |
| 1164 | Implement reporting | 2025-01-27 A | 2025-02-14 → 2025-02-21 A (+7d) | 15d → 20d | 0% → 100% | 125d → none |  |  |
| 1165 | **SIT Non-Functional Test Readiness Report** |  |  |  | 49% → 63% |  |  |  |
| 1166 | **SIT Non-Functional Theme 1 Overarching Test Readiness Report** |  |  |  | 73% → 99% |  |  |  |
| 1170 | NFTWG review the Non-Functional Theme 1 Overarching Test Readiness Report | 2025-02-18 A | 2025-02-18 A |  | 0% → 100% | 736d → none |  |  |
| 1171 | Update Non-Functional Theme 1 Overarching Test Readiness Report following SRO / NFTWG feedback | 2025-02-19 A | 2025-02-26 A |  | 0% → 100% | 736d → none |  |  |
| 1172 | FTIG Recommendation | 2025-02-21 A | 2025-02-21 A |  | 0% → 100% | 739d → none |  |  |
| 1186 | **SIT Operational Preparation** |  |  |  | 91% → 93% |  |  |  |
| 1309 | **Theme 3 Test Cases Approved** |  |  |  | 93% → 98% |  |  |  |
| 1336 | **Theme 3 (Batch 2) Supplementary** |  |  |  | 24% → 74% |  |  |  |
| 1338 | Develop DIP Onboarding / Offboarding Test Scenarios & Test Cases (Batch 2) Supplementary |  | 2025-02-11 A |  | 25% → 100% | 721d → none |  |  |
| 1339 | SRO Review | 2025-02-12 A | 2025-02-18 A |  | 0% → 100% | 721d → none |  |  |
| 1340 | Industry Consultation (Batch 2) Supplementary | 2025-02-19 A |  |  | 0% → 50% |  |  |  |
| 1355 | **SIT Operational Programme RTTM (Theme 1, 2 & 3 (Batch 2))** |  | 2025-03-07 → 2025-03-21 (+14d) | 45d → 55d | 50% → 56% | 729d → 719d |  |  |
| 1356 | Develop SIT Operational (Theme 1, 2 & 3 (Batch 2)) RTTM |  | 2025-02-07 → 2025-02-21 (+14d) | 25d → 35d | 90% → 89% | 729d → 719d |  |  |
| 1357 | SRO review of SIT Operational (Theme 1, 2 & 3 (Batch 2)) RTTM | 2025-02-10 → 2025-02-24 (+14d) | 2025-02-14 → 2025-02-28 (+14d) |  |  | 729d → 719d |  |  |
| 1358 | DIP Manager / Code Bodies / Full SRO to review | 2025-02-17 → 2025-03-03 (+14d) | 2025-02-21 → 2025-03-07 (+14d) |  |  | 729d → 719d |  |  |
| 1359 | Incorporate feedback | 2025-02-24 → 2025-03-10 (+14d) | 2025-02-28 → 2025-03-14 (+14d) |  |  | 729d → 719d |  |  |
| 1360 | Reissued to DIP Manager / Code Bodies / SRO for review | 2025-03-03 → 2025-03-17 (+14d) | 2025-03-07 → 2025-03-21 (+14d) |  |  | 729d → 719d |  |  |
| 1361 | DIP Manager / Code Bodies / SRO acceptance of (Theme 1, 2 & 3 (Batch 2)) Operational RTTM | 2025-03-07 → 2025-03-21 (+14d) | 2025-03-07 → 2025-03-21 (+14d) |  |  | 729d → 719d |  |  |
| 1362 | SIT Operational (Theme 1, 2 & 3 (Batch 2)) RTTM Complete | 2025-03-07 → 2025-03-21 (+14d) | 2025-03-07 → 2025-03-21 (+14d) |  |  | 729d → 719d |  |  |
| 1369 | **SIT Operational Theme 1, 2 & 3 (Batch 2) DITL** | 2025-02-24 A |  |  | 0% → 3% |  |  | baseline start none → 2025-02-24; baseline finish none → 2025-03-26 |
| 1370 | DITL + Familiarisation session development | 2025-02-24 A |  |  | 0% → 5% |  |  | baseline start none → 2025-02-24; baseline finish none → 2025-03-14 |
| 1371 | SRO Review |  |  |  |  |  |  | baseline start none → 2025-03-17; baseline finish none → 2025-03-21 |
| 1372 | Post-SRO Review Changes |  |  |  |  |  |  | baseline start none → 2025-03-24; baseline finish none → 2025-03-26 |
| 1373 | Familiarisation session Service Management test case schedule + mapping |  |  |  |  |  |  | baseline start none → 2025-03-26; baseline finish none → 2025-03-26 |
| 1374 | Publish Cycle 3 DITL / Cycle 3 DITL Online Sessions for SIT PPs |  |  |  |  |  |  | baseline start none → 2025-03-26; baseline finish none → 2025-03-26 |
| 1378 | **SIT Operational Execution Model** |  |  |  | 77% → 88% |  |  |  |
| 1386 | **Theme 1, 2 and 3 (Batch 2)** |  |  |  | 31% → 63% |  |  |  |
| 1387 | Develop execution model Theme 1, 2 and 3 (Batch 2) |  | 2025-02-14 A |  | 75% → 100% | 730d → none |  |  |
| 1388 | SRO provide feedback | 2025-02-17 A | 2025-02-21 A |  | 0% → 100% | 730d → none |  |  |
| 1396 | **SIT Operational Overarching Test Readiness Reports** |  |  |  | 57% → 76% |  |  |  |
| 1407 | **SI SIT Operational Theme 1, 2 and 3 (Batch 2) Overarching Test Readiness Report** |  |  |  | 26% → 59% |  |  |  |
| 1408 | Develop Overarching SIT Operational Theme 1, 2 and 3 (Batch 2) Overarching Test Readiness Report |  | 2025-02-21 A |  | 50% → 100% | 734d → none |  |  |
| 1409 | SRO review | 2025-02-24 A |  |  | 0% → 50% |  |  |  |
| 1418 | **Test Data - Non-Functional and Operational (SIT B)** | 2025-02-24 A |  |  | 0% → 1% | 1d → 714d |  |  |
| 1419 | **Data Load** | 2025-02-24 A |  |  | 0% → 1% | 1d → 714d |  |  |
| 1420 | Non-Functional Theme 1 (Avenade) Data Load | 2025-02-24 A |  |  | 0% → 5% | 1d → 6d |  |  |
| 1426 | **Regression Test Preparation** |  |  |  | 47% → 42% |  |  |  |
| 1427 | **Regression Test Approach** |  |  |  | 97% → 99% |  |  |  |
| 1432 | Updates to approach doc on back of industry feedback |  | 2025-02-11 A |  | 80% → 100% | 11d → none |  |  |
| 1433 | eSITWG paper day | 2025-02-11 A | 2025-02-11 A |  | 0% → 100% | 11d → none |  |  |
| 1434 | eSITWG Recommendation | 2025-02-18 A | 2025-02-18 A |  | 0% → 100% | 735d → none |  |  |
| 1435 | Incorporate eSITWG feedback into approach doc | 2025-02-19 A | 2025-02-20 A |  | 0% → 100% | 735d → none |  |  |
| 1436 | eSITAG paper day | 2025-02-20 A | 2025-02-20 A |  | 0% → 100% | 735d → none |  |  |
| 1439 | **Regression Core Test Pack** |  | 2025-04-16 → 2025-04-24 (+8d) | 46d → 52d |  | 11d → 7d |  | was named Regression Test Suite |
| 1441 | Build Regression Framework |  | 2025-02-28 → 2025-02-27 (-1d) | 13d → 12d |  | 11d → 7d |  | was named Build Regression Test Suite |
| 1442 | SITWG paper day |  |  | 1d → 0d |  | 12d → 7d | 1441SS → 1441 |  |
| 1443 | SITWG provides feedback on Regression Framework approach |  |  |  |  | 12d → 7d |  | was named SITWG provides feedback on regression suite approach |
| 1444 | LDP walkthrough of Regression Core Pack | 2025-02-28 → 2025-02-27 (-1d) |  | 1d → 2d |  |  | 1441FF → 1440SS | was named LDP walkthrough of Regression Test Suite; constraint none → start no earlier than 2025-02-27 |
| 1445 | SRO Review of Regression Core Pack |  |  |  |  | 11d → 9d | 1441 → 1440SS | was named SRO Review of regression suite doc; constraint none → start no earlier than 2025-03-03 |
| 1446 | Incorporate SRO feedback into Regression Core Pack | 2025-03-03 → 2025-03-05 (+2d) | 2025-03-07 → 2025-03-06 (-1d) | 5d → 2d |  | 11d → 7d |  | was named Incorporate SRO feedback into regression suite doc |
| 1447 | Industry review of Regression Core Pack |  |  |  |  | 11d → 7d | 1446 → 1446FS+1d, 1440FS+1d | was named Industry review of Regression Test Suite |

| ID | Task | Start | Finish | Duration | Complete | Total float | Predecessors | Other |
| --- | --- | --- | --- | --- | --- | --- | --- | --- |
| 1448 | Incorporate Industry feedback into Regression Core Pack |  | 2025-03-27 → 2025-03-28 (+1d) | 4d → 5d |  | 11d → 7d |  | was named Incorporate Industry feedback into regression suite doc |
| 1450 | Incorporate industry feedback into regression Core Pack | 2025-04-04 → 2025-04-07 (+3d) | 2025-04-04 → 2025-04-08 (+4d) | 1d → 2d |  | 11d → 7d | SITWG endorses regression suite doc → 1449 | was named Incorporate SITWG feedback into regression suite doc |
| 1454 | eSITAG paper day | 2025-04-09 → 2025-04-17 (+8d) | 2025-04-09 → 2025-04-17 (+8d) |  |  | 8d → 7d | 1450 → 1453 |  |
| 1455 | eSITAG (inc SRO) Approval of regression Core Pack | 2025-04-16 → 2025-04-24 (+8d) | 2025-04-16 → 2025-04-24 (+8d) |  |  | 8d → 7d |  | was named eSITAG (inc SRO) Approval of regression suite doc |
| 1456 | SIT Regression Approval | 2025-04-16 → 2025-04-24 (+8d) | 2025-04-16 → 2025-04-24 (+8d) |  |  | 8d → 7d |  |  |
| 1461 | **Single Instance ADO** |  | 2024-10-03 A |  | 98% → 100% | 840d → none |  |  |
| 1481 | **Reporting Changes - PowerBI & QIP** |  | 2024-09-24 A |  | 70% → 100% | 847d → none |  |  |
| 1510 | **SIT Execution** |  |  |  | 43% → 48% |  |  |  |
| 1527 | **SIT - Minimum Viable Cohort (MVC)** |  |  |  | 45% → 51% |  |  |  |
| 1528 | **SIT Functional Testing (MVC)** |  |  |  | 55% → 62% |  |  |  |
| 1530 | **SIT Functional Testing Execution (Minimum Viable Cohort)** |  |  |  | 81% → 85% |  |  |  |
| 1540 | **Cycle 3 (Defect retests and targeted regression testing)** |  |  |  | 60% → 68% |  |  |  |
| 1548 | Sprint 11 |  | 2025-02-14 A |  | 70% → 100% | 0d → none |  |  |
| 1549 | Sprint 12 | 2025-02-17 A |  |  | 0% → 75% | 0d → 5d |  |  |
| 1555 | **SIT Scope Traceability** |  |  |  | 33% → 75% |  |  |  |
| 1558 | SRO review | 2025-02-12 A | 2025-02-18 A |  | 0% → 100% | 721d → none |  |  |
| 1559 | Updates to reflect SRO feedback | 2025-02-12 A | 2025-02-18 A |  | 0% → 100% | 721d → none |  |  |
| 1560 | Industry Review | 2025-02-19 A |  |  | 0% → 50% |  |  |  |
| 1561 | SITWG paper day | 2025-02-27 A | 2025-02-27 A |  | 0% → 100% | 721d → none |  |  |
| 1567 | **SIT Functional Settlement Testing** |  |  |  | 31% → 35% |  |  |  |
| 1569 | **SIT-B Settlement Testing Cycle 3** |  | 2025-02-21 A |  | 88% → 100% | 1d → none |  |  |
| 1582 | Sprint 11 |  | 2025-02-14 A |  | 33% → 100% | 1d → none |  |  |
| 1583 | Sprint 11 Review | 2025-02-14 A | 2025-02-14 A |  | 0% → 100% | 1d → none |  |  |
| 1584 | Sprint 12 | 2025-02-17 A | 2025-02-21 A |  | 0% → 100% | 1d → none |  |  |
| 1585 | End of Settlement Testing Cycle 3 | 2025-02-21 A | 2025-02-21 A |  | 0% → 100% | 1d → none |  |  |
| 1586 | SIT-A Settlement Testing |  |  |  |  | 0d → 5d |  | was named SIT-A CoS Settlement Testing |
| 1598 | **Helix E2E Settlement Assurance Testing (SAT)** |  |  |  | 45% → 55% |  |  |  |
| 1626 | **SIT Migration Testing (MVC)** |  |  |  | 64% → 67% |  |  |  |
| 1628 | **SIT Migration Testing Execution (Minimum Viable Cohort)** |  |  |  | 64% → 67% |  |  |  |
| 1638 | **Cycle 3 (Defect retests and targeted regression testing)** |  |  |  | 61% → 69% |  |  |  |
| 1646 | Sprint 11 |  | 2025-02-14 A |  | 70% → 100% | 0d → none |  |  |
| 1647 | Sprint 12 | 2025-02-17 A |  |  | 0% → 75% | 0d → 5d |  |  |
| 1664 | **SIT Non-Functional Testing (all SIT PPs)** |  | 2025-06-05 → 2025-06-06 (+1d) | 69d? → 70d? |  | 1d → 6d |  |  |
| 1667 | Theme 2 SIT Non-Functional Testing Start | 2025-03-28 → 2025-03-31 (+3d) | 2025-03-28 → 2025-03-31 (+3d) |  |  | 95d → 99d | 1535, 1098, 1102, 1109, 1115, 1121, 1585, 1183FS+1d, 1422, 1164 → 1535, 1098, 1102, 1109, 1115, 1121, 1585, 1183FS+2d, 1422, 1164 |  |
| 1668 | Theme 2 SIT Non-Functional Testing Execution | 2025-03-28 → 2025-03-31 (+3d) | 2025-05-22 → 2025-05-23 (+1d) |  |  | 56d → 60d |  | baseline start 2025-05-01 → 2025-03-31; baseline finish 2025-06-25 → 2025-05-23 |
| 1669 | Theme 3 SIT Non-Functional Testing Start | 2025-03-28 → 2025-03-31 (+3d) | 2025-03-28 → 2025-03-31 (+3d) |  |  | 56d → 60d | 1183, 1422 → 1183FS+1d, 1422 |  |
| 1670 | Theme 3 SIT Non-Functional Testing Execution | 2025-03-28 → 2025-03-31 (+3d) | 2025-05-22 → 2025-05-23 (+1d) |  |  | 56d → 60d |  | baseline start 2025-05-02 → 2025-03-31; baseline finish 2025-06-26 → 2025-05-23 |
| 1672 | Assurance of PPs Test Completion Reports | 2025-05-02 → 2025-05-05 (+3d) | 2025-05-29 → 2025-05-30 (+1d) |  |  | 56d → 60d |  |  |
| 1673 | **SIT Non-Functional Testing Test Completion Report (all SIT PPs)** | 2025-05-02 → 2025-05-05 (+3d) | 2025-05-29 → 2025-05-30 (+1d) |  |  | 56d → 60d |  |  |
| 1674 | Develop document | 2025-05-02 → 2025-05-05 (+3d) |  |  |  | 56d → 60d |  |  |
| 1675 | Review & agree document | 2025-05-23 → 2025-05-26 (+3d) | 2025-05-29 → 2025-05-30 (+1d) |  |  | 56d → 60d |  |  |
| 1676 | SIT Non-Functional Testing Test Completion Report (all SIT PPs) Approved | 2025-06-05 → 2025-06-06 (+1d) | 2025-06-05 → 2025-06-06 (+1d) |  |  | 56d → 60d |  |  |
| 1806 | **M10 Readiness** |  |  |  |  |  |  | baseline start none → 2025-01-06; baseline finish none → 2025-03-14 |
| 1807 | Define guiding principles and approach |  |  |  |  |  |  | baseline start none → 2025-01-06; baseline finish none → 2025-01-24 |
| 1808 | Engage IPA |  |  |  |  |  |  | baseline start none → 2025-01-13; baseline finish none → 2025-01-24 |
| 1809 | Mobilise Get to Go-Live Group |  |  |  |  |  |  | baseline start none → 2025-01-27; baseline finish none → 2025-02-07 |
| 1810 | Progress against the M10 Readiness Criteria |  |  |  |  |  |  | baseline start none → 2025-02-10; baseline finish none → 2025-03-14 |
| 1811 | **Downstream milestone feasibility assessment** |  |  |  |  |  |  | baseline start none → 2025-01-06; baseline finish none → 2025-03-14 |
| 1812 | Define guiding principles and approach to addressing points 1 - 3 |  |  |  |  |  |  | baseline start none → 2025-01-06; baseline finish none → 2025-01-31 |
| 1813 | Assess capacity within migration envelopes (Point 1 - Bringing M15 forwards) |  |  |  |  |  |  | baseline start none → 2025-01-20; baseline finish none → 2025-02-14 |
| 1814 | Review M16 process (Point 3 - Bringing M16 forwards) |  |  |  |  |  |  | baseline start none → 2025-01-20; baseline finish none → 2025-02-21 |
| 1815 | Develop M16 process review findings |  |  |  |  |  |  | baseline start none → 2025-02-24; baseline finish none → 2025-03-07 |
| 1816 | Agree M16 process review findings with Code Bodies |  |  |  |  |  |  | baseline start none → 2025-03-10; baseline finish none → 2025-03-14 |
| 1817 | Agree M16 process review findings with PAB |  |  |  |  |  |  | baseline start none → 2025-03-10; baseline finish none → 2025-03-14 |
| 1818 | Run PPIR with impacted parties (Point 2 - Bringing M14 forwards) |  |  |  |  |  |  | baseline start none → 2025-03-03; baseline finish none → 2025-03-14 |
| 1819 | **Checkpoint governance** |  |  |  |  |  |  | baseline start none → 2022-10-31; baseline finish none → 2025-04-02 |
| 1820 | PSG Updated on progress |  |  |  |  |  |  | baseline start none → 2025-03-05; baseline finish none → 2025-03-05 |
| 1821 | Review final M10 Readiness outputs with IPA |  |  |  |  |  |  | baseline start none → 2025-03-17; baseline finish none → 2025-03-21 |
| 1822 | Review final M10 Readiness outputs with Ofgem |  |  |  |  |  |  | baseline start none → 2025-03-17; baseline finish none → 2025-03-26 |
| 1823 | QAG paper day |  |  |  |  |  |  | baseline start none → 2022-10-31; baseline finish none → 2022-10-31 |
| 1824 | QAG recommend M10 Checkpoint |  |  |  |  |  |  | baseline start none → 2022-10-31; baseline finish none → 2022-10-31 |
| 1825 | MCAG paper day |  |  |  |  |  |  | baseline start none → 2022-10-31; baseline finish none → 2022-10-31 |
| 1826 | MCAG recommend M10 Checkpoint |  |  |  |  |  |  | baseline start none → 2022-10-31; baseline finish none → 2022-10-31 |
| 1827 | PSG paper day |  |  |  |  |  |  | baseline start none → 2025-03-26; baseline finish none → 2025-03-26 |
| 1828 | PSG M10 Checkpoint Meeting |  |  |  |  |  |  | baseline start none → 2025-04-02; baseline finish none → 2025-04-02 |
| 1842 | **NON SIT LDSO QUALIFICATION** |  |  |  | 70% → 79% |  |  |  |
| 1888 | **Test Data** |  |  |  | 65% → 84% |  |  |  |
| 1895 | Test Data Loaded |  | 2024-12-06 A |  | 90% → 100% | 679d → none |  |  |
| 1896 | Test Data Signed Off | 2024-12-06 A | 2024-12-06 A |  | 0% → 100% | 679d → none |  |  |
| 1897 | Test Execution Data Support | 2024-12-09 A |  |  | 0% → 50% |  |  |  |

| ID | Task | Start | Finish | Duration | Complete | Total float | Predecessors | Other |
| --- | --- | --- | --- | --- | --- | --- | --- | --- |
| 1908 | Non-SIT LDSO Participants have submitted functional PIT Test Completion Report & evidence for QT Entry​ | 2024-11-29 A | 2024-11-29 A |  | 0% → 100% | 799d → none |  |  |
| 1929 | **Test Readiness** |  | 2024-12-20 A |  | 90% → 100% | 784d → none |  |  |
| 1932 | LDSO Update Readiness Report & Final Assurance by Programme |  | 2024-12-12 A |  | 95% → 100% | 10d → none |  |  |
| 1933 | Final Test Readiness Report Submitted to MHHS Programme | 2024-12-13 A | 2024-12-13 A |  | 0% → 100% | 789d → none |  |  |
| 1934 | Final Programme Assurance of LDSO Test Readiness | 2024-12-13 A | 2024-12-20 A |  | 0% → 100% | 10d → none |  |  |
| 1936 | Qualification Testing for Non-SIT LDSOs (Functional, Migration, NFT, Operational) Test Readiness Confirmed (Final Test Readiness Review for LDSO) |  | 2024-12-20 A |  | 90% → 100% | 10d → none |  |  |
| 1937 | **Test Window** |  |  |  | 23% → 46% |  |  |  |
| 1938 | **All Non-SIT LDSOs Qualification Testing** |  |  |  | 26% → 51% |  |  |  |
| 1940 | LDSO Alpha |  |  |  | 12% → 53% |  |  |  |
| 1941 | LDSO Bravo |  |  |  | 5% → 23% |  |  |  |
| 1942 | LDSO Charlie |  |  |  | 30% → 51% |  |  |  |
| 1943 | LDSO Delta |  |  |  | 15% → 42% |  |  |  |
| 1944 | LDSO Echo |  |  |  | 57% → 82% |  |  |  |
| 1946 | LDSO Golf |  |  |  | 47% → 90% |  |  |  |
| 1947 | LDSO Hotel |  |  |  | 37% → 60% |  |  |  |
| 1948 | LDSO India |  |  |  | 25% → 46% |  |  |  |
| 1958 | **S & A QUALIFICATION** |  |  |  | 59% → 60% |  |  |  |
| 2020 | **MHHS Qualification - SIT Participants** |  |  |  | 9% → 15% | 0d → 504d |  |  |
| 2022 | SIT Participants submit Initial QAD |  | 2025-02-14 A |  | 65% → 100% | 55d → none |  |  |
| 2023 | Code Bodies review Initial QAD | 2025-02-14 A |  |  | 0% → 10% | 55d → 60d |  |  |
| 2037 | **MHHS Qualification - Non-SIT LDSO** |  |  |  | 18% → 28% | 4d → 9d |  |  |
| 2039 | Non-SIT LDSO Participants submit initial QAD |  | 2025-02-14 A |  | 65% → 100% | 53d → none |  |  |
| 2040 | Non-SIT LDSO QT Participants have submitted their initial QAD | 2025-02-14 A | 2025-02-14 A |  | 0% → 100% | 53d → none |  |  |
| 2041 | Code Bodies review of Non-SIT LDSO participants Initial QAD | 2025-02-17 A |  |  | 0% → 10% | 53d → 83d |  |  |
| 2044 | Non-SIT LDSO Participants submit Final QAD | 2025-04-21 → 2025-04-07 (-14d) |  | 25d → 35d |  | 44d → 49d | 1952SS, 2043SS → 2043SS-1d |  |
| 2049 | **MHHS Qualification - Qualification Waves** |  |  |  | 56% → 57% |  |  |  |
| 2050 | **Qualification Wave Prep** |  |  |  | 91% → 93% |  |  |  |
| 2088 | **Qualification Testing Framework (Test Stubs and Supporting UI)** |  |  |  | 90% → 91% |  |  |  |
| 2102 | QTF Test Cases DBT Refinement, Execution and Results Validation, Defect Management, Error Handling |  | 2025-02-20 A |  | 80% → 100% | 722d → none |  |  |
| 2121 | **QTF Deployment into Production** | 2025-02-20 A |  |  | 0% → 26% |  |  |  |
| 2122 | App Deployment | 2025-02-20 A | 2025-02-26 A |  | 0% → 100% | 722d → none |  |  |
| 2154 | **MPANs, DIP Messages, Settlement, Consumption, Reference** |  |  |  | 77% → 78% |  |  |  |
| 2214 | **Governance** |  |  |  | 89% → 92% |  |  |  |
| 2219 | BETA Testing 2 |  |  |  | 40% → 60% |  |  |  |
| 2320 | **Qualification Wave 4** | 2025-01-23 A |  |  |  | 192d → 235d |  |  |
| 2353 | **PAB dates** | 2025-01-23 A |  |  | 0% → 99% |  |  |  |
| 2354 | PAB288 | 2025-01-23 A | 2025-01-23 A |  | 0% → 100% | 761d → none |  |  |
| 2355 | PAB289 | 2025-02-26 A | 2025-02-27 A |  | 0% → 100% | 735d → none |  |  |
| 2514 | **MIGRATION** |  |  |  | 36% → 57% |  |  |  |
| 2518 | **Migration Framework Agreed and Implemented** |  |  |  | 84% → 88% |  |  |  |
| 2533 | **Consultation 3 - Parameters** |  | 2025-02-25 A |  | 99% → 100% | 691d → none |  |  |
| 2538 | MWG Recommendation | 2025-02-13 A | 2025-02-13 A |  | 0% → 100% | 695d → none |  |  |
| 2539 | MCAG Paper Day | 2025-02-18 A | 2025-02-18 A |  | 0% → 100% | 695d → none |  |  |
| 2540 | MCAG Approval of Consultation 3 | 2025-02-25 A | 2025-02-25 A |  | 0% → 100% | 691d → none |  |  |
| 2541 | **Consultation 4** |  |  |  | 28% → 46% |  |  |  |
| 2543 | Book MWG |  |  | 0d → 1d |  |  |  |  |
| 2544 | Prepare Consultation 4 content | 2025-02-10 A | 2025-02-20 A |  | 0% → 100% | 692d → none |  |  |
| 2545 | MWG paper day | 2025-02-20 A | 2025-02-20 A | 0d → 1d | 0% → 100% | 735d → none |  |  |
| 2546 | MWG recommend Consultation 4 content go for industry consultation | 2025-02-27 → 2025-03-04 (+5d) | 2025-02-27 → 2025-03-04 (+5d) |  |  | 735d → 732d | 2545FS+5d → 2545FS+8d | constraint none → finish no earlier than 2025-03-04; baseline start 2025-02-27 → 2025-03-04; baseline finish 2025-02-27 → 2025-03-04 |
| 2547 | Industry Consultation | 2025-02-21 → 2025-03-03 (+10d) | 2025-03-06 → 2025-03-14 (+8d) |  |  | 692d → 694d |  | constraint none → start no earlier than 2025-03-03; baseline start 2025-03-12 → 2025-03-03; baseline finish 2025-03-25 → 2025-03-14 |
| 2548 | Comment responses by PPs | 2025-03-07 → 2025-03-17 (+10d) | 2025-03-20 → 2025-03-28 (+8d) |  |  | 692d → 694d |  | constraint none → start no earlier than 2025-03-17; baseline start 2025-03-26 → 2025-03-17; baseline finish 2025-04-08 → 2025-03-28 |
| 2549 | Respond to comments and issue artefacts | 2025-03-21 → 2025-03-31 (+10d) | 2025-04-03 → 2025-04-11 (+8d) |  |  | 692d → 694d |  | constraint none → start no earlier than 2025-03-31 |
| 2550 | Assurance meeting | 2025-04-10 → 2025-04-22 (+12d) | 2025-04-10 → 2025-04-22 (+12d) |  |  |  |  | constraint none → finish no earlier than 2025-04-22; baseline start 2025-04-09 → 2025-04-22 |
| 2551 | MCAG paper day |  |  |  |  |  | 2550FS+8d → 2550 | constraint none → start no earlier than 2025-04-22 |
| 2552 | MCAG Approval of Consultation 4 |  |  |  |  |  |  | constraint none → start no earlier than 2025-04-29; baseline start 2025-04-22 → 2025-04-29; baseline finish 2025-04-22 → 2025-04-29 |
| 2553 | Framework Baselined at MCAG |  |  |  |  |  |  | constraint none → start no earlier than 2025-04-29; baseline start 2025-04-22 → 2025-04-29; baseline finish 2025-04-22 → 2025-04-29 |
| 2554 | **Migration Schedule Agreed and Maintained** | 2022-10-31 A → 2024-07-01 A (+609d) | 2024-12-20 A | 560d? → 125d? | 99% → 100% | 784d → none |  |  |
| 2599 | **Migration Artefact Development and Publication** |  |  |  | 91% → 76% |  |  |  |
| 2642 | **Data Cleanse Plan** |  |  |  | 84% → 63% |  |  |  |
| 2647 | **MTDs** |  | 2025-01-24 A → 2025-07-18 (+175d) | 115d → 240d | 100% → 23% | none → 634d |  |  |
| 2648 | **ESME ID** |  | 2024-12-20 A → 2025-05-16 (+147d) | 90d → 195d | 100% → 23% | none → 679d |  |  |
| 2653 | ESME ID Complete | 2024-12-20 A → 2025-05-16 (+147d) | 2024-12-20 A → 2025-05-16 (+147d) |  | 100% → 0% | none → 679d | 2651 → 2652 |  |
| 2654 | **Meter Location and Number of Displayed Register Digits** |  | 2025-01-24 A → 2025-07-18 (+175d) | 96d → 221d | 100% → 24% | none → 634d |  |  |
| 2659 | Meter Location and Number of Displayed Register Digits Complete | 2025-01-24 A → 2025-07-18 (+175d) | 2025-01-24 A → 2025-07-18 (+175d) |  | 100% → 0% | none → 634d | 2657 → 2657, 2658 |  |
| 2704 | **Preparation for Cutover to Live** |  | 2025-10-17 → 2027-05-05 (+565d) | 341d → 744d |  | 569d → 166d |  |  |
| 2752 | **Cutover Governance M11** |  | 2025-10-17 → 2025-10-22 (+5d) | 16d → 19d |  | 3d → 5d |  |  |
| 2753 | Confirmation of Qualified Parties from Code Bodies |  | 2025-10-10 → 2025-10-14 (+4d) | 11d → 13d |  | 3d → 7d | 2751FS+1d → 2751FS+1d, 2369 |  |
| 2754 | Self-Declaration that MHHS Functionality will be deployed to Production by Qualified parties | 2025-10-10 → 2025-10-14 (+4d) | 2025-10-10 → 2025-10-14 (+4d) |  |  | 3d → 7d |  | constraint none → finish no earlier than 2025-10-14 |
| 2755 | Production Service Activation Activities have taken place | 2025-10-10 → 2025-10-14 (+4d) | 2025-10-10 → 2025-10-14 (+4d) |  |  | 3d → 7d |  | constraint none → finish no earlier than 2025-10-14 |
| 2756 | TORWG (Confirmation of Qualified Parties from TORWG) | 2025-10-13 → 2025-10-17 (+4d) | 2025-10-13 → 2025-10-17 (+4d) |  |  | 3d → 5d |  | constraint none → finish no earlier than 2025-10-17 |

| ID | Task | Start | Finish | Duration | Complete | Total float | Predecessors | Other |
| --- | --- | --- | --- | --- | --- | --- | --- | --- |
| 2757 | MCAG (Provide recommendation to PSG on M11 decision) | 2025-10-15 → 2025-10-20 (+5d) | 2025-10-15 → 2025-10-20 (+5d) |  |  | 3d → 5d | 2756FS+2d → 2756FS+1d | constraint none → finish no earlier than 2025-10-20 |
| 2758 | PSG (OFGEM and PSG Decision to Confirm M11 and M12) | 2025-10-17 → 2025-10-22 (+5d) | 2025-10-17 → 2025-10-22 (+5d) |  |  | 3d → 5d |  |  |
| 2862 | Full transition complete (M15) |  |  |  |  |  | SIT MVC UMS / Advanced Migration, SIT Non-MVC UMS / Advanced Migration, Wave 1 UMS / Advanced Migration, Wave 2 UMS / Advanced Migration, Wave 3 UMS / Advanced Migration, Wave 4 UMS / Advanced Migration, SIT MVC Smart / Non-Smart Migration, SIT Non-MVC Smart / Non-Smart Migration, Wave 1 Smart / Non-Smart Migration, Wave 2 Smart / Non-Smart Migration, Wave 3 Smart / Non-Smart Migration, Wave 4 Smart / Non-Smart Migration, 2841FS+2d → 2841FS+2d |  |
| 2864 | **BUSINESS & OPERATIONAL READINESS** |  |  |  | 6% → 11% |  |  |  |
| 2865 | **Service Management** | 2023-09-19 A → 2022-10-31 A (-323d) | 2027-06-24 → 2026-01-14 (-526d) | 983d → 838d | 26% → 41% | 130d → 506d |  |  |
| 2870 | **Early Life Support Model** |  | 2024-07-30 → 2025-04-29 (+273d) | 110d → 305d | 82% → 97% | 887d → 692d |  |  |
| 2871 | Draft Document |  | 2024-06-10 → 2025-02-13 A (+248d) | 74d → 252d | 96% → 100% | 887d → none |  | constraint none → finish no earlier than 2025-02-13 |
| 2872 | Share Document with SRO | 2024-06-11 → 2025-02-14 A (+248d) | 2024-06-11 → 2025-02-14 A (+248d) |  | 0% → 100% | 887d → none |  |  |
| 2873 | Industry Consultation | 2024-06-18 → 2025-02-21 A (+248d) | 2024-07-02 → 2025-03-07 (+248d) |  | 0% → 30% | 887d → 709d |  |  |
| 2874 | Assurance Meeting | 2024-07-16 → 2025-04-03 (+261d) | 2024-07-16 → 2025-04-03 (+261d) |  |  | 887d → 700d |  | constraint none → finish no earlier than 2025-04-03 |
| 2875 | MCAG Approval of Early Life Support Model | 2024-07-30 → 2025-04-29 (+273d) | 2024-07-30 → 2025-04-29 (+273d) |  |  | 887d → 692d |  | constraint none → finish no earlier than 2025-04-29 |
| 2876 | **Service Management Arrangements Implementation** | 2025-09-25 → 2022-10-31 (-1060d) | 2027-06-24 → 2026-01-14 (-526d) | 456d → 838d |  | 130d → 506d |  |  |
| 2878 | Monitor Elexon implementation of Service Management arrangements | 2025-10-23 → 2022-10-31 (-1088d) | 2027-06-24 → 2024-07-01 (-1088d) |  |  | 130d → 908d | SIT MVC UMS / Advanced MigrationSS, SIT MVC Smart / Non-Smart MigrationSS → none |  |

## Version 3 (data date 2025-03-25, saved 2025-03-26, file MHHS-DEL1139 - MHHS Plan v6.21.mpp)

Last finish stays 2027-12-23. Complete tasks 1593 → 1683.

Added:

| ID | Task | Duration | Start | Finish | Predecessors | Constraint |
| --- | --- | --- | --- | --- | --- | --- |
| 162 | **Interim Release 8.9** | 45d | 2025-02-05 A | 2025-04-08 |  |  |
| 163 | Update baselined artefacts | 4d | 2025-02-05 A | 2025-02-10 A |  | start no earlier than 2025-02-05 |
| 164 | Interim Release 8.9 Published | 0d | 2025-03-11 A | 2025-03-11 A | 163FS+1d | finish no earlier than 2025-03-26 |
| 165 | Interim Release 8.9 Deployed to SIT by Participants | 20d | 2025-03-12 A | 2025-04-08 | 164 |  |
| 166 | **Interim Release 8.10** | 56d | 2025-02-05 A | 2025-04-23 |  |  |
| 167 | Update baselined artefacts | 4d | 2025-02-05 A | 2025-02-10 A |  | start no earlier than 2025-02-05 |
| 168 | Interim Release 8.10 Published | 1d | 2025-03-26 A | 2025-03-26 A | 167FS+1d | finish no earlier than 2025-03-26 |
| 169 | Interim Release 8.10 Deployed to SIT by Participants | 20d | 2025-03-27 | 2025-04-23 | 168 | finish no earlier than 2025-03-27 |
| 1454 | Regression Test Framework Core Pack - PP Walkthrough | 1d? | 2025-03-20 A | 2025-03-20 A | 1453SS | start no earlier than 2025-03-20 |
| 1455 | Regression Test Framework Core Pack - Q&A Drop in session | 1d? | 2025-03-27 | 2025-03-27 | 1453SS | start no earlier than 2025-03-27 |
| 1462 | Regression Test Approach and Plan Uplift | 1d? | 2025-04-16 | 2025-04-16 | 1460 |  |
| 1463 | Industry Review on the Uplifted Test Approach and Plan | 4d | 2025-04-17 | 2025-04-22 | 1462 |  |
| 1597 | SIT-A Settlement Testing Start | 0d | 2025-05-19 | 2025-05-19 | 1470FS+1d |  |
| 1598 | SIT-A Settlement Testing | 20d | 2025-05-20 | 2025-06-16 | 1597 |  |
| 1599 | SIT-A Settlement Decision Point Exit Criteria | 0d | 2025-06-13 | 2025-06-13 | 1598FS-2d |  |
| 1600 | SIT-A Settlement Testing Completed | 0d | 2025-06-13 | 2025-06-13 | 1599 |  |
| 1603 | Regression Execution | 5d | 2025-06-16 | 2025-06-20 | 1602FS-1d |  |
| 1607 | Regression Contingency Week | 5d | 2025-08-04 | 2025-08-08 | 1606 |  |
| 1642 | **MHHS Programme Assurance of Helix E2E SAT** | 219d | 2024-09-02 A | 2025-07-03 |  |  |
| 1643 | MHHS Programme Assurance Start | 0d | 2024-09-02 A | 2024-09-02 A | 1616SS |  |
| 1644 | Ongoing MHHS Programme Assurance | 219d | 2024-09-02 | 2025-07-03 | 1643 |  |
| 1645 | MHHS Programme Assurance End | 0d | 2025-07-03 | 2025-07-03 | 1644, 1641 |  |
| 1674 | Regression Test Execution Start | 0d | 2025-06-16 | 2025-06-16 | 1600FS+2d |  |
| 1675 | Regression Execution | 5d | 2025-06-16 | 2025-06-20 | 1674FS-1d |  |
| 1679 | Regression Contingency Week | 5d | 2025-08-04 | 2025-08-08 | 1678 |  |
| 1754 | Discussion at QWG to reconfirm value provided from E2E Sandbox (UIT) | 0d | 2025-03-11 A | 2025-03-11 A |  | finish no earlier than 2025-03-11 |
| 1755 | Create PPIR to request PP responses on subject to gather views | 5d | 2025-03-10 | 2025-03-14 |  | finish no earlier than 2025-03-14 |
| 1756 | PPIR shared to industry | 10d | 2025-03-24 | 2025-04-04 | 1755 | start no earlier than 2025-03-24 |
| 1757 | Evaluate PPIR responses | 5d | 2025-04-07 | 2025-04-11 | 1756 |  |
| 1758 | Discuss PPIR results at QWG | 1d? | 2025-04-08 | 2025-04-08 | 1757SF-5d | finish no earlier than 2025-04-08 |
| 1830 | SIT PPs E2E Sandbox Testing End | 1d? | 2022-10-31 | 2022-10-31 |  |  |
| 2532 | **M8 Code Change Preperation** | 155d | 2025-01-31 A | 2025-09-05 |  |  |
| 2533 | Resources confirmed | 0d | 2025-01-31 A | 2025-01-31 A |  | finish no earlier than 2025-01-31 |
| 2534 | CDWG Endorsement | 0d | 2025-06-10 | 2025-06-10 |  | finish no earlier than 2025-06-10 |
| 2535 | CCAG Endorsement | 0d | 2025-06-25 | 2025-06-25 |  | finish no earlier than 2025-06-25 |
| 2536 | Send to Ofgem for SCR Direction | 0d | 2025-06-25 | 2025-06-25 |  | finish no earlier than 2025-06-25 |
| 2537 | Freeze M8 Change Control Log 1.0 and create V2.0 | 0d | 2025-07-02 | 2025-07-02 |  | finish no earlier than 2025-07-02 |
| 2538 | Agree Fast Track Code Change Process | 0d | 2025-07-02 | 2025-07-02 |  | finish no earlier than 2025-07-02 |
| 2539 | Ofgem direct SCR Code change | 0d | 2025-07-03 | 2025-07-03 |  | finish no earlier than 2025-07-03 |
| 2540 | Present to Panel | 0d | 2025-07-10 | 2025-07-10 |  | finish no earlier than 2025-07-10 |
| 2541 | Code Change Industry Consultation | 0d | 2025-07-29 | 2025-07-29 |  | finish no earlier than 2025-07-29 |
| 2542 | Panel Recommendation | 0d | 2025-08-14 | 2025-08-14 |  | finish no earlier than 2025-08-14 |
| 2543 | Ofgem Decision | 0d | 2025-09-05 | 2025-09-05 |  | finish no earlier than 2025-09-05 |
| 2775 | Confirmation that all LDSOs have deployed MPRS 9 to production | 0d | 2025-09-01 | 2025-09-01 |  | finish no earlier than 2025-09-01 |
| 2776 | Confirmation that population of Domestic Premises Indicator is complete | 0d | 2025-09-08 | 2025-09-08 | 2775 | finish no earlier than 2025-09-08 |
| 2778 | Confirmation that Market Segment has been populated for 95% of LDSO portfolios | 0d | 2025-09-12 | 2025-09-12 |  | finish no earlier than 2025-09-12 |

Removed: 1360 Reissued to DIP Manager / Code Bodies / SRO for review; 1392 SITWG update on execution model; 1669 Theme 3 SIT Non-Functional Testing Start; 1670 Theme 3 SIT Non-Functional Testing Execution

Changed:

| ID | Task | Start | Finish | Duration | Complete | Total float | Other |
| --- | --- | --- | --- | --- | --- | --- | --- |
| 1 | **PROGRAMME PLAN.** |  |  |  | 60% → 66% |  |  |
| 3 | **PROGRAMME MANAGEMENT** |  |  |  | 44% → 57% |  |  |
| 4 | **Programme Management** |  |  |  | 43% → 56% |  |  |
| 5 | Sprint-based prioritisation planning and execution |  |  |  | 43% → 56% |  |  |
| 6 | Programme governance secretariat |  |  |  | 43% → 56% |  |  |
| 7 | RAID management and reporting |  |  |  | 43% → 56% |  |  |
| 8 | Tracking against Programme outcomes and KPIs |  |  |  | 43% → 56% |  |  |
| 9 | Change control and reporting |  |  |  | 43% → 56% |  |  |
| 10 | Ongoing identification of lessons learned relating to the PMO and implementation of improvements |  |  |  | 43% → 56% |  |  |
| 11 | **Programme Internal Assurance Reviews** |  |  |  | 43% → 56% |  |  |
| 12 | Programme Internal Assurance Reviews |  |  |  | 43% → 56% |  |  |
| 13 | **Engagement with PPs** |  |  |  | 43% → 56% |  |  |
| 14 | Ongoing PP liaison activities |  |  |  | 43% → 56% |  |  |
| 15 | Milestone and Control Point objective setting |  |  |  | 43% → 56% |  |  |
| 16 | Reporting |  |  |  | 43% → 56% |  |  |
| 17 | **PP Engagement Events** |  |  |  | 43% → 56% |  |  |
| 18 | Bilateral meetings |  |  |  | 43% → 56% |  |  |
| 19 | Monthly webinars |  |  |  | 43% → 56% |  |  |
| 20 | Open days |  |  |  | 43% → 56% |  |  |
| 21 | **PP Communications** |  |  |  | 43% → 56% |  |  |
| 22 | The Clock updates (weekly) |  |  |  | 43% → 56% |  |  |
| 23 | Maintain and update content on public-facing Portal (and ongoing feedback reviews to identify and implement Portal improvements) |  |  |  | 43% → 56% |  |  |
| 24 | **Code Change Support / Other Programme Alignment** |  |  |  | 43% → 56% |  |  |
| 25 | Support DCC/BEIS on SEC change |  |  |  | 43% → 56% |  |  |
| 26 | Support on Smart Meters Act changes |  |  |  | 43% → 56% |  |  |
| 27 | Support DCC/RECCo on CSS change |  |  |  | 43% → 56% |  |  |
| 28 | Support Elexon on BSC change |  |  |  | 43% → 56% |  |  |
| 29 | Support code change inside & outside CCIAG |  |  |  | 43% → 56% |  |  |
| 30 | Support code change inside & outside CCAG |  |  |  | 43% → 56% |  |  |
| 45 | **DESIGN, BUILD & TEST (PIT)** |  |  |  | 77% → 83% |  |  |
| 46 | **Design Baseline & Enduring PP Support** |  |  |  | 71% → 79% |  |  |
| 56 | **Establish Design Change Management Processes** |  |  |  | 36% → 54% |  |  |
| 61 | Maintain E2E MHHS Design (post-M5 design change management processes operational) |  |  |  | 34% → 52% |  |  |
| 96 | **Design Artefact Releases** |  | 2025-03-12 → 2025-04-23 (+42d) | 536d? → 566d? | 96% → 94% | 726d → 696d |  |
| 136 | **Interim release 8** |  | 2025-03-12 → 2025-04-23 (+42d) | 281d? → 311d? | 85% → 80% | 726d → 696d |  |
| 158 | **Interim Release 8.8** |  | 2025-03-12 A | 26d? → 26d | 40% → 100% | 726d → none | baseline start none → 2025-02-05; baseline finish none → 2025-03-12 |
| 159 | Update baselined artefacts |  |  |  |  |  | baseline start none → 2025-02-05; baseline finish none → 2025-02-10 |
| 160 | Interim Release 8.8 Published |  |  | 1d? → 1d |  |  | baseline start none → 2025-02-12; baseline finish none → 2025-02-12 |
| 161 | Interim Release 8.8 Deployed to SIT by Participants |  | 2025-03-12 A |  | 25% → 100% | 726d → none | baseline start none → 2025-02-13; baseline finish none → 2025-03-12 |
| 412 | SIT Non-Functional PIT Completion Report Theme 1 MHHS Review Completed |  | 2024-12-20 A |  | 50% → 100% | 784d → none |  |
| 499 | **DBT Monitoring and Assurance** |  |  |  | 69% → 85% |  |  |
| 500 | **Planning and DBT Progress Monitoring of PPs** |  |  |  | 67% → 89% |  |  |
| 501 | Monitor Non-SIT PPs Planning and DBT1 progress (to inform confirmation of Qualification Testing Tranche participants milestones) |  |  |  | 67% → 89% |  |  |
| 502 | **DBT Progress Monitoring of Consequential Change** |  |  |  | 51% → 71% |  |  |
| 503 | Monitor & report data cleanse progress |  |  |  | 51% → 71% |  |  |
| 504 | **Design Assurance** |  |  |  | 80% → 89% |  |  |
| 535 | **Non-SIT PPs design assurance** |  |  |  | 53% → 75% |  |  |
| 536 | Non-SIT PPs design assurance (risk-based sample) |  |  |  | 53% → 75% |  |  |
| 537 | **Test Assurance** |  |  |  | 71% → 87% |  |  |
| 538 | Non-SIT PPs test assurance |  |  |  | 71% → 87% |  |  |
| 545 | **SYSTEMS INTEGRATION TESTING (SIT)** |  |  |  | 75% → 77% |  |  |
| 546 | **SIT Preparation** |  |  |  | 97% → 99% |  |  |
| 627 | **SIT Stage-Specific Preparation** |  |  |  | 97% → 99% |  |  |
| 1100 | **SIT Non-Functional Preparation** |  |  |  | 97% → 99% |  |  |
| 1148 | **Environments (SIT B)** |  | 2025-02-28 A |  | 0% → 100% | 25d → none |  |
| 1153 | **Helix and Avanade Environments Upscale** | 2025-02-24 A | 2025-02-28 A |  | 0% → 100% | 25d → none |  |
| 1154 | Environment Uplift Window (Technical Check) | 2025-02-24 A | 2025-02-28 A |  | 0% → 100% | 25d → none |  |
| 1155 | **SIT Non-Functional Execution Model** |  | 2025-03-18 A |  | 99% → 100% | 722d → none |  |
| 1163 | **Theme 2 & 3** |  | 2025-03-18 A |  | 99% → 100% | 722d → none |  |
| 1168 | NFTWG paper day | 2025-03-11 A | 2025-03-11 A |  | 0% → 100% | 722d → none |  |
| 1169 | NFTWG update on execution model | 2025-03-18 A | 2025-03-18 A |  | 0% → 100% | 722d → none |  |
| 1173 | **SIT Non-Functional Test Readiness Report** |  |  |  | 63% → 99% | 715d → 99d |  |
| 1174 | **SIT Non-Functional Theme 1 Overarching Test Readiness Report** |  | 2025-02-28 A |  | 99% → 100% | 734d → none |  |
| 1181 | eSITAG paper day | 2025-02-26 A | 2025-02-26 A |  | 0% → 100% | 736d → none |  |
| 1182 | eSITAG approve Non-Functional Theme 1 Overarching Test Readiness Report | 2025-02-28 A | 2025-02-28 A |  | 0% → 100% | 6d → none |  |
| 1183 | **SIT Non-Functional Overarching Test Readiness Report Theme 2 & 3** |  |  |  | 25% → 99% | 715d → 99d |  |
| 1184 | Develop Overarching SIT Non-Functional Overarching Test Readiness Report Theme 2 & 3 |  | 2025-03-04 A |  | 50% → 100% | 732d → none |  |
| 1185 | SRO review | 2025-03-05 A | 2025-03-11 A |  | 0% → 100% | 61d → none |  |
| 1186 | NFTWG paper day | 2025-03-11 A | 2025-03-11 A |  | 0% → 100% | 61d → none |  |
| 1187 | NFTWG review the Non-Functional Overarching Test Readiness Report Theme 2 & 3 | 2025-03-18 A | 2025-03-18 A |  | 0% → 100% | 61d → none |  |

| ID | Task | Start | Finish | Duration | Complete | Total float | Predecessors | Other |
| --- | --- | --- | --- | --- | --- | --- | --- | --- |
| 1188 | Update Non-Functional Overarching Test Readiness Report Theme 2 & 3 following SRO / NFTWG feedback | 2025-03-19 A | 2025-03-26 A |  | 0% → 100% | 61d → none |  |  |
| 1189 | GLIG Recommendation | 2025-03-21 A | 2025-03-21 A |  | 0% → 100% | 64d → none |  | was named FTIG Recommendation |
| 1190 | eSITAG paper day | 2025-03-26 A | 2025-03-26 A |  | 0% → 100% | 61d → none |  |  |
| 1192 | SIT Non-Functional Testing Preparation Complete Theme 1 | 2025-02-28 A | 2025-02-28 A |  | 0% → 100% | 734d → none |  |  |
| 1193 | SIT Non-Functional Testing Preparation Complete Theme 2 & 3 |  |  |  |  |  | 413FS+5d, 1427, 1428 → 413FS+5d, 1427, 1428, 1169, 1172, 1147, 1141, 1136 |  |
| 1194 | **SIT Operational Preparation** |  |  |  | 93% → 99% |  |  |  |
| 1317 | **Theme 3 Test Cases Approved** |  | 2025-03-19 A |  | 98% → 100% | 721d → none |  |  |
| 1344 | **Theme 3 (Batch 2) Supplementary** |  | 2025-03-19 A |  | 74% → 100% | 721d → none |  |  |
| 1348 | Industry Consultation (Batch 2) Supplementary |  | 2025-03-04 A |  | 50% → 100% | 721d → none |  |  |
| 1349 | SITWG Paper Day | 2025-02-27 A | 2025-02-27 A |  | 0% → 100% | 726d → none |  |  |
| 1350 | Review Feedback and Update | 2025-03-05 A | 2025-03-05 A |  | 0% → 100% | 721d → none |  |  |
| 1351 | SITWG endorse Theme 3 (Batch 2) Supplementary | 2025-03-06 A | 2025-03-06 A |  | 0% → 100% | 721d → none |  |  |
| 1352 | SITAG paper day | 2025-03-12 A | 2025-03-12 A |  | 0% → 100% | 721d → none |  |  |
| 1353 | SITAG approve Theme 3 (Batch 2) Supplementary | 2025-03-19 A | 2025-03-19 A |  | 0% → 100% | 721d → none |  |  |
| 1363 | **SIT Operational Programme RTTM (Theme 1, 2 & 3 (Batch 2))** |  | 2025-03-21 → 2025-03-28 (+7d) | 55d → 59d | 56% → 92% | 719d → 715d |  |  |
| 1364 | Develop SIT Operational (Theme 1, 2 & 3 (Batch 2)) RTTM |  | 2025-02-21 → 2025-02-24 A (+3d) | 35d → 36d | 89% → 100% | 719d → none |  |  |
| 1365 | SRO review of SIT Operational (Theme 1, 2 & 3 (Batch 2)) RTTM | 2025-02-24 → 2025-02-25 A (+1d) | 2025-02-28 → 2025-03-07 A (+7d) | 5d → 9d | 0% → 100% | 719d → none |  | baseline start 2025-02-10 → 2025-02-25; baseline finish 2025-02-14 → 2025-03-07 |
| 1366 | DIP Manager / Code Bodies / Full SRO to review | 2025-03-03 → 2025-03-10 A (+7d) | 2025-03-07 → 2025-03-21 (+14d) | 5d → 10d | 0% → 75% | 719d → 30d |  | baseline start 2025-02-17 → 2025-03-10; baseline finish 2025-02-21 → 2025-03-21 |
| 1367 | Incorporate feedback | 2025-03-10 A | 2025-03-14 → 2025-03-21 (+7d) | 5d → 10d | 0% → 75% |  | 1366 → 1366FF | baseline start 2025-02-24 → 2025-03-10; baseline finish 2025-02-28 → 2025-03-21 |
| 1368 | DIP Manager / Code Bodies / SRO acceptance of (Theme 1, 2 & 3 (Batch 2)) Operational RTTM | 2025-03-21 → 2025-03-24 (+3d) | 2025-03-21 → 2025-03-24 (+3d) |  |  | 719d → 30d | Reissued to DIP Manager / Code Bodies / SRO for review → 1366FS+1d | baseline start 2025-03-07 → 2025-03-24; baseline finish 2025-03-07 → 2025-03-24 |
| 1369 | SIT Operational (Theme 1, 2 & 3 (Batch 2)) RTTM Complete | 2025-03-21 → 2025-03-28 (+7d) | 2025-03-21 → 2025-03-28 (+7d) |  |  | 719d → 27d |  | constraint none → start no earlier than 2025-03-28; baseline start 2025-03-07 → 2025-03-24; baseline finish 2025-03-07 → 2025-03-24 |
| 1376 | **SIT Operational Theme 1, 2 & 3 (Batch 2) DITL** |  |  |  | 3% → 99% | 716d → 28d |  |  |
| 1377 | DITL + Familiarisation session development |  | 2025-03-14 A |  | 5% → 100% | 716d → none |  |  |
| 1378 | SRO Review | 2025-03-17 A | 2025-03-21 A |  | 0% → 100% | 716d → none |  |  |
| 1379 | Post-SRO Review Changes | 2025-03-24 A | 2025-03-26 A |  | 0% → 100% | 716d → none |  |  |
| 1380 | Familiarisation session Service Management test case schedule + mapping | 2025-03-26 A | 2025-03-26 A |  | 0% → 100% | 716d → none |  |  |
| 1385 | **SIT Operational Execution Model** |  |  |  | 88% → 100% |  |  |  |
| 1393 | **Theme 1, 2 and 3 (Batch 2)** |  |  | 23d → 23d? | 63% → 100% |  |  |  |
| 1395 | SRO provide feedback | 2025-02-17 A → 2025-02-25 A (+8d) | 2025-02-21 A → 2025-03-03 A (+10d) |  |  |  |  |  |
| 1396 | Address SRO feedback on execution model | 2025-02-17 → 2025-03-04 A (+15d) | 2025-02-21 → 2025-03-10 A (+17d) |  | 0% → 100% | 730d → none | 1395FF → 1395 |  |
| 1397 | Finalise execution model | 2025-02-24 → 2025-03-11 A (+15d) | 2025-02-27 → 2025-03-17 A (+18d) | 4d → 5d | 0% → 100% | 730d → none |  |  |
| 1398 | Execution Model shared with industry | 2025-02-27 → 2025-03-17 A (+18d) | 2025-02-27 → 2025-03-17 A (+18d) |  | 0% → 100% | 730d → none |  | was named SITWG paper day |
| 1402 | **SIT Operational Overarching Test Readiness Reports** |  |  |  | 76% → 99% |  |  |  |
| 1413 | **SI SIT Operational Theme 1, 2 and 3 (Batch 2) Overarching Test Readiness Report** |  |  |  | 59% → 99% | 714d → 25d |  |  |
| 1415 | SRO review |  | 2025-02-28 A |  | 50% → 100% | 734d → none |  |  |
| 1416 | SITWG Paper day | 2025-02-27 A | 2025-02-27 A |  | 0% → 100% | 735d → none |  |  |
| 1417 | SITWG review the Operational Theme 1, 2 and 3 (Batch 2) Overarching Test Readiness Report | 2025-03-06 A | 2025-03-06 A |  | 0% → 100% | 30d → none |  |  |
| 1418 | Update Operational Theme 1, 2 and 3 (Batch 2) Overarching Test Readiness Report following SRO feedback | 2025-03-07 A | 2025-03-25 A |  | 0% → 100% | 717d → none |  |  |
| 1419 | GLIG recommendation | 2025-03-21 A | 2025-03-21 A |  | 0% → 100% | 30d → none |  | was named FTIG recommendation |
| 1420 | eSITAG paper day | 2025-03-26 A | 2025-03-26 A |  | 0% → 100% | 716d → none |  |  |
| 1423 | SIT Operational Theme 1, 2, 3 (Batch 2) Testing Preparation Complete |  |  |  |  |  | 430, 1211, 1217, 1343, 1421 → 430, 1211, 1217, 1343, 1421, 1401, 1381, 1369, 1353 |  |
| 1424 | **Test Data - Non-Functional and Operational (SIT B)** |  |  |  | 1% → 82% |  |  |  |
| 1425 | **Data Load** |  |  |  | 1% → 82% |  |  |  |
| 1426 | Non-Functional Theme 1 (Avenade) Data Load |  | 2025-02-28 A |  | 5% → 100% | 6d → none |  |  |
| 1427 | Non-Functional Theme 2 & 3 (Helix, Avenade & PPs) Data Load | 2025-03-24 A |  |  | 0% → 40% |  |  |  |
| 1428 | Non-Functional Themes 2 & 3 (LDSO's) Data Load | 2025-03-03 A | 2025-03-21 A |  | 0% → 100% | 64d → none |  | was named Non-Functional Themes 2 & 3 (LDSO's and DCC) Data Load |
| 1429 | Operational Themes 1, 2 & 3 (Batch 2) (LDSO's) Data Load | 2025-03-03 A |  |  | 0% → 85% |  |  | was named Operational Themes 1, 2 & 3 (Batch 2) (LDSO's and DCC) Data Load |
| 1430 | Operational Themes 1, 2 & 3 (Batch 2) (Helix, Avenade & PPs) Data Load | 2025-03-24 A |  |  | 0% → 40% |  |  |  |
| 1432 | **Regression Test Preparation** |  |  |  | 42% → 69% |  |  |  |
| 1433 | **Regression Test Approach** |  |  |  | 99% → 100% |  |  |  |
| 1443 | eSITAG (inc SRO) Approval | 2025-02-28 A | 2025-02-28 A |  | 0% → 100% | 734d → none |  |  |
| 1444 | SIT Regression Testing Approach and Plan Approval | 2025-02-28 A | 2025-02-28 A |  | 0% → 100% | 734d → none |  |  |
| 1445 | **Regression Core Test Pack** | 2025-02-12 A |  | 52d → 52d? | 0% → 72% |  |  |  |
| 1446 | Build Regression Core Pack | 2025-02-12 A | 2025-03-06 A |  | 0% → 100% | 7d → none |  |  |
| 1447 | Build Regression Framework | 2025-02-12 A | 2025-02-27 A |  | 0% → 100% | 7d → none |  |  |
| 1448 | SITWG paper day | 2025-02-27 A | 2025-02-27 A |  | 0% → 100% | 7d → none |  |  |
| 1449 | SITWG provides feedback on Regression Framework approach | 2025-03-06 A | 2025-03-06 A |  | 0% → 100% | 7d → none |  |  |
| 1450 | LDP walkthrough of Regression Core Pack | 2025-02-27 A | 2025-02-28 → 2025-03-03 A (+3d) | 2d → 3d | 0% → 100% | 734d → none |  |  |
| 1451 | SRO Review of Regression Core Pack | 2025-03-03 → 2025-03-07 A (+4d) | 2025-03-07 → 2025-03-14 A (+7d) | 5d → 6d | 0% → 100% | 9d → none |  | constraint start no earlier than 2025-03-03 → start no earlier than 2025-03-07 |
| 1452 | Incorporate SRO feedback into Regression Core Pack | 2025-03-05 → 2025-03-07 A (+2d) | 2025-03-06 → 2025-03-14 A (+8d) | 2d → 6d | 0% → 100% | 7d → none | 1451SS, 1449FF → 1451SS |  |
| 1453 | Industry review of Regression Core Pack | 2025-03-10 → 2025-03-17 A (+7d) | 2025-03-21 → 2025-03-28 (+7d) |  | 0% → 70% |  | 1452FS+1d, 1446FS+1d → 1452, 1446 | constraint none → start no earlier than 2025-03-13; baseline start 2025-03-10 → 2025-03-17; baseline finish 2025-03-21 → 2025-03-28 |
| 1456 | Incorporate Industry feedback into Regression Core Pack | 2025-03-24 → 2025-03-31 (+7d) | 2025-03-28 → 2025-04-02 (+5d) | 5d → 3d |  |  | 1453 → 1453, 1454, 1455 | baseline start 2025-03-24 → 2025-03-31; baseline finish 2025-03-27 → 2025-04-02 |
| 1457 | Second industry review of Regression Core Pack | 2025-03-31 → 2025-04-03 (+3d) | 2025-04-04 → 2025-04-09 (+5d) |  |  |  |  | baseline start none → 2025-04-03; baseline finish none → 2025-04-09 |
| 1458 | Incorporate industry feedback into regression Core Pack | 2025-04-07 → 2025-04-10 (+3d) | 2025-04-08 → 2025-04-10 (+2d) | 2d → 1d |  |  |  | baseline start 2025-04-04 → 2025-04-10; baseline finish 2025-04-04 → 2025-04-10 |
| 1459 | eSITWG paper day | 2025-04-08 → 2025-04-10 (+2d) | 2025-04-08 → 2025-04-10 (+2d) |  |  |  |  | baseline start none → 2025-04-10; baseline finish none → 2025-04-10 |
| 1460 | eSITWG endorses regression Core Pack |  |  |  |  |  | 1459FS+5d → 1459FS+3d | baseline start none → 2025-04-15; baseline finish none → 2025-04-15 |
| 1461 | Incorporate SITWG feedback into regression Core Pack |  |  |  |  |  |  | baseline start none → 2025-04-16; baseline finish none → 2025-04-17 |
| 1464 | eSITAG paper day |  |  |  |  |  |  | baseline start 2025-04-09 → 2025-04-17; baseline finish 2025-04-09 → 2025-04-17 |
| 1465 | eSITAG (inc SRO) Approval of regression Core Pack |  |  |  |  |  | 1464FS+5d → 1464FS+5d, 1463 | baseline start 2025-04-16 → 2025-04-24; baseline finish 2025-04-16 → 2025-04-24 |
| 1466 | SIT Regression Approval |  |  |  |  |  |  | baseline start 2025-04-16 → 2025-04-24; baseline finish 2025-04-16 → 2025-04-24 |

| ID | Task | Start | Finish | Duration | Complete | Total float | Predecessors | Other |
| --- | --- | --- | --- | --- | --- | --- | --- | --- |
| 1520 | **SIT Execution** |  | 2025-11-27 → 2025-11-26 (-1d) | 544d? → 543d? | 48% → 54% | 540d → 541d |  |  |
| 1537 | **SIT - Minimum Viable Cohort (MVC)** |  |  |  | 51% → 58% |  |  |  |
| 1538 | **SIT Functional Testing (MVC)** |  |  |  | 62% → 67% |  |  |  |
| 1540 | **SIT Functional Testing Execution (Minimum Viable Cohort)** |  |  |  | 85% → 92% |  |  |  |
| 1550 | **Cycle 3 (Defect retests and targeted regression testing)** |  |  |  | 68% → 82% |  |  |  |
| 1559 | Sprint 12 |  | 2025-02-28 A |  | 75% → 100% | 5d → none |  |  |
| 1560 | Sprint 13 (RTTM Gap Analysis + CR056) | 2025-03-03 A | 2025-03-14 A |  | 0% → 100% | 5d → none |  |  |
| 1561 | Sprint 14 (RTTM Gap Analysis + CR056) | 2025-03-17 A |  |  | 0% → 70% |  |  |  |
| 1565 | **SIT Scope Traceability** |  | 2025-03-19 → 2025-04-24 (+36d) | 38d → 64d | 75% → 99% | 721d → 695d |  |  |
| 1570 | Industry Review |  | 2025-03-04 A |  | 50% → 100% | 732d → none |  |  |
| 1571 | SITWG paper day | 2025-02-27 A → 2025-04-08 (+40d) | 2025-02-27 A → 2025-04-08 (+40d) |  | 100% → 0% | none → 695d | 1569FS+7d → 1569FS+35d | baseline start 2025-02-27 → 2025-04-08; baseline finish 2025-02-27 → 2025-04-08 |
| 1572 | SITWG recommends Scope Tracability document | 2025-03-06 → 2025-04-15 (+40d) | 2025-03-06 → 2025-04-15 (+40d) |  |  | 721d → 695d |  | baseline start 2025-03-06 → 2025-04-15; baseline finish 2025-03-06 → 2025-04-15 |
| 1573 | Update document to reflect industry consultation views | 2025-03-07 → 2025-03-05 A (-2d) | 2025-03-12 → 2025-03-14 A (+2d) | 4d → 8d | 0% → 100% | 721d → none | 1572 → 1570 | baseline start 2025-03-07 → 2025-03-05; baseline finish 2025-03-12 → 2025-03-14 |
| 1574 | SITAG paper day | 2025-03-12 → 2025-04-17 (+36d) | 2025-03-12 → 2025-04-17 (+36d) |  |  | 721d → 695d | 1573 → 1572FS+2d, 1573 | baseline start 2025-03-12 → 2025-04-17; baseline finish 2025-03-12 → 2025-04-17 |
| 1575 | SITAG approve SIT Scope Traceability document | 2025-03-19 → 2025-04-24 (+36d) | 2025-03-19 → 2025-04-24 (+36d) |  |  | 721d → 695d |  | baseline start 2025-03-19 → 2025-04-24; baseline finish 2025-03-19 → 2025-04-24 |
| 1576 | SIT Scope Traceability Approved | 2025-03-19 → 2025-04-24 (+36d) | 2025-03-19 → 2025-04-24 (+36d) |  |  | 721d → 695d |  | baseline start 2025-03-19 → 2025-04-24; baseline finish 2025-03-19 → 2025-04-24 |
| 1577 | **SIT Functional Settlement Testing** |  |  |  | 35% → 36% |  |  |  |
| 1578 | SIT-B Settlement Testing Cycle 2 | 2025-03-10 A |  |  | 0% → 5% |  |  |  |
| 1596 | **SIT-A Settlement Testing** |  | 2025-06-13 → 2025-06-16 (+3d) | 20d? → 20d |  |  | 1470 → none |  |
| 1602 | Regression Test Execution Start |  |  | 1d → 0d |  | 658d → 5d | 1470, 1596 → 1470FS+2d, 1600FS+2d |  |
| 1604 | Regression Sprint 1 | 2025-06-16 → 2025-06-23 (+7d) | 2025-06-27 → 2025-07-04 (+7d) |  |  |  | 1596, 1464 → 1603 | baseline start 2025-06-16 → 2025-06-23; baseline finish 2025-06-27 → 2025-07-04 |
| 1605 | Regression Sprint 2 | 2025-06-30 → 2025-07-07 (+7d) |  | 15d → 10d |  |  |  | baseline start 2025-06-30 → 2025-07-07 |
| 1606 | Regression Sprint 3 |  | 2025-08-08 → 2025-08-01 (-7d) | 15d → 10d |  |  |  | baseline finish 2025-08-08 → 2025-08-01 |
| 1608 | SIT Functional Testing End (Minimum Viable Cohort) (incl. confirmation that PPs have submitted their Test Completion Reports to Programme for assurance) |  |  |  |  |  | 1606 → 1607 |  |
| 1611 | Develop document |  |  |  |  |  |  | constraint none → start no earlier than 2025-07-21 |
| 1614 | **Helix E2E Settlement Assurance Testing (SAT)** |  |  |  | 55% → 60% |  |  |  |
| 1615 | **Test design** |  | 2025-02-21 A |  | 42% → 100% | 739d → none |  |  |
| 1617 | Test Automation and Supporting Tools | 2024-11-04 A | 2025-02-21 A |  | 0% → 100% | 739d → none |  |  |
| 1618 | SAT tests batch 3 | 2024-12-16 A | 2025-02-21 A |  | 0% → 100% | 739d → none |  |  |
| 1623 | **Execution** |  |  |  | 31% → 46% |  |  |  |
| 1626 | Programme agreement to start SAT testing | 2025-02-06 A | 2025-02-06 A |  | 0% → 100% | 645d → none |  |  |
| 1627 | SAT Testing Start | 2025-02-06 A | 2025-02-06 A |  | 0% → 100% | 645d → none |  |  |
| 1628 | SAT first run | 2025-02-07 A |  |  | 0% → 77% |  |  |  |
| 1632 | **Contingency test time** | 2025-03-06 → 2025-04-07 (+32d) |  | 70d → 48d |  |  |  |  |
| 1635 | **NESO** | 2025-03-06 → 2025-04-07 (+32d) |  | 70d → 48d |  |  |  |  |
| 1636 | P210 Test files to NESO | 2025-03-06 → 2025-04-07 (+32d) | 2025-03-06 → 2025-04-07 (+32d) |  |  | 731d → 709d |  | constraint start no earlier than 2025-03-06 → start no earlier than 2025-04-07; baseline start 2025-03-06 → 2025-04-07; baseline finish 2025-03-06 → 2025-04-07 |
| 1646 | **SIT Migration Testing (MVC)** |  |  |  | 67% → 71% |  |  |  |
| 1648 | **SIT Migration Testing Execution (Minimum Viable Cohort)** |  |  |  | 67% → 71% |  |  |  |
| 1658 | **Cycle 3 (Defect retests and targeted regression testing)** |  |  |  | 69% → 83% |  |  |  |
| 1667 | Sprint 12 |  | 2025-02-28 A |  | 75% → 100% | 5d → none |  |  |
| 1668 | Sprint 13 | 2025-03-03 A | 2025-03-14 A |  | 0% → 100% | 5d → none |  |  |
| 1669 | Sprint 14 (RTTM Gap Analysis + CR056) | 2025-03-17 A |  |  | 0% → 70% |  |  |  |
| 1673 | **SIT Migration MVC Regression Testing (code freeze)** |  | 2025-08-01 → 2025-08-08 (+7d) | 35d? → 40d? |  | 609d → 614d |  |  |
| 1676 | Regression Sprint 1 | 2025-06-16 → 2025-06-23 (+7d) | 2025-06-27 → 2025-07-04 (+7d) | 10d? → 10d |  | 609d → 614d | 1596 → 1675 | baseline start 2025-06-16 → 2025-06-23; baseline finish 2025-06-27 → 2025-07-04 |
| 1677 | Regression Sprint 2 | 2025-06-30 → 2025-07-07 (+7d) | 2025-07-11 → 2025-07-18 (+7d) |  |  | 609d → 614d |  | baseline start 2025-06-30 → 2025-07-07; baseline finish 2025-07-11 → 2025-07-18 |
| 1678 | Regression Sprint 3 | 2025-07-14 → 2025-07-21 (+7d) |  | 15d? → 10d |  | 609d → 619d |  |  |
| 1680 | SIT Migration Testing End (Minimum Viable Cohort) (incl. confirmation that PPs have submitted their Test Completion Reports to Programme for assurance) | 2025-08-01 → 2025-08-08 (+7d) | 2025-08-01 → 2025-08-08 (+7d) |  |  | 609d → 619d | 1678 → 1679 | baseline start 2025-08-01 → 2025-08-08; baseline finish 2025-08-01 → 2025-08-08 |
| 1682 | Develop document |  |  |  |  |  | 1680FF → 1677SS | constraint none → start no earlier than 2025-07-14 |
| 1687 | **SIT Non-Functional Testing (all SIT PPs)** | 2025-03-03 A |  |  | 0% → 16% | 6d → 60d |  |  |
| 1688 | Theme 1 (Helix and DIP Volume Testing) Start | 2025-03-03 A | 2025-03-03 A |  | 0% → 100% | 6d → none |  |  |
| 1689 | Theme 1 (Helix and DIP Volume Testing) Execution | 2025-03-03 A | 2025-03-21 A |  | 0% → 100% | 6d → none |  |  |
| 1690 | Theme 2 & 3 SIT Non-Functional Testing Start |  |  |  |  |  |  | was named Theme 2 SIT Non-Functional Testing Start |
| 1691 | Theme 2 & 3 SIT Non-Functional Testing Execution |  |  |  |  |  |  | was named Theme 2 SIT Non-Functional Testing Execution |
| 1692 | SIT Non-Functional Testing End (all SIT PPs) (incl. confirmation that PPs have submitted their Test Completion Reports to Programme for assurance) |  |  |  |  |  | 1691FF, Theme 3 SIT Non-Functional Testing ExecutionFF → 1691FF |  |
| 1698 | **SIT Operational Testing (all SIT PPs)** |  |  |  | 3% → 17% |  |  |  |
| 1699 | **Non-SIT B Testing** |  | 2025-03-07 A |  | 15% → 100% | 115d → none |  |  |
| 1701 | SIT Operational Testing Execution Window (Theme 3 - Batch 1 (Service Management)) |  | 2025-03-07 A |  | 15% → 100% | 115d → none |  |  |
| 1717 | **SIT (non-MVC)** | 2025-06-16 → 2025-06-13 (-3d) | 2025-11-27 → 2025-11-26 (-1d) |  |  | 504d → 505d |  |  |
| 1718 | **SIT Functional Testing (non-MVC)** | 2025-06-16 → 2025-06-13 (-3d) | 2025-11-14 → 2025-11-13 (-1d) |  |  | 504d → 505d |  |  |
| 1719 | **SIT Functional Testing Execution (non-MVC)** | 2025-06-16 → 2025-06-13 (-3d) | 2025-10-24 → 2025-10-23 (-1d) |  |  | 504d → 505d |  |  |
| 1720 | Test Execution (Cycle 3 Completion and Regression Testing) | 2025-06-16 → 2025-06-13 (-3d) | 2025-10-24 → 2025-10-23 (-1d) |  |  | 504d → 505d | 1596 → 1600 |  |
| 1721 | SIT Functional Testing End (non-MVC) (incl. confirmation that PPs have submitted their Test Completion Reports to Programme for assurance) | 2025-10-24 → 2025-10-23 (-1d) | 2025-10-24 → 2025-10-23 (-1d) |  |  | 504d → 505d |  |  |
| 1722 | Assurance of PPs Test Completion Reports | 2025-11-03 → 2025-10-31 (-3d) | 2025-11-07 → 2025-11-06 (-1d) |  |  | 504d → 505d |  |  |
| 1723 | **SIT Functional Testing Test Completion Report (non-MVC)** | 2025-10-06 → 2025-10-03 (-3d) | 2025-11-07 → 2025-11-06 (-1d) |  |  | 504d → 505d |  |  |
| 1724 | Develop document | 2025-10-06 → 2025-10-03 (-3d) | 2025-10-24 → 2025-10-23 (-1d) |  |  | 509d → 510d |  |  |
| 1725 | Review & agree document | 2025-11-03 → 2025-10-31 (-3d) | 2025-11-07 → 2025-11-06 (-1d) |  |  | 504d → 505d |  |  |
| 1726 | SIT Functional Testing Test Completion Report (non-MVC) Approved | 2025-11-14 → 2025-11-13 (-1d) | 2025-11-14 → 2025-11-13 (-1d) |  |  | 504d → 505d |  |  |
| 1727 | **SIT Migration Testing (non-MVC)** | 2025-06-16 → 2025-06-13 (-3d) | 2025-11-14 → 2025-11-13 (-1d) |  |  | 504d → 505d |  |  |
| 1728 | Test Execution (Cycle 3 Completion and Regression Testing) | 2025-06-16 → 2025-06-13 (-3d) | 2025-10-24 → 2025-10-23 (-1d) |  |  | 504d → 505d | 1596 → 1600 |  |
| 1729 | SIT Migration Testing End (non-MVC) (incl. confirmation that PPs have submitted their Test Completion Reports to Programme for assurance) | 2025-10-24 → 2025-10-23 (-1d) | 2025-10-24 → 2025-10-23 (-1d) |  |  | 504d → 505d |  |  |

| ID | Task | Start | Finish | Duration | Complete | Total float | Predecessors | Other |
| --- | --- | --- | --- | --- | --- | --- | --- | --- |
| 1730 | Assurance of PPs Test Completion Reports | 2025-11-03 → 2025-10-31 (-3d) | 2025-11-07 → 2025-11-06 (-1d) |  |  | 504d → 505d |  |  |
| 1731 | **SIT Migration Testing Test Completion Report (non-MVC)** | 2025-10-06 → 2025-10-03 (-3d) | 2025-11-07 → 2025-11-06 (-1d) |  |  | 504d → 505d |  |  |
| 1732 | Develop document | 2025-10-06 → 2025-10-03 (-3d) | 2025-10-24 → 2025-10-23 (-1d) |  |  | 509d → 510d |  |  |
| 1733 | Review & agree document | 2025-11-03 → 2025-10-31 (-3d) | 2025-11-07 → 2025-11-06 (-1d) |  |  | 504d → 505d |  |  |
| 1734 | SIT Migration Testing Test Completion Report (non-MVC Approved) | 2025-11-14 → 2025-11-13 (-1d) | 2025-11-14 → 2025-11-13 (-1d) |  |  | 504d → 505d |  |  |
| 1735 | **SIT non-MVC Test Exit Report** | 2025-10-27 → 2025-10-24 (-3d) | 2025-11-21 → 2025-11-20 (-1d) |  |  | 504d → 505d |  |  |
| 1736 | Develop document | 2025-10-27 → 2025-10-24 (-3d) | 2025-11-14 → 2025-11-13 (-1d) |  |  | 504d → 505d |  |  |
| 1737 | Review & agree document | 2025-11-17 → 2025-11-14 (-3d) | 2025-11-21 → 2025-11-20 (-1d) |  |  | 504d → 505d |  |  |
| 1738 | SIT non-MVC Complete | 2025-11-27 → 2025-11-26 (-1d) | 2025-11-27 → 2025-11-26 (-1d) |  |  | 504d → 505d |  |  |
| 1739 | **UIT Environment Preparation** |  |  |  | 51% → 52% |  |  |  |
| 1740 | **Test Artefact Development** |  | 2025-04-16 → 2025-04-17 (+1d) | 556d? → 557d? | 51% → 66% | 701d → 700d |  |  |
| 1741 | **E2E Sandbox Guidance** |  | 2025-03-24 → 2025-04-17 (+24d) | 539d? → 557d? | 71% → 96% | 718d → 700d |  |  |
| 1745 | Update E2E Sandbox guidance to reflect CR055 | 2025-01-13 A | 2025-02-20 → 2025-03-14 A (+22d) | 29d → 45d | 0% → 100% | 718d → none |  | was named Update E2E Sandbox guidance to reflect CR55; constraint start no earlier than 2025-01-13 → finish no earlier than 2025-03-14; baseline finish 2025-02-20 → 2025-03-14 |
| 1746 | Internal SI review | 2025-02-21 → 2025-03-17 A (+24d) | 2025-02-27 → 2025-03-21 A (+22d) |  | 0% → 100% | 718d → none |  | constraint none → start no earlier than 2025-03-17; baseline start 2025-02-21 → 2025-03-17; baseline finish 2025-02-27 → 2025-03-21 |
| 1747 | SRO / Code Bodies review | 2025-02-28 → 2025-03-24 A (+24d) | 2025-03-06 → 2025-03-28 (+22d) |  | 0% → 40% | 718d → 713d |  | constraint none → finish no earlier than 2025-03-28; baseline start 2025-02-28 → 2025-03-24; baseline finish 2025-03-06 → 2025-03-28 |
| 1748 | Submit version to QWG | 2025-03-07 → 2025-04-01 (+25d) | 2025-03-11 → 2025-04-01 (+21d) | 3d → 0d |  | 718d → 711d |  | constraint none → finish no earlier than 2025-04-01; baseline start 2025-03-07 → 2025-04-01; baseline finish 2025-03-11 → 2025-04-01 |
| 1749 | Artefact Recommendation for Approval (via QWG) | 2025-03-11 → 2025-04-08 (+28d) | 2025-03-11 → 2025-04-08 (+28d) |  |  | 718d → 706d |  | was named Artefact Approval (via QWG); constraint none → finish no earlier than 2025-04-08; baseline start 2025-03-11 → 2025-04-08; baseline finish 2025-03-11 → 2025-04-08 |
| 1750 | Final Document updates post QWG review | 2025-03-13 → 2025-04-09 (+27d) | 2025-03-13 → 2025-04-09 (+27d) |  |  | 718d → 706d | 1749FS+1d → 1749 | constraint none → start no earlier than 2025-04-09; baseline start 2025-03-13 → 2025-04-09; baseline finish 2025-03-13 → 2025-04-09 |
| 1751 | Submit final version to QAG | 2025-03-17 → 2025-04-10 (+24d) | 2025-03-17 → 2025-04-10 (+24d) |  |  | 718d → 701d | 1750FS+1d → none | constraint none → finish no earlier than 2025-04-10; baseline start 2025-03-17 → 2025-04-10; baseline finish 2025-03-17 → 2025-04-10 |
| 1752 | E2E Sandbox guidance update approved at QAG | 2025-03-24 → 2025-04-17 (+24d) | 2025-03-24 → 2025-04-17 (+24d) |  |  | 718d → 700d | 1751FS+4d → 1751FS+3d | was named E2E Sandbox guidance update approved; constraint none → finish no earlier than 2025-04-17; baseline start 2025-03-24 → 2025-04-17; baseline finish 2025-03-24 → 2025-04-17 |
| 1753 | **E2E Sandbox Test Data Approach & Plan** | 2025-01-13 A |  | 68d → 68d? |  |  |  |  |
| 1827 | **SIT PPs Early Sandbox Testing Execution (SIT-A)** | 2025-08-08 → 2022-10-31 (-1012d) | 2025-10-24 → 2025-10-17 (-7d) | 56d → 775d? |  | 564d → 569d |  |  |
| 1828 | SIT PPs E2E Sandbox Testing Start | 2025-08-08 → 2025-08-01 (-7d) | 2025-08-08 → 2025-08-01 (-7d) |  |  | 619d → 624d |  | baseline start 2025-08-08 → 2025-08-01; baseline finish 2025-08-08 → 2025-08-01 |
| 1829 | SIT PPs E2E Sandbox Testing Execution | 2025-08-08 → 2025-08-01 (-7d) | 2025-10-24 → 2025-10-17 (-7d) |  |  | 564d → 569d |  |  |
| 1831 | **System Integration Testing - Tier 1 Milestones** | 2022-10-31 A → 2025-01-06 A (+798d) |  | 823d? → 253d? | 20% → 99% |  |  |  |
| 1832 | **M10 Checkpoint** | 2022-10-31 A → 2025-01-06 A (+798d) |  | 633d? → 63d? | 20% → 99% |  |  |  |
| 1833 | **M10 Readiness** |  | 2025-03-14 A |  | 58% → 100% | 724d → none |  |  |
| 1837 | Progress against the M10 Readiness Criteria | 2025-02-10 A | 2025-03-14 A |  | 0% → 100% | 724d → none |  |  |
| 1838 | **Downstream milestone feasibility assessment** | 2025-01-06 A | 2025-03-14 A |  | 0% → 100% | 711d → none |  |  |
| 1839 | Define guiding principles and approach to addressing points 1 - 3 | 2025-01-06 A | 2025-01-31 A |  | 0% → 100% | 721d → none |  |  |
| 1840 | Assess capacity within migration envelopes (Point 1 - Bringing M15 forwards) | 2025-01-20 A | 2025-02-14 A |  | 0% → 100% | 711d → none |  |  |
| 1841 | Review M16 process (Point 3 - Bringing M16 forwards) | 2025-01-20 A | 2025-02-21 A |  | 0% → 100% | 711d → none |  |  |
| 1842 | Develop M16 process review findings | 2025-02-24 A | 2025-03-07 A |  | 0% → 100% | 711d → none |  |  |
| 1843 | Agree M16 process review findings with Code Bodies | 2025-03-10 A | 2025-03-14 A |  | 0% → 100% | 711d → none |  |  |
| 1844 | Agree M16 process review findings with PAB | 2025-03-10 A | 2025-03-14 A |  | 0% → 100% | 711d → none |  |  |
| 1845 | Run PPIR with impacted parties (Point 2 - Bringing M14 forwards) | 2025-03-03 A | 2025-03-14 A |  | 0% → 100% | 711d → none |  |  |
| 1846 | **Checkpoint governance** | 2022-10-31 → 2025-03-05 A (+856d) |  | 633d? → 21d | 0% → 99% |  |  |  |
| 1847 | PSG Updated on progress | 2025-03-05 A | 2025-03-05 A |  | 0% → 100% | 732d → none | none → 1837SS |  |
| 1848 | Review final M10 Readiness outputs with IPA | 2025-03-17 A | 2025-03-21 A |  | 0% → 100% | 719d → none | 1843, 1844, 1845 → 1843, 1844, 1845, 1837 |  |
| 1849 | Review final M10 Readiness outputs with Ofgem | 2025-03-17 A | 2025-03-26 A |  | 0% → 100% | 711d → none | 1843, 1844, 1845 → 1843, 1844, 1845, 1837, 1848SS |  |
| 1850 | QAG paper day | 2022-10-31 → 2025-03-13 A (+864d) | 2022-10-31 → 2025-03-13 A (+864d) | 1d? → 0d | 0% → 100% | 1343d → none | none → 1837SS | constraint none → start no earlier than 2025-03-13; baseline start 2022-10-31 → 2025-03-13; baseline finish 2022-10-31 → 2025-03-13 |
| 1851 | QAG recommend M10 Checkpoint | 2022-10-31 → 2025-03-20 A (+871d) | 2022-10-31 → 2025-03-20 A (+871d) | 1d? → 0d | 0% → 100% | 1343d → none | none → 1850FS+6d | baseline start 2022-10-31 → 2025-03-20; baseline finish 2022-10-31 → 2025-03-20 |
| 1852 | MCAG paper day | 2022-10-31 → 2025-03-24 A (+875d) | 2022-10-31 → 2025-03-24 A (+875d) | 1d? → 0d | 0% → 100% | 1343d → none | none → 1837FS+6d | baseline start 2022-10-31 → 2025-03-24; baseline finish 2022-10-31 → 2025-03-24 |
| 1853 | MCAG recommend M10 Checkpoint | 2022-10-31 → 2025-04-01 (+883d) | 2022-10-31 → 2025-04-01 (+883d) | 1d? → 0d |  | 1343d → 712d | none → 1852FS+6d | baseline start 2022-10-31 → 2025-04-01; baseline finish 2022-10-31 → 2025-04-01 |
| 1855 | PSG M10 Checkpoint Meeting |  |  |  |  |  | 1854FS+5d → 1854FS+5d, 1853, 1851, 1848, 1849 |  |
| 1869 | **NON SIT LDSO QUALIFICATION** |  |  |  | 79% → 83% |  |  |  |
| 1929 | **Pre-Integration Testing** |  |  |  | 84% → 86% |  |  |  |
| 1934 | PIT Execution (Non-Functional and Operational) |  |  |  | 22% → 33% |  |  |  |
| 1964 | **Test Window** |  |  |  | 46% → 64% |  |  |  |
| 1965 | **All Non-SIT LDSOs Qualification Testing** |  |  |  | 51% → 70% |  |  |  |
| 1967 | LDSO Alpha |  |  |  | 53% → 79% |  |  |  |
| 1968 | LDSO Bravo |  | 2025-03-27 → 2025-05-05 (+39d) | 59d → 86d | 23% → 54% | 36d → 9d |  | constraint none → finish no earlier than 2025-05-05; baseline finish 2025-03-27 → 2025-05-05 |
| 1969 | LDSO Charlie |  |  |  | 51% → 92% |  |  |  |
| 1970 | LDSO Delta |  |  |  | 42% → 65% |  |  |  |
| 1971 | LDSO Echo |  | 2025-04-10 A |  | 82% → 100% | 26d → none |  |  |
| 1972 | LDSO Foxtrot | 2025-01-20 A | 2025-03-20 → 2025-05-15 (+56d) | 44d → 84d | 0% → 12% | 41d → 1d |  | constraint none → finish no earlier than 2025-05-15 |
| 1973 | LDSO Golf |  |  |  | 90% → 99% |  |  |  |
| 1974 | LDSO Hotel |  | 2025-03-07 → 2025-05-05 (+59d) | 45d → 86d | 60% → 59% | 50d → 9d |  | constraint none → finish no earlier than 2025-05-05; baseline finish 2025-03-07 → 2025-05-05 |
| 1975 | LDSO India |  |  |  | 46% → 77% |  |  |  |
| 1985 | **S & A QUALIFICATION** |  |  |  | 60% → 61% |  |  |  |
| 2047 | **MHHS Qualification - SIT Participants** |  | 2025-12-18 → 2025-12-17 (-1d) | 249d → 248d | 15% → 23% | 504d → 505d |  |  |
| 2050 | Code Bodies review Initial QAD |  |  |  | 10% → 64% |  |  |  |
| 2058 | **MHHS Qualification - SIT Non-MVC Participants** |  | 2025-12-18 → 2025-12-17 (-1d) | 154d → 153d |  | 504d → 505d |  |  |
| 2062 | QAD Sign Off Deadline (Non-MVC) | 2025-11-28 → 2025-11-27 (-1d) | 2025-11-28 → 2025-11-27 (-1d) |  |  | 504d → 505d |  |  |
| 2063 | REC Code Manager / BSC PAB Approval of Qualification (Non-MVC) | 2025-12-18 → 2025-12-17 (-1d) | 2025-12-18 → 2025-12-17 (-1d) |  |  | 504d → 505d |  |  |
| 2064 | **MHHS Qualification - Non-SIT LDSO** |  |  |  | 28% → 43% |  |  |  |
| 2068 | Code Bodies review of Non-SIT LDSO participants Initial QAD |  |  |  | 10% → 63% |  |  |  |
| 2115 | **Qualification Testing Framework (Test Stubs and Supporting UI)** |  |  |  | 91% → 92% |  |  |  |
| 2130 | **Environments** |  |  |  | 98% → 99% |  |  |  |
| 2148 | **QTF Deployment into Production** |  |  |  | 26% → 74% |  |  |  |

| ID | Task | Start | Finish | Duration | Complete | Total float | Predecessors | Other |
| --- | --- | --- | --- | --- | --- | --- | --- | --- |
| 2150 | Smoke Test | 2025-02-27 A | 2025-02-28 A |  | 0% → 100% | 722d → none |  |  |
| 2151 | PEN Test | 2025-03-03 A | 2025-03-04 A |  | 0% → 100% | 722d → none |  |  |
| 2152 | Regression Test | 2025-03-05 A |  |  | 0% → 50% |  |  |  |
| 2181 | **MPANs, DIP Messages, Settlement, Consumption, Reference** |  |  |  | 78% → 80% |  |  |  |
| 2241 | **Governance** |  |  |  | 92% → 97% |  |  |  |
| 2246 | BETA Testing 2 |  |  |  | 60% → 86% |  |  |  |
| 2383 | PAB290 | 2025-03-12 A | 2025-03-12 A |  | 0% → 100% | 727d → none |  |  |
| 2530 | **Releases** |  | 2025-12-24 → 2025-02-27 A (-300d) | 292d → 78d | 93% → 100% | 521d → none |  |  |
| 2544 | **Main Code Release** | 2025-09-17 → 2025-09-15 (-2d) |  | 71d → 73d |  |  |  |  |
| 2545 | Release preparation (e.g. preparing release documentation) | 2025-09-17 → 2025-09-15 (-2d) | 2025-09-24 → 2025-09-22 (-2d) |  |  | 586d → 588d |  |  |
| 2546 | Implement new code on day of code release | 2025-09-24 → 2025-09-22 (-2d) | 2025-09-24 → 2025-09-22 (-2d) |  |  | 586d → 588d |  |  |
| 2547 | Code changes delivered (M8) | 2025-09-24 → 2025-09-22 (-2d) | 2025-09-24 → 2025-09-22 (-2d) |  |  |  | 2527, 2506, 1857SS → 2527, 2506, 1857SS-3d, 2543 | constraint none → finish no earlier than 2025-09-22 |
| 2548 | Code changes delivered (M8*) late exit |  |  |  |  |  | 2547FS+65d → 2547FS+67d |  |
| 2553 | **MIGRATION** |  |  |  | 57% → 63% |  |  |  |
| 2557 | **Migration Framework Agreed and Implemented** |  |  |  | 88% → 93% |  |  |  |
| 2580 | **Consultation 4** |  |  |  | 46% → 67% |  |  |  |
| 2582 | Book MWG |  |  | 1d → 0d |  |  |  |  |
| 2584 | MWG paper day |  |  | 1d → 0d |  |  |  |  |
| 2585 | MWG recommend Consultation 4 content go for industry consultation | 2025-03-04 A | 2025-03-04 A |  | 0% → 100% | 732d → none |  | constraint finish no earlier than 2025-03-04 → none; baseline start 2025-03-04 → 2025-02-27; baseline finish 2025-03-04 → 2025-02-27 |
| 2586 | Industry Consultation | 2025-03-03 A | 2025-03-14 A |  | 0% → 100% | 694d → none |  | constraint start no earlier than 2025-03-03 → finish no earlier than 2025-03-14; baseline start 2025-03-03 → 2025-03-12; baseline finish 2025-03-14 → 2025-03-25 |
| 2587 | Comment responses by PPs | 2025-03-17 A |  |  | 0% → 20% |  |  | constraint start no earlier than 2025-03-17 → finish no earlier than 2025-03-28; baseline start 2025-03-17 → 2025-03-26; baseline finish 2025-03-28 → 2025-04-08 |
| 2588 | Respond to comments and issue artefacts |  |  |  |  |  |  | constraint start no earlier than 2025-03-31 → finish no earlier than 2025-04-11; baseline start none → 2025-03-31; baseline finish none → 2025-04-11 |
| 2589 | Assurance meeting |  |  |  |  |  |  | baseline start 2025-04-22 → 2025-04-09 |
| 2590 | MCAG paper day |  |  |  |  |  |  | constraint start no earlier than 2025-04-22 → finish no earlier than 2025-04-22; baseline start none → 2025-04-22; baseline finish none → 2025-04-22 |
| 2591 | MCAG Approval of Consultation 4 |  |  |  |  |  |  | constraint start no earlier than 2025-04-29 → finish no earlier than 2025-04-29 |
| 2592 | Framework Baselined at MCAG |  |  |  |  |  |  | constraint start no earlier than 2025-04-29 → finish no earlier than 2025-04-29 |
| 2599 | **Supplier Commission 2** | 2025-03-03 A |  |  | 0% → 52% |  |  |  |
| 2600 | Confirm / validate contacts for all Suppliers | 2025-03-03 A |  |  | 0% → 55% |  |  |  |
| 2613 | **MCC Stood up** | 2024-11-18 A |  |  | 0% → 30% |  |  |  |
| 2614 | Migration Planning Management Tool Delivery | 2024-11-18 A |  |  | 0% → 30% |  |  |  |
| 2633 | **PP's Prepared for Migration** |  |  |  | 23% → 47% |  |  |  |
| 2636 | Guides Creation | 2025-02-27 A |  |  | 0% → 31% |  |  | baseline start 2025-01-28 → 2025-02-27; baseline finish 2025-03-31 → 2025-04-30 |
| 2637 | Support Channels | 2025-02-27 A |  |  | 0% → 31% |  |  | baseline start 2025-01-28 → 2025-02-27; baseline finish 2025-03-31 → 2025-04-30 |
| 2638 | **Migration Artefact Development and Publication** |  |  |  | 76% → 89% |  |  |  |
| 2681 | **Data Cleanse Plan** |  |  |  | 63% → 83% |  |  |  |
| 2685 | Monitor Programme Participant adherence to Data Cleanse Plan |  |  |  | 80% → 97% |  |  |  |
| 2686 | **MTDs** |  |  |  | 23% → 55% |  |  |  |
| 2687 | **ESME ID** |  |  |  | 23% → 69% |  |  |  |
| 2691 | Suppliers complete Work Off plans |  |  |  | 10% → 64% |  |  | baseline start none → 2024-12-23; baseline finish none → 2025-05-16 |
| 2692 | ESME ID Complete |  |  |  |  |  |  | baseline start 2024-12-20 → 2025-05-16; baseline finish 2024-12-20 → 2025-05-16 |
| 2693 | **Meter Location and Number of Displayed Register Digits** |  |  |  | 24% → 43% |  |  |  |
| 2697 | Suppliers complete Work Off plans |  |  |  | 10% → 33% |  |  | baseline start none → 2025-01-29; baseline finish none → 2025-07-18 |
| 2698 | Meter Location and Number of Displayed Register Digits Complete |  |  |  |  |  |  | baseline start 2025-01-31 → 2025-07-18; baseline finish 2025-01-31 → 2025-07-18 |
| 2774 | **Cutover Governance M10** | 2025-09-10 → 2025-09-01 (-9d) |  | 11d → 17d |  |  |  |  |
| 2777 | Confirmation that Pre-migration Data Cleanse Activities have successfully taken place |  |  |  |  |  | none → 2776 |  |
| 2779 | Confirmation of Helix E2E Settlement Testing Complete |  |  |  |  | 7d → 5d | none → 2778 |  |
| 2786 | TORWG (Recommendation from TORWG that the Programme should enter M10) |  |  |  |  |  | 2777FS+1d, 2781FS+1d, 2783FS+1d, 2757FS+1d, 2758FS+1d, 2939FS+1d, 2779FS+1d, 2780FS+1d, 2782FS+1d, 2784, 2785 → 2777FS+1d, 2781FS+1d, 2783FS+3d, 2757FS+1d, 2758FS+1d, 2939FS+1d, 2779FS+3d, 2780FS+3d, 2782FS+3d, 2784, 2785 |  |
| 2795 | Confirmation of Qualified Parties from Code Bodies |  |  |  |  |  |  | baseline finish 2025-10-10 → 2025-10-14 |
| 2796 | Self-Declaration that MHHS Functionality will be deployed to Production by Qualified parties |  |  |  |  |  |  | baseline start 2025-10-10 → 2025-10-14; baseline finish 2025-10-10 → 2025-10-14 |
| 2797 | Production Service Activation Activities have taken place |  |  |  |  |  |  | baseline start 2025-10-10 → 2025-10-14; baseline finish 2025-10-10 → 2025-10-14 |
| 2798 | TORWG (Confirmation of Qualified Parties from TORWG) |  |  |  |  |  |  | baseline start 2025-10-13 → 2025-10-17; baseline finish 2025-10-13 → 2025-10-17 |
| 2799 | MCAG (Provide recommendation to PSG on M11 decision) |  |  |  |  |  |  | baseline start 2025-10-15 → 2025-10-20; baseline finish 2025-10-15 → 2025-10-20 |
| 2800 | PSG (OFGEM and PSG Decision to Confirm M11 and M12) |  |  |  |  |  |  | baseline start 2025-10-17 → 2025-10-22; baseline finish 2025-10-17 → 2025-10-22 |
| 2801 | **Migration Sprints** | 2025-05-06 → 2025-09-25 (+142d) |  | 522d → 420d |  |  |  |  |
| 2828 | Non-SIT Participants Migration Start |  |  | 1d → 0d |  |  | 2984 → 2984FS+1d | baseline start none → 2026-05-15; baseline finish none → 2026-05-15 |
| 2830 | **Migration Sprint 3** | 2025-05-06 → 2026-05-06 (+365d) | 2025-08-04 → 2026-08-04 (+365d) |  |  | 623d → 362d |  | baseline start 2025-05-06 → 2026-05-06; baseline finish 2025-08-04 → 2026-08-04 |
| 2831 | Sprint 3 Planning start date | 2025-05-06 → 2026-05-06 (+365d) | 2025-05-13 → 2026-05-13 (+365d) |  |  | 623d → 362d |  | constraint start no earlier than 2025-05-06 → start no earlier than 2026-05-06; baseline start 2025-05-06 → 2026-05-06; baseline finish 2025-05-13 → 2026-05-13 |
| 2832 | Issue Envelope | 2025-05-13 → 2026-05-13 (+365d) | 2025-05-13 → 2026-05-13 (+365d) |  |  | 623d → 362d |  | baseline start 2025-05-13 → 2026-05-13; baseline finish 2025-05-13 → 2026-05-13 |
| 2833 | Supplier Submission Deadline | 2025-05-20 → 2026-05-20 (+365d) | 2025-05-20 → 2026-05-20 (+365d) |  |  | 623d → 362d |  | baseline start 2025-05-20 → 2026-05-20; baseline finish 2025-05-20 → 2026-05-20 |
| 2834 | Baseline Schedule Publication | 2025-05-27 → 2026-05-27 (+365d) | 2025-05-27 → 2026-05-27 (+365d) |  |  | 623d → 362d |  | baseline start 2025-05-27 → 2026-05-27; baseline finish 2025-05-27 → 2026-05-27 |
| 2835 | Migration Sprint 3 Schedule Baselined | 2025-05-27 → 2026-05-27 (+365d) | 2025-05-27 → 2026-05-27 (+365d) |  |  | 623d → 362d |  | baseline start 2025-05-27 → 2026-05-27; baseline finish 2025-05-27 → 2026-05-27 |
| 2836 | Sprint Execution Start | 2025-06-03 → 2026-06-03 (+365d) | 2025-06-03 → 2026-06-03 (+365d) |  |  | 623d → 362d |  | baseline start 2025-06-03 → 2026-06-03; baseline finish 2025-06-03 → 2026-06-03 |
| 2837 | Sprint Execution | 2025-06-04 → 2026-06-04 (+365d) | 2025-08-04 → 2026-08-04 (+365d) |  |  | 623d → 362d |  | baseline start 2025-06-04 → 2026-06-04; baseline finish 2025-08-04 → 2026-08-04 |
| 2838 | Sprint Execution End | 2025-08-04 → 2026-08-04 (+365d) | 2025-08-04 → 2026-08-04 (+365d) |  |  | 623d → 362d |  | baseline start 2025-08-04 → 2026-08-04; baseline finish 2025-08-04 → 2026-08-04 |
| 2907 | **Service Management** |  |  |  | 41% → 42% |  |  |  |
| 2912 | **Early Life Support Model** |  |  |  | 97% → 99% |  |  |  |
| 2915 | Industry Consultation |  | 2025-03-07 A |  | 30% → 100% | 709d → none |  |  |
| 2922 | **Phase 1 - Preparation** |  | 2026-01-19 → 2026-01-16 (-3d) | 841d? → 840d? |  | 503d → 504d |  |  |
| 2957 | **SIT Non-MVC** |  | 2026-01-19 → 2026-01-16 (-3d) | 841d? → 840d? |  | 503d → 504d |  |  |
| 2961 | **SIT Non-MVC Service Activation Implementation** | 2025-12-19 → 2025-12-18 (-1d) | 2025-12-29 → 2025-12-26 (-3d) |  |  | 504d → 505d |  |  |

| ID | Task | Start | Finish | Total float | Predecessors |
| --- | --- | --- | --- | --- | --- |
| 2962 | Add EDF to DIP | 2025-12-19 → 2025-12-18 (-1d) | 2025-12-19 → 2025-12-18 (-1d) | 504d → 505d |  |
| 2963 | DIP Promoted to Production | 2025-12-22 → 2025-12-19 (-3d) | 2025-12-22 → 2025-12-19 (-3d) | 504d → 505d |  |
| 2964 | SIT non-MVC S&As Create Certificates and Test Connectivity | 2025-12-23 → 2025-12-22 (-1d) | 2025-12-23 → 2025-12-22 (-1d) | 522d → 523d |  |
| 2965 | Create M16 in Customer Solution | 2025-12-23 → 2025-12-22 (-1d) | 2025-12-24 → 2025-12-23 (-1d) | 504d → 505d |  |
| 2966 | Publish ISD | 2025-12-25 → 2025-12-24 (-1d) | 2025-12-26 → 2025-12-25 (-1d) | 504d → 505d |  |
| 2967 | SIT non-MVC S&As to update systems with ISD | 2025-12-29 → 2025-12-26 (-3d) | 2025-12-29 → 2025-12-26 (-3d) | 518d → 519d |  |
| 2968 | SIT Non-MVC Service Activation Implementation Complete | 2025-12-26 → 2025-12-25 (-1d) | 2025-12-26 → 2025-12-25 (-1d) | 519d → 520d |  |
| 2969 | **SIT Non-MVC Service Activation Implementation MDD** | 2025-12-29 → 2025-12-26 (-3d) | 2026-01-16 → 2026-01-15 (-1d) | 504d → 505d |  |
| 2970 | MDD Manual Load | 2025-12-29 → 2025-12-26 (-3d) | 2026-01-06 → 2026-01-05 (-1d) | 504d → 505d |  |
| 2971 | MDD Update | 2026-01-07 → 2026-01-06 (-1d) | 2026-01-16 → 2026-01-15 (-1d) | 504d → 505d |  |
| 2972 | SIT Non-MVC Service Activation Implementation MDD Complete | 2026-01-16 → 2026-01-15 (-1d) | 2026-01-16 → 2026-01-15 (-1d) | 504d → 505d |  |
| 2973 | **Non-SIT MVC Service Activation Hypercare** | 2025-12-19 → 2025-12-18 (-1d) | 2026-01-19 → 2026-01-16 (-3d) | 503d → 504d |  |
| 2974 | Service& Process Monitoring | 2025-12-19 → 2025-12-18 (-1d) | 2026-01-13 → 2026-01-12 (-1d) | 507d → 508d |  |
| 2975 | Daily Reporting | 2025-12-19 → 2025-12-18 (-1d) | 2026-01-13 → 2026-01-12 (-1d) | 507d → 508d |  |
| 2976 | Issue Management | 2025-12-19 → 2025-12-18 (-1d) | 2026-01-13 → 2026-01-12 (-1d) | 507d → 508d |  |
| 2977 | SA Hypercare Close Down Activities | 2025-12-19 → 2025-12-18 (-1d) | 2026-01-13 → 2026-01-12 (-1d) | 503d → 504d |  |
| 2978 | Handover to MHHSP | 2026-01-14 → 2026-01-13 (-1d) | 2026-01-19 → 2026-01-16 (-3d) | 503d → 504d |  |
| 2979 | Non-SIT MVC Service Activation Hypercare Complete (M) | 2026-01-19 → 2026-01-16 (-3d) | 2026-01-19 → 2026-01-16 (-3d) | 503d → 504d |  |
| 3114 | Central Parties BCDRs in Place |  |  |  | 2547FS-40d → 2547FS-38d |

## Version 4 (data date 2025-04-08, saved 2025-04-10, file MHHS-DEL1139 - MHHS Plan v6.221.mpp)

Last finish stays 2027-12-23. Complete tasks 1683 → 1735.

Added:

| ID | Task | Duration | Start | Finish | Predecessors | Constraint |
| --- | --- | --- | --- | --- | --- | --- |
| 1705 | SIT Operational Testing Execution Theme 1 | 70d | 2025-03-31 A | 2025-07-04 | 1703FS-1d | finish no earlier than 2025-07-04 |
| 1706 | SIT Operational Testing Execution Theme 2 | 45d | 2025-05-05 | 2025-07-04 | 1703 | finish no earlier than 2025-07-04 |
| 1707 | SIT Operational Testing Execution Theme 3 Batch 2 | 20d | 2025-06-09 | 2025-07-04 | 1703 | start no earlier than 2025-06-09 |
| 1860 | M10 Checkpoint 2 Complete | 0d | 2025-07-02 | 2025-07-02 |  | finish no earlier than 2025-07-02 |
| 1861 | **M10 Acceptance Criteria** | 358d | 2024-05-28 A | 2025-10-10 |  |  |
| 1862 | End of SIT MVC testing | 0d | 2025-08-22 | 2025-08-22 | 1719 | finish no earlier than 2025-08-22 |
| 1863 | IPA M10 Assurance Report developed and agreed | 0d | 2025-09-19 | 2025-09-19 |  | finish no earlier than 2025-09-19 |
| 1864 | Non-SIT LDSO Qualification Testing complete | 0d | 2025-05-16 | 2025-05-16 | 2013 | finish no earlier than 2025-05-16 |
| 1865 | A minimum of 1 supplier & required contracted agents are qualified and ready to operate under new MHHS arrangements | 0d | 2025-09-12 | 2025-09-12 |  | finish no earlier than 2025-09-12 |
| 1866 | All LDSOs qualified | 0d | 2025-09-10 | 2025-09-10 |  | finish no earlier than 2025-09-10 |
| 1867 | All pre-migration data cleanse activities complete | 0d | 2025-08-13 | 2025-08-13 |  | finish no earlier than 2025-08-13 |
| 1868 | All data migration activities set out in the cutover plan complete | 0d | 2025-09-24 | 2025-09-24 |  | finish no earlier than 2025-09-24 |
| 1869 | ISD fully populated by Elexon | 0d | 2025-09-22 | 2025-09-22 |  | finish no earlier than 2025-09-22 |
| 1870 | Significant Code Review Powers (SCR) enacted by Ofgem (M7) and updates to regulatory code ready to be implemented at M8 | 0d | 2024-12-11 A | 2024-12-11 A | 2564 | finish no earlier than 2024-12-11 |
| 1871 | Migration Schedule approved | 0d | 2025-08-19 | 2025-08-19 |  | finish no earlier than 2025-08-19 |
| 1872 | Migration Framework approved | 0d | 2025-04-30 | 2025-04-30 |  | finish no earlier than 2025-04-30 |
| 1873 | Migration Control Centre (MCC) delegation of authority approved | 0d | 2025-04-30 | 2025-04-30 |  | finish no earlier than 2025-04-30 |
| 1874 | Migration incentives implemented | 0d | 2025-04-30 | 2025-04-30 |  | finish no earlier than 2025-04-30 |
| 1875 | MCC tested and ready to operate | 0d | 2025-09-19 | 2025-09-19 |  | finish no earlier than 2025-09-19 |
| 1876 | Service Delivery Operating Model in place | 0d | 2025-09-19 | 2025-09-19 |  | finish no earlier than 2025-09-19 |
| 1877 | Service Delivery Operating Model in place (Self-Certification) | 0d | 2025-07-03 | 2025-07-03 |  | finish no earlier than 2025-07-03 |
| 1878 | Early Life Support Model defined | 0d | 2025-04-29 | 2025-04-29 | 2982 | finish no earlier than 2025-03-31 |
| 1879 | Early Life Support Model arrangements in place and operational | 0d | 2025-09-12 | 2025-09-12 |  | finish no earlier than 2025-09-12 |
| 1880 | Early Life Support Model arrangements in place and operational (Self-Certification) | 0d | 2025-09-12 | 2025-09-12 |  | finish no earlier than 2025-09-12 |
| 1881 | M10/M11 Cutover Plan in place | 0d | 2024-05-28 | 2024-05-28 |  | finish no earlier than 2024-05-28 |
| 1882 | Central Programme Party Cutover Plans in place | 0d | 2025-07-15 | 2025-07-15 |  | finish no earlier than 2025-07-15 |
| 1883 | Production environment in place for LDSOs and Central Parties | 0d | 2025-09-22 | 2025-09-22 |  | finish no earlier than 2025-09-22 |
| 1884 | Service activation complete to DIP Production environment for Central Parties and LDSOs | 0d | 2025-10-10 | 2025-10-10 |  | finish no earlier than 2025-10-10 |
| 1885 | Cutover Plan executed | 0d | 2025-09-23 | 2025-09-23 |  | finish no earlier than 2025-09-23 |
| 1886 | M10 Risk Assessment undertaken | 0d | 2025-09-03 | 2025-09-03 |  | finish no earlier than 2025-09-03 |
| 1887 | Roles and responsibilities post-M10 agreed and accepted | 0d | 2025-09-19 | 2025-09-19 |  | finish no earlier than 2025-09-19 |
| 1888 | M10 Work off plan agreed (if required) | 0d | 2025-09-19 | 2025-09-19 |  | finish no earlier than 2025-09-19 |
| 1889 | Qualification Operating Model in place and operational for all post-M10 activities | 0d | 2025-09-19 | 2025-09-19 |  | finish no earlier than 2025-09-19 |
| 1890 | Programme Governance updated to reflect required changes to support Programme delivery post-M10. | 0d | 2025-07-01 | 2025-07-01 |  | finish no earlier than 2025-07-01 |
| 1891 | All Suppliers and Agents have made the necessary changes to support losing an MPAN via the Forward Migration Process and gaining an MPAN via the Reverse Migration Process. | 0d | 2025-09-19 | 2025-09-19 |  | finish no earlier than 2025-09-19 |
| 1892 | Performance Assurance measures are understood and in place to maintain BAU performance during the Migration period. | 0d | 2025-09-12 | 2025-09-12 |  | finish no earlier than 2025-09-12 |
| 1893 | Programme monitoring, assurance and escalation process for beyond M10 is in place and operational | 0d | 2025-09-12 | 2025-09-12 |  | finish no earlier than 2025-09-12 |
| 2750 | **Connection Type and Meter Type Misalignments** | 433d | 2025-03-03 A | 2026-10-28 |  |  |
| 2751 | **Traditional Meters installed on Current Transformers** | 433d | 2025-03-03 A | 2026-10-28 |  |  |
| 2752 | Suppliers investigate all MPANs with Traditional Meters installed on a Current Transformer Connection Type | 65d | 2025-03-03 A | 2025-05-30 |  | finish no earlier than 2025-05-30 |
| 2753 | Suppliers to raise the relevant SDEP cases with LDSOs in pot 3 | 0d | 2025-05-30 | 2025-05-30 |  | finish no earlier than 2025-05-30 |
| 2754 | Suppliers to have ensured that Meter Operators have sent the necessary D0312s for MPANs in pot 2 | 21d | 2025-06-02 | 2025-06-30 | 2752 | start no earlier than 2025-06-02 |
| 2755 | LDSOs will be required to have corrected all of these Connection Types in pot 3 | 40d | 2025-06-02 | 2025-07-25 | 2753 | start no earlier than 2025-06-02 |
| 2756 | Suppliers to have completed meter exchanges for those MPANs in pot 1 | 368d | 2025-06-02 | 2026-10-28 | 2752 | start no earlier than 2025-06-02 |
| 2757 | Traditional Meters installed on Current Transformers complete | 0d | 2026-10-28 | 2026-10-28 | 2756 | finish no earlier than 2026-10-28 |
| 2758 | **CHECK Meters** | 66d | 2025-03-03 A | 2025-06-02 |  |  |
| 2759 | Suppliers and their appointed Meter Operator investigate MPANs within their portfolio that have incorrectly populated meters with the Meter Type CHECK within MPRS. Meter Operators are required to send a D0312 to remove the CHECK meter from MPRS. | 65d | 2025-03-03 A | 2025-05-30 |  | finish no earlier than 2025-05-30 |
| 2760 | Once CHECK meters are either removed from MPRS or the Meter Type is changed to a valid Meter Type, the LDSO should check that the Connection Type assigned to the MPAN is still valid. | 65d | 2025-03-03 | 2025-05-30 |  | finish no earlier than 2025-05-30 |
| 2761 | Suppliers confirm to the Programme that they have completed this activity | 0d | 2025-06-02 | 2025-06-02 | 2759 | finish no earlier than 2025-06-02 |
| 2762 | CHECK Meters complete | 0d | 2025-06-02 | 2025-06-02 | 2760 | finish no earlier than 2025-06-02 |
| 2763 | **Smart Meter Types installed on CT Connection Types** | 90d | 2025-03-21 A | 2025-07-25 |  |  |
| 2764 | Programme shares data via email with LDSOs and Suppliers on the total number of misalignments to inform work they will have to complete | 0d | 2025-03-21 A | 2025-03-21 A |  | finish no earlier than 2025-03-21 |
| 2765 | LDSOs investigate Connection Type misalignments and correct where appropriate | 50d | 2025-03-24 | 2025-05-30 | 2764 | finish no earlier than 2025-05-30 |
| 2766 | LDSOs raise SDEP queries with Suppliers where they believe there is an issue | 0d | 2025-05-30 | 2025-05-30 | 2765 | finish no earlier than 2025-05-30 |
| 2767 | Suppliers resolve all issues | 40d | 2025-06-02 | 2025-07-25 | 2766 | finish no earlier than 2025-07-25 |
| 2768 | Smart Meter Types installed on CT Connection Types complete | 0d | 2025-07-25 | 2025-07-25 | 2767 | finish no earlier than 2025-07-25 |
| 2769 | **Linked Import / Export MPANs** | 105d | 2025-03-03 A | 2025-07-25 |  |  |
| 2770 | LDSOs review and correct linked Import / Export MPANs with Different Connection Types | 105d | 2025-03-03 A | 2025-07-25 |  | finish no earlier than 2025-07-25 |
| 2771 | LDSOs, Import and Export Suppliers review and correct linked Import / Export MPANs with meters in the Advanced and Traditional or Smart Meter Groups | 105d | 2025-03-03 A | 2025-07-25 |  | finish no earlier than 2025-07-25 |
| 2772 | Linked Import / Export MPANs complete | 0d | 2025-07-25 | 2025-07-25 | 2770, 2771 | finish no earlier than 2025-07-25 |
| 2773 | **Related MPANs** | 105d | 2025-03-03 A | 2025-07-25 |  |  |
| 2774 | LDSOs review and correct related MPANs with different Connection Types | 80d | 2025-03-03 A | 2025-06-20 |  |  |
| 2775 | Suppliers unrelate any MPANs required | 25d | 2025-06-23 | 2025-07-25 | 2774 | finish no earlier than 2025-07-25 |
| 2776 | Suppliers should investigate Related MPANs within different meter groups and verify that they are correct or request that their Meter Operators update the Meter Types where they are incorrect | 105d | 2025-03-03 A | 2025-07-25 |  | start no earlier than 2025-03-03 |
| 2777 | Related MPANs complete | 0d | 2025-07-25 | 2025-07-25 | 2775, 2776 | finish no earlier than 2025-07-25 |

Changed:

| ID | Task | Start | Finish | Duration | Complete | Total float | Predecessors | Other |
| --- | --- | --- | --- | --- | --- | --- | --- | --- |
| 45 | **DESIGN, BUILD & TEST (PIT)** |  |  |  | 83% → 84% |  |  |  |
| 96 | **Design Artefact Releases** |  | 2025-04-23 A |  | 94% → 100% | 696d → none |  |  |
| 136 | **Interim release 8** |  | 2025-04-23 A |  | 80% → 100% | 696d → none |  |  |
| 162 | **Interim Release 8.9** |  | 2025-04-08 A |  | 58% → 100% | 707d → none |  |  |
| 165 | Interim Release 8.9 Deployed to SIT by Participants |  | 2025-04-08 A |  | 50% → 100% | 707d → none |  |  |
| 166 | **Interim Release 8.10** |  | 2025-04-23 A |  | 20% → 100% | 696d → none |  |  |
| 169 | Interim Release 8.10 Deployed to SIT by Participants | 2025-03-27 A | 2025-04-23 A |  | 0% → 100% | 696d → none |  |  |
| 187 | **PP Design, Build & Test (DBT)** |  |  |  | 74% → 75% |  |  |  |
| 327 | **SIT Participants DBT** |  |  |  | 80% → 85% |  |  |  |
| 362 | **All SIT Programme Participants PIT (SIT Functional)** |  |  |  | 62% → 70% |  |  |  |
| 396 | **All SIT Programme Participants PIT (SIT Non Functional)** |  |  |  | 63% → 76% |  |  |  |
| 397 | **Test Approach & Plan** |  | 2024-11-22 A |  | 0% → 100% | 799d → none |  |  |
| 399 | SIT Non-Functional Test approach and plan MHHS Review Completed |  | 2024-11-22 A |  | 0% → 100% | 799d → none |  |  |
| 402 | **Requirements to test Traceability Matrix (RTTM)** |  | 2024-11-29 A |  | 0% → 100% | 794d → none |  |  |
| 404 | SIT Non-Functional RTTM MHHS Review Completed | 2024-11-29 A | 2024-11-29 A |  | 0% → 100% | 794d → none |  |  |
| 405 | **Test Scenarios** |  | 2024-11-29 A |  | 0% → 100% | 794d → none |  |  |
| 407 | SIT Non-Functional Test scenarios MHHS Review Completed | 2024-11-29 A | 2024-11-29 A |  | 0% → 100% | 794d → none |  |  |
| 408 | **PIT execution** |  |  |  | 61% → 75% |  |  |  |
| 409 | PIT Test Execution Progress Report |  |  |  | 56% → 75% |  |  |  |
| 410 | PIT Execution |  |  |  | 66% → 75% |  |  |  |
| 414 | **SIT Programme Participants PIT (SIT Operational Theme 1, 2, 3 (Batch 2))** |  |  |  | 46% → 75% | 66d → 754d |  |  |
| 418 | **Test Readiness Report** |  |  |  | 42% → 75% | 0d → 12d |  |  |
| 419 | Test readiness reporting |  |  |  | 42% → 75% | 0d → 12d |  |  |
| 426 | **PIT execution** |  |  |  | 47% → 75% | 66d → 754d |  |  |
| 427 | PIT Test Execution Progress Report |  |  |  | 45% → 75% | 104d → 792d |  |  |
| 428 | PIT Execution |  |  |  | 49% → 75% | 66d → 754d |  |  |
| 502 | **DBT Progress Monitoring of Consequential Change** |  |  |  | 71% → 74% |  |  |  |
| 503 | Monitor & report data cleanse progress |  |  |  | 71% → 74% |  |  |  |
| 1100 | **SIT Non-Functional Preparation** |  | 2025-03-28 A |  | 99% → 100% | 714d → none |  |  |
| 1173 | **SIT Non-Functional Test Readiness Report** |  | 2025-03-28 A |  | 99% → 100% | 99d → none |  |  |
| 1183 | **SIT Non-Functional Overarching Test Readiness Report Theme 2 & 3** |  | 2025-03-28 A |  | 99% → 100% | 99d → none |  |  |
| 1191 | eSITAG approve Non-Functional Overarching Test Readiness Report Theme 2 & 3 | 2025-03-28 A | 2025-03-28 A |  | 0% → 100% | 99d → none |  |  |
| 1193 | SIT Non-Functional Testing Preparation Complete Theme 2 & 3 | 2025-03-28 A | 2025-03-28 A |  | 0% → 100% | 714d → none |  |  |
| 1194 | **SIT Operational Preparation** | 2022-10-31 A → 2022-10-31 |  |  |  |  |  |  |
| 1363 | **SIT Operational Programme RTTM (Theme 1, 2 & 3 (Batch 2))** |  |  |  | 92% → 97% |  |  |  |
| 1366 | DIP Manager / Code Bodies / Full SRO to review |  |  |  | 75% → 90% | 30d → 718d |  |  |
| 1367 | Incorporate feedback |  |  |  | 75% → 90% |  |  |  |
| 1376 | **SIT Operational Theme 1, 2 & 3 (Batch 2) DITL** |  | 2025-03-26 A |  | 99% → 100% | 28d → none |  |  |
| 1381 | Publish Cycle 3 DITL / Cycle 3 DITL Online Sessions for SIT PPs | 2025-03-26 A | 2025-03-26 A |  | 0% → 100% | 28d → none |  |  |
| 1402 | **SIT Operational Overarching Test Readiness Reports** |  |  |  | 99% → 100% |  |  |  |
| 1413 | **SI SIT Operational Theme 1, 2 and 3 (Batch 2) Overarching Test Readiness Report** |  | 2025-03-28 A |  | 99% → 100% | 25d → none |  |  |
| 1421 | eSITAG approve Operational Theme 1, 2 and 3 (Batch 2) Overarching Test Readiness Report | 2025-03-28 A | 2025-03-28 A |  | 0% → 100% | 25d → none |  |  |
| 1423 | SIT Operational Theme 1, 2, 3 (Batch 2) Testing Preparation Complete | 2025-03-28 A | 2025-03-28 A |  | 0% → 100% | 26d → none |  |  |
| 1424 | **Test Data - Non-Functional and Operational (SIT B)** |  | 2025-03-28 A |  | 82% → 100% | 714d → none |  |  |
| 1425 | **Data Load** |  | 2025-03-28 A |  | 82% → 100% | 714d → none |  |  |
| 1427 | Non-Functional Theme 2 & 3 (Helix, Avenade & PPs) Data Load |  | 2025-03-28 A |  | 40% → 100% | 6d → none |  |  |
| 1429 | Operational Themes 1, 2 & 3 (Batch 2) (LDSO's) Data Load |  | 2025-03-28 A |  | 85% → 100% | 25d → none |  |  |
| 1430 | Operational Themes 1, 2 & 3 (Batch 2) (Helix, Avenade & PPs) Data Load |  | 2025-03-28 A |  | 40% → 100% | 25d → none |  |  |
| 1431 | Non-Functional and Operational Test Data Preparation Complete | 2025-03-28 A | 2025-03-28 A |  | 0% → 100% | 714d → none |  |  |
| 1432 | **Regression Test Preparation** |  |  |  | 69% → 80% |  |  |  |
| 1445 | **Regression Core Test Pack** |  |  | 52d? → 51d? | 72% → 89% | 7d → 696d |  |  |
| 1453 | Industry review of Regression Core Pack |  | 2025-03-28 A |  | 70% → 100% | 7d → none |  |  |
| 1455 | Regression Test Framework Core Pack - Q&A Drop in session | 2025-03-27 A | 2025-03-27 A |  | 0% → 100% | 8d → none |  |  |
| 1456 | Incorporate Industry feedback into Regression Core Pack | 2025-03-31 A | 2025-04-02 A |  | 0% → 100% | 7d → none |  |  |
| 1457 | Second industry review of Regression Core Pack | 2025-04-03 A | 2025-04-09 A |  | 0% → 100% | 7d → none |  |  |
| 1459 | SITWG paper day | 2025-04-10 → 2025-04-08 A (-2d) | 2025-04-10 → 2025-04-08 A (-2d) |  | 0% → 100% | 7d → none | 1458 → none | was named eSITWG paper day; constraint none → finish no earlier than 2025-04-08 |
| 1460 | SITWG endorses regression Core Pack |  |  |  |  | 7d → 9d |  | was named eSITWG endorses regression Core Pack; constraint none → finish no earlier than 2025-04-15 |
| 1461 | Incorporate SITWG feedback into regression Core Pack |  |  |  |  | 7d → 700d |  | constraint none → start no earlier than 2025-04-16 |
| 1462 | Regression Test Approach and Plan Uplift |  |  | 1d? → 0d |  |  |  | constraint none → start no earlier than 2025-04-16 |
| 1463 | Industry Review on the Uplifted Test Approach and Plan |  | 2025-04-22 → 2025-04-23 (+1d) | 4d → 5d |  | 9d → 8d |  | constraint none → finish no earlier than 2025-04-23 |
| 1464 | SITAG paper day | 2025-04-17 → 2025-04-15 (-2d) | 2025-04-17 → 2025-04-15 (-2d) |  |  | 7d → 10d | 1461 → none | was named eSITAG paper day; constraint finish no earlier than 2025-04-09 → start no earlier than 2025-04-15 |
| 1465 | SITAG (inc SRO) Approval of regression Core Pack |  |  |  |  | 7d → 8d |  | was named eSITAG (inc SRO) Approval of regression Core Pack; constraint finish no earlier than 2025-04-16 → start no earlier than 2025-04-24 |
| 1467 | **Regression Test Data Load Window (SIT Functional and Migration) - SIT A** |  |  |  | 0% → 21% |  |  |  |
| 1468 | Data Load preparation activities | 2025-03-31 A |  |  | 0% → 35% |  |  |  |
| 1537 | **SIT - Minimum Viable Cohort (MVC)** |  |  |  | 58% → 57% |  |  |  |
| 1538 | **SIT Functional Testing (MVC)** |  |  |  | 67% → 71% |  |  |  |
| 1540 | **SIT Functional Testing Execution (Minimum Viable Cohort)** |  | 2025-04-28 A |  | 92% → 100% | 693d → none |  |  |
| 1550 | **Cycle 3 (Defect retests and targeted regression testing)** |  |  |  | 82% → 100% |  |  |  |
| 1561 | Sprint 14 (RTTM Gap Analysis + CR056) |  | 2025-03-28 A |  | 70% → 100% | 5d → none |  |  |
| 1562 | Sprint 15 (Contingency 1) | 2025-03-31 A | 2025-04-11 A |  | 0% → 100% | 5d → none |  |  |

| ID | Task | Start | Finish | Duration | Complete | Total float | Predecessors | Other |
| --- | --- | --- | --- | --- | --- | --- | --- | --- |
| 1563 | Sprint 16 (Contingency 2) | 2025-04-14 A | 2025-04-25 A |  | 0% → 100% | 5d → none |  |  |
| 1564 | SIT Functional Cycle 3 Complete | 2025-04-28 A | 2025-04-28 A |  | 0% → 100% | 693d → none |  |  |
| 1571 | SITWG paper day | 2025-04-08 A | 2025-04-08 A |  | 0% → 100% | 695d → none |  | constraint none → start no earlier than 2025-04-08 |
| 1646 | **SIT Migration Testing (MVC)** |  |  |  | 71% → 75% |  |  |  |
| 1648 | **SIT Migration Testing Execution (Minimum Viable Cohort)** |  |  |  | 71% → 75% |  |  |  |
| 1658 | **Cycle 3 (Defect retests and targeted regression testing)** |  |  |  | 83% → 96% |  |  |  |
| 1669 | Sprint 14 (RTTM Gap Analysis + CR056) |  | 2025-03-28 A |  | 70% → 100% | 5d → none |  |  |
| 1670 | Sprint 15 (Contingency 1) | 2025-03-31 A |  |  | 0% → 70% | 5d → 7d |  |  |
| 1671 | Sprint 16 (Contingency 2) | 2025-04-14 A |  |  | 0% → 70% |  |  |  |
| 1672 | SIT Migration Cycle 3 Complete | 2025-04-25 A |  |  | 0% → 70% |  |  |  |
| 1687 | **SIT Non-Functional Testing (all SIT PPs)** |  |  |  | 16% → 22% |  |  |  |
| 1690 | Theme 2 & 3 SIT Non-Functional Testing Start | 2025-03-31 A | 2025-03-31 A |  | 0% → 100% | 99d → none |  |  |
| 1691 | Theme 2 & 3 SIT Non-Functional Testing Execution | 2025-03-31 A |  |  | 0% → 15% |  |  |  |
| 1698 | **SIT Operational Testing (all SIT PPs)** |  |  |  | 17% → 11% |  |  |  |
| 1702 | **SIT B Testing** | 2025-03-31 A |  |  | 0% → 3% | 25d → 30d |  |  |
| 1703 | SIT Operational Testing Start (SIT B) | 2025-03-31 A | 2025-03-31 A |  | 0% → 100% | 25d → none |  |  |
| 1710 | SIT Operational Testing End (all SIT PPs) (incl. confirmation that PPs have submitted their Test Completion Reports to Programme for assurance) |  |  |  |  |  | 1709FS+5d, 1701 → 1709FS+5d, 1701, 1705, 1706, 1707 |  |
| 1743 | **Test Artefact Development** |  |  |  | 66% → 73% |  |  |  |
| 1756 | **E2E Sandbox Test Data Approach & Plan** |  |  | 68d? → 68d | 0% → 22% |  |  |  |
| 1758 | Create PPIR to request PP responses on subject to gather views | 2025-03-10 A | 2025-03-14 A |  | 0% → 100% | 709d → none |  |  |
| 1759 | PPIR shared to industry | 2025-03-24 A | 2025-04-04 → 2025-04-03 A (-1d) | 10d → 9d | 0% → 100% | 704d → none |  | baseline start 2025-03-17 → 2025-03-24; baseline finish 2025-03-28 → 2025-04-03 |
| 1760 | Evaluate PPIR responses | 2025-04-07 → 2025-04-04 A (-3d) | 2025-04-11 → 2025-04-07 A (-4d) | 5d → 2d | 0% → 100% | 704d → none | 1759 → none | constraint none → start no earlier than 2025-04-04; baseline start 2025-03-31 → 2025-04-04; baseline finish 2025-04-04 → 2025-04-07 |
| 1761 | Discuss PPIR results at QWG |  |  | 1d? → 1d |  |  |  |  |
| 1830 | **SIT PPs Early Sandbox Testing Execution (SIT-A)** | 2022-10-31 → 2025-08-11 (+1015d) | 2025-10-17 → 2025-10-24 (+7d) | 775d? → 55d |  | 569d → 564d |  |  |
| 1831 | SIT PPs E2E Sandbox Testing Start | 2025-08-01 → 2025-08-11 (+10d) | 2025-08-01 → 2025-08-11 (+10d) |  |  | 624d → 618d | 1825FS+5d, 1606 → 1825FS+5d, 1607 | constraint start no earlier than 2025-02-10 → finish no earlier than 2025-08-11; baseline start 2025-08-01 → 2025-08-11; baseline finish 2025-08-01 → 2025-08-11 |
| 1832 | SIT PPs E2E Sandbox Testing Execution | 2025-08-01 → 2025-08-11 (+10d) | 2025-10-17 → 2025-10-24 (+7d) | 56d → 55d |  | 569d → 564d |  |  |
| 1833 | SIT PPs E2E Sandbox Testing End | 2022-10-31 → 2025-10-24 (+1089d) | 2022-10-31 → 2025-10-24 (+1089d) | 1d? → 0d |  | 1343d → 564d | none → 1832 | baseline start none → 2025-10-24; baseline finish none → 2025-10-24 |
| 1834 | **System Integration Testing - Tier 1 Milestones** | 2025-01-06 A → 2024-05-28 A (-223d) |  | 253d? → 411d? |  |  |  |  |
| 1835 | **M10 Checkpoint 1** |  | 2025-04-02 A |  | 99% → 100% | 711d → none |  | was named M10 Checkpoint |
| 1849 | **Checkpoint governance** |  | 2025-04-02 A |  | 99% → 100% | 711d → none |  |  |
| 1856 | MCAG recommend M10 Checkpoint | 2025-04-01 A | 2025-04-01 A |  | 0% → 100% | 712d → none |  |  |
| 1857 | PSG paper day | 2025-03-26 A | 2025-03-26 A |  | 0% → 100% | 711d → none |  |  |
| 1858 | PSG M10 Checkpoint Meeting | 2025-04-02 A | 2025-04-02 A |  | 0% → 100% | 711d → none |  |  |
| 1859 | M10 Checkpoint 1 complete | 2025-04-02 A | 2025-04-02 A |  | 0% → 100% | 711d → none |  | was named M10 Checkpoint complete |
| 1906 | **NON SIT LDSO QUALIFICATION** |  |  |  | 83% → 87% |  |  |  |
| 2001 | **Test Window** |  |  |  | 64% → 77% |  |  |  |
| 2002 | **All Non-SIT LDSOs Qualification Testing** |  |  |  | 70% → 84% |  |  |  |
| 2004 | LDSO Alpha |  |  |  | 79% → 85% |  |  |  |
| 2005 | LDSO Bravo |  |  |  | 54% → 85% |  |  |  |
| 2006 | LDSO Charlie |  | 2025-05-07 A |  | 92% → 100% | 7d → none |  |  |
| 2007 | LDSO Delta |  |  |  | 65% → 74% |  |  |  |
| 2009 | LDSO Foxtrot |  |  |  | 12% → 40% |  |  | baseline finish 2025-03-20 → 2025-05-15 |
| 2010 | LDSO Golf |  | 2025-04-07 → 2025-04-25 (+18d) | 66d → 80d |  | 29d → 15d |  | constraint none → finish no earlier than 2025-04-25; baseline finish 2025-04-07 → 2025-04-25 |
| 2011 | LDSO Hotel |  |  |  | 59% → 91% |  |  |  |
| 2012 | LDSO India |  |  |  | 77% → 84% |  |  |  |
| 2022 | **S & A QUALIFICATION** |  |  |  | 61% → 62% |  |  |  |
| 2084 | **MHHS Qualification - SIT Participants** |  |  |  | 23% → 30% |  |  |  |
| 2087 | Code Bodies review Initial QAD |  | 2025-04-04 A |  | 64% → 100% | 60d → none |  |  |
| 2088 | Completion of Code Bodies review of Initial QAD | 2025-04-04 A | 2025-04-04 A |  | 0% → 100% | 60d → none |  |  |
| 2089 | **MHHS Qualification - SIT MVC Participants** | 2025-04-07 A |  |  | 0% → 4% |  |  |  |
| 2090 | Final QAD Submission Window (MVC) opens | 2025-04-07 A | 2025-04-07 A |  | 0% → 100% | 60d → none |  |  |
| 2091 | SIT MVC Participants submit Final QAD (exc Test Reports) | 2025-04-07 A |  |  | 0% → 8% |  |  |  |
| 2096 | Final QAD Submission Window (Non-MVC) opens |  |  |  |  |  |  | constraint none → start no earlier than 2025-04-07 |
| 2101 | **MHHS Qualification - Non-SIT LDSO** |  |  |  | 43% → 56% |  |  |  |
| 2105 | Code Bodies review of Non-SIT LDSO participants Initial QAD |  | 2025-04-04 A |  | 63% → 100% | 83d → none |  |  |
| 2106 | Completion of Code Bodies review of Initial QAD | 2025-04-04 A | 2025-04-04 A |  | 0% → 100% | 83d → none |  |  |
| 2107 | Final QAD Submission window opens | 2025-04-07 A | 2025-04-07 A |  | 0% → 100% | 83d → none |  |  |
| 2108 | Non-SIT LDSO Participants submit Final QAD | 2025-04-07 A |  |  | 0% → 6% |  |  |  |
| 2114 | **Qualification Wave Prep** |  |  |  | 93% → 94% |  |  |  |
| 2152 | **Qualification Testing Framework (Test Stubs and Supporting UI)** |  |  |  | 92% → 93% |  |  |  |
| 2167 | **Environments** |  |  |  | 99% → 100% | 625d → none |  |  |
| 2185 | **QTF Deployment into Production** |  | 2025-03-18 A |  | 74% → 100% | 722d → none |  |  |
| 2189 | Regression Test |  | 2025-03-18 A |  | 50% → 100% | 722d → none |  |  |
| 2218 | **MPANs, DIP Messages, Settlement, Consumption, Reference** |  |  |  | 80% → 81% |  |  |  |
| 2278 | **Governance** |  | 2025-03-28 A |  | 97% → 100% | 714d → none |  |  |
| 2283 | BETA Testing 2 |  | 2025-03-28 A |  | 86% → 100% | 714d → none |  |  |
| 2284 | Qualification Testing Framework Readiness Confirmed | 2025-03-28 A | 2025-03-28 A |  | 0% → 100% | 714d → none |  |  |
| 2421 | PAB291 | 2025-03-27 A | 2025-03-27 A |  | 0% → 100% | 716d → none |  |  |
| 2584 | Code changes delivered (M8) |  |  |  |  |  |  | baseline start 2025-09-24 → 2025-09-22; baseline finish 2025-09-24 → 2025-09-22 |
| 2590 | **MIGRATION** |  |  |  | 63% → 55% |  |  |  |

| ID | Task | Start | Finish | Duration | Complete | Total float | Predecessors | Other |
| --- | --- | --- | --- | --- | --- | --- | --- | --- |
| 2594 | **Migration Framework Agreed and Implemented** |  |  |  | 93% → 99% |  |  |  |
| 2617 | **Consultation 4** |  |  |  | 67% → 94% |  |  |  |
| 2624 | Comment responses by PPs |  | 2025-03-28 A |  | 20% → 100% | 694d → none |  |  |
| 2625 | Respond to comments and issue artefacts | 2025-03-31 A |  |  | 0% → 70% |  |  |  |
| 2633 | **V1.0 of Migration Schedule Baseline** | 2025-04-01 A |  |  |  |  |  |  |
| 2634 | Confirm Supplier Migration start dates, MPID groups (SIT & NonSIT) | 2025-04-01 A | 2025-04-01 A |  | 0% → 100% | 632d → none |  |  |
| 2636 | **Supplier Commission 2** |  |  |  | 52% → 96% |  |  |  |
| 2637 | Confirm / validate contacts for all Suppliers |  | 2025-04-01 A |  | 55% → 100% | 632d → none |  |  |
| 2675 | **Migration Artefact Development and Publication** |  | 2025-10-15 → 2026-10-28 (+378d) | 773d → 1043d | 89% → 55% | 571d → 301d |  |  |
| 2718 | **Data Cleanse Plan** |  |  |  | 83% → 87% |  |  |  |
| 2722 | Monitor Programme Participant adherence to Data Cleanse Plan |  | 2025-03-28 A |  | 97% → 100% | 714d → none |  |  |
| 2723 | **MTDs** |  |  |  | 55% → 62% |  |  |  |
| 2724 | **ESME ID** |  |  |  | 69% → 77% |  |  |  |
| 2728 | Suppliers complete Work Off plans |  |  |  | 64% → 73% |  |  |  |
| 2730 | **Meter Location and Number of Displayed Register Digits** |  |  |  | 43% → 50% |  |  |  |
| 2734 | Suppliers complete Work Off plans |  |  |  | 33% → 41% |  |  |  |
| 2745 | **Domestic Premises Indicator** | 2025-09-19 → 2025-09-05 (-14d) |  | 19d → 29d |  |  |  |  |
| 2746 | The DCC to extract Domestic Premises Indicator from the CSS and provide a file to each LDSO and EES. | 2025-09-19 → 2025-09-05 (-14d) | 2025-09-22 → 2025-09-08 (-14d) |  |  | 571d → 597d | 1894FS-4d → 1894FS-14d | constraint start no earlier than 2025-08-08 → start no earlier than 2025-09-05; baseline start 2025-09-19 → 2025-09-05; baseline finish 2025-09-22 → 2025-09-08 |
| 2747 | Each LDSO notifies the MHHS Programme SI of any exceptions which have occurred because of the data load and the reason for that exception | 2025-09-23 → 2025-09-24 (+1d) | 2025-09-23 → 2025-09-24 (+1d) |  |  | 571d → 586d |  | was named Each LDSO notifies the DCC of any exceptions; constraint none → start no earlier than 2025-09-24; baseline start 2025-09-23 → 2025-09-24; baseline finish 2025-09-23 → 2025-09-24 |
| 2748 | Each LDSO and DCC completes investigation and resolution of exceptions |  |  |  |  |  | 2746FS+15d, 2747FS+15d → none | constraint none → start no earlier than 2025-10-15 |
| 2749 | Domestic Premises Indicator Complete | 2025-10-15 → 2025-09-24 (-21d) | 2025-10-15 → 2025-09-24 (-21d) |  |  | 571d → 586d | 2748 → 2747 | constraint none → finish no earlier than 2025-09-24; baseline start 2025-10-15 → 2025-09-24; baseline finish 2025-10-15 → 2025-09-24 |
| 2778 | **Export / Import MPANs** |  | 2024-10-18 A → 2025-08-13 (+299d) | 151d → 363d | 100% → 99% | none → 617d |  |  |
| 2981 | Assurance Meeting | 2025-04-03 A | 2025-04-03 A |  | 0% → 100% | 700d → none |  | baseline start 2024-07-16 → 2025-04-03; baseline finish 2024-07-16 → 2025-04-03 |
| 2982 | MCAG Approval of Early Life Support Model |  |  |  |  |  |  | baseline start 2024-07-30 → 2025-04-29; baseline finish 2024-07-30 → 2025-04-29 |
| 3307 | **MILESTONE RANGE CHECKPOINTS** | 2022-10-31 → 2025-07-31 (+1004d) |  | 1160d? → 442d |  |  |  |  |
| 3314 | **M16 milestone checkpoint** | 2022-10-31 → 2027-04-12 (+1624d) |  | 1160d? → 0d |  |  |  |  |

## Version 5 (data date 2025-05-21, saved 2025-05-22, file MHHS-DEL1139 - MHHS Plan v6.251.mpp)

Last finish stays 2027-12-23. Complete tasks 1735 → 1840.

Added:

| ID | Task | Duration | Start | Finish | Predecessors | Constraint |
| --- | --- | --- | --- | --- | --- | --- |
| 1611 | Programme drafts Functional & Migration PP Exit Report | 20d | 2025-04-28 A | 2025-05-23 | 1564 |  |
| 1612 | SRO Review PP Exit Reports | 2d | 2025-05-22 | 2025-05-23 | 1611SS | start no earlier than 2025-05-22 |
| 1613 | Functional & Migration PP Exit Reports shared with PPs | 0d | 2025-05-23 | 2025-05-23 | 1612 | finish no earlier than 2025-05-23 |
| 1614 | PPs complete and return Exit Reports | 10d | 2025-05-26 | 2025-06-06 | 1613 | start no earlier than 2025-05-26 |
| 1615 | PPs Exit Report submission deadline | 0d | 2025-06-06 | 2025-06-06 | 1614 | start no earlier than 2025-06-06 |
| 1616 | Programme drafts SI SIT Functional & Migration Overarching Exit Report | 13d | 2025-05-26 | 2025-06-11 | 1613, 1615FF | start no earlier than 2025-05-26 |
| 1617 | SITWG Review status of SI SIT Functional & Migration Overarching Exit Report | 0d | 2025-06-05 | 2025-06-05 | 1616SS | start no earlier than 2025-06-05 |
| 1618 | SRO Review SI SIT Functional & Migration Overarching Exit Report | 5d | 2025-06-02 | 2025-06-06 | 1616SS | start no earlier than 2025-06-02 |
| 1619 | SITAG endorses the SI SIT Functional & Migration Overarching Test Exit Report | 0d | 2025-06-18 | 2025-06-18 | 1616FS+3d, 1617 | finish no earlier than 2025-06-18 |
| 1620 | **SIT Settlement and Regression Test Exit Report** | 38d | 2025-06-30 | 2025-08-20 |  |  |
| 1621 | Programme drafts Settlement and Regression PP Exit Reports (when Participant completes Regression testing) | 30d | 2025-06-30 | 2025-08-08 | 1604SS | start no earlier than 2025-06-30 |
| 1622 | All Settlement and Regression PP Exit Reports shared with PPs | 0d | 2025-08-08 | 2025-08-08 | 1621 |  |
| 1623 | PPs complete and return Exit Reports | 25d | 2025-07-07 | 2025-08-08 | 1621SS, 1710SS | start no earlier than 2025-07-07 |
| 1624 | PPs Exit Report and Regression Exit Decleration submission deadline | 0d | 2025-08-08 | 2025-08-08 | 1623 | finish no earlier than 2025-08-08 |
| 1625 | Programme drafts SI SIT Settlement and Regression Overarching Exit Report | 25d | 2025-07-07 | 2025-08-08 | 1623SS, 1712SS |  |
| 1626 | SRO Review SI SIT Settlement and Regression Overarching Exit Report | 5d | 2025-08-04 | 2025-08-08 | 1625SS | start no earlier than 2025-08-04 |
| 1627 | SITWG Review status of SI SIT Settlement and Regression Overarching Exit Report | 0d | 2025-08-12 | 2025-08-12 | 1625 | finish no earlier than 2025-08-12 |
| 1631 | SITAG Approves SI SIT Functional & Migration (Post-Regression) Overarching Test Exit Report | 0d | 2025-08-20 | 2025-08-20 | 1629FF, 1625, 1627, 1607 | finish no earlier than 2025-08-20 |
| 1700 | Programme drafts Functional & Migration PP Exit Report | 20d | 2025-04-28 A | 2025-05-23 | 1690 | finish no earlier than 2025-05-16 |
| 1701 | SRO Review PP Exit Reports | 2d | 2025-05-22 | 2025-05-23 | 1700SS | start no earlier than 2025-05-22 |
| 1702 | Functional & Migration PP Exit Reports shared with PPs | 0d | 2025-05-23 | 2025-05-23 | 1701 | start no earlier than 2025-05-16 |
| 1703 | PPs complete and return Exit Reports | 10d | 2025-05-26 | 2025-06-06 | 1702 | finish no earlier than 2025-05-30 |
| 1704 | PPs Exit Report submission deadline | 0d | 2025-06-06 | 2025-06-06 | 1703 | start no earlier than 2025-05-30 |
| 1705 | Programme drafts SI SIT Functional & Migration Overarching Exit Report | 13d | 2025-05-26 | 2025-06-11 | 1702, 1703FF | start no earlier than 2025-05-26 |
| 1706 | SITWG Review status of Functional & Migration Overarching Completion Report | 0d | 2025-06-05 | 2025-06-05 | 1705SS | start no earlier than 2025-06-05 |
| 1707 | SRO Review SI SIT Functional & Migration Overarching Exit Report | 5d | 2025-06-02 | 2025-06-06 | 1705SS | finish no earlier than 2025-06-06 |
| 1708 | SITAG endorses the SI SIT Functional & Migration Overarching Test Exit Report | 0d | 2025-06-18 | 2025-06-18 | 1705FS+3d, 1706 | finish no earlier than 2025-06-18 |
| 1709 | **SIT Settlement and Regression Test Exit Report** | 43d | 2025-06-30 | 2025-08-27 |  |  |
| 1710 | Programme drafts Settlement and Regression PP Exit Report (when Participant completes Regression testing) | 30d | 2025-06-30 | 2025-08-08 | 1694SS | finish no earlier than 2025-08-08 |
| 1711 | All Settlement and Regression PP Exit Reports shared with PPs | 0d | 2025-08-08 | 2025-08-08 | 1710 | start no earlier than 2025-08-08 |
| 1712 | PPs complete and return PP Exit Reports | 25d | 2025-07-07 | 2025-08-08 | 1710SS | start no earlier than 2025-07-07 |
| 1713 | PPs Exit Report and Regression Exit Deceleration submission deadline | 0d | 2025-08-08 | 2025-08-08 | 1712 | finish no earlier than 2025-08-08 |
| 1714 | Programme drafts SI SIT Settlement and Regression Overarching Exit Report | 25d | 2025-07-07 | 2025-08-08 | 1712SS | start no earlier than 2025-07-07 |
| 1715 | SRO Review SI SIT Settlement and Regression Overarching Exit Report | 5d | 2025-08-04 | 2025-08-08 | 1714SS | start no earlier than 2025-08-04 |
| 1716 | SITWG Review status of SI SIT Settlement and Regression Overarching Exit Report | 0d | 2025-08-12 | 2025-08-12 |  | finish no earlier than 2025-08-12 |
| 1721 | SITAG Approves SI SIT Functional & Migration (Post-Regression) Overarching Test Exit Report | 0d | 2025-08-20 | 2025-08-20 | 1717FF, 1714 | finish no earlier than 2025-08-20 |
| 1731 | Programme drafts Non-Functional PP Exit Report | 15d | 2025-05-26 | 2025-06-13 | 1728 |  |
| 1732 | Non-Functional PP Exit Reports shared with PPs | 0d | 2025-06-13 | 2025-06-13 | 1731 | start no earlier than 2025-06-09 |
| 1733 | PPs complete and return PP Exit Reports | 10d | 2025-06-16 | 2025-06-27 | 1731SS | finish no earlier than 2025-06-27 |
| 1734 | PPs Exit Report submission deadline | 0d | 2025-06-27 | 2025-06-27 | 1733 |  |
| 1735 | Programme drafts SI SIT Non-Functional Overarching Exit Report | 15d | 2025-06-16 | 2025-07-04 | 1733SS | start no earlier than 2025-06-16 |
| 1736 | SRO Review SI SIT Non-Functional Overarching Exit Report | 5d | 2025-06-23 | 2025-06-27 | 1735SS | start no earlier than 2025-06-23 |
| 1737 | SITWG Review status of SI SIT Non-Functional Overarching Exit Report | 0d | 2025-07-03 | 2025-07-03 |  | start no earlier than 2025-07-03 |
| 1741 | SITAG Approves SI SIT Non-Functional Overarching Test Exit Report | 0d | 2025-07-16 | 2025-07-16 | 1739FF+5d, 1735FS+3d | start no earlier than 2025-07-16 |
| 1751 | **SIT Operational Testing Re-test Theme 3 (Batch 1)** | 30d | 2025-05-05 A | 2025-06-13 |  |  |
| 1752 | SRO Review of re-testing approach | 10d | 2025-05-05 A | 2025-05-16 A |  | start no earlier than 2025-05-05 |
| 1753 | Scripts uploaded to ADO / Project Created | 5d | 2025-05-19 A | 2025-05-23 | 1752 |  |
| 1754 | SIT Operational Testing Re-test Execution Theme 3 (Batch 1) | 5d | 2025-06-09 | 2025-06-13 | 1753 | start no earlier than 2025-06-09 |
| 1758 | Programme drafts PP Exit Report (when Participant completes Operational testing) | 30d | 2025-06-02 | 2025-07-11 | 1748SS | start no earlier than 2025-06-02 |
| 1759 | All Operational Completion PP Exit Reports have been shared with PPs | 0d | 2025-07-11 | 2025-07-11 | 1758 |  |
| 1760 | PPs complete and return PP Exit Reports | 31d | 2025-06-13 | 2025-07-25 | 1758SS | start no earlier than 2025-06-13 |
| 1761 | PPs Exit Report submission deadline | 0d | 2025-07-25 | 2025-07-25 | 1760 |  |
| 1762 | Programme drafts SI SIT Operational Overarching Exit Report | 30d | 2025-06-23 | 2025-08-01 | 1760SS | start no earlier than 2025-06-23 |
| 1763 | SITWG Review status of SI SIT Operational Overarching Exit Report | 0d | 2025-07-03 | 2025-07-03 |  | start no earlier than 2025-07-03 |
| 1764 | SRO Review SI SIT Operational Overarching Exit Report | 5d | 2025-07-21 | 2025-07-25 | 1762SS | start no earlier than 2025-07-21 |
| 1768 | SITAG Approves SI SIT Operational Testing Test Exit Report | 0d | 2025-08-06 | 2025-08-06 | 1766FF+5d, 1762FS+3d | start no earlier than 2025-08-06 |
| 1881 | **Sandbox Testing Execution (UIT) - LDSO Participants** | 169d | 2025-06-02 | 2026-01-22 |  |  |
| 1882 | Sandbox Testing Start (UIT) - LDSO Participants | 0d | 2025-06-02 | 2025-06-02 | 1876 | finish no earlier than 2025-06-02 |
| 1883 | Sandbox Testing Execution (UIT) - LDSO Participants | 169d | 2025-06-02 | 2026-01-22 | 1882SS-1d | start no earlier than 2024-11-04 |
| 1884 | Sandbox Testing End (UIT) - LDSO Participants | 0d | 2026-01-22 | 2026-01-22 | 1883 |  |
| 2075 | Non-SIT LDSO Regression Testing | 26d | 2025-05-16 | 2025-06-20 | 2072 |  |
| 2077 | **SERVICE MANAGEMENT** | 130d | 2025-03-03 A | 2025-09-01 |  |  |
| 2078 | **Stage 2 - M10 Readiness** | 130d | 2025-03-03 A | 2025-09-01 |  |  |
| 2079 | **Service Model Design (Cross Party Service Desk)** | 105d | 2025-03-03 A | 2025-07-25 |  |  |
| 2080 | **Cross Party Service Desk** | 55d | 2025-03-03 A | 2025-05-19 |  |  |
| 2081 | Cross Party Service Desk Definition and Design | 24d | 2025-03-03 A | 2025-04-03 A |  |  |
| 2082 | Cross Party Service Desk Design Document MHHS Review | 0d | 2025-04-03 A | 2025-04-03 A | 2081 | start no earlier than 2025-04-03 |
| 2083 | Cross Party Service Desk Model Issued | 0d | 2025-04-07 A | 2025-04-07 A | 2082 | start no earlier than 2025-04-07 |
| 2084 | Cross Party Service Desk Model Reissued | 0d | 2025-04-15 A | 2025-04-15 A | 2083 | start no earlier than 2025-04-15 |
| 2085 | **Cross Party Service Desk Consultation** | 30d | 2025-04-07 A | 2025-05-19 |  |  |
| 2086 | Cross Party Service Desk Consultation | 16d | 2025-04-07 A | 2025-04-28 A | 2082, 2084FF | finish no earlier than 2025-04-28 |
| 2087 | Cross Party Service Desk Consultation Completed | 0d | 2025-04-28 A | 2025-04-28 A | 2086 | start no earlier than 2025-03-28 |
| 2088 | Cross Party Service Desk Model Updates (Feedback Review) | 8d | 2025-04-29 A | 2025-05-08 A | 2087 | start no earlier than 2025-04-23 |
| 2089 | Cross Party Service Desk Model Spotlight at Elexon Service Management Steering Group | 0d | 2025-05-07 A | 2025-05-07 A | 2088FF-1d | start no earlier than 2025-05-07 |
| 2090 | Updated Consultation Documents Shared with MHHS and Industry | 0d | 2025-05-08 A | 2025-05-08 A | 2088 | start no earlier than 2025-04-14 |
| 2091 | TORWG Post-Consultation Update (CPSD) | 0d | 2025-05-14 | 2025-05-14 | 2090 | start no earlier than 2025-05-14 |
| 2092 | Updated Consultation Documents Released to Industry for eTORWG | 0d | 2025-05-16 | 2025-05-16 | 2091FS+3d |  |
| 2093 | CPSD, Operating Hours & Triage Updates Endorsement (eTORWG) | 0d | 2025-05-19 | 2025-05-19 | 2092 | start no earlier than 2025-05-19 |
| 2094 | Cross Party Service Desk Model Completed | 0d | 2025-05-19 | 2025-05-19 | 2093 | start no earlier than 2025-03-28 |
| 2095 | **Service Documentation** | 64d | 2025-04-29 A | 2025-07-25 |  |  |
| 2096 | Operations Manual and LLSD Updates Post-Consultation | 13d | 2025-04-29 A | 2025-05-15 | 2087 | start no earlier than 2025-04-23 |
| 2097 | Service User LLSD Version 1.2 | 0d | 2025-05-15 | 2025-05-15 | 2096 |  |
| 2098 | Operations Manual Version 1.3 | 0d | 2025-05-15 A | 2025-05-15 A | 2096 |  |
| 2099 | Post-ORT Operations Manual and LLSD Updates | 10d | 2025-07-14 | 2025-07-25 | 2097, 2098 | start no earlier than 2025-07-14 |
| 2100 | M10 Operations Manual Version 2.0 & LLSD ORT Learning | 0d | 2025-07-25 | 2025-07-25 | 2099 | start no earlier than 2025-04-01 |
| 2101 | **Operational Readiness Testing** | 109d | 2025-03-03 A | 2025-07-31 |  |  |
| 2102 | **ORT Design** | 72d | 2025-03-03 A | 2025-06-10 |  |  |
| 2103 | ORT Test Scope and Approach | 25d | 2025-03-03 A | 2025-04-04 A | 2081FF | start no earlier than 2025-03-03 |
| 2104 | ORT Test Approach Shared with MHHS (Initial Review) | 0d | 2025-04-02 A | 2025-04-02 A | 2103FS-3d | start no earlier than 2025-04-02 |
| 2105 | ORT Test Scenarios Shared with MHHS (Initial Review) | 0d | 2025-04-02 A | 2025-04-02 A | 2103FS-3d | start no earlier than 2025-04-02 |
| 2106 | ORT Test Scope and Approach Documents Shared with Industry | 0d | 2025-04-07 A | 2025-04-07 A | 2105 | start no earlier than 2025-04-07 |
| 2107 | **ORT Test Scope and Approach Consultation (Test Scope and Approach & Test Scripts)** | 29d | 2025-04-08 A | 2025-05-19 |  |  |
| 2108 | ORT Test Scope and Approach Consultation | 15d | 2025-04-08 A | 2025-04-28 A | 2106 | finish no earlier than 2025-04-28 |
| 2109 | ORT Test Scope and Approach Consultation Completed | 0d | 2025-04-28 A | 2025-04-28 A | 2108 | start no earlier than 2025-03-28 |
| 2110 | ORT Test Scope and Approach Updates (Feedback Review) | 8d | 2025-04-29 A | 2025-05-08 A | 2109 | start no earlier than 2025-04-14 |
| 2111 | Updated ORT Test Scope and Approach Documents Shared with MHHS and Industry | 0d | 2025-05-08 A | 2025-05-08 A | 2110 | start no earlier than 2025-04-14 |
| 2112 | TORWG Post-Consultation Update (ORT Approach) | 0d | 2025-05-14 | 2025-05-14 | 2111 | start no earlier than 2025-05-14 |
| 2113 | Updated ORT Test Scope and Approach Documents Released to Industry for eSITWG | 0d | 2025-05-16 | 2025-05-16 | 2111, 2112 | start no earlier than 2025-05-16 |
| 2114 | ORT Test Scope and Approach Endorsement (eSITWG) | 0d | 2025-05-19 | 2025-05-19 | 2113 | start no earlier than 2025-05-19 |
| 2115 | ORT Test Script Production and Updates | 23d | 2025-04-08 A | 2025-05-08 A | 2109FF, 2110FF, 2086FF | start no earlier than 2025-04-07 |
| 2116 | ORT Test Scripts Shared | 0d | 2025-05-08 A | 2025-05-08 A | 2115 | start no earlier than 2025-05-07 |
| 2117 | **ORT Test Scripts Consultation** | 25d | 2025-05-07 A | 2025-06-10 |  |  |
| 2118 | ORT Spotlight (Test Approach) at Elexon Service Management Helix Steering Group | 0d | 2025-05-07 A | 2025-05-07 A |  | start no earlier than 2025-05-07 |
| 2119 | ORT Test Scripts Consultation | 6d | 2025-05-09 | 2025-05-16 | 2115, 2116 | start no earlier than 2025-05-01 |
| 2120 | ORT Test Scripts Consultation Completed | 0d | 2025-05-16 | 2025-05-16 | 2119 | start no earlier than 2025-03-28 |
| 2121 | ORT Test Scripts Updates (Feedback Review) | 4d | 2025-05-19 | 2025-05-22 | 2120 | start no earlier than 2025-04-02 |
| 2122 | ORT Test Scipts Updates Shared with MHHS and Industry | 0d | 2025-05-22 | 2025-05-22 | 2121 | start no earlier than 2025-04-14 |
| 2123 | Industry Assurance Review Session Post-Consultation Update (ORT Test Scripts) | 0d | 2025-05-30 | 2025-05-30 | 2122FS+6d | start no earlier than 2025-04-14 |
| 2124 | Updated ORT Test Script Consultation Documents Released to industry for eSITWG | 0d | 2025-06-03 | 2025-06-03 | 2123FS+2d | start no earlier than 2025-04-04 |
| 2125 | ORT Test Scripts and Readiness Spotlight at Elexon Service Management Steering Group | 0d | 2025-06-04 | 2025-06-04 | 2124FS+1d | start no earlier than 2025-04-22 |
| 2126 | ORT Test Scipt Updates Endorsement (eSITWG) | 0d | 2025-06-10 | 2025-06-10 | 2124FS+5d | start no earlier than 2025-04-14 |
| 2127 | **ORT Preparation** | 32d | 2025-05-01 A | 2025-06-13 |  |  |
| 2128 | ORT Participant/User Scheduling | 12d | 2025-05-01 A | 2025-05-16 |  | start no earlier than 2025-05-01 |
| 2129 | ORT Participant/User Scheduling Completed | 0d | 2025-05-16 | 2025-05-16 | 2128 | start no earlier than 2025-03-28 |
| 2130 | ORT Training and Preparation | 6d | 2025-06-04 | 2025-06-11 | 2108, 2115, 2118, 2122 | start no earlier than 2025-06-04 |
| 2131 | ORT DITL Session | 0d | 2025-06-12 | 2025-06-12 | 2120FS+2d, 2123 | start no earlier than 2025-06-12 |
| 2132 | ORT Orientation (JiT) | 0d | 2025-06-13 | 2025-06-13 | 2130FS+2d | start no earlier than 2025-05-30 |
| 2133 | **ORT Execution** | 20d | 2025-06-16 | 2025-07-11 |  |  |
| 2134 | ORT Execution | 20d | 2025-06-16 | 2025-07-11 | 2130, 2132, 2114 | start no earlier than 2025-06-02 |
| 2135 | ORT Execution Completed | 0d | 2025-07-11 | 2025-07-11 | 2134 | start no earlier than 2025-03-28 |
| 2136 | **ORT Exit** | 14d | 2025-07-14 | 2025-07-31 | 2114, 2121, 2124, 2128 |  |
| 2137 | ORT Wrap Up | 5d | 2025-07-14 | 2025-07-18 | 2135 | start no earlier than 2025-04-22 |
| 2138 | ORT Exit Report | 10d | 2025-07-14 | 2025-07-25 | 2135 | start no earlier than 2025-04-02 |
| 2139 | ORT Exit Report Shared with Participants | 0d | 2025-07-25 | 2025-07-25 | 2138 | start no earlier than 2025-04-22 |
| 2140 | ORT eSITAG Exit Report Endorsement | 0d | 2025-07-31 | 2025-07-31 | 2139FS+4d | start no earlier than 2025-04-02 |
| 2141 | **Service Go-Live Governance** | 22d | 2025-07-31 | 2025-09-01 |  |  |
| 2142 | Service Management Go/No Go Decision | 0d | 2025-07-31 | 2025-07-31 | 2102, 2108, 2131, 2137 | start no earlier than 2025-07-31 |
| 2143 | Helix Service Management Live | 0d | 2025-09-01 | 2025-09-01 | 2142 | start no earlier than 2025-09-01 |
| 2215 | **SIT / LDSO Pathway 1** | 16d | 2025-07-23 | 2025-08-13 |  |  |
| 2218 | **SIT / LDSO Pathway 2** | 16d | 2025-08-07 | 2025-08-28 |  |  |
| 2219 | QAD Sign Off Deadline + Test Reports | 0d | 2025-08-07 | 2025-08-07 | 2214, 1694FF | start no earlier than 2025-08-07 |
| 2220 | REC Code Manager / BSC PAB Approval of Qualification (M10-Ready) | 0d | 2025-08-28 | 2025-08-28 | 2219FS+16d |  |
| 2221 | **SIT / LDSO Pathway 3** | 13d | 2025-08-22 | 2025-09-10 |  |  |
| 2222 | QAD Sign Off Deadline + Test Reports | 0d | 2025-08-22 | 2025-08-22 | 2214, 1772, 1694FF |  |
| 2223 | REC Code Manager / BSC PAB Approval of Qualification (M10-Ready) | 2d | 2025-09-09 | 2025-09-10 | 2222FS+11d |  |
| 2224 | M10-Ready SIT Participants are qualified | 0d | 2025-09-10 | 2025-09-10 | 2223 |  |
| 2225 | **MHHS Qualification - M11-Ready** | 137d? | 2025-04-07 A | 2025-10-15 |  |  |
| 2226 | Final QAD Submission Window opens | 0d | 2025-04-07 A | 2025-04-07 A | 2209, 2205, 2210FS+1d |  |
| 2227 | SIT M11-ready Participants submit Final QAD (exc Test Reports) | 44d | 2025-04-08 A | 2025-06-06 | 2226 |  |
| 2228 | Completion of Code Bodies review of Final QAD (M11-Ready) | 20d? | 2025-06-09 | 2025-07-04 | 2227 |  |
| 2229 | **SIT Pathway 4** | 16d | 2025-09-04 | 2025-09-25 |  |  |
| 2230 | QAD Sign Off Deadline + Test Reports | 0d | 2025-09-04 | 2025-09-04 | 2228, 1694FF | start no earlier than 2025-09-04 |
| 2231 | REC Code Manager / BSC PAB Approval of Qualification (M11-Ready) | 0d | 2025-09-25 | 2025-09-25 | 2230FS+16d |  |
| 2232 | **SIT Pathway 5** | 16d | 2025-09-24 | 2025-10-15 |  |  |
| 2233 | QAD Sign Off Deadline + Test Reports | 0d | 2025-09-24 | 2025-09-24 | 2228, 1694FF | start no earlier than 2025-09-24 |
| 2234 | REC Code Manager / BSC PAB Approval of Qualification | 0d | 2025-10-15 | 2025-10-15 | 2233FS+16d |  |
| 2235 | 'M11-Ready SIT Participants are qualified' | 0d | 2025-10-15 | 2025-10-15 | 2234 |  |
| 2240 | **SIT Pathway 6** | 15d | 2025-11-27 | 2025-12-17 |  |  |
| 2253 | QAD Finalisation | 45d | 2025-06-23 | 2025-08-22 | 2252 |  |
| 2813 | M11 Readiness Checkpoint | 45d | 2025-07-28 | 2025-09-26 |  | finish no earlier than 2025-09-26 |
| 2961 | Central Party Cutover Plan Assurance | 45d | 2025-04-14 A | 2025-06-13 | 2959FF | start no earlier than 2025-04-14 |
| 2962 | Consolidated MHHS Cutover Plan Developed | 20d | 2025-05-19 | 2025-06-13 | 2959 | start no earlier than 2025-05-19 |
| 2963 | LDSO Cutover Plan Assurance | 15d | 2025-06-30 | 2025-07-18 | 2960FF | start no earlier than 2025-06-30 |
| 2964 | SIT Supplier and SIT Agent Cutover Plan Assurance | 40d | 2025-06-30 | 2025-08-22 | 2960FF | start no earlier than 2025-06-30 |
| 3131 | **Phase 1 - Preparation** | 1d? | 2022-10-31 A | 2022-10-31 |  |  |
| 3132 | **Business Service Activation Governance, Planning & Scope** | 1d | 2022-10-31 | 2022-10-31 |  |  |
| 3133 | Create and Confirm SA Scope | 9d | 2024-06-03 A | 2024-06-13 A |  | start no earlier than 2024-06-03 |
| 3134 | POAP Service Activation | 13d | 2024-06-03 A | 2024-06-19 A |  | start no earlier than 2024-06-03 |
| 3135 | Service Activation Working Group | 62d | 2024-04-04 A | 2024-06-28 A |  | start no earlier than 2024-04-04 |
| 3136 | Business Readiness Governance Framework | 42d | 2024-08-02 A | 2024-09-30 A |  | start no earlier than 2024-08-02 |
| 3137 | Service Activation Governance Framework Completed | 0d | 2024-09-30 A | 2024-09-30 A | 3133, 3134, 3135, 3136 |  |
| 3138 | **Service Activation High Level Process Models** | 1d | 2022-10-31 | 2022-10-31 |  |  |
| 3139 | Transition Process Model | 70d | 2024-04-02 A | 2024-07-08 A |  | start no earlier than 2024-04-02 |
| 3140 | Migration Process Model | 14d | 2024-08-13 A | 2024-08-30 A |  | start no earlier than 2024-08-13 |
| 3141 | Enduring Process Model | 44d | 2024-06-03 A | 2024-08-01 A |  | start no earlier than 2024-06-03 |
| 3142 | Service Activation High Level Process Models Completed | 0d | 2024-08-30 A | 2024-08-30 A | 3139, 3140, 3141 |  |
| 3143 | **Target Operating Model for Service Activation** | 1d? | 2022-10-31 | 2022-10-31 |  |  |
| 3144 | MHHSP Engagement Team understanding | 25d | 2024-06-21 A | 2024-07-25 A |  | start no earlier than 2024-06-21 |
| 3145 | Define and produce organisation model for Service Activation in Elexon | 83d | 2024-06-21 A | 2024-10-15 A |  | start no earlier than 2024-06-21 |
| 3146 | Implement Target Operating model | 1d | 2024-10-15 A | 2024-10-15 A |  | start no earlier than 2024-10-15 |
| 3147 | Target Operating Model for Service Activation Completed | 0d | 2024-10-15 A | 2024-10-15 A | 3144, 3145, 3146 |  |
| 3148 | **SIT Operational Testing for Service Activation** | 5d | 2024-08-12 A | 2024-08-16 A |  |  |
| 3149 | Review and validate test cases | 5d | 2024-08-12 A | 2024-08-16 A |  | start no earlier than 2024-08-12 |
| 3150 | SIT Operational Testing for Service Activation Completed | 0d | 2024-08-16 A | 2024-08-16 A | 3149 |  |
| 3151 | **Operational Readiness E2E Testing** | 1d | 2022-10-31 | 2022-10-31 |  |  |
| 3152 | Define Service Activation Scenarios & Scripts | 25d | 2024-07-29 A | 2024-08-30 A |  | start no earlier than 2024-07-29 |
| 3153 | Define Service Activation Test plan | 10d | 2024-08-19 A | 2024-08-30 A |  | start no earlier than 2024-08-19 |
| 3154 | Test Execution [Placeholder] | 26d | 2025-04-01 | 2025-05-06 |  | start no earlier than 2025-04-01 |
| 3155 | Service Activation Test Scenarios Completed | 0d | 2025-05-06 | 2025-05-06 | 3154 |  |
| 3156 | **Operational Training for Service Activation** | 1d | 2022-10-31 | 2022-10-31 |  |  |
| 3157 | Training Execution [Placeholder] | 153d | 2024-11-13 | 2025-06-13 |  | start no earlier than 2024-11-13 |
| 3158 | Service Activation Training Completed | 0d | 2025-07-25 | 2025-07-25 |  | start no earlier than 2025-07-25 |
| 3159 | **Service Activation Readiness** | 1d | 2022-10-31 | 2022-10-31 |  |  |
| 3160 | Dress Rehearsal 1 | 2d | 2025-08-04 | 2025-08-05 | 3137, 3142, 3155, 3158, 3150 | start no earlier than 2025-08-04 |
| 3161 | Dress Rehearsal 1 Complete | 0d | 2025-08-05 | 2025-08-05 | 3160 |  |
| 3162 | Dress Rehearsal 2 | 2d | 2025-08-11 | 2025-08-12 | 3161FS+3d |  |
| 3163 | Dress Rehearsal 2 Complete | 0d | 2025-08-12 | 2025-08-12 | 3162 |  |
| 3164 | **Service Activation Go / No Go** | 1d? | 2022-10-31 | 2022-10-31 |  |  |
| 3165 | **Final Service Activation Go/No Go Decision** | 1d? | 2022-10-31 | 2022-10-31 |  |  |
| 3166 | DIP Team Ready | 1d? | 2025-08-22 | 2025-08-22 | 3160, 3162 | start no earlier than 2025-08-22 |
| 3167 | DIP Technical Onboarding Processes Completed | 0d | 2025-08-22 | 2025-08-22 |  | start no earlier than 2025-08-22 |
| 3168 | PM Team Ready | 1d? | 2025-08-21 | 2025-08-22 | 3160, 3162 | finish no earlier than 2025-08-22 |
| 3169 | Operational Support Ready (Ops Control Centre, Account Managers) | 1d? | 2025-08-21 | 2025-08-22 |  | finish no earlier than 2025-08-22 |
| 3170 | Service Management Activity Completed (Resolver Groups) | 1d? | 2025-08-21 | 2025-08-22 |  | finish no earlier than 2025-08-22 |
| 3171 | Process 1.1.1 ISD and Related LWIs Completed | 0d | 2025-08-22 | 2025-08-22 |  | start no earlier than 2025-08-22 |
| 3172 | Service Activation Go / No Go | 0d | 2025-08-22 | 2025-08-22 | 3167, 3171 |  |
| 3173 | **SOLR Consultation** | 1d | 2022-10-31 | 2022-10-31 | 3172 |  |
| 3174 | SOLR workshop 1 | 1d | 2024-04-10 A | 2024-04-10 A |  | start no earlier than 2024-04-10 |
| 3175 | SOLR workshop 2 | 1d | 2024-04-29 A | 2024-04-29 A |  | start no earlier than 2024-04-29 |
| 3176 | SOLR consultation | 23d | 2024-04-30 | 2024-05-30 |  | start no earlier than 2024-04-30 |
| 3177 | SOLR comms to MHHS for review | 0d | 2024-05-07 | 2024-05-07 |  | start no earlier than 2024-05-07 |
| 3178 | **MDR Process** | 1d | 2022-10-31 | 2022-10-31 |  |  |
| 3179 | MDR workshop 1 | 1d | 2025-04-16 A | 2025-04-16 A |  | start no earlier than 2024-04-16 |
| 3180 | MDR workshop 2 | 1d | 2025-04-30 A | 2025-04-30 A |  | start no earlier than 2024-04-30 |
| 3181 | MDR consultation | 18d | 2025-05-07 A | 2025-05-30 |  | start no earlier than 2024-05-07 |
| 3182 | **Phase 2 - Implementation** | 751d? | 2022-10-31 A | 2025-09-15 |  |  |
| 3183 | **Non-SIT LDSO & SIT MVC Data Loading (M10 Ready)** | 317d | 2024-06-07 A | 2025-08-25 |  |  |
| 3184 | Define Non-SIT LDSO Upfront Activities | 6d | 2024-06-07 A | 2024-06-14 A |  | finish no earlier than 2024-06-15 |
| 3185 | **Perform Non-SIT LDSO Activities (M10 Ready)** | 7d | 2025-08-15 | 2025-08-25 |  |  |
| 3186 | Create Entity Forms in Customer Solution | 2d | 2025-08-22 | 2025-08-25 |  | start no earlier than 2025-08-22 |
| 3187 | DIP - Add EFD to DIP | 2d | 2025-08-15 | 2025-08-18 |  | start no earlier than 2025-08-15 |
| 3188 | DIP - Promote to production Environment | 2d | 2025-08-19 | 2025-08-20 | 3187 |  |
| 3189 | DIP - Enable Technology capabilities for participants | 2d | 2025-08-15 | 2025-08-18 |  | start no earlier than 2025-08-15 |
| 3190 | ISD - Replicate Entity Forms from CS | 2d | 2025-08-15 | 2025-08-18 |  | start no earlier than 2025-08-15 |
| 3191 | ISD - Replicate Entity Forms from CS Completed | 0d | 2025-08-18 | 2025-08-18 | 3190, 3189 |  |
| 3192 | MDD - Load MHHS roles | 2d | 2025-08-15 | 2025-08-18 |  | start no earlier than 2025-08-15 |
| 3193 | Non-SIT LDSO Service Activation Data Loading Completed | 0d | 2025-08-25 | 2025-08-25 | 3190, 3191, 3192, 3185, 3187, 3188 |  |
| 3194 | **Non-SIT LDSO & SIT MCV Activation Preparation Tasks (M10 Ready)** | 1d? | 2022-10-31 | 2022-10-31 | 3186, 3188, 3189, 3193 |  |
| 3195 | Identify Resources | 1d | 2025-08-25 | 2025-08-25 | 3184, 3193FS-1d | start no earlier than 2025-08-25 |
| 3196 | Confirmation from Qualification of Wave Participants Complete | 0d | 2025-08-25 | 2025-08-25 |  | start no earlier than 2025-08-25 |
| 3197 | Agree & Understand Support Model | 1d | 2025-08-26 | 2025-08-26 |  | start no earlier than 2025-08-26 |
| 3198 | Confirm Training complete | 0d | 2025-08-27 | 2025-08-27 |  | start no earlier than 2025-08-27 |
| 3199 | Confirm IDNOs gobal sigin comleted prior to M10 | 1d | 2025-08-28 | 2025-08-28 |  | start no earlier than 2025-08-28 |
| 3200 | Engagement / Communications with Participants | 1d | 2025-08-29 | 2025-08-29 |  | start no earlier than 2025-08-29 |
| 3201 | **Internal Communications** | 1d | 2022-10-31 | 2022-10-31 |  |  |
| 3202 | Agree Content for Livewire | 1d | 2025-09-01 | 2025-09-01 |  | start no earlier than 2025-09-01 |
| 3203 | Publish Content for Livewire | 0d | 2025-09-01 | 2025-09-01 |  | start no earlier than 2025-09-01 |
| 3204 | Validate User Access | 1d | 2025-09-02 | 2025-09-02 |  | start no earlier than 2025-09-02 |
| 3205 | Target Systems and Environments Ready | 1d | 2025-09-03 | 2025-09-03 |  | start no earlier than 2025-09-03 |
| 3206 | Publish the guidence with Parties | 1d | 2025-09-04 | 2025-09-04 |  | start no earlier than 2025-09-04 |
| 3207 | Provide LWIs | 1d? | 2025-09-05 | 2025-09-05 |  | start no earlier than 2025-09-05 |
| 3208 | Business Readiness Governance Approval | 1d | 2025-09-05 | 2025-09-05 |  | start no earlier than 2025-09-05 |
| 3209 | Non-SIT LDSO & SIT MVC Service Activation Preparation Completed | 2d | 2025-09-05 | 2025-09-08 | 3195, 3197, 3198, 3199, 3200, 3201, 3204, 3205, 3206, 3208FS-1d |  |
| 3210 | **Non-SIT LDSO & SIT MVC Service Activation Implementation (M10 Ready Pathway 1)** | 1d? | 2022-10-31 | 2022-10-31 |  |  |
| 3211 | PAB Approval Completed | 0d | 2025-08-13 | 2025-08-13 | 2217 |  |
| 3212 | MHHSP Enabled Confirmation | 0d | 2025-08-13 | 2025-08-13 | 3211 |  |
| 3213 | Add EFD (ISD Calendar Date) to DIP | 1d | 2025-09-08 | 2025-09-08 | 3204, 3205, 3208, 3211, 3212, 3207 |  |
| 3214 | DIP Promoted to Production | 1d | 2025-09-09 | 2025-09-09 | 3213 |  |
| 3215 | Create M16 in Customer Solution Started | 0d | 2022-10-31 | 2022-10-31 |  |  |
| 3216 | Create M16 in Customer Solution | 1d | 2025-09-08 | 2025-09-08 | 3215SS, 3219SS |  |
| 3217 | DIP Production Success Checks | 1d? | 2022-10-31 | 2022-10-31 |  |  |
| 3218 | 1st ISD Publish Started | 0d | 2022-10-31 | 2022-10-31 |  |  |
| 3219 | 1st ISD Publish | 6d | 2025-09-08 | 2025-09-15 | 3213SS, 3218SS |  |
| 3220 | Go-Live ISD | 1d? | 2022-10-31 | 2022-10-31 |  |  |
| 3221 | Non-SIT LDSO SIT MVC Service Activation Implementation Completed | 0d | 2025-09-15 | 2025-09-15 | 3211, 3213, 3214, 3216, 3219 |  |
| 3222 | **Non-SIT LDSO & SIT MVC Service Activation Implementation MDD (M10 Ready)** | 1d | 2022-10-31 | 2022-10-31 | 3221 |  |
| 3223 | MDD Final Circular Completed | 0d | 2022-10-31 | 2022-10-31 |  |  |
| 3224 | MDD Manual Update | 3d | 2022-10-31 | 2022-11-02 | 3223SF |  |
| 3225 | MDD Publish | 6d | 2022-10-31 | 2022-11-07 | 3224SF |  |
| 3226 | MDD Go Live | 0d | 2022-11-07 | 2022-11-07 | 3225 |  |
| 3227 | Non-SIT LDSO & SIT MVC Service Activation Implementation MDD Completed | 0d | 2022-11-07 | 2022-11-07 | 3223, 3224, 3225, 3226 |  |
| 3228 | **Non-SIT LDSO & SIT MVC Service Activation Hypercare (M10 Ready)** | 1d | 2022-10-31 | 2022-10-31 | 3211, 3227 |  |
| 3229 | Monitoring | 54d | 2022-11-08 | 2023-01-20 | 3227 |  |
| 3230 | Reporting | 54d | 2022-11-08 | 2023-01-20 | 3227 |  |
| 3231 | Issue Management | 54d | 2022-11-08 | 2023-01-20 | 3227 |  |
| 3232 | Closed Down Activities | 1d | 2022-11-08 | 2022-11-08 | 3229SS, 3230SS, 3231SS |  |
| 3233 | Inform MHHSP | 1d | 2022-11-08 | 2022-11-08 | 3232SS |  |
| 3234 | Non-SIT LDSO Service &SIT MVC Activation Hypercare Completed | 0d | 2023-01-20 | 2023-01-20 | 3229, 3230, 3231, 3232, 3233 |  |
| 3235 | **Non-SIT LDSO & SIT MVC Service Activation Retro and Go/No-Go (M11 Ready)** | 1d | 2022-10-31 | 2022-10-31 |  |  |
| 3236 | Review | 0d | 2023-01-20 | 2023-01-20 | 3234 |  |
| 3237 | Lessons Learned | 5d | 2023-01-23 | 2023-01-27 | 3236 |  |
| 3238 | SIT Non-MVC Service Activation Readiness Review Against Entry/Exit Criteria | 5d | 2023-01-30 | 2023-02-03 | 3237 |  |
| 3239 | **SIT Non-MVC Service Activation Preparation Tasks (M11 Not Ready)** | 1d | 2022-10-31 | 2022-10-31 |  |  |
| 3240 | Review Entry/Exit Criteria & Lessons Learned | 0d | 2022-10-31 | 2022-10-31 |  |  |
| 3241 | Identify Resources | 1d | 2022-10-31 | 2022-10-31 |  |  |
| 3242 | Confirmation from Qualification of Wave Participants Complete | 0d | 2022-10-31 | 2022-10-31 |  |  |
| 3243 | Agree & Understand Support Model | 2d | 2022-10-31 | 2022-11-01 |  |  |
| 3244 | Confirm Training complete | 1d | 2022-10-31 | 2022-10-31 |  |  |
| 3245 | Engagement / Communications with Participants | 1d | 2022-10-31 | 2022-10-31 |  |  |
| 3246 | **Internal Communications** | 1d | 2022-10-31 | 2022-10-31 |  |  |
| 3247 | Agree Content for Livewire | 1d | 2022-10-31 | 2022-10-31 |  |  |
| 3248 | Publish Content for Livewire | 0d | 2022-10-31 | 2022-10-31 |  |  |
| 3249 | Validate User Access | 1d | 2022-10-31 | 2022-10-31 |  |  |
| 3250 | Target Systems and Environments Ready | 1d | 2022-10-31 | 2022-10-31 |  |  |
| 3251 | Provide LWIs | 1d | 2022-10-31 | 2022-10-31 |  |  |
| 3252 | Business Readiness Governance Approval | 1d | 2022-10-31 | 2022-10-31 |  |  |
| 3253 | SIT Non-MVC Service Activation Preparation Tasks Completed | 0d | 2022-11-01 | 2022-11-01 | 3241, 3243, 3244, 3245, 3246, 3249, 3250, 3251, 3252 |  |
| 3254 | **SIT Non-MVC Service Activation Implementation (M11 Not Ready)** | 1d | 2022-10-31 | 2022-10-31 |  |  |
| 3255 | MHHSP Enabled Confirmation | 1d | 2022-10-31 | 2022-10-31 |  |  |
| 3256 | PAB Approval | 0d | 2022-10-31 | 2022-10-31 |  |  |
| 3257 | Add EFD(ISD Calendar Date) to DIP | 2d | 2022-11-01 | 2022-11-02 | 3249, 3250, 3251, 3252, 3255, 3256 |  |
| 3258 | DIP Promoted to Production | 1d | 2022-11-01 | 2022-11-01 | 3257SS |  |
| 3259 | Create M16 in Customer Solution | 1d | 2022-10-31 | 2022-10-31 |  |  |
| 3260 | DIP Production Success Checks | 7d | 2022-11-03 | 2022-11-11 | 3257, 3259 |  |
| 3261 | Publish ISD | 5d | 2022-11-01 | 2022-11-07 | 3257SS |  |
| 3262 | Go Live ISD | 0d | 2022-11-07 | 2022-11-07 | 3261 |  |
| 3263 | SIT Non-MVC Service Activation Implementation Completed | 0d | 2022-11-11 | 2022-11-11 | 3255, 3256, 3257, 3258, 3259, 3260, 3261, 3262 |  |
| 3264 | **SIT Non-MVC Service Activation Implementation MDD (M11 Not Ready)** | 1d | 2022-10-31 | 2022-10-31 |  |  |
| 3265 | MDD Final Circular | 0d | 2022-10-31 | 2022-10-31 | 3256 |  |
| 3266 | MDD Manual Update | 3d | 2022-10-31 | 2022-11-02 | 3265SF |  |
| 3267 | MDD Publish | 5d | 2022-10-31 | 2022-11-04 | 3266SF |  |
| 3268 | MDD Go Live | 0d | 2022-11-04 | 2022-11-04 | 3267 |  |
| 3269 | SIT Non-MVC Service Activation Implementation MDD Completed | 0d | 2022-11-04 | 2022-11-04 | 3265, 3268 |  |
| 3270 | **SIT Non-MVC Service Activation Hypercare (M11 Not Ready)** | 1d | 2022-10-31 | 2022-10-31 |  |  |
| 3271 | Monitoring | 11d | 2022-10-31 | 2022-11-14 |  |  |
| 3272 | Reporting | 11d | 2022-10-31 | 2022-11-14 |  |  |
| 3273 | Issue Management | 11d | 2022-10-31 | 2022-11-14 |  |  |
| 3274 | Closed Down Activities | 3d | 2022-10-31 | 2022-11-02 | 3271SS, 3272SS, 3273SS |  |
| 3275 | Inform MHHSP | 2d | 2022-10-31 | 2022-11-01 | 3274SS |  |
| 3276 | Non-SIT LDSO Service Activation Hypercare Completed | 0d | 2022-11-14 | 2022-11-14 | 3271, 3272, 3273, 3274, 3275 |  |
| 3277 | **SIT Non-MVC Service Activation Retro & Go/No Go (M11 Not Ready)** | 1d | 2022-10-31 | 2022-10-31 |  |  |
| 3278 | Review | 0d | 2022-10-31 | 2022-10-31 |  |  |
| 3279 | Lessons Learned | 5d | 2022-10-31 | 2022-11-04 | 3278SS |  |
| 3280 | Wave 1 - Service Activation Readiness Review Against Entry/Exit Criteria | 5d | 2022-11-07 | 2022-11-11 | 3279 |  |

Removed: 1704 SIT Operational Testing Execution Theme 3 Batch 2; 1708 SIT Operational Testing Execution Theme 1; 1709 SIT Operational Testing Execution Theme 2; 1765 Submit proposed version to QWG; 1766 Discuss document at QWG; 2016 LDSOs Develop & Submit Test Report (QT Test Completion Report); 2748 Each LDSO and DCC completes investigation and resolution of exceptions; 2814 Development of Implementation Group; 2815 Implementation Group Established; 2820 Programme SIT Participant Cutover Plan Assurance

Changed:

| ID | Task | Start | Finish | Duration | Complete | Total float | Predecessors | Other |
| --- | --- | --- | --- | --- | --- | --- | --- | --- |
| 113 | Publish updated baselined artefacts |  | 2023-06-12 A → 2023-06-06 A (-6d) |  |  |  |  |  |
| 187 | **PP Design, Build & Test (DBT)** |  |  |  | 75% → 77% |  |  |  |
| 327 | **SIT Participants DBT** |  |  |  | 85% → 89% |  |  |  |
| 362 | **All SIT Programme Participants PIT (SIT Functional)** |  |  |  | 70% → 78% |  |  |  |
| 396 | **All SIT Programme Participants PIT (SIT Non Functional)** |  |  |  | 76% → 98% |  |  |  |
| 408 | **PIT execution** |  | 2025-02-21 A |  | 75% → 100% | 739d → none |  |  |
| 409 | PIT Test Execution Progress Report |  | 2024-11-21 A |  | 75% → 100% | 805d → none |  |  |
| 410 | PIT Execution |  | 2024-11-29 A |  | 75% → 100% | 799d → none |  |  |
| 413 | SIT Non-Functional PIT Completion Report Theme 2 & 3 MHHS Review Completed | 2025-02-21 A | 2025-02-21 A |  | 0% → 100% | 739d → none |  |  |
| 414 | **SIT Programme Participants PIT (SIT Operational Theme 1, 2, 3 (Batch 2))** |  |  |  | 75% → 90% |  |  |  |
| 418 | **Test Readiness Report** |  |  |  | 75% → 90% | 12d → 18d |  |  |
| 419 | Test readiness reporting |  |  |  | 75% → 90% | 12d → 18d |  |  |
| 426 | **PIT execution** |  |  |  | 75% → 90% |  |  |  |
| 427 | PIT Test Execution Progress Report |  |  |  | 75% → 90% |  |  |  |
| 428 | PIT Execution |  |  |  | 75% → 90% |  |  |  |
| 545 | **SYSTEMS INTEGRATION TESTING (SIT)** |  |  |  | 77% → 76% |  |  |  |
| 546 | **SIT Preparation** |  | 2025-05-16 → 2025-05-23 (+7d) | 665d? → 670d? |  | 679d → 674d |  |  |
| 627 | **SIT Stage-Specific Preparation** |  | 2025-05-16 → 2025-05-23 (+7d) | 665d? → 670d? |  | 679d → 674d |  |  |
| 639 | Development of test scenarios |  | 2023-04-28 A → 2023-01-02 A (-116d) |  |  |  |  |  |
| 640 | Review test scenarios with SIT Working Group |  | 2023-08-09 A → 2023-02-15 A (-175d) |  |  |  |  |  |
| 1194 | **SIT Operational Preparation** |  | 2025-03-28 → 2025-05-23 (+56d) | 630d? → 670d? | 99% → 98% | 714d → 674d |  |  |
| 1363 | **SIT Operational Programme RTTM (Theme 1, 2 & 3 (Batch 2))** |  | 2025-03-28 → 2025-05-23 (+56d) | 59d → 100d | 97% → 75% | 715d → 674d |  |  |
| 1366 | DIP Manager / Code Bodies / Full SRO to review |  | 2025-03-21 → 2025-04-24 (+34d) | 10d → 34d |  | 718d → 694d |  |  |
| 1367 | Incorporate feedback |  | 2025-03-21 → 2025-04-24 (+34d) | 10d → 34d | 90% → 26% | 719d → 695d |  |  |
| 1368 | DIP Manager / Code Bodies / SRO acceptance of (Theme 1, 2 & 3 (Batch 2)) Operational RTTM | 2025-03-24 → 2025-04-25 (+32d) | 2025-03-24 → 2025-04-25 (+32d) |  |  | 718d → 694d |  |  |
| 1369 | SIT Operational (Theme 1, 2 & 3 (Batch 2)) RTTM Complete | 2025-03-28 → 2025-05-23 (+56d) | 2025-03-28 → 2025-05-23 (+56d) |  |  | 715d → 674d |  | constraint start no earlier than 2025-03-28 → finish no earlier than 2025-05-23 |
| 1423 | SIT Operational Theme 1, 2, 3 (Batch 2) Testing Preparation Complete |  |  |  |  |  | 430, 1211, 1217, 1343, 1421, 1401, 1381, 1369, 1353 → 430, 1211, 1217, 1343, 1421, 1401, 1381, 1353 |  |
| 1432 | **Regression Test Preparation** |  |  |  | 80% → 100% |  |  |  |
| 1445 | **Regression Core Test Pack** |  | 2025-04-24 A | 51d? → 52d? | 89% → 100% | 696d → none |  |  |
| 1458 | Incorporate industry feedback into regression Core Pack | 2025-04-10 A | 2025-04-10 A |  | 0% → 100% | 705d → none |  |  |
| 1460 | SITWG endorses regression Core Pack | 2025-04-15 A | 2025-04-15 A |  | 0% → 100% | 9d → none |  |  |
| 1461 | Incorporate SITWG feedback into regression Core Pack | 2025-04-16 A | 2025-04-17 A |  | 0% → 100% | 700d → none |  |  |
| 1462 | Regression Test Approach and Plan Uplift | 2025-04-16 A | 2025-04-16 A |  | 0% → 100% | 9d → none |  |  |
| 1463 | Industry Review on the Uplifted Test Approach and Plan | 2025-04-17 A | 2025-04-23 A |  | 0% → 100% | 8d → none |  |  |
| 1464 | SITAG paper day | 2025-04-15 → 2025-04-17 A (+2d) | 2025-04-15 → 2025-04-17 A (+2d) |  | 0% → 100% | 10d → none |  | constraint start no earlier than 2025-04-15 → finish no earlier than 2025-04-17 |
| 1465 | SITAG (inc SRO) Approval of regression Core Pack | 2025-04-24 A | 2025-04-24 A |  | 0% → 100% | 8d → none |  |  |
| 1466 | SIT Regression Approval | 2025-04-24 A | 2025-04-24 A |  | 0% → 100% | 8d → none |  |  |
| 1467 | **Regression Test Data Load Window (SIT Functional and Migration) - SIT A** |  |  |  | 21% → 100% |  |  |  |
| 1468 | Data Load preparation activities |  | 2025-04-25 A |  | 35% → 100% | 6d → none |  |  |
| 1469 | Regression Test Data Load Start | 2025-04-28 A | 2025-04-28 A |  | 0% → 100% | 5d → none |  |  |
| 1470 | Regression Test Data Load Window | 2025-04-29 A | 2025-05-16 A |  | 0% → 100% | 5d → none |  |  |
| 1520 | **SIT Execution** |  |  |  | 54% → 52% |  |  |  |
| 1537 | **SIT** |  | 2025-08-22 → 2025-08-27 (+5d) | 380d? → 383d? | 57% → 54% | 609d → 606d |  | was named SIT - Minimum Viable Cohort (MVC) |
| 1538 | **SIT Functional Testing (MVC)** |  | 2025-08-15 → 2025-08-20 (+5d) | 375d? → 378d? | 71% → 61% | 614d → 611d |  |  |
| 1540 | **SIT Functional Testing Execution (Minimum Viable Cohort)** |  |  | 296d? → 295d? |  |  |  |  |
| 1564 | SIT Functional Cycle 3 Complete |  |  | 1d? → 0d |  |  |  |  |
| 1565 | **SIT Scope Traceability** |  | 2025-04-24 A |  | 99% → 100% | 695d → none |  |  |
| 1572 | SITWG recommends Scope Tracability document | 2025-04-15 A | 2025-04-15 A |  | 0% → 100% | 695d → none |  |  |
| 1574 | SITAG paper day | 2025-04-17 A | 2025-04-17 A |  | 0% → 100% | 695d → none |  |  |
| 1575 | SITAG approve SIT Scope Traceability document | 2025-04-24 A | 2025-04-24 A |  | 0% → 100% | 695d → none |  |  |
| 1576 | SIT Scope Traceability Approved | 2025-04-24 A | 2025-04-24 A |  | 0% → 100% | 695d → none |  |  |
| 1577 | **SIT Functional Settlement Testing** |  |  |  | 36% → 29% |  |  |  |
| 1596 | **SIT-A Settlement Testing** | 2025-05-19 A |  |  | 0% → 10% | 5d → 10d |  |  |
| 1597 | SIT-A Settlement Testing Start | 2025-05-19 A | 2025-05-19 A |  | 0% → 100% | 5d → none |  |  |
| 1598 | SIT-A Settlement Testing | 2025-05-20 A |  |  | 0% → 10% | 5d → 10d |  |  |
| 1601 | **SIT Functional Regression Testing (code freeze)** |  |  |  |  | 5d → 10d |  | was named SIT Functional MVC Regression Testing (code freeze) |
| 1607 | Regression Contingency Week |  |  |  |  | 5d → 10d | 1606 → 1606, 1621FF |  |
| 1608 | SIT Functional Testing End |  |  |  |  | 5d → 10d |  | was named SIT Functional Testing End (Minimum Viable Cohort) (incl. confirmation that PPs have submitted their Test Completion Reports to Programme for assurance) |
| 1610 | **SIT Functional & Migration Overarching Exit Report** | 2025-07-21 → 2025-04-28 A (-84d) | 2025-08-15 → 2025-06-18 (-58d) | 20d → 38d | 0% → 36% | 5d → 656d |  | was named SIT Functional Test Completion Report (Minimum Viable Cohort) |
| 1630 | SI SIT Functional Testing Test Exit Report Approved | 2025-08-15 → 2025-08-20 (+5d) | 2025-08-15 → 2025-08-20 (+5d) |  |  | 5d → 8d | 1629FF → 1629FF, 1625, 1627, 1607 | was named SIT Functional Testing Test Completion Report (Minimum Viable Cohort) Approved; constraint none → start no earlier than 2025-08-20; baseline start 2025-08-15 → 2025-08-20; baseline finish 2025-08-15 → 2025-08-20 |
| 1664 | **SIT Migration Testing** |  | 2025-08-22 → 2025-08-27 (+5d) | 380d? → 383d? | 75% → 61% | 609d → 606d |  | was named SIT Migration Testing (MVC) |
| 1666 | **SIT Migration Testing Execution** |  | 2025-08-22 → 2025-08-27 (+5d) | 380d? → 383d? | 75% → 61% | 609d → 606d |  | was named SIT Migration Testing Execution (Minimum Viable Cohort) |
| 1676 | **Cycle 3 (Defect retests and targeted regression testing)** |  | 2025-04-25 A |  | 96% → 100% | 694d → none |  |  |
| 1688 | Sprint 15 (Contingency 1) |  | 2025-04-11 A |  | 70% → 100% | 7d → none |  |  |
| 1689 | Sprint 16 (Contingency 2) |  | 2025-04-25 A |  | 70% → 100% | 5d → none |  |  |
| 1690 | SIT Migration Cycle 3 Complete |  | 2025-04-25 A |  | 70% → 100% | 694d → none |  |  |
| 1691 | **SIT Migration Regression Testing (code freeze)** |  |  |  |  | 614d → 15d |  | was named SIT Migration MVC Regression Testing (code freeze) |
| 1696 | Regression Sprint 3 |  |  |  |  |  |  | baseline start 2025-07-14 → 2025-07-21 |
| 1697 | Regression Contingency Week |  |  |  |  |  | 1696 → 1696, 1710FF | baseline start none → 2025-08-04; baseline finish none → 2025-08-08 |
| 1698 | SIT Migration Testing End (incl. confirmation that PPs have submitted their Test Completion Reports to Programme for assurance) |  |  |  |  |  |  | was named SIT Migration Testing End (Minimum Viable Cohort) (incl. confirmation that PPs have submitted their Test Completion Reports to Programme for assurance) |

| ID | Task | Start | Finish | Duration | Complete | Total float | Predecessors | Other |
| --- | --- | --- | --- | --- | --- | --- | --- | --- |
| 1699 | **SIT Functional & Migration Test Exit Report** | 2025-07-14 → 2025-04-28 A (-77d) | 2025-08-15 → 2025-06-18 (-58d) | 25d → 38d | 0% → 36% | 609d → 656d |  | was named SIT Migration Test Completion Report (Minimum Viable Cohort) |
| 1719 | SIT Migration Testing Test Exit Report Approved | 2025-08-15 → 2025-08-20 (+5d) | 2025-08-15 → 2025-08-20 (+5d) |  |  | 609d → 7d |  | was named SIT Migration Testing Test Completion Report (Minimum Viable Cohort) Approved; constraint none → finish no earlier than 2025-08-20; baseline start 2025-08-15 → 2025-08-20; baseline finish 2025-08-15 → 2025-08-20 |
| 1720 | SIT Migration Testing End (incl. confirmation that PPs have submitted their Test Exit Reports to Programme for assurance) |  |  |  |  |  | 1717FF, 1719 → 1717FF, 1714 | was named SIT Migration Testing End (Minimum Viable Cohort) (incl. confirmation that PPs have submitted their Test Completion Reports to Programme for assurance); constraint start no earlier than 2025-03-14 → finish no earlier than 2025-08-15 |
| 1722 | Assurance of PPs Test Completion Reports | 2025-07-14 → 2025-07-17 (+3d) | 2025-08-22 → 2025-08-27 (+5d) |  |  | 609d → 606d | 1720FF+5d → 1720FF+5d, 1721FF+5d |  |
| 1723 | **SIT Non-Functional Testing (all SIT PPs)** |  | 2025-06-06 → 2025-07-16 (+40d) | 70d? → 98d? | 22% → 29% | 60d → 636d |  |  |
| 1727 | Theme 2 & 3 SIT Non-Functional Testing Execution |  |  |  | 15% → 65% |  |  |  |
| 1730 | **SIT Non-Functional Testing Test Exit Report (all SIT PPs)** |  | 2025-05-30 → 2025-07-16 (+47d) | 20d → 53d |  |  |  | was named SIT Non-Functional Testing Test Completion Report (all SIT PPs) |
| 1740 | SIT Non-Functional Testing Test Exit Report (all SIT PPs) Approved | 2025-06-06 → 2025-07-16 (+40d) | 2025-06-06 → 2025-07-16 (+40d) |  |  | 60d → 32d | 1739FF+5d → 1739FF+5d, 1735FS+3d | was named SIT Non-Functional Testing Test Completion Report (all SIT PPs) Approved; constraint none → finish no earlier than 2025-07-16; baseline start 2025-06-06 → 2025-07-16; baseline finish 2025-06-06 → 2025-07-16 |
| 1742 | **SIT Operational Testing (all SIT PPs)** |  | 2025-07-25 → 2025-08-06 (+12d) | 125d? → 133d? | 11% → 30% | 25d → 621d |  |  |
| 1746 | **SIT B Testing** |  |  | 70d? → 70d | 3% → 47% |  |  |  |
| 1748 | SIT Operational Testing Execution Theme 1 |  |  |  | 9% → 50% |  |  |  |
| 1749 | SIT Operational Testing Execution Theme 2 | 2025-05-05 A |  |  | 0% → 60% |  |  |  |
| 1755 | SIT Operational Testing End (all SIT PPs) (incl. confirmation that PPs have submitted their Test Completion Reports to Programme for assurance) | 2025-07-11 → 2025-07-04 (-7d) | 2025-07-11 → 2025-07-04 (-7d) |  |  | 25d → 30d | SIT Operational Testing Execution Theme 2FS+5d, 1745, 1748, 1749, 1750 → 1745, 1748, 1749, 1750, 1754 |  |
| 1756 | Assurance of PPs Test Completion Reports | 2025-06-09 → 2025-06-02 (-7d) | 2025-07-18 → 2025-07-11 (-7d) |  |  | 25d → 30d |  |  |
| 1757 | **SIT Operational Testing Test Exit Report (all SIT PPs)** | 2025-06-23 → 2025-06-02 (-21d) | 2025-07-18 → 2025-08-06 (+19d) | 20d → 48d |  | 25d → 32d |  | was named SIT Operational Testing Test Completion Report (all SIT PPs) |
| 1765 | Develop document | 2025-06-23 → 2025-06-16 (-7d) | 2025-07-11 → 2025-07-04 (-7d) |  |  | 25d → 30d |  | baseline start 2025-06-23 → 2025-06-16; baseline finish 2025-07-11 → 2025-07-04 |
| 1766 | Review & agree document | 2025-07-14 → 2025-07-07 (-7d) | 2025-07-18 → 2025-07-11 (-7d) |  |  | 25d → 30d |  | baseline start 2025-07-14 → 2025-07-07; baseline finish 2025-07-18 → 2025-07-11 |
| 1767 | SIT Operational Testing Test Exit Report (all SIT PPs) Approved | 2025-07-25 → 2025-08-06 (+12d) | 2025-07-25 → 2025-08-06 (+12d) |  |  | 25d → 17d | 1766FF+5d → 1766FF+5d, 1762FS+3d | was named SIT Operational Testing Test Completion Report (all SIT PPs) Approved; baseline start 2025-07-25 → 2025-08-06; baseline finish 2025-07-25 → 2025-08-06 |
| 1769 | **SIT Test Exit Report** |  |  |  |  |  |  | was named SIT MVC Test Exit Report |
| 1772 | SIT Complete (SIT Test Exit Report Approved) |  |  |  |  |  | 1536, 1630FS+5d, 1740, 1767 → 1536, 1630, 1740, 1767, 1719, 1768, 1741, 1631 | was named SIT Minimum Viable Cohort Complete (SIT Minimum Viable Cohort Test Exit Report Approved); constraint none → finish no earlier than 2025-08-22 |
| 1773 | **SIT (Contingency)** |  |  |  |  |  |  | was named SIT (non-MVC) |
| 1774 | **SIT Functional Testing (Contingency)** |  |  |  |  |  |  | was named SIT Functional Testing (non-MVC) |
| 1775 | **SIT Functional Testing Execution (Contingency)** |  |  |  |  |  |  | was named SIT Functional Testing Execution (non-MVC) |
| 1777 | SIT Functional Testing End (Contingency) (incl. confirmation that PPs have submitted their Test Exit Reports to Programme for assurance) |  |  |  |  |  |  | was named SIT Functional Testing End (non-MVC) (incl. confirmation that PPs have submitted their Test Completion Reports to Programme for assurance) |
| 1778 | Assurance of PPs Test Exit Reports |  |  |  |  |  |  | was named Assurance of PPs Test Completion Reports |
| 1779 | **SIT Functional Testing Test Completion Report (Contingency)** |  |  |  |  |  |  | was named SIT Functional Testing Test Completion Report (non-MVC) |
| 1782 | SIT Functional Testing Test Exit Report (Contingency) Approved |  |  |  |  |  |  | was named SIT Functional Testing Test Completion Report (non-MVC) Approved |
| 1783 | **SIT Migration Testing (Contingency)** |  |  |  |  |  |  | was named SIT Migration Testing (non-MVC) |
| 1785 | SIT Migration Testing End (Contingency) (incl. confirmation that PPs have submitted their Test Exit Reports to Programme for assurance) |  |  |  |  |  |  | was named SIT Migration Testing End (non-MVC) (incl. confirmation that PPs have submitted their Test Completion Reports to Programme for assurance) |
| 1786 | Assurance of PPs Test Exit Reports |  |  |  |  |  |  | was named Assurance of PPs Test Completion Reports |
| 1787 | **SIT Migration Testing Test Completion Report (Contingency)** |  |  |  |  |  |  | was named SIT Migration Testing Test Completion Report (non-MVC) |
| 1790 | SIT Migration Testing Test Exit Report (Contingency) Approved |  |  |  |  |  |  | was named SIT Migration Testing Test Completion Report (non-MVC Approved) |
| 1791 | **SIT Contingency Test Exit Report** |  |  |  |  |  |  | was named SIT non-MVC Test Exit Report |
| 1794 | SIT Contingency Complete |  |  |  |  |  |  | was named SIT non-MVC Complete |
| 1795 | **UIT Environment Preparation** |  | 2025-06-06 → 2025-06-19 (+13d) | 680d? → 689d | 52% → 53% | 664d → 655d |  |  |
| 1796 | **Test Artefact Development** |  | 2025-04-17 → 2025-06-19 (+63d) | 557d? → 602d | 73% → 89% | 700d → 655d |  |  |
| 1797 | **E2E Sandbox Guidance** |  | 2025-04-17 → 2025-06-19 (+63d) | 557d? → 602d |  | 700d → 655d |  |  |
| 1801 | Update E2E Sandbox guidance to reflect CR055 | 2025-01-13 A → 2025-03-17 A (+63d) | 2025-03-14 A → 2025-05-16 A (+63d) |  |  |  |  | constraint finish no earlier than 2025-03-14 → finish no earlier than 2025-05-16; baseline start 2025-01-13 → 2025-03-17; baseline finish 2025-03-14 → 2025-05-16 |
| 1802 | Internal SI review | 2025-03-17 A → 2025-05-19 A (+63d) | 2025-03-21 A → 2025-05-23 (+63d) |  | 100% → 60% | none → 674d |  | baseline start 2025-03-17 → 2025-05-19; baseline finish 2025-03-21 → 2025-05-23 |
| 1803 | SRO / Code Bodies review | 2025-03-24 A → 2025-05-19 (+56d) | 2025-03-28 → 2025-05-23 (+56d) |  | 40% → 0% | 713d → 674d | 1802 → none | constraint finish no earlier than 2025-03-28 → finish no earlier than 2025-05-23; baseline start 2025-03-24 → 2025-05-19; baseline finish 2025-03-28 → 2025-05-23 |
| 1804 | Submit version to QWG | 2025-04-01 → 2025-06-03 (+63d) | 2025-04-01 → 2025-06-03 (+63d) |  |  | 711d → 667d | 1803 → none | constraint finish no earlier than 2025-04-01 → finish no earlier than 2025-06-03; baseline start 2025-04-01 → 2025-06-03; baseline finish 2025-04-01 → 2025-06-03 |
| 1805 | Artefact Recommendation for Approval (via QWG) | 2025-04-08 → 2025-06-10 (+63d) | 2025-04-08 → 2025-06-10 (+63d) |  |  | 706d → 662d |  | constraint finish no earlier than 2025-04-08 → finish no earlier than 2025-06-10; baseline start 2025-04-08 → 2025-06-10; baseline finish 2025-04-08 → 2025-06-10 |
| 1806 | Final Document updates post QWG review | 2025-04-09 → 2025-06-11 (+63d) | 2025-04-09 → 2025-06-11 (+63d) | 1d → 0d |  | 706d → 661d |  | constraint start no earlier than 2025-04-09 → finish no earlier than 2025-06-11; baseline start 2025-04-09 → 2025-06-11; baseline finish 2025-04-09 → 2025-06-11 |
| 1807 | Submit final version to QAG | 2025-04-10 → 2025-06-12 (+63d) | 2025-04-10 → 2025-06-12 (+63d) | 1d? → 0d |  | 701d → 657d |  | constraint finish no earlier than 2025-04-10 → finish no earlier than 2025-06-12; baseline start 2025-04-10 → 2025-06-12; baseline finish 2025-04-10 → 2025-06-12 |
| 1808 | E2E Sandbox guidance update approved at QAG | 2025-04-17 → 2025-06-19 (+63d) | 2025-04-17 → 2025-06-19 (+63d) | 1d? → 0d |  | 700d → 655d |  | constraint finish no earlier than 2025-04-17 → finish no earlier than 2025-06-19; baseline start 2025-04-17 → 2025-06-19; baseline finish 2025-04-17 → 2025-06-19 |
| 1809 | **E2E Sandbox Test Data Approach & Plan** | 2025-01-13 A → 2025-03-10 A (+56d) | 2025-04-16 → 2025-06-17 (+62d) | 68d → 72d | 22% → 74% | 701d → 657d |  |  |
| 1814 | Discuss PPIR results at QWG | 2025-04-08 A | 2025-04-08 A |  | 0% → 100% | 707d → none |  |  |
| 1815 | Develop document | 2025-01-13 → 2025-04-10 A (+87d) | 2025-02-18 → 2025-05-16 A (+87d) |  | 0% → 100% | 701d → none |  | constraint start no earlier than 2025-01-13 → finish no earlier than 2025-05-16; baseline start 2025-01-13 → 2025-04-10; baseline finish 2025-02-18 → 2025-05-16 |
| 1816 | Internal SI review and updates | 2025-02-19 → 2025-05-19 A (+89d) | 2025-02-25 → 2025-05-23 (+87d) |  | 0% → 60% | 701d → 674d |  | baseline start 2025-02-19 → 2025-05-19; baseline finish 2025-02-25 → 2025-05-23 |
| 1817 | SRO / Code Bodies review | 2025-02-26 → 2025-05-19 A (+82d) | 2025-03-04 → 2025-05-23 (+80d) |  | 0% → 60% | 701d → 664d | 1816 → 1816SS | baseline start 2025-02-26 → 2025-05-19; baseline finish 2025-03-04 → 2025-05-23 |
| 1818 | Final updates prior to consultation | 2025-03-12 → 2025-05-26 (+75d) | 2025-03-17 → 2025-05-26 (+70d) | 4d → 1d |  | 701d → 664d | Discuss document at QWG → 1817 | baseline start 2025-03-12 → 2025-05-26; baseline finish 2025-03-17 → 2025-05-26 |
| 1819 | Industry Consultation for E2E Sandbox Test Data Approach and Plan document | 2025-03-18 → 2025-05-26 (+69d) | 2025-03-31 → 2025-06-06 (+67d) |  |  | 701d → 664d | 1818 → 1818SS | baseline start 2025-03-18 → 2025-05-26; baseline finish 2025-03-31 → 2025-06-06 |
| 1820 | Document updates post Industry Consultation | 2025-04-01 → 2025-06-05 (+65d) | 2025-04-03 → 2025-06-09 (+67d) |  |  | 701d → 663d | 1819 → 1819SS | constraint finish no earlier than 2024-04-22 → finish no earlier than 2025-06-09; baseline start 2025-04-01 → 2025-06-07; baseline finish 2025-04-03 → 2025-06-09 |
| 1821 | Submit Proposed Version to QWG | 2025-04-04 → 2025-06-10 (+67d) | 2025-04-08 → 2025-06-10 (+63d) | 3d → 0d |  | 701d → 660d | 1820 → none | constraint none → finish no earlier than 2025-06-10; baseline start 2025-04-04 → 2025-06-10; baseline finish 2025-04-08 → 2025-06-10 |
| 1822 | Artefact Approval (via QWG) | 2025-04-08 → 2025-06-10 (+63d) | 2025-04-08 → 2025-06-10 (+63d) |  |  | 701d → 660d |  | constraint none → finish no earlier than 2025-06-10; baseline start 2025-04-08 → 2025-06-10; baseline finish 2025-04-08 → 2025-06-10 |
| 1823 | Final Document updates post QWG review | 2025-04-09 → 2025-06-11 (+63d) | 2025-04-09 → 2025-06-11 (+63d) |  |  | 701d → 660d |  | baseline start 2025-04-09 → 2025-06-11; baseline finish 2025-04-09 → 2025-06-11 |
| 1824 | Submit final version to QAG | 2025-04-10 → 2025-06-12 (+63d) | 2025-04-10 → 2025-06-12 (+63d) |  |  | 701d → 660d | 1823FS+1d → 1823FS+1d, 1820 | baseline start 2025-04-10 → 2025-06-12; baseline finish 2025-04-10 → 2025-06-12 |
| 1825 | E2E Sandbox Test Data Approach and Plan Approved at QAG | 2025-04-16 → 2025-06-17 (+62d) | 2025-04-16 → 2025-06-17 (+62d) |  |  | 701d → 657d | 1824FS+4d → 1824 | was named E2E Sandbox Test Data Approach and Plan; constraint start no earlier than 2024-05-09 → finish no earlier than 2025-06-17 |
| 1877 | **Sandbox Testing Execution (UIT) - Supplier & Agent Participants** |  |  |  |  |  |  | was named Sandbox Testing Execution (UIT) |
| 1878 | Sandbox Testing Start (UIT) - Supplier & Agent Participants |  |  |  |  |  |  | was named Sandbox Testing Start (UIT) |
| 1879 | Sandbox Testing Execution (UIT) - Supplier & Agent Participants |  |  |  |  |  |  | was named Sandbox Testing Execution (UIT) |
| 1880 | Sandbox Testing End (UIT) - Supplier & Agent Participants |  |  |  |  |  |  | was named Sandbox Testing End (UIT) |
| 1885 | **SIT PPs Early Sandbox Testing Execution (SIT-A)** | 2025-08-11 → 2025-07-21 (-21d) |  | 55d → 70d |  |  |  | baseline start 2025-02-07 → 2025-07-21; baseline finish 2026-04-24 → 2025-10-24 |
| 1886 | SIT PPs E2E Sandbox Testing Start | 2025-08-11 → 2025-07-21 (-21d) | 2025-08-11 → 2025-07-21 (-21d) |  |  | 618d → 634d | 1876FS+5d, 1607 → 1876FS+5d, 1605 | constraint finish no earlier than 2025-08-11 → start no earlier than 2025-07-21; baseline start 2025-08-11 → 2025-07-21; baseline finish 2025-08-11 → 2025-07-21 |
| 1887 | SIT PPs E2E Sandbox Testing Execution | 2025-08-11 → 2025-07-21 (-21d) |  | 55d → 70d |  |  |  | constraint start no earlier than 2024-11-04 → start no earlier than 2025-07-21; baseline start 2025-02-07 → 2025-07-21; baseline finish 2026-04-24 → 2025-10-24 |
| 1916 | **M10 Acceptance Criteria** |  |  |  |  |  |  | baseline start none → 2024-05-28; baseline finish none → 2025-10-10 |
| 1917 | End of SIT MVC testing |  |  |  |  |  |  | baseline start none → 2025-08-22; baseline finish none → 2025-08-22 |
| 1918 | IPA M10 Assurance Report developed and agreed |  |  |  |  |  |  | baseline start none → 2025-09-19; baseline finish none → 2025-09-19 |
| 1919 | Non-SIT LDSO Qualification Testing complete |  |  |  |  |  |  | baseline start none → 2025-05-16; baseline finish none → 2025-05-16 |
| 1920 | A minimum of 1 supplier & required contracted agents are qualified and ready to operate under new MHHS arrangements |  |  |  |  |  |  | baseline start none → 2025-09-12; baseline finish none → 2025-09-12 |

| ID | Task | Start | Finish | Duration | Complete | Total float | Predecessors | Other |
| --- | --- | --- | --- | --- | --- | --- | --- | --- |
| 1921 | All LDSOs qualified |  |  |  |  |  |  | baseline start none → 2025-09-10; baseline finish none → 2025-09-10 |
| 1922 | All pre-migration data cleanse activities complete |  |  |  |  |  |  | baseline start none → 2025-08-13; baseline finish none → 2025-08-13 |
| 1923 | All data migration activities set out in the cutover plan complete |  |  |  |  |  |  | baseline start none → 2025-09-24; baseline finish none → 2025-09-24 |
| 1924 | ISD fully populated by Elexon |  |  |  |  |  |  | baseline start none → 2025-09-22; baseline finish none → 2025-09-22 |
| 1925 | Significant Code Review Powers (SCR) enacted by Ofgem (M7) and updates to regulatory code ready to be implemented at M8 |  |  |  |  |  |  | baseline start none → 2024-12-11; baseline finish none → 2024-12-11 |
| 1926 | Migration Schedule approved |  |  |  |  |  | none → 2778 | baseline start none → 2025-08-19; baseline finish none → 2025-08-19 |
| 1927 | Migration Framework approved | 2025-04-30 A | 2025-04-30 A |  | 0% → 100% | 691d → none |  | baseline start none → 2025-04-30; baseline finish none → 2025-04-30 |
| 1928 | Migration Control Centre (MCC) delegation of authority approved | 2025-04-30 A | 2025-04-30 A |  | 0% → 100% | 691d → none |  | baseline start none → 2025-04-30; baseline finish none → 2025-04-30 |
| 1929 | Migration incentives implemented | 2025-04-30 A | 2025-04-30 A |  | 0% → 100% | 691d → none |  | baseline start none → 2025-04-30; baseline finish none → 2025-04-30 |
| 1930 | MCC tested and ready to operate |  |  |  |  |  | none → 2811 | baseline start none → 2025-09-19; baseline finish none → 2025-09-19 |
| 1931 | Service Delivery Operating Model in place |  |  |  |  |  |  | baseline start none → 2025-09-19; baseline finish none → 2025-09-19 |
| 1932 | Service Delivery Operating Model in place (Self-Certification) |  |  |  |  |  |  | baseline start none → 2025-07-03; baseline finish none → 2025-07-03 |
| 1933 | Early Life Support Model defined | 2025-04-29 A | 2025-04-29 A |  | 0% → 100% | 692d → none |  | baseline start none → 2025-04-29; baseline finish none → 2025-04-29 |
| 1934 | Early Life Support Model arrangements in place and operational |  |  |  |  |  |  | baseline start none → 2025-09-12; baseline finish none → 2025-09-12 |
| 1935 | Early Life Support Model arrangements in place and operational (Self-Certification) |  |  |  |  |  |  | baseline start none → 2025-09-12; baseline finish none → 2025-09-12 |
| 1936 | M10/M11 Cutover Plan in place | 2024-05-28 A | 2024-05-28 A |  | 0% → 100% | 932d → none |  | baseline start none → 2024-05-28; baseline finish none → 2024-05-28 |
| 1937 | Central Programme Party Cutover Plans in place |  |  |  |  |  |  | baseline start none → 2025-07-15; baseline finish none → 2025-07-15 |
| 1938 | Production environment in place for LDSOs and Central Parties |  |  |  |  |  |  | baseline start none → 2025-09-22; baseline finish none → 2025-09-22 |
| 1939 | Service activation complete to DIP Production environment for Central Parties and LDSOs |  |  |  |  |  |  | baseline start none → 2025-10-10; baseline finish none → 2025-10-10 |
| 1940 | Cutover Plan executed |  |  |  |  |  |  | baseline start none → 2025-09-23; baseline finish none → 2025-09-23 |
| 1941 | M10 Risk Assessment undertaken |  |  |  |  |  |  | baseline start none → 2025-09-03; baseline finish none → 2025-09-03 |
| 1942 | Roles and responsibilities post-M10 agreed and accepted |  |  |  |  |  |  | baseline start none → 2025-09-19; baseline finish none → 2025-09-19 |
| 1943 | M10 Work off plan agreed (if required) |  |  |  |  |  |  | baseline start none → 2025-09-19; baseline finish none → 2025-09-19 |
| 1944 | Qualification Operating Model in place and operational for all post-M10 activities |  |  |  |  |  |  | baseline start none → 2025-09-19; baseline finish none → 2025-09-19 |
| 1945 | Programme Governance updated to reflect required changes to support Programme delivery post-M10. |  |  |  |  |  |  | baseline start none → 2025-07-01; baseline finish none → 2025-07-01 |
| 1946 | All Suppliers and Agents have made the necessary changes to support losing an MPAN via the Forward Migration Process and gaining an MPAN via the Reverse Migration Process. |  |  |  |  |  |  | baseline start none → 2025-09-19; baseline finish none → 2025-09-19 |
| 1947 | Performance Assurance measures are understood and in place to maintain BAU performance during the Migration period. |  |  |  |  |  |  | baseline start none → 2025-09-12; baseline finish none → 2025-09-12 |
| 1948 | Programme monitoring, assurance and escalation process for beyond M10 is in place and operational |  |  |  |  |  |  | baseline start none → 2025-09-12; baseline finish none → 2025-09-12 |
| 1949 | Central systems ready for migrating MPANs (M10) |  |  |  |  |  | 1772FS+20d, 3449, 2981FS+2d, 2978, 2996, 2957, Programme SIT Participant Cutover Plan Assurance → 1772FS+20d, 3449, 2981FS+2d, 2978, 2996, 2957, 2964 |  |
| 1961 | **NON SIT LDSO QUALIFICATION** |  | 2025-09-19 → 2025-08-22 (-28d) | 489d? → 469d? | 87% → 93% | 589d → 609d |  |  |
| 2021 | **Pre-Integration Testing** |  |  |  | 86% → 97% |  |  |  |
| 2026 | PIT Execution (Non-Functional and Operational) |  |  |  | 33% → 85% |  |  |  |
| 2056 | **Test Window** |  |  |  | 77% → 91% |  |  |  |
| 2057 | **All Non-SIT LDSOs Qualification Testing** |  | 2025-05-16 A |  | 84% → 100% | 1d → none |  |  |
| 2059 | LDSO Alpha |  | 2025-05-05 A |  | 85% → 100% | 9d → none |  |  |
| 2060 | LDSO Bravo |  | 2025-05-05 A |  | 85% → 100% | 9d → none |  |  |
| 2062 | LDSO Delta |  | 2025-04-30 A |  | 74% → 100% | 12d → none |  |  |
| 2064 | LDSO Foxtrot |  | 2025-05-15 A |  | 40% → 100% | 1d → none |  |  |
| 2065 | LDSO Golf |  | 2025-04-25 A |  | 99% → 100% | 15d → none |  |  |
| 2066 | LDSO Hotel |  | 2025-05-05 A |  | 91% → 100% | 9d → none |  |  |
| 2067 | LDSO India |  | 2025-05-05 A |  | 84% → 100% | 9d → none |  |  |
| 2068 | Qualification Testing for Non-SIT LDSOs (Functional, Migration, NFT, Operational) 1 End | 2025-05-16 A | 2025-05-16 A |  | 0% → 100% | 1d → none |  |  |
| 2070 | **Test Result Assurance** | 2025-04-21 → 2025-04-04 A (-17d) | 2025-05-29 → 2025-05-16 (-13d) | 29d → 30d | 0% → 90% | 650d → 680d |  |  |
| 2071 | Test Reports Reviewed By MHHS & Code Bodies & Finalised | 2025-05-16 → 2025-04-04 A (-42d) | 2025-05-29 → 2025-05-16 (-13d) | 10d → 30d | 0% → 90% | 650d → 680d | LDSOs Develop & Submit Test Report (QT Test Completion Report) → 2068FF | baseline start 2025-05-16 → 2025-04-04; baseline finish 2025-05-29 → 2025-05-16 |
| 2072 | Non-SIT LDSOs submission deadline for their QT Test Completion Report to MHHS Programme | 2025-05-29 → 2025-05-16 A (-13d) | 2025-05-29 → 2025-05-16 A (-13d) |  | 0% → 100% | 650d → none | 2071, 2057 → 2071, 2057, 2068 | baseline start 2025-05-29 → 2025-05-16; baseline finish 2025-05-29 → 2025-05-16 |
| 2073 | **Non-SIT LDSO Qualification Closure** | 2025-08-25 → 2025-05-16 (-101d) | 2025-09-19 → 2025-06-27 (-84d) | 20d → 31d |  | 589d → 649d |  |  |
| 2074 | Non-SIT LDSO Qualification Learned Captured | 2025-08-25 → 2025-05-16 (-101d) | 2025-09-12 → 2025-05-29 (-106d) | 15d → 10d |  | 589d → 670d | 2072, 2254 → 2072 | constraint none → start no earlier than 2025-04-16; baseline start 2025-05-30 → 2025-05-16; baseline finish 2025-06-19 → 2025-05-29 |
| 2076 | Non-SIT LDSO Qualification Closure Down | 2025-09-15 → 2025-06-23 (-84d) | 2025-09-19 → 2025-06-27 (-84d) |  |  | 589d → 649d | 2074 → 2075 | constraint none → finish no earlier than 2025-06-26; baseline start 2025-06-20 → 2025-06-23; baseline finish 2025-06-26 → 2025-06-27 |
| 2144 | **S & A QUALIFICATION** |  |  |  | 62% → 63% |  |  |  |
| 2145 | **MHHS Qualification - Qualification Deliverables** |  |  |  | 95% → 96% |  |  |  |
| 2173 | **Qualification Assessment Document** |  |  |  | 87% → 90% |  |  |  |
| 2192 | **Qualification Assessment Document Portal** |  |  |  | 77% → 82% |  |  |  |
| 2200 | QT Wave 1 Participant QAD Application Creation in Portal | 2025-04-21 A | 2025-05-02 A |  | 0% → 100% | 420d → none |  |  |
| 2206 | **MHHS Qualification - SIT Participants** |  |  | 248d → 248d? | 30% → 44% | 505d → 526d |  |  |
| 2211 | **MHHS Qualification - M10-Ready** |  | 2025-09-11 → 2025-09-10 (-1d) | 114d → 113d | 4% → 66% | 5d → 596d |  | was named MHHS Qualification - SIT MVC Participants |
| 2212 | Final QAD Submission Window opens |  |  |  |  |  |  | was named Final QAD Submission Window (MVC) opens |
| 2213 | SIT M10-ready Participants submit Final QAD (exc Test Reports) |  | 2025-05-09 A |  | 8% → 100% | 60d → none |  | was named SIT MVC Participants submit Final QAD (exc Test Reports) |
| 2214 | Completion of Code Bodies review of Final QAD (M10-Ready) | 2025-05-12 A |  |  | 0% → 30% |  |  | was named Completion of Code Bodies review of Final QAD (MVC) |
| 2216 | QAD Sign Off Deadline + Test Reports | 2025-08-22 → 2025-07-23 (-30d) | 2025-08-22 → 2025-07-23 (-30d) |  |  | 5d → 610d | 1772, 2214, 1755 → 2214, 1694FF | was named QAD Sign Off Deadline (MVC) + Test Reports; constraint start no earlier than 2025-07-11 → start no earlier than 2025-07-23; baseline start 2025-08-22 → 2025-07-23; baseline finish 2025-08-22 → 2025-07-23 |
| 2217 | REC Code Manager / BSC PAB Approval of Qualification | 2025-09-11 → 2025-08-13 (-29d) | 2025-09-11 → 2025-08-13 (-29d) |  |  | 5d → 610d | 2216FS+14d → 2216FS+16d | was named REC Code Manager / BSC PAB Approval of Qualification (MVC); baseline start 2025-09-11 → 2025-08-13; baseline finish 2025-09-11 → 2025-08-13 |
| 2236 | **MHHS Qualification - Not M11-Ready** | 2025-05-19 A |  |  | 0% → 1% |  |  | was named MHHS Qualification - SIT Non-MVC Participants; baseline finish 2025-12-22 → 2025-12-17 |
| 2237 | Final QAD Submission Window opens | 2025-05-19 A | 2025-05-19 A |  | 0% → 100% | 613d → none |  | was named Final QAD Submission Window (Non-MVC) opens |
| 2238 | SIT Not M11-Ready Participants submit Final QAD | 2025-05-19 A |  |  | 0% → 1% |  |  | was named SIT Non-MVC Participants submit Final QAD |
| 2239 | Completion of Code Bodies review of Final QAD (Not M11-Ready) |  |  |  |  |  |  | was named Completion of Code Bodies review of Final QAD (Non-MVC) |
| 2241 | QAD Sign Off Deadline (Not M11-Ready) |  |  |  |  |  |  | was named QAD Sign Off Deadline (Non-MVC); baseline start 2025-11-28 → 2025-11-27; baseline finish 2025-11-28 → 2025-11-27 |
| 2242 | SIT Participants are Qualified |  |  |  |  |  |  | was named REC Code Manager / BSC PAB Approval of Qualification (Non-MVC); baseline start 2025-12-22 → 2025-12-17; baseline finish 2025-12-22 → 2025-12-17 |
| 2243 | **MHHS Qualification - Non-SIT LDSO (M10-Ready)** |  |  |  | 56% → 58% |  |  | was named MHHS Qualification - Non-SIT LDSO; baseline finish 2025-09-11 → 2025-09-10 |
| 2250 | Non-SIT LDSO Participants submit Final QAD |  |  |  | 6% → 89% | 49d → 9d | 2249SS-1d → 2249SS-1d, 2068 | constraint none → finish no earlier than 2025-05-23 |
| 2254 | QAD Sign Off Deadline (Non-SIT LDSOs) |  |  |  |  |  | 2252FS+5d, 1772, 2068 → 2252FS+5d, 1772, 2068, 2253 |  |
| 2256 | **MHHS Qualification - Qualification Waves** |  |  |  | 57% → 58% |  |  |  |

| ID | Task | Start | Finish | Duration | Complete | Total float | Predecessors | Other |
| --- | --- | --- | --- | --- | --- | --- | --- | --- |
| 2257 | **Qualification Wave Prep** |  | 2026-02-06 → 2026-02-19 (+13d) | 560d? → 569d? | 94% → 96% | 489d → 480d |  |  |
| 2295 | **Qualification Testing Framework (Test Stubs and Supporting UI)** |  | 2026-02-06 → 2026-02-19 (+13d) | 530d? → 539d? | 93% → 96% | 489d → 480d |  |  |
| 2361 | **MPANs, DIP Messages, Settlement, Consumption, Reference** |  |  |  | 81% → 88% |  |  |  |
| 2402 | Test Data Request + Templates Completed | 2025-06-02 → 2025-07-14 (+42d) | 2025-06-06 → 2025-07-15 (+39d) | 5d → 2d |  | 440d → 426d |  | constraint start no earlier than 2025-06-02 → start no earlier than 2025-07-14; baseline start 2025-06-02 → 2025-07-14; baseline finish 2025-06-06 → 2025-07-15 |
| 2403 | Test Data Generated | 2025-06-09 → 2025-07-16 (+37d) | 2025-06-13 → 2025-07-17 (+34d) | 5d → 2d |  | 440d → 426d |  | baseline start 2025-06-09 → 2025-07-16; baseline finish 2025-06-13 → 2025-07-17 |
| 2404 | Test Data Loaded into QP Systems | 2025-06-16 → 2025-07-18 (+32d) | 2025-07-04 → 2025-08-07 (+34d) |  |  | 440d → 426d |  | baseline start 2025-06-16 → 2025-07-18; baseline finish 2025-07-04 → 2025-08-07 |
| 2405 | Test Data Loaded into QTF + ADO | 2025-07-07 → 2025-08-11 (+35d) | 2025-07-25 → 2025-08-15 (+21d) | 15d → 5d |  | 440d → 425d |  | constraint finish no earlier than 2025-06-17 → finish no earlier than 2025-08-15; baseline start 2025-07-07 → 2025-08-11; baseline finish 2025-07-25 → 2025-08-15 |
| 2407 | Test Data Request + Templates Completed | 2025-07-28 → 2025-09-17 (+51d) | 2025-08-01 → 2025-09-18 (+48d) | 5d → 2d |  | 407d → 387d |  | constraint start no earlier than 2025-07-28 → start no earlier than 2025-09-17; baseline start 2025-07-28 → 2025-09-17; baseline finish 2025-08-01 → 2025-09-18 |
| 2408 | Test Data Generated | 2025-08-04 → 2025-09-19 (+46d) | 2025-08-08 → 2025-09-22 (+45d) | 5d → 2d |  | 407d → 387d |  | baseline start 2025-08-04 → 2025-09-19; baseline finish 2025-08-08 → 2025-09-22 |
| 2409 | Test Data Loaded into QP Systems | 2025-08-11 → 2025-09-23 (+43d) | 2025-08-29 → 2025-10-13 (+45d) |  |  | 407d → 387d |  | baseline start 2025-08-11 → 2025-09-23; baseline finish 2025-08-29 → 2025-10-13 |
| 2410 | Test Data Loaded into QTF + ADO | 2025-09-01 → 2025-10-14 (+43d) | 2025-09-19 → 2025-10-17 (+28d) | 15d → 4d |  | 407d → 387d |  | baseline start 2025-09-01 → 2025-10-14; baseline finish 2025-09-19 → 2025-10-17 |
| 2412 | Test Data Request + Templates Completed | 2025-10-20 → 2025-11-10 (+21d) | 2025-10-24 → 2025-11-11 (+18d) | 5d → 2d |  | 376d → 377d |  | constraint start no earlier than 2025-10-20 → start no earlier than 2025-11-10; baseline start 2025-10-20 → 2025-11-10; baseline finish 2025-10-24 → 2025-11-11 |
| 2413 | Test Data Generated | 2025-10-27 → 2025-11-12 (+16d) | 2025-10-31 → 2025-11-13 (+13d) | 5d → 2d |  | 376d → 377d |  | baseline start 2025-10-27 → 2025-11-12; baseline finish 2025-10-31 → 2025-11-13 |
| 2414 | Test Data Loaded into QP Systems | 2025-11-03 → 2025-11-14 (+11d) | 2025-11-21 → 2025-12-04 (+13d) |  |  | 376d → 377d |  | baseline start 2025-11-03 → 2025-11-14; baseline finish 2025-11-21 → 2025-12-04 |
| 2415 | Test Data Loaded into QTF + ADO | 2025-11-24 → 2025-12-05 (+11d) | 2025-12-12 → 2025-12-11 (-1d) | 15d → 5d |  | 376d → 377d |  | baseline start 2025-11-24 → 2025-12-05; baseline finish 2025-12-12 → 2025-12-11 |
| 2417 | Test Data Request + Templates Completed | 2025-12-15 → 2026-01-19 (+35d) | 2025-12-19 → 2026-01-20 (+32d) | 5d → 2d |  | 256d → 247d |  | constraint start no earlier than 2025-12-15 → start no earlier than 2026-01-19; baseline start 2025-12-15 → 2026-01-19; baseline finish 2025-12-19 → 2026-01-20 |
| 2418 | Test Data Generated | 2025-12-22 → 2026-01-21 (+30d) | 2025-12-26 → 2026-01-22 (+27d) | 5d → 2d |  | 256d → 247d |  | baseline start 2025-12-22 → 2026-01-21; baseline finish 2025-12-26 → 2026-01-22 |
| 2419 | Test Data Loaded into QP Systems | 2025-12-29 → 2026-01-23 (+25d) | 2026-01-16 → 2026-02-12 (+27d) |  |  | 256d → 247d |  | baseline start 2025-12-29 → 2026-01-23; baseline finish 2026-01-16 → 2026-02-12 |
| 2420 | Test Data Loaded into QTF + ADO | 2026-01-19 → 2026-02-13 (+25d) | 2026-02-06 → 2026-02-19 (+13d) | 15d → 5d |  | 256d → 247d |  | baseline start 2026-01-19 → 2026-02-13; baseline finish 2026-02-06 → 2026-02-19 |
| 2437 | **Qualification Wave 1** | 2025-05-05 A |  |  |  |  |  |  |
| 2438 | **Qualification Wave 1 QAD Prep** | 2025-05-05 A |  |  |  | 420d → 419d |  |  |
| 2439 | Initial QAD Submission window opens | 2025-05-05 A | 2025-05-05 A |  | 0% → 100% | 420d → none |  |  |
| 2457 | Qualification Wave 1 QT Execution Start |  |  |  |  |  | 2456, 2453, 1630FS+6d, 2405 → 2456FS+1d, 2453, 2405 |  |
| 2565 | PAB292 | 2025-04-09 A | 2025-04-09 A |  | 0% → 100% | 707d → none |  |  |
| 2566 | PAB293 | 2025-04-24 A | 2025-04-24 A |  | 0% → 100% | 696d → none |  |  |
| 2567 | PAB294 | 2025-05-14 A | 2025-05-14 A |  | 0% → 100% | 682d → none |  |  |
| 2733 | **MIGRATION** |  |  |  | 55% → 62% |  |  |  |
| 2734 | **Regulatory Governance** |  | 2025-01-01 → 2025-06-27 (+177d) | 198d → 325d | 47% → 83% | 776d → 649d |  |  |
| 2735 | Incentive Mods Created |  | 2024-08-30 A |  | 85% → 100% | 776d → none |  |  |
| 2736 | Incentives Implemented | 2024-09-02 → 2025-03-31 A (+210d) | 2025-01-01 → 2025-06-27 (+177d) | 88d → 65d | 0% → 55% | 776d → 649d |  | constraint start no earlier than 2024-07-02 → start no earlier than 2025-03-31; baseline start 2024-09-02 → 2025-03-31; baseline finish 2025-01-01 → 2025-06-27 |
| 2737 | **Migration Framework Agreed and Implemented** |  | 2025-04-29 A |  | 99% → 100% | 692d → none |  |  |
| 2760 | **Consultation 4** |  | 2025-04-29 A |  | 94% → 100% | 692d → none |  |  |
| 2768 | Respond to comments and issue artefacts |  | 2025-04-11 A |  | 70% → 100% | 694d → none |  |  |
| 2769 | Assurance meeting | 2025-04-22 A | 2025-04-22 A |  | 0% → 100% | 692d → none |  |  |
| 2770 | MCAG paper day | 2025-04-22 A | 2025-04-22 A |  | 0% → 100% | 692d → none |  |  |
| 2771 | MCAG Approval of Consultation 4 | 2025-04-29 A | 2025-04-29 A |  | 0% → 100% | 692d → none |  |  |
| 2772 | Framework Baselined at MCAG | 2025-04-29 A | 2025-04-29 A |  | 0% → 100% | 692d → none |  |  |
| 2781 | Supplier submission issued | 2025-04-25 A | 2025-04-25 A |  | 0% → 100% | 632d → none |  | constraint none → start no earlier than 2025-04-25 |
| 2785 | **Supplier Submission Support** | 2025-04-25 A |  |  | 0% → 99% |  |  |  |
| 2786 | Support guides issued | 2025-04-25 A | 2025-04-25 A |  | 0% → 100% | 666d → none |  |  |
| 2787 | Envelope webinar | 2025-05-02 A | 2025-05-02 A |  | 0% → 100% | 666d → none |  |  |
| 2788 | De-minimus webinar | 2025-05-02 A | 2025-05-02 A |  | 0% → 100% | 666d → none |  |  |
| 2789 | Drop-in session 1 | 2025-05-14 A | 2025-05-14 A |  | 0% → 100% | 666d → none |  |  |
| 2793 | **MCC Stood up** |  |  |  | 30% → 49% |  |  |  |
| 2794 | Migration Planning Management Tool Delivery |  |  |  | 30% → 49% |  |  |  |
| 2795 | **MCC Operational** | 2025-04-18 → 2025-04-23 A (+5d) |  | 96d → 93d |  |  |  |  |
| 2796 | **MCC Dress Rehersal 1 - Initialise Schedule (Weekly) Drop 1, 2** | 2025-04-18 → 2025-04-23 A (+5d) |  | 63d → 60d |  |  |  |  |
| 2797 | Issue Dress Rehearsal support information to Participants | 2025-04-18 → 2025-04-23 A (+5d) | 2025-04-18 → 2025-04-23 A (+5d) |  | 0% → 100% | 637d → none |  | constraint start no earlier than 2025-04-18 → start no earlier than 2025-04-23; baseline start 2025-04-18 → 2025-04-23; baseline finish 2025-04-18 → 2025-04-23 |
| 2798 | Kestrel Webinar 1 | 2025-04-18 → 2025-04-23 A (+5d) | 2025-04-18 → 2025-04-23 A (+5d) |  | 0% → 100% | 637d → none |  | baseline start 2025-04-18 → 2025-04-23; baseline finish 2025-04-18 → 2025-04-23 |
| 2799 | Onboard and connectivity testing - Dress Rehearsal with Suppliers (All SIT and Wave 1 mandatory) | 2025-04-25 A | 2025-04-25 A |  | 0% → 100% | 637d → none | 2798FS+6d → 2798FS+3d |  |
| 2800 | Dress rehearsal start | 2025-04-28 A | 2025-04-28 A |  | 0% → 100% | 637d → none |  |  |
| 2814 | **SIT Participant's Prepared for Migration** |  |  |  | 47% → 49% |  |  | was named PP's Prepared for Migration |
| 2817 | Guides Creation |  | 2025-04-30 → 2025-04-24 (-6d) | 45d → 41d | 31% → 34% | 691d → 695d |  | constraint none → finish no earlier than 2025-04-24 |
| 2819 | **Migration Artefact Development and Publication** |  |  |  | 55% → 67% |  |  |  |
| 2862 | **Data Cleanse Plan** |  | 2025-10-15 → 2025-09-24 (-21d) | 685d → 670d | 87% → 93% | 571d → 586d |  |  |
| 2867 | **MTDs** |  | 2025-07-18 → 2025-07-21 (+3d) | 240d → 241d | 62% → 79% | 634d → 633d |  |  |
| 2868 | **ESME ID** |  |  |  | 77% → 93% |  |  |  |
| 2872 | Suppliers complete Work Off plans |  |  |  | 73% → 92% |  |  |  |
| 2874 | **Meter Location and Number of Displayed Register Digits** |  | 2025-07-18 → 2025-07-21 (+3d) | 221d → 222d | 50% → 67% | 634d → 633d |  |  |
| 2878 | Suppliers complete Work Off plans |  | 2025-07-18 → 2025-07-21 (+3d) | 123d → 124d | 41% → 60% | 634d → 633d |  |  |
| 2879 | Meter Location and Number of Displayed Register Digits Complete | 2025-07-18 → 2025-07-21 (+3d) | 2025-07-18 → 2025-07-21 (+3d) |  |  | 634d → 633d |  |  |
| 2880 | **Registration Data** |  | 2025-10-15 → 2025-09-24 (-21d) | 289d → 274d | 81% → 85% | 571d → 586d |  |  |
| 2889 | **Domestic Premises Indicator** |  | 2025-10-15 → 2025-09-24 (-21d) | 29d → 14d |  | 571d → 586d |  |  |
| 2893 | **Connection Type and Meter Type Misalignments** |  |  |  | 14% → 35% |  |  |  |
| 2894 | **Traditional Meters installed on Current Transformers** |  |  |  | 5% → 11% |  |  |  |
| 2895 | Suppliers investigate all MPANs with Traditional Meters installed on a Current Transformer Connection Type |  |  |  | 42% → 80% |  |  |  |
| 2901 | **CHECK Meters** |  |  |  | 21% → 80% |  |  |  |
| 2902 | Suppliers and their appointed Meter Operator investigate MPANs within their portfolio that have incorrectly populated meters with the Meter Type CHECK within MPRS. Meter Operators are required to send a D0312 to remove the CHECK meter from MPRS. |  |  |  | 42% → 80% |  |  |  |
| 2903 | Once CHECK meters are either removed from MPRS or the Meter Type is changed to a valid Meter Type, the LDSO should check that the Connection Type assigned to the MPAN is still valid. | 2025-03-03 A |  |  | 0% → 80% |  |  |  |
| 2906 | **Smart Meter Types installed on CT Connection Types** |  |  |  | 0% → 41% |  |  |  |

| ID | Task | Start | Finish | Duration | Complete | Total float | Predecessors | Other |
| --- | --- | --- | --- | --- | --- | --- | --- | --- |
| 2908 | LDSOs investigate Connection Type misalignments and correct where appropriate | 2025-03-24 A |  |  | 0% → 74% |  |  |  |
| 2912 | **Linked Import / Export MPANs** |  | 2025-07-25 → 2025-07-28 (+3d) | 105d → 106d | 26% → 49% | 629d → 628d |  |  |
| 2913 | LDSOs review and correct linked Import / Export MPANs with Different Connection Types |  | 2025-07-25 → 2025-07-28 (+3d) | 105d → 106d | 26% → 49% | 629d → 628d |  |  |
| 2914 | LDSOs, Import and Export Suppliers review and correct linked Import / Export MPANs with meters in the Advanced and Traditional or Smart Meter Groups |  | 2025-07-25 → 2025-07-28 (+3d) | 105d → 106d | 26% → 49% | 629d → 628d |  |  |
| 2915 | Linked Import / Export MPANs complete | 2025-07-25 → 2025-07-28 (+3d) | 2025-07-25 → 2025-07-28 (+3d) |  |  | 629d → 628d |  |  |
| 2916 | **Related MPANs** |  |  |  | 26% → 50% |  |  |  |
| 2917 | LDSOs review and correct related MPANs with different Connection Types |  |  |  | 34% → 65% |  |  |  |
| 2919 | Suppliers should investigate Related MPANs within different meter groups and verify that they are correct or request that their Meter Operators update the Meter Types where they are incorrect |  |  |  | 26% → 50% |  |  |  |
| 2951 | **Preparation for Cutover to Live** |  |  |  | 0% → 11% |  |  |  |
| 2952 | **Central Systems Prepare for Cutover to Live** |  |  |  | 0% → 31% |  |  |  |
| 2954 | **Development of Comms Approach and Declaration Guidance** | 2025-04-28 A |  |  | 0% → 20% |  |  |  |
| 2955 | Draft Cutover Comms Approach | 2025-04-28 A |  |  | 0% → 20% |  |  |  |
| 2957 | Finalised Cutover Comms Approach shared |  |  |  |  |  | 2956FS+20d, Implementation Group EstablishedFS+20d → 2956FS+20d |  |
| 2958 | **Development of Cutover Plan requirements with Participants** | 2025-04-28 → 2025-04-11 A (-17d) | 2025-09-04 → 2025-08-22 (-13d) | 94d → 96d | 0% → 33% | 19d → 609d |  |  |
| 2959 | Development of Central Parties Cutover Plans | 2025-04-28 → 2025-04-11 A (-17d) | 2025-07-17 → 2025-05-16 (-62d) | 59d → 26d | 0% → 88% | 19d → 659d |  | was named Development of SIT Participant Cutover Plans; constraint start no earlier than 2025-04-28 → start no earlier than 2025-04-11 |
| 2960 | Development of Programme Participant Cutover Plans | 2025-07-17 → 2025-04-11 A (-97d) | 2025-07-17 → 2025-06-30 (-17d) | 0d → 57d | 0% → 40% | 19d → 67d | 2959 → 2959SS | was named SIT Participant Cutover Plans Ready; constraint none → finish no earlier than 2025-06-27 |
| 3115 | **BUSINESS & OPERATIONAL READINESS** |  |  |  | 11% → 18% |  |  |  |
| 3121 | **Early Life Support Model** |  | 2025-04-29 A |  | 99% → 100% | 692d → none |  |  |
| 3126 | MCAG Approval of Early Life Support Model | 2025-04-29 A | 2025-04-29 A |  | 0% → 100% | 692d → none |  |  |
| 3130 | **Service Activation** | 2022-10-31 A |  |  | 0% → 20% |  |  |  |
| 3296 | Add EFD to DIP |  |  |  |  |  | 2217SS, 3294, 3293 → 3294, 3293, 2223SS+3d |  |

## Version 6 (data date 2025-07-01, saved 2025-07-02, file MHHS-DEL1139 - MHHS Plan v6.28.mpp)

Last finish stays 2027-12-23. Complete tasks 1840 → 1978.

Added:

| ID | Task | Duration | Start | Finish | Predecessors | Constraint |
| --- | --- | --- | --- | --- | --- | --- |
| 1563 | eSITAG decision point on end of SIT A testing | 0d | 2025-06-26 A | 2025-06-26 A |  | finish no earlier than 2025-06-26 |
| 1572 | Regression Sprint 4 | 15d | 2025-08-25 | 2025-09-12 | 1571 |  |
| 1581 | SRO/Code Bodies Review SI SIT Funcational & Migration Overarching Exit Report | 5d | 2025-06-26 A | 2025-07-02 | 1580SS | finish no earlier than 2025-07-02 |
| 1583 | SI SIT Functional & Migration Overarching Exit Report Industry Review | 10d | 2025-07-04 | 2025-07-17 | 1582 |  |
| 1586 | SRO Review Settlement and Regression Pathway 2 PP Exit Reports | 5d | 2025-07-17 | 2025-07-23 | 1585SS | finish no earlier than 2025-07-23 |
| 1589 | Programme drafts Settlement and Regression Pathway 3 PP Exit Reports | 13d | 2025-07-28 | 2025-08-13 | 1570SS | start no earlier than 2025-07-28 |
| 1590 | SRO Review Settlement and Regression Pathway 3 PP Exit Reports | 5d | 2025-08-07 | 2025-08-13 | 1589SS | finish no earlier than 2025-08-13 |
| 1591 | Pathway 3 PPs review and sign off Exit Reports | 5d | 2025-08-11 | 2025-08-15 | 1589SS | start no earlier than 2025-08-11 |
| 1592 | Programme drafts Settlement and Regression Pathway 4, 5 & 6 PP Exit Reports | 25d | 2025-08-18 | 2025-09-19 | 1571SS | start no earlier than 2025-08-18 |
| 1596 | SI SIT Migration Testing Test Exit Report Approved | 0d | 2025-08-15 | 2025-08-15 |  | start no earlier than 2025-08-15 |
| 1598 | SI SIT Migration Testing End (incl. confirmation that PPs have submitted their Test Exit Reports to Programme for assurance) | 0d | 2025-08-15 | 2025-08-15 | 1648 | finish no earlier than 2025-08-15 |
| 1667 | SRO / Code Bodies / DIP Manager formal review SI SIT Non-Functional Overarching Exit Report | 5d | 2025-07-14 | 2025-07-18 | 1666 |  |
| 1669 | SI SIT Non-Functional Overarching Exit Report published to PPs for industry review | 0d | 2025-07-18 | 2025-07-18 | 1668 |  |
| 1670 | SI SIT Non-Functional Overarching Exit Report industry review | 10d | 2025-07-21 | 2025-08-01 | 1669 |  |
| 1692 | Programme drafts Pathway 3 PP Exit Report (when Participant completes Operational testing) | 15d | 2025-07-21 | 2025-08-08 | 1688 | start no earlier than 2025-07-21 |
| 1693 | All Pathway 3 Operational Exit Reports and Exit Declarations shared with PPs | 0d | 2025-08-08 | 2025-08-08 | 1688, 1692 |  |
| 1694 | Pathway 3 PPs have reviewed Exit Report and signed Exit Declaration | 5d | 2025-08-11 | 2025-08-15 | 1693 |  |
| 1696 | Programme drafts Pathway 4, 5 & 6 PP Exit Report (when Participant completes Operational testing) | 15d | 2025-08-11 | 2025-08-29 | 1692 |  |
| 1698 | SRO/Code Bodies/DIP Manager Review SI SIT Operational Overarching Exit Report | 5d | 2025-07-28 | 2025-08-01 | 1697SS | finish no earlier than 2025-08-01 |
| 1700 | SI SIT Operational Overarching Exit Report industry review | 10d | 2025-08-04 | 2025-08-15 | 1699 |  |
| 1784 | LDSO Onboarding and Test Data Creation and Support | 169d | 2025-06-02 A | 2026-01-22 |  | start no earlier than 2025-06-02 |
| 1785 | Supplier & Agent Onboarding and Test Data Creation and Support | 260d | 2025-09-01 | 2026-08-28 |  | start no earlier than 2025-09-01 |
| 1810 | **Sandbox Execution** | 330d | 2025-05-26 A | 2026-08-28 |  |  |
| 1816 | UIT E2E Sandbox Preparation Complete | 0d | 2025-05-26 A | 2025-05-26 A |  | start no earlier than 2025-05-26 |
| 1821 | UIT E2E Sandbox Preparation Complete - Supplier and Agent | 0d | 2025-08-25 | 2025-08-25 |  | start no earlier than 2025-08-25 |
| 1886 | M10 Acceptance Criteria Ratification | 0d | 2025-09-24 | 2025-09-24 | 1885FS+2d |  |
| 2035 | Operations Manual Updates Pre-ORT | 14d | 2025-05-16 A | 2025-06-04 A | 2034 | start no earlier than 2025-05-16 |
| 2036 | Operations Manual version 1.4 (ORT) (TORWG Paper Day) | 0d | 2025-06-04 A | 2025-06-04 A |  | start no earlier than 2025-06-04 |
| 2037 | Service User LLSD Updates Post Consultation | 13d | 2025-05-19 A | 2025-06-04 A |  | start no earlier than 2025-05-19 |
| 2038 | Service User LLSD Version 1.2 (ORT) (TORWG Paper Day) | 0d | 2025-06-04 A | 2025-06-04 A | 2036 |  |
| 2039 | CPSD Scenarios and Runbook | 19d | 2025-04-29 A | 2025-05-23 A |  | start no earlier than 2025-04-29 |
| 2040 | CPSD Scenarios and Runbook Shared with MHHS Team for Review | 0d | 2025-05-23 A | 2025-05-23 A | 2039 |  |
| 2041 | CPSD Scenarios and Runbook Review Window | 8d | 2025-05-26 A | 2025-06-04 A | 2040 |  |
| 2042 | CPSD Scenarios and Runbook Released for TORWG (Paper Day) | 0d | 2025-06-04 A | 2025-06-04 A | 2041 |  |
| 2043 | Parent/Child Industry Engagement Session | 0d | 2025-06-06 A | 2025-06-06 A | 2042 | start no earlier than 2025-06-06 |
| 2044 | CPSD Runbook Completed | 0d | 2025-06-11 A | 2025-06-11 A | 2042FS+5d |  |
| 2045 | **Service Documentation V2** | 23d | 2025-07-14 | 2025-08-13 |  |  |
| 2048 | Operations Manual and LLSD v2 Consultation | 10d | 2025-07-17 | 2025-07-30 | 2047 |  |
| 2049 | Operations Manual and LLSD v2 Consultation Completed | 0d | 2025-07-30 | 2025-07-30 | 2048 |  |
| 2050 | Consultation Feedback Implemented Operations Manual and LLSD v2 | 5d | 2025-07-31 | 2025-08-06 | 2049 |  |
| 2051 | Operations Manual and LLSD v2 Feedback Implemented | 0d | 2025-08-06 | 2025-08-06 | 2050 |  |
| 2052 | TORWG Paper Day | 0d | 2025-08-06 | 2025-08-06 | 2051 |  |
| 2053 | TORWG Operations Manual and LLSD v2 Approval | 0d | 2025-08-13 | 2025-08-13 | 2052FS+5d |  |
| 2054 | Operations Manual and LLSD v2 Approved and Completed | 0d | 2025-08-13 | 2025-08-13 | 2053 |  |
| 2095 | **Codification of Service** | 81d | 2025-05-09 A | 2025-08-29 |  |  |
| 2096 | OFGEM Review Meeting | 0d | 2025-05-09 A | 2025-05-09 A |  | start no earlier than 2025-04-04 |
| 2097 | Codification Update at TORWG | 0d | 2025-05-14 A | 2025-05-14 A | 2096 | start no earlier than 2025-05-14 |
| 2098 | "Codify Service Management" - Item raised | 0d | 2025-07-02 | 2025-07-02 | 2099 | start no earlier than 2025-07-02 |
| 2099 | "Codify Service Management" Item Preparation | 36d | 2025-05-14 A | 2025-07-02 | 2097 |  |
| 2100 | Committee Views Ahead of Panel | 6d | 2025-07-03 | 2025-07-10 | 2098 |  |
| 2101 | Initial Panel Committee Views | 0d | 2025-07-10 | 2025-07-10 | 2100 | start no earlier than 2025-07-10 |
| 2102 | Consultation on Codify Service Management | 10d | 2025-07-14 | 2025-07-25 | 2101FS+1d | finish no earlier than 2025-07-25 |
| 2103 | Committee Views Ahead of Final Panel | 14d | 2025-07-28 | 2025-08-14 | 2102 |  |
| 2104 | Final Panel Committee Views | 0d | 2025-08-14 | 2025-08-14 | 2103 | start no earlier than 2025-08-14 |
| 2105 | Submission for Decision to Ofgem ("Codify Service Management") | 0d | 2025-08-18 | 2025-08-18 | 2104FS+1d | start no earlier than 2025-08-18 |
| 2106 | "Codify Service Management" Final Decision Process | 10d | 2025-08-18 | 2025-08-29 | 2105 |  |
| 2107 | "Codify Service Management" Decision Due (TBC and Indicitavely by End of Aug) | 0d | 2025-08-29 | 2025-08-29 | 2106 | start no earlier than 2025-08-29 |
| 2111 | Registration of LDSOs into ServiceNow | 3d | 2025-07-31 | 2025-08-04 | 2110, 2094FF |  |
| 2112 | Helix Service Management Live for LDSO DIP Onboarding | 0d | 2025-08-04 | 2025-08-04 | 2111 | start no earlier than 2025-08-04 |
| 2113 | Helix Service Management Live for MHHS Enduring Arrangements | 500d | 2025-09-01 | 2027-07-30 | 2116 | start no earlier than 2025-09-01 |
| 2114 | **Business Readiness (inc DIP)** | 457d? | 2024-04-02 A | 2025-12-31 |  |  |
| 2115 | Knowledge Transfer triage | 35d? | 2025-04-28 A | 2025-06-13 A |  | start no earlier than 2025-04-28 |
| 2116 | Elexon Leading Triage | 55d | 2025-06-16 A | 2025-08-29 | 2115 | start no earlier than 2025-06-16 |
| 2117 | MHHS Transition (Knowledge Transfer) | 64d | 2025-05-06 A | 2025-08-01 |  | start no earlier than 2025-05-06 |
| 2118 | Artefact Handshake with MHHS | 0d | 2025-08-01 | 2025-08-01 | 2117 |  |
| 2119 | Operational Control Centre (OCC) Development | 85d | 2025-04-07 A | 2025-08-01 |  | start no earlier than 2025-04-07 |
| 2120 | Operational Control Centre (OCC) Live (Service and ULT Triage) | 0d | 2025-08-04 | 2025-08-04 | 2119FS+1d |  |
| 2121 | Operational Control Centre (OCC) Live | 0d | 2025-08-29 | 2025-08-29 |  | finish no earlier than 2025-08-29 |
| 2122 | **DIP Guidance Notes** | 55d | 2025-05-05 A | 2025-07-18 |  |  |
| 2123 | GN/LWI creation & publication | 55d | 2025-05-05 A | 2025-07-18 |  | start no earlier than 2025-05-05 |
| 2124 | Tranche 1 GN/LWI created & published (critical for M10) | 0d | 2025-06-20 A | 2025-06-20 A |  | start no earlier than 2025-06-20 |
| 2125 | Tranche 2 GN/LWI created & published | 0d | 2025-07-04 | 2025-07-04 |  | start no earlier than 2025-07-04 |
| 2126 | Tranche 3 GN/LWI created & published | 0d | 2025-07-18 | 2025-07-18 |  | start no earlier than 2025-07-18 |
| 2127 | DIP Reporting (M11) | 65d | 2025-05-12 A | 2025-08-08 |  | start no earlier than 2025-05-12 |
| 2128 | Functional Training Execution | 85d | 2025-05-05 A | 2025-08-29 |  | start no earlier than 2025-05-05 |
| 2130 | Phase 1 Test Execution (Service Activation and Participant Management) | 48d | 2025-05-14 A | 2025-07-18 |  | finish no earlier than 2025-07-18 |
| 2131 | Phase 2 Test Execution (S&I) | 17d | 2025-06-11 A | 2025-07-11 |  | finish no earlier than 2025-07-11 |
| 2132 | Phase 3 Test Execution (Assurance & mop-up) | 13d | 2025-07-02 | 2025-07-18 |  | start no earlier than 2025-07-02 |
| 2133 | E2E Operational Testing Completed | 1d | 2025-08-08 | 2025-08-08 | 2130, 2131, 2132 | finish no earlier than 2025-08-08 |
| 2158 | **Service Activation Readiness** | 7d | 2025-08-04 | 2025-08-12 |  |  |
| 2174 | **SOLR consultation** | 81d | 2025-04-10 | 2025-07-31 |  |  |
| 2175 | LDSO Workshop | 0d | 2025-06-30 | 2025-06-30 |  | start no earlier than 2025-06-30 |
| 2176 | GLIG | 0d | 2025-07-04 | 2025-07-04 |  | start no earlier than 2025-07-04 |
| 2177 | QWG | 0d | 2025-07-08 | 2025-07-08 |  | start no earlier than 2025-07-08 |
| 2178 | GLIG (Second presentation) | 0d | 2025-07-18 | 2025-07-18 |  | start no earlier than 2025-07-18 |
| 2183 | MDR workshop | 1d | 2025-05-27 A | 2025-05-27 A |  | start no earlier than 2025-05-27 |
| 2185 | MDR consultation ongoing actions | 62d | 2025-05-07 A | 2025-07-31 |  | start no earlier than 2025-05-07 |
| 2190 | **M10-Ready Activation Preparation Tasks** | 11d? | 2025-08-25 | 2025-09-08 | 2189 |  |
| 2205 | M10-Ready Participants Service Activation Preparation Completed | 0d | 2025-09-08 | 2025-09-08 | 2191, 2193, 2194, 2195, 2196, 2197, 2200, 2201, 2202, 2204 | start no earlier than 2025-09-05 |
| 2206 | **M10-Ready (Inlcuding Non-SIT LDSOs) Service Activation Implementation** | 31d? | 2025-08-06 | 2025-09-19 |  |  |
| 2210 | Non-LDSO SIT PP DIP User Promoted to Production | 1d | 2025-09-12 | 2025-09-12 | 2209 | start no earlier than 2025-09-12 |
| 2215 | 1st ISD Publish (7 day window for this activity is consistent with Code requirements) | 6d | 2025-09-11 | 2025-09-18 | 2209SS, 2214SS | start no earlier than 2025-09-11 |
| 2217 | M10-Ready Service Activation Implementation Completed | 0d | 2025-09-19 | 2025-09-19 | 2208, 2207, 2209, 2210, 2212, 2215, 2216 | start no earlier than 2025-09-19 |
| 2219 | **M10-Ready Service Activation Implementation MDD** | 7d | 2025-09-10 | 2025-09-19 |  |  |
| 2225 | Non-SIT LDSO & SIT MVC Service Activation Implementation MDD Completed | 0d | 2025-09-19 | 2025-09-19 | 2224 | finish no earlier than 2025-09-19 |
| 2226 | **Non-SIT LDSO & SIT Service Activation Hypercare (M10 Ready)** | 54d | 2025-09-18 | 2025-12-02 |  |  |
| 2232 | **DIP Guidance Notes** | 55d | 2025-05-05 A | 2025-07-18 |  |  |
| 2233 | GN/LWI creation & publication | 55d | 2025-05-05 A | 2025-07-18 |  | start no earlier than 2025-05-05 |
| 2234 | Tranche 1 GN/LWI created & published (critical for M10) | 0d | 2025-06-20 A | 2025-06-20 A |  | start no earlier than 2025-06-20 |
| 2235 | Tranche 2 GN/LWI created & published | 0d | 2025-07-04 | 2025-07-04 |  | start no earlier than 2025-07-04 |
| 2236 | Tranche 3 GN/LWI created & published | 0d | 2025-07-18 | 2025-07-18 |  | start no earlier than 2025-07-18 |
| 2237 | DIP Reporting (M11) | 65d | 2025-05-12 A | 2025-08-08 |  | start no earlier than 2025-05-12 |
| 2238 | Functional Training Execution | 85d | 2025-05-05 A | 2025-08-29 |  | start no earlier than 2025-05-05 |
| 2239 | **Operational Readiness E2E Testing** | 64d | 2025-05-13 A | 2025-08-08 |  |  |
| 2240 | Phase 1 Test Execution (Service Activation and Participant Management) | 44d | 2025-05-13 A | 2025-07-11 |  | start no earlier than 2025-05-13 |
| 2241 | Phase 2 Test Execution (S&I) | 24d | 2025-06-10 A | 2025-07-11 |  | start no earlier than 2025-06-03 |
| 2242 | Phase 3 Test Execution (Assurance & mop-up) | 12d | 2025-06-26 | 2025-07-11 |  | start no earlier than 2025-06-26 |
| 2243 | E2E Operational Testing Completed | 0d | 2025-08-08 | 2025-08-08 | 2240, 2241, 2242 | finish no earlier than 2025-08-08 |
| 2244 | **M11-Ready Activation Preparation Tasks** | 9d? | 2025-10-06 | 2025-10-16 | 2189 |  |
| 2253 | M11-Ready Participants Service Activation Preparation Completed | 0d | 2025-10-16 | 2025-10-16 | 2245, 2246, 2247, 2248, 2249, 2250, 2252 | start no earlier than 2025-09-05 |
| 2254 | **M11-Ready Service Activation Implementation** | 19d? | 2025-09-25 | 2025-10-22 |  |  |
| 2255 | **Pathway 4 PPs** | 6d? | 2025-09-25 | 2025-10-03 |  |  |
| 2256 | PAB Approval Completed | 0d | 2025-09-25 | 2025-09-25 | 2507, 2510 | start no earlier than 2025-09-10 |
| 2258 | Add EFD (ISD Calendar Date) to DIP | 0d | 2025-09-25 | 2025-09-25 | 2257 |  |
| 2263 | Go Live ISD | 0d | 2025-10-03 | 2025-10-03 | 2262 |  |
| 2264 | Publish MDD | 6d | 2025-09-26 | 2025-10-03 | 2257 |  |
| 2266 | Pathway 4 Service Activation Implementation Completed | 0d | 2025-10-03 | 2025-10-03 | 2258, 2259, 2260, 2263, 2265 | start no earlier than 2025-09-19 |
| 2267 | **Pathway 5 PPs** | 5d? | 2025-10-15 | 2025-10-22 |  |  |
| 2268 | PAB Approval Completed | 0d | 2025-10-15 | 2025-10-15 | 2507, 2510 | start no earlier than 2025-09-10 |
| 2270 | Add EFD (ISD Calendar Date) to DIP | 0d | 2025-10-15 | 2025-10-15 | 2269 | start no earlier than 2025-10-15 |
| 2273 | DIP Production Success Checks | 1d? | 2025-10-16 | 2025-10-16 | 2270, 2272 |  |
| 2275 | Go Live ISD | 0d | 2025-10-22 | 2025-10-22 | 2274 | start no earlier than 2025-10-17 |
| 2276 | Publish MDD | 5d | 2025-10-16 | 2025-10-22 | 2269 |  |
| 2277 | MDD Go Live | 0d | 2025-10-22 | 2025-10-22 | 2276 |  |
| 2278 | Pathway 5 Service Activation Implementation Completed | 0d | 2025-10-22 | 2025-10-22 | 2269, 2268, 2270, 2271, 2272, 2275 | start no earlier than 2025-09-19 |
| 2279 | **M11-Ready Service Activation Implementation MDD** | 5d | 2025-10-13 | 2025-10-17 |  |  |
| 2280 | MDD Final Circular Completed | 0d | 2025-10-15 | 2025-10-15 | 2257, 2269 | finish no earlier than 2025-09-10 |
| 2283 | MDD Go Live | 0d | 2025-10-17 | 2025-10-17 | 2282 | finish no earlier than 2025-09-18 |
| 2284 | M11-Ready Service Activation Implementation MDD Completed | 0d | 2025-10-17 | 2025-10-17 | 2280, 2281, 2282, 2283 | finish no earlier than 2025-09-18 |
| 2285 | **M11-Ready Service Activation Hypercare** | 16d | 2025-10-15 | 2025-11-05 |  |  |
| 2291 | M11-Ready Service Activation Hypercare Completed | 0d | 2025-11-05 | 2025-11-05 | 2290 |  |
| 2292 | **Not M11-Ready Service Activation Preparation Tasks** | 44d? | 2025-10-13 | 2025-12-11 | 2189 |  |
| 2293 | Review Entry / Exit Criteria & Lessons Learned | 1d? | 2025-12-01 | 2025-12-01 |  | start no earlier than 2025-12-01 |
| 2294 | Identify Resources | 1d | 2025-12-01 | 2025-12-01 | 2186 | start no earlier than 2025-12-01 |
| 2295 | Agree & Understand Support Model | 1d | 2025-12-02 | 2025-12-02 |  | start no earlier than 2025-12-02 |
| 2296 | Confirm Training complete | 1d | 2025-12-03 | 2025-12-03 | 2295 | start no earlier than 2025-08-27 |
| 2297 | Engagement / Communications with Participants | 1d | 2025-10-16 | 2025-10-16 | 2296 | start no earlier than 2025-10-16 |
| 2300 | Provide LWIs | 1d? | 2025-12-10 | 2025-12-10 |  | start no earlier than 2025-12-10 |
| 2302 | Not M11-Ready Participants Service Activation Preparation Completed | 0d | 2025-12-11 | 2025-12-11 | 2294, 2295, 2296, 2297, 2298, 2299, 2301 | start no earlier than 2025-09-05 |
| 2303 | **Not M11-Ready Service Activation Implementation** | 43d? | 2025-10-30 | 2025-12-30 |  |  |
| 2304 | **First Pathway 6 PAB** | 38d? | 2025-10-30 | 2025-12-23 |  |  |
| 2305 | PAB Approval Completed | 0d | 2025-12-17 | 2025-12-17 | 2520 | start no earlier than 2025-09-10 |
| 2307 | Add EFD (ISD Calendar Date) to DIP | 0d | 2025-10-30 | 2025-10-30 | 2306, 2305 | start no earlier than 2025-09-11 |
| 2310 | DIP Production Success Checks | 1d? | 2025-12-23 | 2025-12-23 | 2307, 2309 | start no earlier than 2025-12-23 |
| 2312 | Go Live ISD | 0d | 2025-11-07 | 2025-11-07 | 2311 | start no earlier than 2025-09-18 |
| 2313 | Publish MDD | 6d | 2025-10-31 | 2025-11-07 | 2306 |  |
| 2314 | MDD Go Live | 0d | 2025-11-07 | 2025-11-07 | 2313 |  |
| 2315 | Service Activation Implementation Completed | 0d | 2025-11-07 | 2025-11-07 | 2312, 2314, 2307, 2308, 2309, 2311 |  |
| 2316 | **Final Pathway 6 PAB** | 9d? | 2025-12-17 | 2025-12-30 |  |  |
| 2318 | Add EFD (ISD Calendar Date) to DIP | 0d | 2025-12-17 | 2025-12-17 | 2317 | start no earlier than 2025-09-11 |
| 2320 | DIP Production Success Checks | 1d? | 2025-12-23 | 2025-12-23 | 2318, 2319 | start no earlier than 2025-12-23 |
| 2322 | Go Live ISD | 0d | 2025-12-30 | 2025-12-30 | 2321 | start no earlier than 2025-09-18 |
| 2323 | Publish MDD | 7d | 2025-12-22 | 2025-12-30 | 2317FS+2d |  |
| 2324 | MDD Go Live | 0d | 2025-12-30 | 2025-12-30 | 2323 |  |
| 2325 | Service Activation Implementation Completed | 0d | 2025-12-30 | 2025-12-30 | 2322, 2324 |  |
| 2326 | **Not M11-Ready Service Activation Implementation MDD** | 9d | 2025-12-17 | 2025-12-30 |  |  |
| 2328 | MDD Manual Update | 3d | 2025-12-24 | 2025-12-26 | 2327FS+4d | finish no earlier than 2025-09-15 |
| 2329 | MDD Publish | 5d | 2025-12-24 | 2025-12-30 | 2328SS | start no earlier than 2025-12-22 |
| 2330 | MDD Go Live | 0d | 2025-12-30 | 2025-12-30 | 2329 | finish no earlier than 2025-09-18 |
| 2331 | Non-SIT LDSO & SIT MVC Service Activation Implementation MDD Completed | 0d | 2025-12-30 | 2025-12-30 | 2327, 2328, 2329, 2330 | finish no earlier than 2025-09-18 |
| 2332 | **Not M11-Ready Service Activation Hypercare** | 11d | 2025-12-17 | 2025-12-31 |  |  |
| 2333 | Monitoring | 11d | 2025-12-17 | 2025-12-31 |  | start no earlier than 2025-12-17 |
| 2334 | Reporting | 11d | 2025-12-17 | 2025-12-31 |  | start no earlier than 2025-12-17 |
| 2336 | Closed Down Activities | 3d | 2025-12-29 | 2025-12-31 | 2333SS, 2334SS, 2335SS | start no earlier than 2025-12-29 |
| 2337 | Inform MHHSP | 2d | 2025-12-30 | 2025-12-31 | 2336SS | start no earlier than 2025-12-30 |
| 2338 | Not M11-Ready Service Activation Hypercare Completed | 0d | 2025-12-31 | 2025-12-31 | 2337 |  |
| 2339 | **Helix Solution Build** | 255d? | 2024-08-19 A | 2025-08-08 |  |  |
| 2340 | M10 Build Candidate | 52d | 2025-04-28 A | 2025-07-08 |  | start no earlier than 2025-04-28 |
| 2341 | Helix Code Uplifts (TBC) | 23d | 2025-07-09 | 2025-08-08 | 2340 | start no earlier than 2025-07-09 |
| 2356 | **SAT Cycle 1** | 114d | 2025-02-07 A | 2025-07-16 | 2355 |  |
| 2357 | **Legacy** | 99d | 2025-02-07 A | 2025-06-25 A |  |  |
| 2358 | GMT | 89d | 2025-02-07 A | 2025-06-11 A |  |  |
| 2359 | P0210 file shared for NESO Validation | 0d | 2025-05-23 A | 2025-05-23 A |  | start no earlier than 2025-05-23 |
| 2360 | NESO Validation Period (GMT) | 5d | 2025-05-28 A | 2025-06-03 A | 2359 | start no earlier than 2025-05-28 |
| 2361 | Long | 13d | 2025-05-28 A | 2025-06-13 A |  | start no earlier than 2025-05-28 |
| 2362 | Helix SAT Confidence Check 1 | 0d | 2025-06-10 A | 2025-06-10 A |  | finish no earlier than 2025-06-10 |
| 2363 | P0210 file shared for NESO Validation | 0d | 2025-06-13 A | 2025-06-13 A | 2361 | start no earlier than 2025-06-13 |
| 2364 | Helix SAT Confidence Check 2 | 0d | 2025-06-13 A | 2025-06-13 A |  | finish no earlier than 2025-06-13 |
| 2365 | NESO Validation Period (Long) | 5d | 2025-06-16 A | 2025-06-20 A | 2363 | start no earlier than 2025-06-16 |
| 2366 | BST | 13d | 2025-06-02 A | 2025-06-18 A |  | start no earlier than 2025-06-02 |
| 2367 | P0210 file shared for NESO Validation | 0d | 2025-06-18 A | 2025-06-18 A | 2366 |  |
| 2368 | NESO Validation Period (BST) | 5d | 2025-06-19 A | 2025-06-25 A |  | start no earlier than 2025-06-19 |
| 2369 | Trading Dispute | 3d | 2025-06-18 A | 2025-06-20 A |  | start no earlier than 2025-06-18 |
| 2370 | **Transition** | 36d | 2025-05-28 A | 2025-07-16 |  |  |
| 2371 | GMT | 19d | 2025-05-28 A | 2025-06-23 |  | start no earlier than 2025-05-28 |
| 2372 | P0210 file shared for NESO Validation | 0d | 2025-06-13 A | 2025-06-13 A |  | finish no earlier than 2025-06-13 |
| 2373 | NESO Validation Period (GMT) | 5d | 2025-06-17 A | 2025-06-23 A | 2372 | finish no earlier than 2025-06-23 |
| 2374 | Long | 4d | 2025-06-24 A | 2025-06-27 |  | start no earlier than 2025-06-24 |
| 2375 | P0210 file shared for NESO Validation | 0d | 2025-06-27 A | 2025-06-27 A | 2374 |  |
| 2376 | NESO Validation Period (Long) | 5d | 2025-06-30 A | 2025-07-04 A | 2375 | start no earlier than 2025-06-30 |
| 2377 | BST | 4d | 2025-06-26 A | 2025-07-01 |  | start no earlier than 2025-06-26 |
| 2378 | P0210 file shared for NESO Validation | 0d | 2025-07-01 A | 2025-07-01 A | 2377 |  |
| 2379 | NESO Validation Period (BST) | 5d | 2025-07-03 A | 2025-07-09 | 2378 | finish no earlier than 2025-07-09 |
| 2380 | Short | 3d | 2025-07-01 A | 2025-07-03 |  | start no earlier than 2025-07-01 |
| 2381 | P0210 file shared for NESO Validation | 0d | 2025-07-03 A | 2025-07-03 | 2380 |  |
| 2382 | NESO Validation Period (Short) | 5d | 2025-07-04 | 2025-07-10 | 2381 | start no earlier than 2025-07-04 |
| 2383 | DCP MPAN Mig | 3d | 2025-07-01 A | 2025-07-03 A |  | start no earlier than 2025-07-01 |
| 2384 | ISD | 3d | 2025-07-01 | 2025-07-03 |  | start no earlier than 2025-07-01 |
| 2385 | Data Agg | 6d | 2025-07-04 A | 2025-07-11 |  | start no earlier than 2025-07-04 |
| 2386 | M16 | 3d | 2025-07-14 A | 2025-07-16 A |  | start no earlier than 2025-07-14 |
| 2387 | End of Cycle 1 | 0d | 2025-07-16 | 2025-07-16 |  | start no earlier than 2025-07-16 |
| 2388 | **SAT Cycle 2** | 12d | 2025-07-17 | 2025-08-01 |  |  |
| 2389 | **Legacy** | 12d | 2025-07-17 | 2025-08-01 |  |  |
| 2390 | Pre-M10 | 1d | 2025-07-17 | 2025-07-17 |  | start no earlier than 2025-07-17 |
| 2391 | GMT & BST & Long | 6d | 2025-07-18 | 2025-07-25 |  | start no earlier than 2025-07-18 |
| 2392 | NESO Validation Period (GMT & BST & Long) | 5d | 2025-07-28 | 2025-08-01 | 2391 |  |
| 2393 | Trading Dispute | 2d | 2025-07-28 | 2025-07-29 |  | start no earlier than 2025-07-28 |
| 2394 | **Transition** | 4d | 2025-07-24 | 2025-07-29 |  |  |
| 2395 | ISD | 4d | 2025-07-24 | 2025-07-29 |  | start no earlier than 2025-07-24 |
| 2396 | Data Agg | 3d | 2025-07-24 | 2025-07-28 |  | start no earlier than 2025-07-24 |
| 2397 | End of Cycle 2 | 0d | 2025-08-01 | 2025-08-01 |  | start no earlier than 2025-08-01 |
| 2398 | SAT Exit Report | 5d | 2025-08-01 | 2025-08-07 | 2397 |  |
| 2399 | SAT Complete | 0d | 2025-08-01 | 2025-08-01 |  | start no earlier than 2025-08-01 |
| 2400 | DR Testing | 45d | 2025-04-28 A | 2025-06-27 |  | start no earlier than 2025-04-28 |
| 2401 | Pen Testing | 40d? | 2025-04-28 A | 2025-06-20 A |  | start no earlier than 2025-04-28 |
| 2402 | Production Environment Build | 24d | 2025-06-30 | 2025-07-31 |  | finish no earlier than 2025-07-31 |
| 2403 | Production Environment Base Platform Sign-off | 0d | 2025-08-08 | 2025-08-08 | 2402FF | finish no earlier than 2025-08-08 |
| 2404 | **Implementation (Helix & DIP)** | 116d | 2025-04-28 A | 2025-10-06 |  |  |
| 2405 | Go / No-Go (DIP & SM) | 0d | 2025-07-31 | 2025-07-31 | 2110, 2124, 2125, 2126 | start no earlier than 2025-07-31 |
| 2406 | Implementation Readiness (inc Technical Readiness, Approach and Runbook, Walkthrough / Rehearsals | 71d | 2025-04-28 A | 2025-08-04 |  | start no earlier than 2025-04-28 |
| 2407 | M10 Implementation Approach & Go-Live Runbook | 46d | 2025-04-28 A | 2025-06-30 |  | start no earlier than 2025-04-28 |
| 2408 | DIP Production Build | 15d | 2025-06-09 A | 2025-06-27 |  | start no earlier than 2025-06-09 |
| 2409 | Final Production Deployment | 19d | 2025-07-07 | 2025-07-31 |  | start no earlier than 2025-07-07 |
| 2410 | DIP Portal Available | 0d | 2025-08-04 | 2025-08-04 | 2409 | finish no earlier than 2025-08-04 |
| 2411 | DIP Technical Onboarding for LDSOs | 34d | 2025-08-04 | 2025-09-18 | 2409, 2410FS-1d, 2112FS-1d, 2405 |  |
| 2412 | ISD Dress Rehearsals | 25d | 2025-07-07 | 2025-08-08 |  | start no earlier than 2025-07-07 |
| 2413 | Go / No-Go (Helix Central Systems) | 0d | 2025-08-08 | 2025-08-08 | 2399, 2403, 1570 | finish no earlier than 2025-08-08 |
| 2414 | Service Activation Implementation | 6d | 2025-08-15 | 2025-08-22 | 2413FS+4d |  |
| 2415 | ISD Data Migration | 6d | 2025-08-15 | 2025-08-22 | 2413FS+4d, 2398, 2412 |  |
| 2416 | DAH & ISD Dark Mode | 0d | 2025-08-26 | 2025-08-26 | 2415FS+2d |  |
| 2417 | Dual Run (Pre-Prod) | 16d | 2025-08-27 | 2025-09-17 | 2416SS-1d | start no earlier than 2025-08-27 |
| 2418 | M10 Cutover Weekend (20/09 and 21/09) | 2d | 2025-09-19 | 2025-09-22 | 2417 | start no earlier than 2025-09-19 |
| 2419 | Post Implementation Review | 1d | 2025-10-06 | 2025-10-06 | 2418FS+9d | start no earlier than 2025-10-06 |
| 2517 | QAD Sign Off Deadline + Test Reports | 0d | 2025-10-09 | 2025-10-09 |  | start no earlier than 2025-10-09 |
| 2518 | REC Code Manager / BSC PAB Approval of Qualification (first Pathway 6 PAB) | 0d | 2025-10-30 | 2025-10-30 | 2517FS+16d |  |
| 2519 | QAD Sign Off Deadline + Test Reports | 0d | 2025-11-26 | 2025-11-26 |  | start no earlier than 2025-11-26 |
| 2520 | REC Code Manager / BSC PAB Approval of Qualification (final Pathway 6 PAB) | 0d | 2025-12-17 | 2025-12-17 | 2519FS+16d |  |
| 3016 | Ofgem Incentives Approval | 0d | 2025-09-22 | 2025-09-22 |  | start no earlier than 2025-09-22 |
| 3017 | Incnentives Implementation | 5d | 2025-09-22 | 2025-09-26 | 3016 |  |
| 3067 | Drop-in session 4 | 0d | 2025-06-18 A | 2025-06-18 A | 3066FS+5d | start no earlier than 2025-06-18 |
| 3077 | Test Scripts shared with Participants | 0d | 2025-06-02 A | 2025-06-02 A |  | start no earlier than 2025-06-02 |
| 3078 | Dress rehearsal 1 start | 0d | 2025-06-09 A | 2025-06-09 A |  | start no earlier than 2025-06-09 |
| 3079 | Supplier Schedule Submission #2 complete | 1d | 2025-06-20 A | 2025-06-20 A |  | start no earlier than 2025-06-20 |
| 3080 | Consolidate baseline schedule | 15d | 2025-06-23 A | 2025-07-11 | 3079 |  |
| 3081 | Consolidated baseline schedule published to industry | 0d | 2025-07-11 | 2025-07-11 | 3080 |  |
| 3082 | Baselined Schedule available for download | 1d | 2025-07-14 | 2025-07-14 | 3081 |  |
| 3086 | MCAG approval of Baseline Migration schedule | 0d | 2025-07-22 | 2025-07-22 | 3085 | finish no earlier than 2025-07-22 |
| 3097 | Supplier Readiness Assessments for Sprint 0 | 20d | 2025-08-29 | 2025-09-25 | 3096 |  |
| 3098 | Legacy Settlement run stability assessment | 16d | 2025-09-25 | 2025-10-16 | 3097FS-1d | start no earlier than 2025-09-25 |
| 3464 | MHHSP Enabled Confirmation | 2d | 2025-12-22 | 2025-12-23 |  | finish no earlier than 2025-12-23 |
| 3488 | MHHSP Enabled Confirmation | 2d | 2026-03-02 | 2026-03-03 |  | finish no earlier than 2026-03-03 |
| 3522 | MHHSP Enabled Confirmation | 2d | 2025-02-24 | 2025-02-25 |  | finish no earlier than 2025-02-25 |
| 3526 | Create M16 in Customer Solution | 2d | 2025-02-26 | 2025-02-27 |  | finish no earlier than 2025-02-27 |
| 3527 | Publish ISD | 2d | 2025-02-26 | 2025-02-27 |  | finish no earlier than 2025-02-27 |

Removed: 199 Design Handover; 200 Creation of the Configuration Management Database; 201 Identify all baselined design artefacts; 202 Create CMBD; 203 Knowledge Transfer; 204 Elexon to document knowledge transfer requirements; 205 Review Requirements; 206 Agree Success Criteria; 207 Identify Key personel with Elexon; 208 Draft Agenda for initial meeting; 209 Define cadence for handover sessions; 210 Share Design Information; 211 Conduct Initial Handover Session; 212 Triage Sessions; 213 Design Triage Sessions; 214 Test Triage Sessions; 215 Knowledge Base; 216 Document Knowledge base update process; 217 Document Design updates to Collaboration Base; 218 FreshDesk; 219 Agree Indicative Handover of FreshDesk Calls to Service Now; 220 Prepare Comms to Industry; 221 Issue Comms to Industry; 222 Redirect Design Mailbox to Service Now; 223 Archive Freshdesk calls; 224 Decommission FreshDesk; 225 iServer; 226 Gather Licensing information; 227 Inform Orbus of iServer support termination; 228 Produce iServer decomissioning pack; 229 Publish iServer decommising pack on the Clock; 230 Clear down old information; 231 Clear down accounts; 232 Identify Collaboration Base Design Dependencies on iServer; 233 Remove Design dependencies; 234 Close down iServer; 1609 Assurance of PPs Test Completion Reports; 1618 SRO Review SI SIT Functional & Migration Overarching Exit Report; 1619 SITAG endorses the SI SIT Functional & Migration Overarching Test Exit Report; 1627 SITWG Review status of SI SIT Settlement and Regression Overarching Exit Report; 1628 Develop document; 1629 Review & agree document; 1646 SAT first run; 1647 First run complete; 1648 SAT test second run; 1649 Second run complete; 1650 Contingency test time; 1651 Demand Disconnection Event (DDE); 1652 Trading Disputes; 1653 NESO; 1654 P210 Test files to NESO; 1655 NESO; 1656 Estimated all SAT tests completed; 1657 Test Completion Report Drafting; 1658 Test Completion Report/Recommendation; 1659 SAT is signed off by the SAA Value Stream Lead / Head of Product (SAT complete); 1660 MHHS Programme Assurance of Helix E2E SAT; 1661 MHHS Programme Assurance Start; 1662 Ongoing MHHS Programme Assurance; 1663 MHHS Programme Assurance End; 1707 SRO Review SI SIT Functional & Migration Overarching Exit Report; 1708 SITAG endorses the SI SIT Functional & Migration Overarching Test Exit Report; 1717 Develop document; 1718 Review & agree document; 1722 Assurance of PPs Test Completion Reports; 1729 Assurance of PPs Test Completion Reports; 1738 Develop document; 1739 Review & agree document; 1756 Assurance of PPs Test Completion Reports; 1764 SRO Review SI SIT Operational Overarching Exit Report; 1765 Develop document; 1766 Review & agree document; 1769 SIT Test Exit Report; 1770 Develop document; 1771 Review & agree document; 2097 Service User LLSD Version 1.2; 2241 QAD Sign Off Deadline (Not M11-Ready); 2779 Supplier Commission 2; 2780 Confirm / validate contacts for all Suppliers; 2781 Supplier submission issued; 2782 Supplier submission deadline; 2783 Second Supplier Submission complete; 2784 Publish and baseline Migration Schedule; 2814 SIT Participant's Prepared for Migration; 2815 Prep for Envelope Webinar; 2816 Envelope/Submission Webinar; 2817 Guides Creation; 2818 Support Channels; 3130 Service Activation; 3152 Define Service Activation Scenarios & Scripts; 3153 Define Service Activation Test plan; 3154 Test Execution [Placeholder]; 3155 Service Activation Test Scenarios Completed; 3176 SOLR consultation; 3185 Perform Non-SIT LDSO Activities (M10 Ready); 3188 DIP - Promote to production Environment; 3191 ISD - Replicate Entity Forms from CS Completed; 3194 Non-SIT LDSO & SIT MCV Activation Preparation Tasks (M10 Ready); 3209 Non-SIT LDSO & SIT MVC Service Activation Preparation Completed; 3210 Non-SIT LDSO & SIT MVC Service Activation Implementation (M10 Ready Pathway 1); 3219 1st ISD Publish; 3220 Go-Live ISD; 3221 Non-SIT LDSO SIT MVC Service Activation Implementation Completed; 3222 Non-SIT LDSO & SIT MVC Service Activation Implementation MDD (M10 Ready); 3228 Non-SIT LDSO & SIT MVC Service Activation Hypercare (M10 Ready); 3234 Non-SIT LDSO Service &SIT MVC Activation Hypercare Completed; 3235 Non-SIT LDSO & SIT MVC Service Activation Retro and Go/No-Go (M11 Ready); 3236 Review; 3237 Lessons Learned; 3238 SIT Non-MVC Service Activation Readiness Review Against Entry/Exit Criteria; 3239 SIT Non-MVC Service Activation Preparation Tasks (M11 Not Ready); 3240 Review Entry/Exit Criteria & Lessons Learned; 3242 Confirmation from Qualification of Wave Participants Complete; 3246 Internal Communications; 3247 Agree Content for Livewire; 3248 Publish Content for Livewire; 3253 SIT Non-MVC Service Activation Preparation Tasks Completed; 3254 SIT Non-MVC Service Activation Implementation (M11 Not Ready); 3257 Add EFD(ISD Calendar Date) to DIP; 3263 SIT Non-MVC Service Activation Implementation Completed; 3264 SIT Non-MVC Service Activation Implementation MDD (M11 Not Ready); 3269 SIT Non-MVC Service Activation Implementation MDD Completed; 3270 SIT Non-MVC Service Activation Hypercare (M11 Not Ready); 3276 Non-SIT LDSO Service Activation Hypercare Completed; 3277 SIT Non-MVC Service Activation Retro & Go/No Go (M11 Not Ready); 3278 Review; 3279 Lessons Learned; 3280 Wave 1 - Service Activation Readiness Review Against Entry/Exit Criteria; 3281 Phase 1 - Preparation; 3282 SIT MVC; 3283 SIT MVC Service Activation Preparation Tasks; 3284 Identify operational resources; 3285 Define and approve operational support model; 3286 Confirm SA Training completed; 3287 Participant Engagement / Communications; 3288 Internal Communications; 3291 Provide opeartional resources with LWIs; 3293 SIT MVC Service Activation Preparation Tasks Complete; 3294 MHHSP Confirms SIT MVC PPs MHHS Enabled; 3295 SIT MVC Service Activation Implementation; 3298 SIT LDSOs Create Certificates and Test Connectivity; 3299 SIT MVC S&As Create Certificates and Test Connectivity; 3302 SIT LDSOs to update systems with ISD; 3303 SIT MVC S&As to update systems with ISD; 3304 SIT MVC Service Activation Implementation Complete; 3305 SIT MVC Service Activation Implementation MDD; 3308 SIT MVC Service Activation Implementation MDD Complete; 3309 SIT MVC Service Activation Hypercare; 3310 Service & Process Monitoring; 3315 SIT MVC Service Activation Hypercare Complete; 3316 SIT Non-MVC; 3319 MHHSP Confirms SIT Non-MVC PPs MHHS Enabled; 3320 SIT Non-MVC Service Activation Implementation; 3321 Add EDF to DIP; 3323 SIT non-MVC S&As Create Certificates and Test Connectivity; 3326 SIT non-MVC S&As to update systems with ISD; 3327 SIT Non-MVC Service Activation Implementation Complete; 3328 SIT Non-MVC Service Activation Implementation MDD; 3331 SIT Non-MVC Service Activation Implementation MDD Complete; 3332 Non-SIT MVC Service Activation Hypercare; 3338 Non-SIT MVC Service Activation Hypercare Complete (M); 3425 MDD Manual Load; 3426 MDD Update; 3430 Daily Reporting; 3432 SA Hypercare Close Down Activities; 3433 Handover to MHHSP; 3439 Create Entity Forms in Customer Solution; 3441 DIP - Enable Technology capabilities for participants; 3442 DIP - Add EFD to DIP; 3443 ISD - Replicate Entity Forms from CS; 3444 MDD - Load MHHS roles; 3446 SIT Non-MVC Service Activation Preparation Tasks; 3447 Helix Preparatory Activities Complete; 3452 PAB Approval; 3453 Add EFD to DIP; 3454 DIP Promoted to Production; 3459 MDD Manual Load; 3460 MDD Update; 3464 Service& Process Monitoring; 3465 Daily Reporting; 3466 Issue Management; 3467 SA Hypercare Close Down Activities; 3468 Handover to MHHSP

Changed:

| ID | Task | Start | Finish | Duration | Complete | Total float | Predecessors | Other |
| --- | --- | --- | --- | --- | --- | --- | --- | --- |
| 1 | **PROGRAMME PLAN.** |  |  |  | 66% → 69% |  |  |  |
| 45 | **DESIGN, BUILD & TEST (PIT)** |  | 2027-07-05 → 2027-01-18 (-168d) | 1221d? → 1101d? | 84% → 89% | 123d → 243d |  |  |
| 187 | **PP Design, Build & Test (DBT)** |  | 2027-07-05 → 2025-02-21 (-864d) | 1221d? → 605d | 77% → 96% | 123d → 739d |  |  |
| 326 | **All SIT Programme Participants PIT (SIT Functional)** |  |  |  | 78% → 79% |  |  |  |
| 360 | **All SIT Programme Participants PIT (SIT Non Functional)** |  | 2025-02-21 A |  | 98% → 100% | 739d → none |  |  |
| 364 | **Test Readiness Report** |  | 2024-10-22 A |  | 85% → 100% | 827d → none |  |  |
| 365 | Test readiness reporting |  | 2024-10-22 A |  | 85% → 100% | 827d → none |  |  |
| 509 | **SYSTEMS INTEGRATION TESTING (SIT)** |  |  |  | 76% → 77% |  |  |  |
| 1484 | **SIT Execution** |  | 2025-11-26 → 2025-12-10 (+14d) | 543d? → 553d? | 52% → 65% | 541d → 531d |  |  |
| 1501 | **SIT** |  | 2025-08-27 → 2025-09-19 (+23d) | 383d? → 400d? | 54% → 72% | 606d → 589d |  |  |
| 1502 | **SIT Functional Testing (MVC)** |  | 2025-08-20 → 2025-09-19 (+30d) | 378d? → 400d? | 61% → 78% | 611d → 589d |  |  |
| 1541 | **SIT Functional Settlement Testing** |  |  |  | 29% → 62% |  |  |  |
| 1542 | SIT-B Settlement Testing Cycle 2 |  | 2025-06-13 A |  | 5% → 100% | 659d → none |  |  |
| 1560 | **SIT-A Settlement Testing** |  | 2025-06-16 → 2025-06-27 A (+11d) | 20d → 30d | 10% → 100% | 10d → none |  |  |
| 1562 | SIT-A Settlement Testing | 2025-05-20 A → 2025-05-19 A (-1d) | 2025-06-16 → 2025-06-27 A (+11d) | 20d → 30d | 10% → 100% | 10d → none |  | baseline start 2025-05-20 → 2025-05-19; baseline finish 2025-06-16 → 2025-06-27 |
| 1564 | SIT-A Settlement Decision Point Exit Criteria | 2025-06-13 → 2025-06-27 A (+14d) | 2025-06-13 → 2025-06-27 A (+14d) |  | 0% → 100% | 10d → none | 1562FS-2d → 1562FS-1d | baseline start 2025-06-13 → 2025-06-27; baseline finish 2025-06-13 → 2025-06-27 |
| 1565 | SIT-A Settlement Testing Completed | 2025-06-13 → 2025-06-27 A (+14d) | 2025-06-13 → 2025-06-27 A (+14d) |  | 0% → 100% | 10d → none |  | baseline start 2025-06-13 → 2025-06-27; baseline finish 2025-06-13 → 2025-06-27 |
| 1566 | **SIT Functional & Migration Regression Testing (code freeze)** | 2025-06-16 → 2025-06-30 A (+14d) | 2025-08-08 → 2025-09-19 (+42d) | 40d? → 60d? | 0% → 3% | 10d → 589d |  | was named SIT Functional Regression Testing (code freeze) |
| 1567 | Regression Test Execution Start | 2025-06-16 → 2025-06-30 A (+14d) | 2025-06-16 → 2025-06-30 A (+14d) |  | 0% → 100% | 10d → none |  | baseline start 2025-06-16 → 2025-06-30; baseline finish 2025-06-16 → 2025-06-30 |
| 1568 | Regression Execution | 2025-06-16 → 2025-06-30 A (+14d) | 2025-06-20 → 2025-07-04 (+14d) |  | 0% → 40% | 10d → -97d |  | baseline start 2025-06-16 → 2025-06-30; baseline finish 2025-06-20 → 2025-07-04 |
| 1569 | Regression Sprint 1 | 2025-06-23 → 2025-07-07 (+14d) | 2025-07-04 → 2025-07-18 (+14d) |  |  | 10d → -97d |  | baseline start 2025-06-23 → 2025-07-07; baseline finish 2025-07-04 → 2025-07-18 |
| 1570 | Regression Sprint 2 | 2025-07-07 → 2025-07-21 (+14d) | 2025-07-18 → 2025-08-08 (+21d) | 10d → 15d |  | 10d → -97d |  | baseline start 2025-07-07 → 2025-07-21; baseline finish 2025-07-18 → 2025-08-08 |
| 1571 | Regression Sprint 3 | 2025-07-21 → 2025-08-11 (+21d) | 2025-08-01 → 2025-08-22 (+21d) |  |  | 10d → 589d |  | baseline start 2025-07-21 → 2025-08-11; baseline finish 2025-08-01 → 2025-08-22 |
| 1573 | Regression Contingency Week | 2025-08-04 → 2025-09-15 (+42d) | 2025-08-08 → 2025-09-19 (+42d) |  |  | 10d → 589d | 1571, 1585FF → 1572, 1585FF, 1571 |  |
| 1574 | SIT Functional Testing End |  |  | 0d → 1d |  | 10d → 619d | 1573 → none | constraint start no earlier than 2025-03-14 → finish no earlier than 2025-08-08 |
| 1575 | **SIT Functional & Migration Overarching Exit Report** |  | 2025-06-18 → 2025-07-17 (+29d) | 38d → 59d | 36% → 84% | 656d → 635d |  |  |
| 1576 | Programme drafts Functional & Migration PP Exit Report |  | 2025-05-23 → 2025-06-10 A (+18d) | 20d → 32d | 90% → 100% | 674d → none |  | baseline finish 2025-05-23 → 2025-06-10 |
| 1577 | SRO Review PP Exit Reports | 2025-05-22 A | 2025-05-23 → 2025-06-04 A (+12d) | 2d → 10d | 0% → 100% | 658d → none |  | baseline finish 2025-05-23 → 2025-06-04 |
| 1578 | Functional & Migration PP Exit Reports shared with PPs | 2025-05-23 → 2025-06-10 A (+18d) | 2025-05-23 → 2025-06-10 A (+18d) |  | 0% → 100% | 658d → none | 1577 → 1576 | baseline start 2025-05-23 → 2025-06-10; baseline finish 2025-05-23 → 2025-06-10 |
| 1579 | PPs review Exit Report and sign Functional & Migration Exit Declaration | 2025-05-26 → 2025-06-11 A (+16d) | 2025-06-06 → 2025-06-24 A (+18d) |  | 0% → 100% | 661d → none |  | was named PPs complete and return Exit Reports; baseline start 2025-05-26 → 2025-06-11; baseline finish 2025-06-06 → 2025-06-24 |
| 1580 | Programme drafts SI SIT Functional & Migration Overarching Exit Report | 2025-05-26 → 2025-06-11 A (+16d) | 2025-06-11 → 2025-06-27 A (+16d) |  | 0% → 100% | 658d → none | 1578, 1695FF → 1578 | baseline start 2025-05-26 → 2025-06-11; baseline finish 2025-06-11 → 2025-06-27 |
| 1582 | SITWG Review status of SI SIT Functional & Migration Overarching Exit Report | 2025-06-05 → 2025-07-03 (+28d) | 2025-06-05 → 2025-07-03 (+28d) |  |  | 666d → 635d | 1580SS → 1580FS+4d, 1581 | baseline start 2025-06-05 → 2025-07-03; baseline finish 2025-06-05 → 2025-07-03 |
| 1584 | **SIT Settlement and Regression Test Exit Report** | 2025-06-30 → 2025-07-07 (+7d) | 2025-08-20 → 2025-09-19 (+30d) | 38d → 55d |  | 10d → 30d |  |  |
| 1585 | Programme drafts Settlement and Regression Pathway 2 PP Exit Reports | 2025-06-30 → 2025-07-07 (+7d) | 2025-08-08 → 2025-07-23 (-16d) | 30d → 13d |  | 10d → 616d |  | was named Programme drafts Settlement and Regression PP Exit Reports (when Participant completes Regression testing); constraint start no earlier than 2025-06-30 → start no earlier than 2025-07-07 |
| 1587 | All Settlement and Regression Pathway 2 PP Exit Reports shared with PPs | 2025-08-08 → 2025-07-23 (-16d) | 2025-08-08 → 2025-07-23 (-16d) |  |  | 619d → 631d |  | was named All Settlement and Regression PP Exit Reports shared with PPs |
| 1588 | Pathway 2 PPs review and sign off Regression Exit Declaration | 2025-07-07 → 2025-07-21 (+14d) | 2025-08-08 → 2025-07-28 (-11d) | 25d → 6d |  | 15d → 606d | 1585SS, 1644SS → 1585SS | was named PPs complete and return Exit Reports; constraint start no earlier than 2025-07-07 → start no earlier than 2025-07-21 |
| 1593 | Pathway 3 PPs Exit Report and Regression Exit Decleration submission deadline |  |  |  |  |  |  | was named PPs Exit Report and Regression Exit Decleration submission deadline |
| 1594 | Programme drafts SI SIT Settlement and Regression Addendum | 2025-07-07 → 2025-07-21 (+14d) |  | 25d → 15d |  | 15d → 20d | 1588SS, 1646SS → none | was named Programme drafts SI SIT Settlement and Regression Overarching Exit Report; constraint none → start no earlier than 2025-07-21 |
| 1595 | SRO/Code Bodies Review SI SIT Settlement and Regression Addendum |  |  |  |  |  |  | was named SRO Review SI SIT Settlement and Regression Overarching Exit Report |
| 1597 | SI SIT Functional Testing Test Exit Report Approved | 2025-08-20 → 2025-08-15 (-5d) | 2025-08-20 → 2025-08-15 (-5d) |  |  | 8d → 15d | Review & agree documentFF, 1594, SITWG Review status of SI SIT Settlement and Regression Overarching Exit Report, 1573 → 1594, 1570 | constraint start no earlier than 2025-08-20 → finish no earlier than 2025-08-15 |
| 1599 | eSITAG Approves SI SIT Functional & Migration (Post-Regression) Overarching Test Exit Report | 2025-08-20 → 2025-08-15 (-5d) | 2025-08-20 → 2025-08-15 (-5d) |  |  | 7d → 615d | Review & agree documentFF, 1594, SITWG Review status of SI SIT Settlement and Regression Overarching Exit Report, 1573 → 1594, 1570, 1583 | was named SITAG Approves SI SIT Functional & Migration (Post-Regression) Overarching Test Exit Report; constraint finish no earlier than 2025-08-20 → start no earlier than 2025-08-15 |
| 1600 | **SIT Migration Testing** |  | 2025-08-27 → 2025-08-22 (-5d) | 383d? → 380d? | 61% → 71% | 606d → 609d |  |  |
| 1602 | **SIT Migration Testing Execution** |  | 2025-08-27 → 2025-08-22 (-5d) | 383d? → 380d? | 61% → 71% | 606d → 609d |  |  |
| 1627 | **SIT Migration Regression Testing (code freeze)** | 2025-06-16 → 2025-06-30 (+14d) | 2025-08-08 → 2025-08-22 (+14d) |  |  | 15d → 609d |  |  |
| 1628 | Regression Test Execution Start | 2025-06-16 → 2025-06-30 (+14d) | 2025-06-16 → 2025-06-30 (+14d) |  |  | 15d → 609d |  |  |
| 1629 | Regression Execution | 2025-06-16 → 2025-06-30 (+14d) | 2025-06-20 → 2025-07-04 (+14d) |  |  | 15d → 609d |  |  |
| 1630 | Regression Sprint 1 | 2025-06-23 → 2025-07-07 (+14d) | 2025-07-04 → 2025-07-18 (+14d) |  |  | 15d → 609d |  |  |
| 1631 | Regression Sprint 2 | 2025-07-07 → 2025-07-21 (+14d) | 2025-07-18 → 2025-08-01 (+14d) |  |  | 15d → 609d |  |  |
| 1632 | Regression Sprint 3 | 2025-07-21 → 2025-08-04 (+14d) | 2025-08-01 → 2025-08-15 (+14d) |  |  | 619d → 609d |  |  |
| 1633 | Regression Contingency Week | 2025-08-04 → 2025-08-18 (+14d) | 2025-08-08 → 2025-08-22 (+14d) |  |  | 619d → 609d |  |  |
| 1634 | SIT Migration Testing End (incl. confirmation that PPs have submitted their Test Completion Reports to Programme for assurance) | 2025-08-08 → 2025-08-22 (+14d) | 2025-08-08 → 2025-08-22 (+14d) |  |  | 619d → 609d |  |  |
| 1635 | **SIT Functional & Migration Test Exit Report** |  | 2025-06-18 → 2025-07-03 (+15d) | 38d → 49d | 36% → 72% | 656d → 645d |  |  |
| 1636 | Programme drafts Functional & Migration PP Exit Report |  | 2025-05-23 → 2025-06-10 A (+18d) | 20d → 32d | 90% → 100% | 674d → none |  |  |
| 1637 | SRO Review PP Exit Reports | 2025-05-22 A | 2025-05-23 → 2025-06-04 A (+12d) | 2d → 10d | 0% → 100% | 658d → none |  |  |
| 1638 | Functional & Migration PP Exit Reports shared with PPs | 2025-05-23 → 2025-06-10 A (+18d) | 2025-05-23 → 2025-06-10 A (+18d) |  | 0% → 100% | 658d → none | 1637 → 1636 |  |
| 1639 | PPs complete and return Exit Reports | 2025-05-26 → 2025-06-11 A (+16d) | 2025-06-06 → 2025-06-24 (+18d) |  | 0% → 50% | 661d → 652d |  |  |
| 1640 | PPs Exit Report submission deadline | 2025-06-06 → 2025-06-24 (+18d) | 2025-06-06 → 2025-06-24 (+18d) |  |  | 664d → 652d |  |  |
| 1641 | Programme drafts SI SIT Functional & Migration Overarching Exit Report | 2025-05-26 → 2025-06-11 (+16d) | 2025-06-11 → 2025-06-27 (+16d) |  |  | 658d → 645d | 1638, 1639FF → 1638 |  |
| 1642 | SITWG Review status of Functional & Migration Overarching Completion Report | 2025-06-05 → 2025-07-03 (+28d) | 2025-06-05 → 2025-07-03 (+28d) |  |  | 666d → 645d | 1641SS → 1641FS+4d |  |
| 1643 | **SIT Settlement and Regression Test Exit Report** | 2025-06-30 → 2025-07-07 (+7d) | 2025-08-27 → 2025-08-20 (-7d) | 43d → 33d |  | 20d → 45d |  |  |
| 1644 | Programme drafts Settlement and Regression PP Exit Report (when Participant completes Regression testing) | 2025-06-30 → 2025-07-07 (+7d) | 2025-08-08 → 2025-08-15 (+7d) |  |  | 619d → 614d |  |  |
| 1645 | All Settlement and Regression PP Exit Reports shared with PPs | 2025-08-08 → 2025-08-15 (+7d) | 2025-08-08 → 2025-08-15 (+7d) |  |  | 619d → 614d |  |  |
| 1651 | SIT Migration Testing Test Exit Report Approved |  |  |  |  | 7d → 12d | Review & agree documentFS+5d → none |  |
| 1652 | SIT Migration Testing End (incl. confirmation that PPs have submitted their Test Exit Reports to Programme for assurance) |  |  |  |  | 609d → 614d | Develop documentFF, 1648 → 1648 |  |
| 1653 | SITAG Approves SI SIT Functional & Migration (Post-Regression) Overarching Test Exit Report |  |  |  |  | 606d → 611d | Develop documentFF, 1648 → 1648 |  |
| 1654 | **SIT Non-Functional Testing (all SIT PPs)** |  | 2025-07-16 → 2025-08-06 (+21d) | 98d? → 112d? | 29% → 68% | 636d → 622d |  |  |
| 1658 | Theme 2 & 3 SIT Non-Functional Testing Execution |  | 2025-05-23 A |  | 65% → 100% | 60d → none |  |  |
| 1659 | SIT Non-Functional Testing Execution End (all SIT PPs) | 2025-05-23 A | 2025-05-23 A |  | 0% → 100% | 60d → none |  | was named SIT Non-Functional Testing End (all SIT PPs) (incl. confirmation that PPs have submitted their Test Completion Reports to Programme for assurance) |
| 1660 | **SIT Non-Functional Testing Test Exit Report (all SIT PPs)** | 2025-05-05 → 2025-05-26 A (+21d) | 2025-07-16 → 2025-08-06 (+21d) | 53d → 52d | 0% → 43% | 60d → 622d |  |  |
| 1661 | Programme drafts Non-Functional PP Exit Report | 2025-05-26 A | 2025-06-13 → 2025-06-27 A (+14d) | 15d → 25d | 0% → 100% | 659d → none |  | baseline finish 2025-06-13 → 2025-06-27 |

| ID | Task | Start | Finish | Duration | Complete | Total float | Predecessors | Other |
| --- | --- | --- | --- | --- | --- | --- | --- | --- |
| 1662 | Non-Functional PP Exit Reports shared with PPs | 2025-06-13 → 2025-06-27 A (+14d) | 2025-06-13 → 2025-06-27 A (+14d) |  | 0% → 100% | 659d → none |  | baseline start 2025-06-13 → 2025-06-27; baseline finish 2025-06-13 → 2025-06-27 |
| 1663 | PPs review Exit Report and Sign PP Exit Declaration | 2025-06-16 → 2025-06-27 A (+11d) | 2025-06-27 → 2025-07-11 (+14d) | 10d → 11d | 0% → 27% | 649d → 639d |  | was named PPs complete and return PP Exit Reports; constraint finish no earlier than 2025-06-27 → start no earlier than 2025-06-27; baseline start 2025-06-16 → 2025-06-27; baseline finish 2025-06-27 → 2025-07-11 |
| 1664 | PPs Exit Report submission deadline | 2025-06-27 → 2025-07-11 (+14d) | 2025-06-27 → 2025-07-11 (+14d) |  |  | 649d → 639d | 1663 → none | constraint none → finish no earlier than 2025-07-11; baseline start 2025-06-27 → 2025-07-11; baseline finish 2025-06-27 → 2025-07-11 |
| 1665 | Programme drafts SI SIT Non-Functional Overarching Exit Report | 2025-06-16 → 2025-06-27 A (+11d) | 2025-07-04 → 2025-07-18 (+14d) | 15d → 16d | 0% → 19% | 37d → 25d | 1663SS → 1655, 1656, 1657, 1658, 1659 | baseline start 2025-06-16 → 2025-06-27; baseline finish 2025-07-04 → 2025-07-18 |
| 1666 | Draft of SI SIT Non-Functional Overarching Exit Report available for SRO review | 2025-06-23 → 2025-07-07 (+14d) | 2025-06-27 → 2025-07-11 (+14d) |  |  | 649d → 634d |  | was named SRO Review SI SIT Non-Functional Overarching Exit Report; constraint start no earlier than 2025-06-23 → start no earlier than 2025-07-07; baseline start 2025-06-23 → 2025-07-07; baseline finish 2025-06-27 → 2025-07-11 |
| 1668 | SITWG Review status of SI SIT Non-Functional Overarching Exit Report | 2025-07-03 → 2025-07-18 (+15d) | 2025-07-03 → 2025-07-18 (+15d) |  |  | 646d → 25d | none → 1665 | baseline start 2025-07-03 → 2025-07-18; baseline finish 2025-07-03 → 2025-07-18 |
| 1671 | SIT Non-Functional Testing Test Exit Report (all SIT PPs) Approved | 2025-07-16 → 2025-08-06 (+21d) | 2025-07-16 → 2025-08-06 (+21d) |  |  | 32d → 23d | Review & agree documentFF+5d, 1665FS+3d → 1665FS+3d, 1670 | constraint finish no earlier than 2025-07-16 → start no earlier than 2025-08-06; baseline start 2025-07-16 → 2025-08-06; baseline finish 2025-07-16 → 2025-08-06 |
| 1672 | SITAG Approves SI SIT Non-Functional Overarching Test Exit Report | 2025-07-16 → 2025-08-06 (+21d) | 2025-07-16 → 2025-08-06 (+21d) |  |  | 33d → 23d | Review & agree documentFF+5d, 1665FS+3d → 1665FS+3d, 1671 | baseline start 2025-07-16 → 2025-08-06; baseline finish 2025-07-16 → 2025-08-06 |
| 1673 | **SIT Operational Testing (all SIT PPs)** |  | 2025-08-06 → 2025-08-29 (+23d) | 133d? → 150d? | 30% → 60% | 621d → 604d |  |  |
| 1677 | **SIT B Testing** |  |  |  | 47% → 89% | 30d → 644d |  |  |
| 1679 | SIT Operational Testing Execution Theme 1 |  | 2025-07-04 A |  | 50% → 100% | 30d → none |  |  |
| 1680 | SIT Operational Testing Execution Theme 2 |  |  |  | 60% → 90% | 30d → 644d |  |  |
| 1681 | SIT Operational Testing Execution Theme 3 Batch 2 | 2025-06-09 A |  |  | 0% → 35% | 30d → 644d |  |  |
| 1682 | **SIT Operational Testing Re-test Theme 3 (Batch 1)** |  | 2025-06-13 A |  | 55% → 100% | 45d → none |  |  |
| 1684 | Scripts uploaded to ADO / Project Created |  | 2025-05-23 A |  | 20% → 100% | 55d → none |  |  |
| 1685 | SIT Operational Testing Re-test Execution Theme 3 (Batch 1) | 2025-06-09 A | 2025-06-13 A |  | 0% → 100% | 45d → none |  |  |
| 1687 | **SIT Operational Testing Test Exit Report (all SIT PPs)** | 2025-06-02 → 2025-06-23 A (+21d) | 2025-08-06 → 2025-08-29 (+23d) | 48d → 50d? | 0% → 7% | 32d → 604d |  |  |
| 1688 | Programme drafts Pathway 2 PP Exit Report (when Participant completes Operational testing) | 2025-06-02 → 2025-06-30 (+28d) | 2025-07-11 → 2025-07-18 (+7d) | 30d → 15d |  | 32d → 604d | 1679SS → 1679SS, 1680SS | was named Programme drafts PP Exit Report (when Participant completes Operational testing); constraint start no earlier than 2025-06-02 → start no earlier than 2025-06-30; baseline start 2025-06-02 → 2025-06-30; baseline finish 2025-07-11 → 2025-07-18 |
| 1689 | All Pathway 2 Operational Exit Reports and Exit Declarations shared with PPs | 2025-07-11 → 2025-07-21 (+10d) | 2025-07-11 → 2025-07-21 (+10d) |  |  | 639d → 633d | 1688 → 1688FS+1d | was named All Operational Completion PP Exit Reports have been shared with PPs; baseline start 2025-07-11 → 2025-07-21; baseline finish 2025-07-11 → 2025-07-21 |
| 1690 | Pathway 2 PPs have reviewed Exit Report and signed Exit Declaration | 2025-06-13 → 2025-07-21 (+38d) |  | 31d → 5d |  | 23d → 629d | 1688SS → 1688 | was named PPs complete and return PP Exit Reports; baseline start 2025-06-13 → 2025-07-21 |
| 1695 | PPs Exit Report submission deadline | 2025-06-06 → 2025-08-18 (+73d) | 2025-06-06 → 2025-08-18 (+73d) | 0d → 1d? |  | 661d → 613d | 1579 → 1694 | constraint start no earlier than 2025-06-06 → none; baseline start 2025-06-06 → 2025-08-18; baseline finish 2025-06-06 → 2025-08-18 |
| 1697 | Programme drafts SI SIT Operational Overarching Exit Report | 2025-06-23 A |  |  | 0% → 23% | 17d → 621d | 1690SS → none |  |
| 1699 | eSITWG Review SI SIT Operational Overarching Exit Report | 2025-07-03 → 2025-08-01 (+29d) | 2025-07-03 → 2025-08-01 (+29d) |  |  | 646d → 614d |  | was named SITWG Review status of SI SIT Operational Overarching Exit Report; constraint start no earlier than 2025-07-03 → finish no earlier than 2025-08-01; baseline start 2025-07-03 → 2025-08-01; baseline finish 2025-07-03 → 2025-08-01 |
| 1701 | SIT Operational Testing Test Exit Report (all SIT PPs) Approved | 2025-08-06 → 2025-08-15 (+9d) | 2025-08-06 → 2025-08-15 (+9d) |  |  | 17d → 614d | Review & agree documentFF+5d, 1697FS+3d → 1697FS+3d | constraint none → finish no earlier than 2025-08-15; baseline start 2025-08-06 → 2025-08-15; baseline finish 2025-08-06 → 2025-08-15 |
| 1702 | eSITAG Approves SI SIT Operational Testing Test Exit Report | 2025-08-06 → 2025-08-15 (+9d) | 2025-08-06 → 2025-08-15 (+9d) |  |  | 17d → 614d | Review & agree documentFF+5d, 1697FS+3d → 1697FS+3d | was named SITAG Approves SI SIT Operational Testing Test Exit Report; constraint start no earlier than 2025-08-06 → finish no earlier than 2025-08-15; baseline start 2025-08-06 → 2025-08-15; baseline finish 2025-08-06 → 2025-08-15 |
| 1703 | SIT Complete (SIT Test Exit Report Approved) |  |  |  |  | 5d → 10d | 1500, 1597, 1671, 1701, 1651, 1702, 1672, 1599 → 1500, 1671, 1651, 1672, 1596, 1597 |  |
| 1704 | **SIT (Contingency)** | 2025-06-13 → 2025-06-27 (+14d) | 2025-11-26 → 2025-12-10 (+14d) |  |  | 505d → 531d |  |  |
| 1705 | **SIT Functional Testing (Contingency)** | 2025-06-13 → 2025-06-27 (+14d) | 2025-11-13 → 2025-11-27 (+14d) |  |  | 505d → 531d |  |  |
| 1706 | **SIT Functional Testing Execution (Contingency)** | 2025-06-13 → 2025-06-27 (+14d) | 2025-10-23 → 2025-11-06 (+14d) |  |  | 505d → 531d |  |  |
| 1707 | Test Execution (Cycle 3 Completion and Regression Testing) | 2025-06-13 → 2025-06-27 (+14d) | 2025-10-23 → 2025-11-06 (+14d) |  |  | 505d → 531d |  |  |
| 1708 | SIT Functional Testing End (Contingency) (incl. confirmation that PPs have submitted their Test Exit Reports to Programme for assurance) | 2025-10-23 → 2025-11-06 (+14d) | 2025-10-23 → 2025-11-06 (+14d) |  |  | 505d → 531d |  |  |
| 1709 | Assurance of PPs Test Exit Reports | 2025-10-31 → 2025-11-14 (+14d) | 2025-11-06 → 2025-11-20 (+14d) |  |  | 505d → 531d |  |  |
| 1710 | **SIT Functional Testing Test Completion Report (Contingency)** | 2025-10-03 → 2025-10-17 (+14d) | 2025-11-06 → 2025-11-20 (+14d) |  |  | 505d → 531d |  |  |
| 1711 | Develop document | 2025-10-03 → 2025-10-17 (+14d) | 2025-10-23 → 2025-11-06 (+14d) |  |  | 510d → 536d |  |  |
| 1712 | Review & agree document | 2025-10-31 → 2025-11-14 (+14d) | 2025-11-06 → 2025-11-20 (+14d) |  |  | 505d → 531d |  |  |
| 1713 | SIT Functional Testing Test Exit Report (Contingency) Approved | 2025-11-13 → 2025-11-27 (+14d) | 2025-11-13 → 2025-11-27 (+14d) |  |  | 505d → 531d |  |  |
| 1714 | **SIT Migration Testing (Contingency)** | 2025-06-13 → 2025-06-27 (+14d) | 2025-11-13 → 2025-11-27 (+14d) |  |  | 505d → 531d |  |  |
| 1715 | Test Execution (Cycle 3 Completion and Regression Testing) | 2025-06-13 → 2025-06-27 (+14d) | 2025-10-23 → 2025-11-06 (+14d) |  |  | 505d → 531d |  |  |
| 1716 | SIT Migration Testing End (Contingency) (incl. confirmation that PPs have submitted their Test Exit Reports to Programme for assurance) | 2025-10-23 → 2025-11-06 (+14d) | 2025-10-23 → 2025-11-06 (+14d) |  |  | 505d → 531d |  |  |
| 1717 | Assurance of PPs Test Exit Reports | 2025-10-31 → 2025-11-14 (+14d) | 2025-11-06 → 2025-11-20 (+14d) |  |  | 505d → 531d |  |  |
| 1718 | **SIT Migration Testing Test Completion Report (Contingency)** | 2025-10-03 → 2025-10-17 (+14d) | 2025-11-06 → 2025-11-20 (+14d) |  |  | 505d → 531d |  |  |
| 1719 | Develop document | 2025-10-03 → 2025-10-17 (+14d) | 2025-10-23 → 2025-11-06 (+14d) |  |  | 510d → 536d |  |  |
| 1720 | Review & agree document | 2025-10-31 → 2025-11-14 (+14d) | 2025-11-06 → 2025-11-20 (+14d) |  |  | 505d → 531d |  |  |
| 1721 | SIT Migration Testing Test Exit Report (Contingency) Approved | 2025-11-13 → 2025-11-27 (+14d) | 2025-11-13 → 2025-11-27 (+14d) |  |  | 505d → 531d |  |  |
| 1722 | **SIT Contingency Test Exit Report** | 2025-10-24 → 2025-11-07 (+14d) | 2025-11-20 → 2025-12-04 (+14d) |  |  | 505d → 531d |  |  |
| 1723 | Develop document | 2025-10-24 → 2025-11-07 (+14d) | 2025-11-13 → 2025-11-27 (+14d) |  |  | 505d → 531d |  |  |
| 1724 | Review & agree document | 2025-11-14 → 2025-11-28 (+14d) | 2025-11-20 → 2025-12-04 (+14d) |  |  | 505d → 531d |  |  |
| 1725 | SIT Contingency Complete | 2025-11-26 → 2025-12-10 (+14d) | 2025-11-26 → 2025-12-10 (+14d) |  |  | 505d → 531d |  |  |
| 1726 | **UIT Environment Preparation** |  | 2025-06-19 → 2026-08-28 (+435d) | 689d → 1000d | 53% → 50% | 655d → 344d |  |  |
| 1727 | **Test Artefact Development** |  | 2025-06-19 A |  | 89% → 100% | 655d → none |  |  |
| 1728 | **E2E Sandbox Guidance** |  | 2025-06-19 A |  | 96% → 100% | 655d → none |  |  |
| 1733 | Internal SI review |  | 2025-05-23 A |  | 60% → 100% | 674d → none |  |  |
| 1734 | SRO / Code Bodies review | 2025-05-19 A | 2025-05-23 A |  | 0% → 100% | 674d → none |  |  |
| 1735 | Submit version to QWG | 2025-06-03 A | 2025-06-03 A |  | 0% → 100% | 667d → none |  |  |
| 1736 | Artefact Recommendation for Approval (via QWG) | 2025-06-10 A | 2025-06-10 A |  | 0% → 100% | 662d → none |  |  |
| 1737 | Final Document updates post QWG review | 2025-06-11 A | 2025-06-11 A |  | 0% → 100% | 661d → none |  |  |
| 1738 | Submit final version to QAG | 2025-06-12 A | 2025-06-12 A |  | 0% → 100% | 657d → none |  |  |
| 1739 | E2E Sandbox guidance update approved at QAG | 2025-06-19 A | 2025-06-19 A |  | 0% → 100% | 655d → none |  |  |
| 1740 | **E2E Sandbox Test Data Approach & Plan** |  | 2025-06-17 → 2025-06-19 A (+2d) | 72d → 73d | 74% → 100% | 657d → none |  |  |
| 1747 | Internal SI review and updates |  | 2025-05-23 A |  | 60% → 100% | 674d → none |  |  |
| 1748 | SRO / Code Bodies review |  | 2025-05-23 A |  | 60% → 100% | 664d → none |  |  |
| 1749 | Final updates prior to consultation | 2025-05-26 A | 2025-05-26 A |  | 0% → 100% | 664d → none |  |  |
| 1750 | Industry Consultation for E2E Sandbox Test Data Approach and Plan document | 2025-05-26 → 2025-05-27 A (+1d) | 2025-06-06 A | 10d → 9d | 0% → 100% | 664d → none |  |  |
| 1751 | Document updates post Industry Consultation | 2025-06-05 → 2025-06-06 A (+1d) | 2025-06-09 A | 3d → 2d | 0% → 100% | 663d → none |  |  |
| 1752 | Submit Proposed Version to QWG | 2025-06-10 A | 2025-06-10 A |  | 0% → 100% | 660d → none |  |  |
| 1753 | Artefact Approval (via QWG) | 2025-06-10 A | 2025-06-10 A |  | 0% → 100% | 660d → none |  |  |
| 1754 | Final Document updates post QWG review | 2025-06-11 A | 2025-06-11 A |  | 0% → 100% | 660d → none |  |  |
| 1755 | Submit final version to QAG | 2025-06-12 A | 2025-06-12 A |  | 0% → 100% | 660d → none |  |  |
| 1756 | E2E Sandbox Test Data Approach and Plan Approved at QAG | 2025-06-17 → 2025-06-19 A (+2d) | 2025-06-17 → 2025-06-19 A (+2d) |  | 0% → 100% | 657d → none |  | constraint finish no earlier than 2025-06-17 → start no earlier than 2025-06-19 |
| 1763 | **Environments (UIT)** |  |  |  | 50% → 51% |  |  |  |

| ID | Task | Start | Finish | Duration | Complete | Total float | Predecessors | Other |
| --- | --- | --- | --- | --- | --- | --- | --- | --- |
| 1770 | **SI Environments (UIT)** |  | 2024-09-30 A |  | 99% → 100% | 843d → none |  |  |
| 1772 | Assure Central Parties' self-declaration of environment preparation complete (incl. security certificates and security compliance) |  | 2024-08-23 A |  | 97% → 100% | 869d → none |  |  |
| 1776 | Coordinate Central Parties' UIT environment Regression Testing | 2024-07-31 A | 2024-07-31 A |  | 0% → 100% | 886d → none |  |  |
| 1783 | **Onboarding and Test Data (Sandbox UIT)** | 2024-08-26 A | 2024-10-04 → 2026-08-28 (+693d) | 30d → 525d | 0% → 2% | 819d → 344d |  | was named Test Data |
| 1811 | **SIT PPs Early Sandbox Testing Execution (SIT-A)** | 2025-07-21 → 2025-08-08 (+18d) | 2025-10-24 → 2025-11-13 (+20d) |  |  | 564d → 550d |  |  |
| 1812 | SIT PPs E2E Sandbox Testing Start | 2025-07-21 → 2025-08-08 (+18d) | 2025-07-21 → 2025-08-08 (+18d) |  |  | 634d → 619d |  |  |
| 1813 | SIT PPs E2E Sandbox Testing Execution | 2025-07-21 → 2025-08-08 (+18d) | 2025-10-24 → 2025-11-13 (+20d) |  |  | 564d → 550d |  |  |
| 1814 | SIT PPs E2E Sandbox Testing End | 2025-10-24 → 2025-11-13 (+20d) | 2025-10-24 → 2025-11-13 (+20d) |  |  | 564d → 550d |  |  |
| 1815 | **Sandbox Testing Execution (UIT) - LDSO Participants** | 2025-06-02 → 2025-05-26 A (-7d) |  | 169d → 174d | 0% → 7% |  |  |  |
| 1817 | Sandbox Testing Start (UIT) - LDSO Participants | 2025-06-02 A | 2025-06-02 A |  | 0% → 100% | 668d → none | 1809 → 1809, 1816 |  |
| 1818 | Sandbox Testing Execution (UIT) - LDSO Participants | 2025-06-02 A |  |  | 0% → 7% |  |  |  |
| 1820 | **Sandbox Testing Execution (UIT) - Supplier & Agent Participants** | 2025-09-01 → 2025-08-25 (-7d) |  | 260d → 265d |  |  |  |  |
| 1822 | Sandbox Testing Start (UIT) - Supplier & Agent Participants |  |  |  |  |  | 1703, 2736FS+5d, 1809 → 1703, 2736FS+5d, 1809, 1821 |  |
| 1850 | M10 Checkpoint 1 complete |  |  |  |  |  | 1885FS-126d, 1849 → 1849 |  |
| 1851 | M10 Checkpoint 2 Complete | 2025-07-02 A | 2025-07-02 A |  | 0% → 100% | 646d → none |  |  |
| 1855 | Non-SIT LDSO Qualification Testing complete | 2025-05-16 A | 2025-05-16 A |  | 0% → 100% | 679d → none |  |  |
| 1885 | Central systems ready for migrating MPANs (M10) | 2025-09-24 → 2025-09-22 (-2d) | 2025-09-24 → 2025-09-22 (-2d) |  |  | 5d → 7d | 1703FS+20d, 3520, 3261FS+2d, 3258, 3276, 3237, 3244 → 1703FS+18d, 3261, 3258, 3276, 3237, 3244, 2418 | constraint none → start no earlier than 2025-09-22; baseline start 2025-09-24 → 2025-09-22; baseline finish 2025-09-24 → 2025-09-22 |
| 1887 | Central systems ready for migrating MPANs (M10*) - Late Exit |  |  |  |  |  | 1885FS+65d → 1885FS+67d |  |
| 1898 | **NON SIT LDSO QUALIFICATION** |  |  |  | 93% → 98% |  |  |  |
| 1944 | **Test Data** |  | 2025-05-16 A |  | 84% → 100% | 679d → none |  |  |
| 1953 | Test Execution Data Support |  | 2025-05-16 A |  | 50% → 100% | 679d → none |  |  |
| 1993 | **Test Window** |  |  |  | 91% → 94% |  |  |  |
| 2006 | Potential for non-SIT LDSO QT Regression for Qualification | 2025-05-19 A |  |  | 0% → 31% |  |  |  |
| 2007 | **Test Result Assurance** |  | 2025-05-16 A |  | 90% → 100% | 680d → none |  |  |
| 2008 | Test Reports Reviewed By MHHS & Code Bodies & Finalised |  | 2025-05-16 A |  | 90% → 100% | 680d → none |  |  |
| 2010 | **Non-SIT LDSO Qualification Closure** | 2025-05-16 A |  |  | 0% → 94% |  |  |  |
| 2011 | Non-SIT LDSO Qualification Learned Captured | 2025-05-16 A | 2025-05-29 A |  | 0% → 100% | 670d → none |  |  |
| 2012 | Non-SIT LDSO Regression Testing | 2025-05-16 A | 2025-06-20 A |  | 0% → 100% | 649d → none |  |  |
| 2013 | Non-SIT LDSO Qualification Closure Down | 2025-06-23 A |  |  | 0% → 50% |  |  |  |
| 2014 | **HELIX / ELEXON M10 READINESS** | 2025-03-03 A → 2024-04-02 A (-335d) | 2025-09-01 → 2027-07-30 (+697d) | 130d → 869d? | 60% → 53% | 604d → 104d |  | was named SERVICE MANAGEMENT |
| 2015 | **Service Management - M10 Readiness** |  | 2025-09-01 → 2027-07-30 (+697d) | 130d → 630d | 60% → 31% | 604d → 104d |  | was named Stage 2 - M10 Readiness |
| 2016 | **Service Model Design (Cross Party Service Desk)** |  | 2025-07-25 → 2025-08-13 (+19d) | 105d → 118d | 69% → 86% | 629d → 616d |  |  |
| 2017 | **Cross Party Service Desk** |  | 2025-05-19 A |  | 99% → 100% | 679d → none |  |  |
| 2022 | **Cross Party Service Desk Consultation** |  | 2025-05-19 A |  | 99% → 100% | 679d → none |  |  |
| 2028 | TORWG Post-Consultation Update (CPSD) | 2025-05-14 A | 2025-05-14 A |  | 0% → 100% | 679d → none |  |  |
| 2029 | Updated Consultation Documents Released to Industry for eTORWG | 2025-05-16 A | 2025-05-16 A |  | 0% → 100% | 679d → none |  |  |
| 2030 | CPSD, Operating Hours & Triage Updates Endorsement (eTORWG) | 2025-05-19 A | 2025-05-19 A |  | 0% → 100% | 679d → none |  |  |
| 2031 | Cross Party Service Desk Model Completed | 2025-05-19 A | 2025-05-19 A |  | 0% → 100% | 679d → none |  |  |
| 2032 | **Service Documentation** |  | 2025-07-25 → 2025-08-13 (+19d) | 64d → 77d | 4% → 79% | 629d → 616d |  |  |
| 2033 | Operations Manual Updates Post-Consultation |  | 2025-05-15 A |  | 8% → 100% | 670d → none |  | was named Operations Manual and LLSD Updates Post-Consultation |
| 2034 | Operations Manual Version 1.3 (TORWG) |  |  |  |  |  |  | was named Operations Manual Version 1.3 |
| 2046 | Post-ORT Operations Manual and LLSD Updates |  | 2025-07-25 → 2025-07-16 (-9d) | 10d → 3d |  | 629d → 616d | Service User LLSD Version 1.2, 2034 → 2034, 2089 |  |
| 2047 | M10 Operations Manual Version 2.0 & LLSD Issued for Consultation | 2025-07-25 → 2025-07-16 (-9d) | 2025-07-25 → 2025-07-16 (-9d) |  |  | 629d → 616d |  | was named M10 Operations Manual Version 2.0 & LLSD ORT Learning |
| 2055 | **Operational Readiness Testing** |  | 2025-07-31 → 2025-08-29 (+29d) | 109d → 130d | 56% → 66% | 625d → 571d |  |  |
| 2056 | **ORT Design** |  | 2025-06-10 A |  | 88% → 100% | 662d → none |  |  |
| 2061 | **ORT Test Scope and Approach Consultation (Test Scope and Approach & Test Scripts)** |  | 2025-05-19 A |  | 99% → 100% | 645d → none |  |  |
| 2066 | TORWG Post-Consultation Update (ORT Approach) | 2025-05-14 A | 2025-05-14 A |  | 0% → 100% | 648d → none |  |  |
| 2067 | Updated ORT Test Scope and Approach Documents Released to Industry for eSITWG | 2025-05-16 A | 2025-05-16 A |  | 0% → 100% | 646d → none |  |  |
| 2068 | ORT Test Scope and Approach Endorsement (eSITWG) | 2025-05-19 A | 2025-05-19 A |  | 0% → 100% | 645d → none |  |  |
| 2071 | **ORT Test Scripts Consultation** |  | 2025-06-10 A |  | 0% → 100% | 662d → none |  |  |
| 2073 | ORT Test Scripts Consultation | 2025-05-09 A | 2025-05-16 A |  | 0% → 100% | 633d → none |  |  |
| 2074 | ORT Test Scripts Consultation Completed | 2025-05-16 A | 2025-05-16 A |  | 0% → 100% | 633d → none |  |  |
| 2075 | ORT Test Scripts Updates (Feedback Review) | 2025-05-19 A | 2025-05-22 A |  | 0% → 100% | 633d → none |  |  |
| 2076 | ORT Test Scipts Updates Shared with MHHS and Industry | 2025-05-22 A | 2025-05-22 A |  | 0% → 100% | 633d → none |  |  |
| 2077 | Industry Assurance Review Session Post-Consultation Update (ORT Test Scripts) | 2025-05-30 A | 2025-05-30 A |  | 0% → 100% | 653d → none |  |  |
| 2078 | Updated ORT Test Script Consultation Documents Released to industry for eSITWG | 2025-06-03 A | 2025-06-03 A |  | 0% → 100% | 653d → none |  |  |
| 2079 | ORT Test Scripts and Readiness Spotlight at Elexon Service Management Steering Group | 2025-06-04 A | 2025-06-04 A |  | 0% → 100% | 666d → none |  |  |
| 2080 | ORT Test Scipt Updates Endorsement (eSITWG) | 2025-06-10 A | 2025-06-10 A |  | 0% → 100% | 662d → none |  |  |
| 2081 | **ORT Preparation** |  | 2025-06-13 A |  | 22% → 100% | 659d → none |  |  |
| 2082 | ORT Participant/User Scheduling |  | 2025-05-16 → 2025-06-03 A (+18d) | 12d → 24d | 33% → 100% | 665d → none |  |  |
| 2083 | ORT Participant/User Scheduling Completed | 2025-05-16 → 2025-06-03 A (+18d) | 2025-05-16 → 2025-06-03 A (+18d) |  | 0% → 100% | 679d → none |  |  |
| 2084 | ORT Training and Preparation | 2025-06-04 A | 2025-06-11 A |  | 0% → 100% | 625d → none |  |  |
| 2085 | ORT DITL Session | 2025-06-12 A | 2025-06-12 A |  | 0% → 100% | 661d → none |  |  |
| 2086 | ORT Orientation (JiT) | 2025-06-13 A | 2025-06-13 A |  | 0% → 100% | 625d → none |  |  |
| 2087 | **ORT Execution** | 2025-06-16 A |  |  | 0% → 55% | 625d → 592d |  |  |
| 2088 | ORT Execution | 2025-06-16 A |  |  | 0% → 55% | 625d → 592d |  |  |
| 2108 | **Service Go-Live** |  | 2025-09-01 → 2027-07-30 (+697d) | 22d → 522d |  | 604d → 104d |  | was named Service Go-Live Governance |
| 2110 | Helix Service Management Live | 2025-09-01 → 2025-07-31 (-32d) | 2025-09-01 → 2025-07-31 (-32d) |  |  | 604d → 590d |  | constraint start no earlier than 2025-09-01 → none |
| 2129 | **Operational Readiness E2E Testing** | 2022-10-31 → 2025-05-13 (+925d) | 2022-10-31 → 2025-08-08 (+1012d) | 1d → 64d | 57% → 34% |  |  | baseline start none → 2025-05-13; baseline finish none → 2025-08-08 |
| 2134 | **Service Activation Readiness** | 2022-10-31 → 2024-04-02 A (+519d) | 2022-10-31 → 2025-12-31 (+1157d) | 1d → 457d? | 0% → 49% | none → 516d |  | baseline start none → 2024-04-02; baseline finish none → 2025-12-02 |

| ID | Task | Start | Finish | Duration | Complete | Total float | Predecessors | Other |
| --- | --- | --- | --- | --- | --- | --- | --- | --- |
| 2135 | **Phase 1 - Preparation** | 2022-10-31 A → 2024-04-02 A (+519d) | 2022-10-31 → 2025-08-29 (+1033d) | 1d? → 369d? | 66% → 85% | none → 604d |  | baseline start none → 2024-04-02; baseline finish none → 2025-09-26 |
| 2136 | **Business Service Activation Governance, Planning & Scope** | 2022-10-31 → 2024-04-04 A (+521d) | 2022-10-31 → 2024-09-30 A (+700d) | 1d → 128d |  |  |  | baseline start none → 2024-04-04; baseline finish none → 2024-09-30 |
| 2137 | Create and Confirm SA Scope |  |  |  |  |  |  | constraint start no earlier than 2024-06-03 → finish no earlier than 2024-06-13; baseline start none → 2024-06-03; baseline finish none → 2024-06-13 |
| 2138 | POAP Service Activation |  |  |  |  |  |  | constraint start no earlier than 2024-06-03 → finish no earlier than 2024-06-19; baseline start none → 2024-06-03; baseline finish none → 2024-06-19 |
| 2139 | Service Activation Working Group |  |  |  |  |  |  | constraint start no earlier than 2024-04-04 → finish no earlier than 2024-06-28; baseline start none → 2024-04-04; baseline finish none → 2024-06-28 |
| 2140 | Business Readiness Governance Framework |  |  |  |  |  |  | constraint start no earlier than 2024-08-02 → finish no earlier than 2024-09-30; baseline start none → 2024-08-02; baseline finish none → 2024-09-30 |
| 2141 | Service Activation Governance Framework Completed |  |  |  |  |  |  | constraint none → finish no earlier than 2024-06-28; baseline start none → 2024-09-30; baseline finish none → 2024-09-30 |
| 2142 | **Service Activation High Level Process Models** | 2022-10-31 → 2024-04-02 A (+519d) | 2022-10-31 → 2024-08-31 A (+670d) | 1d → 109d |  |  |  | baseline start none → 2024-04-02; baseline finish none → 2024-08-31 |
| 2143 | Transition Process Model |  |  |  |  |  |  | constraint start no earlier than 2024-04-02 → finish no earlier than 2024-07-08; baseline start none → 2024-04-02; baseline finish none → 2024-07-08 |
| 2144 | Migration Process Model |  |  |  |  |  |  | constraint start no earlier than 2024-08-13 → finish no earlier than 2024-08-31; baseline start none → 2024-08-13; baseline finish none → 2024-08-30 |
| 2145 | Enduring Process Model |  |  |  |  |  |  | constraint start no earlier than 2024-06-03 → start no earlier than 2024-06-01; baseline start none → 2024-06-03; baseline finish none → 2024-08-01 |
| 2146 | Service Activation High Level Process Models Completed | 2024-08-30 A → 2024-08-31 A (+1d) | 2024-08-30 A → 2024-08-31 A (+1d) |  |  |  |  | constraint none → start no earlier than 2024-08-31; baseline start none → 2024-08-31; baseline finish none → 2024-08-31 |
| 2147 | **Target Operating Model for Service Activation** | 2022-10-31 → 2024-06-21 A (+599d) | 2022-10-31 → 2024-10-15 A (+715d) | 1d? → 83d |  |  |  | baseline start none → 2024-06-21; baseline finish none → 2024-10-15 |
| 2148 | MHHSP Engagement Team understanding |  |  |  |  |  |  | constraint start no earlier than 2024-06-21 → finish no earlier than 2024-07-25; baseline start none → 2024-06-21; baseline finish none → 2024-07-25 |
| 2149 | Define and produce organisation model for Service Activation in Elexon |  |  |  |  |  |  | constraint start no earlier than 2024-06-21 → finish no earlier than 2024-10-15; baseline start none → 2024-06-21; baseline finish none → 2024-10-15 |
| 2150 | Implement Target Operating model |  |  |  |  |  |  | baseline start none → 2024-10-15; baseline finish none → 2024-10-15 |
| 2151 | Target Operating Model for Service Activation Completed |  |  |  |  |  |  | constraint none → start no earlier than 2024-10-15; baseline start none → 2024-10-15; baseline finish none → 2024-10-15 |
| 2152 | **SIT Operational Testing for Service Activation** |  |  | 5d → 5d? |  |  |  | baseline start none → 2024-08-12; baseline finish none → 2024-08-16 |
| 2153 | Review and validate test cases |  |  |  |  |  |  | constraint start no earlier than 2024-08-12 → finish no earlier than 2024-08-16; baseline start none → 2024-08-12; baseline finish none → 2024-08-16 |
| 2154 | SIT Operational Testing for Service Activation Completed |  |  | 0d → 1d? |  |  | 2153 → none | constraint none → start no earlier than 2024-08-16; baseline start none → 2024-08-16; baseline finish none → 2024-08-16 |
| 2155 | **Operational Training for Service Activation** | 2022-10-31 → 2025-05-15 A (+927d) | 2022-10-31 → 2025-08-29 (+1033d) | 1d → 77d | 0% → 43% | none → 604d |  | baseline start none → 2024-11-13; baseline finish none → 2025-07-25 |
| 2156 | Training Execution [Placeholder] | 2024-11-13 → 2025-05-15 A (+183d) | 2025-06-13 → 2025-08-29 (+77d) | 153d → 77d | 0% → 43% | 659d → 604d |  | baseline start none → 2025-05-15; baseline finish none → 2025-08-29 |
| 2157 | Service Activation Training Completed | 2025-07-25 → 2025-08-29 (+35d) | 2025-07-25 → 2025-08-29 (+35d) |  |  | 622d → 604d | none → 2156 | baseline start none → 2025-08-29; baseline finish none → 2025-08-29 |
| 2159 | Dress Rehearsal 1 |  |  |  |  | 616d → -89d | 2141, 2146, Service Activation Test Scenarios Completed, 2157, 2154 → 2141, 2146, 2151 | baseline start none → 2025-08-04; baseline finish none → 2025-08-05 |
| 2160 | Dress Rehearsal 1 Complete |  |  |  |  | 616d → -89d |  | constraint none → start no earlier than 2025-01-22; baseline start none → 2025-08-05; baseline finish none → 2025-08-05 |
| 2161 | Dress Rehearsal 2 |  |  |  |  | 616d → -89d |  | constraint none → start no earlier than 2025-08-04; baseline start none → 2025-08-11; baseline finish none → 2025-08-12 |
| 2162 | Dress Rehearsal 2 Complete |  |  |  |  | 617d → -89d |  | constraint none → start no earlier than 2025-01-22; baseline start none → 2025-08-12; baseline finish none → 2025-08-12 |
| 2163 | **Service Activation Go / No Go** | 2022-10-31 → 2025-08-22 (+1026d) | 2022-10-31 → 2025-08-22 (+1026d) | 1d? → 1d |  | none → -96d |  | baseline start none → 2025-08-13; baseline finish none → 2025-08-22 |
| 2164 | **Final Service Activation Go/No Go Decision** | 2022-10-31 → 2025-08-22 (+1026d) | 2022-10-31 → 2025-08-22 (+1026d) | 1d? → 1d |  | none → -96d |  | baseline start none → 2025-08-13; baseline finish none → 2025-08-22 |
| 2165 | DIP Team Ready |  |  | 1d? → 1d |  |  | 2159, 2161 → 2162FS+7d, 2160 | constraint start no earlier than 2025-08-22 → none; baseline start none → 2025-08-22; baseline finish none → 2025-08-22 |
| 2166 | DIP Technical Onboarding Processes Completed |  |  |  |  | -357d → -96d |  | baseline start none → 2025-08-22; baseline finish none → 2025-08-22 |
| 2167 | PM Team Ready | 2025-08-21 → 2025-08-22 (+1d) |  | 1d? → 0d |  | 610d → -96d | 2159, 2161 → 2160, 2162 | constraint finish no earlier than 2025-08-22 → start no earlier than 2025-08-22; baseline start none → 2025-08-22; baseline finish none → 2025-08-22 |
| 2168 | Operational Support Ready (Ops Control Centre, Account Managers) | 2025-08-21 → 2025-08-22 (+1d) |  | 1d? → 0d |  | 610d → -96d |  | constraint finish no earlier than 2025-08-22 → start no earlier than 2025-08-22; baseline start none → 2025-08-22; baseline finish none → 2025-08-22 |
| 2169 | Service Management Activity Completed (Resolver Groups) | 2025-08-21 → 2025-08-22 (+1d) |  | 1d? → 0d |  | 610d → -96d |  | constraint finish no earlier than 2025-08-22 → start no earlier than 2025-08-22; baseline start none → 2025-08-22; baseline finish none → 2025-08-22 |
| 2170 | Process 1.1.1 ISD and Related LWIs Completed |  |  |  |  | -357d → -96d | none → 2169 | constraint start no earlier than 2025-08-22 → none; baseline start none → 2025-08-22; baseline finish none → 2025-08-22 |
| 2171 | **SOLR Consultation** | 2022-10-31 → 2025-04-10 A (+892d) | 2022-10-31 → 2025-08-26 (+1030d) | 1d → 99d | 8% → 67% | none → 607d |  | baseline start none → 2025-04-10; baseline finish none → 2025-09-26 |
| 2172 | SOLR workshop 1 | 2024-04-10 A → 2025-04-10 A (+365d) | 2024-04-10 A → 2025-04-10 A (+365d) |  |  |  | none → 2186SF | constraint start no earlier than 2024-04-10 → start no earlier than 2025-04-10; baseline start none → 2025-04-10; baseline finish none → 2025-04-10 |
| 2173 | SOLR workshop 2 | 2024-04-29 A → 2025-04-29 A (+365d) | 2024-04-29 A → 2025-04-29 A (+365d) |  |  |  | none → 2186SF | constraint start no earlier than 2024-04-29 → start no earlier than 2025-04-29; baseline start none → 2025-04-29; baseline finish none → 2025-04-29 |
| 2179 | SOLR comms to MHHS for review | 2024-05-07 → 2025-08-26 (+476d) | 2024-05-07 → 2025-08-26 (+476d) | 0d → 1d |  | 948d → 607d |  | constraint start no earlier than 2024-05-07 → finish no earlier than 2025-08-26; baseline start none → 2025-08-26; baseline finish none → 2025-08-26 |
| 2180 | **MDR Process** | 2022-10-31 → 2025-04-16 A (+898d) | 2022-10-31 → 2025-07-31 (+1004d) | 1d → 77d | 55% → 58% | none → 625d |  | baseline start none → 2025-04-16; baseline finish none → 2025-07-31 |
| 2181 | MDR workshop 1 |  |  |  |  |  |  | constraint start no earlier than 2024-04-16 → start no earlier than 2025-04-16; baseline start none → 2025-04-16; baseline finish none → 2025-04-16 |
| 2182 | MDR workshop 2 |  |  |  |  |  |  | constraint start no earlier than 2024-04-30 → start no earlier than 2025-04-30; baseline start none → 2025-04-30; baseline finish none → 2025-04-30 |
| 2184 | MDR consultation | 2025-05-07 A → 2025-05-06 A (-1d) | 2025-05-30 → 2025-05-21 A (-9d) | 18d → 12d | 50% → 100% | 669d → none |  | constraint start no earlier than 2024-05-07 → start no earlier than 2025-05-06; baseline start none → 2025-05-06; baseline finish none → 2025-05-21 |
| 2186 | Service Activation Go / No Go |  |  |  |  | -357d → -97d | 2166, 2170 → 2166FF, 2167FF, 2168FF, 2169FF, 2120FF, 2170FF, 2414, 2415 | constraint none → finish no earlier than 2025-08-22; baseline start none → 2025-08-22; baseline finish none → 2025-08-22 |
| 2187 | **Phase 2 - Implementation** | 2022-10-31 A → 2024-06-07 A (+585d) | 2025-09-15 → 2025-12-31 (+107d) | 751d? → 409d? | 2% → 19% | 593d → 516d |  | baseline start none → 2024-06-07; baseline finish none → 2025-12-02 |
| 2188 | **Non-SIT LDSO & SIT MVC Data Loading (M10 Ready)** |  | 2025-08-25 → 2024-06-14 A (-437d) | 317d → 6d | 33% → 100% | 606d → none |  | baseline start none → 2024-06-07; baseline finish none → 2024-06-14 |
| 2189 | Define Non-SIT LDSO Upfront Activities |  |  |  |  |  |  | baseline start none → 2024-06-07; baseline finish none → 2024-06-14 |
| 2191 | Identify Resources |  |  |  |  | 606d → 608d | 2189, 2218FS-1d → 2186 | baseline start none → 2025-08-25; baseline finish none → 2025-08-25 |
| 2192 | Confirmation from Qualification of Wave Participants Complete |  |  |  |  |  |  | baseline start none → 2025-08-25; baseline finish none → 2025-08-25 |
| 2193 | Agree & Understand Support Model |  |  |  |  | 605d → 607d |  | baseline start none → 2025-08-26; baseline finish none → 2025-08-26 |
| 2194 | Confirm Training complete |  |  |  |  | 605d → 607d |  | baseline start none → 2025-08-27; baseline finish none → 2025-08-27 |
| 2195 | Confirm IDNOs gobal sigin comleted prior to M10 |  |  |  |  | 603d → 605d |  | baseline start none → 2025-08-28; baseline finish none → 2025-08-28 |
| 2196 | Engagement / Communications with Participants |  |  |  |  | 602d → 604d |  | baseline start none → 2025-08-29; baseline finish none → 2025-08-29 |
| 2197 | **Internal Communications** | 2022-10-31 → 2025-09-01 (+1036d) | 2022-10-31 → 2025-09-01 (+1036d) |  |  | none → 603d |  | baseline start none → 2025-09-01; baseline finish none → 2025-09-01 |
| 2198 | Agree Content for Livewire |  |  |  |  |  |  | baseline start none → 2025-09-01; baseline finish none → 2025-09-01 |
| 2199 | Publish Content for Livewire |  |  |  |  |  |  | baseline start none → 2025-09-01; baseline finish none → 2025-09-01 |
| 2200 | Validate User Access |  |  |  |  |  |  | baseline start none → 2025-09-02; baseline finish none → 2025-09-02 |
| 2201 | Target Systems and Environments Ready |  |  |  |  |  |  | baseline start none → 2025-09-03; baseline finish none → 2025-09-03 |
| 2202 | Publish the guidence with Parties |  |  |  |  | 598d → 592d |  | baseline start none → 2025-09-04; baseline finish none → 2025-09-04 |
| 2203 | Provide LWIs |  |  |  |  | 593d → 592d | none → 2202 | constraint start no earlier than 2025-09-05 → none; baseline start none → 2025-09-05; baseline finish none → 2025-09-05 |
| 2204 | Business Readiness Governance Approval | 2025-09-05 → 2025-09-08 (+3d) | 2025-09-05 → 2025-09-08 (+3d) |  |  | 593d → 592d | none → 2203 | baseline start none → 2025-09-08; baseline finish none → 2025-09-08 |
| 2207 | PAB Approval Completed | 2025-08-13 → 2025-09-10 (+28d) | 2025-08-13 → 2025-09-10 (+28d) |  |  | 610d → 591d | 2493 → none | constraint none → start no earlier than 2025-09-10; baseline start none → 2025-09-10; baseline finish none → 2025-09-10 |
| 2208 | MHHSP Enabled Confirmation | 2025-08-13 → 2025-09-10 (+28d) | 2025-08-13 → 2025-09-10 (+28d) |  |  | 610d → 590d | 2207 → 2493, 2496, 2499 | constraint none → start no earlier than 2025-09-08; baseline start none → 2025-09-10; baseline finish none → 2025-09-10 |
| 2209 | Add EFD (ISD Calendar Date) to DIP | 2025-09-08 → 2025-09-11 (+3d) | 2025-09-08 → 2025-09-11 (+3d) |  |  | 593d → 590d | 2200, 2201, 2204, 2207, 2208, 2203 → 2200, 2201, 2204, 2208, 2207 | constraint none → start no earlier than 2025-09-11; baseline start none → 2025-09-11; baseline finish none → 2025-09-11 |
| 2211 | Create M16 in Customer Solution Started | 2022-10-31 → 2025-09-11 (+1046d) | 2022-10-31 → 2025-09-11 (+1046d) |  |  | 1343d → 594d |  | constraint none → start no earlier than 2025-09-11; baseline start none → 2025-09-11; baseline finish none → 2025-09-11 |
| 2212 | Create M16 in Customer Solution | 2025-09-08 → 2025-09-11 (+3d) | 2025-09-08 → 2025-09-11 (+3d) |  |  | 598d → 594d | 2211SS, 1st ISD PublishSS → 2211SS, 2215SS | constraint none → start no earlier than 2025-09-11; baseline start none → 2025-09-11; baseline finish none → 2025-09-11 |
| 2213 | DIP Production Success Checks | 2022-10-31 → 2025-09-12 (+1047d) | 2022-10-31 → 2025-09-12 (+1047d) |  |  | 1343d → 594d | none → 2209, 2212 | baseline start none → 2025-09-12; baseline finish none → 2025-09-12 |
| 2214 | 1st ISD Publish Started | 2022-10-31 → 2025-09-11 (+1046d) | 2022-10-31 → 2025-09-11 (+1046d) |  |  | 1338d → 590d |  | constraint none → start no earlier than 2025-09-11; baseline start none → 2025-09-11; baseline finish none → 2025-09-11 |
| 2216 | Go Live ISD | 2022-11-07 → 2025-09-18 (+1046d) | 2022-11-07 → 2025-09-18 (+1046d) | 0d → 1d? |  | 1338d → 590d | 2262 → none | constraint none → start no earlier than 2025-09-18; baseline start none → 2025-09-18; baseline finish none → 2025-09-18 |
| 2218 | Non-SIT LDSO Service Activation Data Loading Completed | 2025-08-25 → 2025-08-06 (-19d) | 2025-08-25 → 2025-08-06 (-19d) |  |  | 606d → 621d | 3514, ISD - Replicate Entity Forms from CS Completed, 3515, Perform Non-SIT LDSO Activities (M10 Ready), 3513, DIP - Promote to production Environment → none | constraint none → finish no earlier than 2025-08-06; baseline start none → 2025-08-06; baseline finish none → 2025-08-06 |

| ID | Task | Start | Finish | Duration | Complete | Total float | Predecessors | Other |
| --- | --- | --- | --- | --- | --- | --- | --- | --- |
| 2220 | MDD Final Circular Completed | 2022-10-31 → 2025-09-10 (+1045d) | 2022-10-31 → 2025-09-10 (+1045d) |  |  | 1280d → 596d | none → 2204 | constraint none → finish no earlier than 2025-09-10; baseline start none → 2025-09-10; baseline finish none → 2025-09-10 |
| 2221 | MDD Manual Update | 2022-10-31 → 2025-09-11 (+1046d) | 2022-11-02 → 2025-09-15 (+1048d) |  |  | 1277d → 593d | 2220SF → 2220FF | constraint none → finish no earlier than 2025-09-15; baseline start none → 2025-09-11; baseline finish none → 2025-09-15 |
| 2222 | MDD Publish | 2022-10-31 → 2025-09-11 (+1046d) | 2022-11-07 → 2025-09-18 (+1046d) |  |  | 1274d → 590d |  | constraint none → finish no earlier than 2025-09-18; baseline start none → 2025-09-11; baseline finish none → 2025-09-18 |
| 2223 | MDD Go Live | 2022-11-07 → 2025-09-18 (+1046d) | 2022-11-07 → 2025-09-18 (+1046d) |  |  | 1274d → 590d |  | constraint none → finish no earlier than 2025-09-18; baseline start none → 2025-09-18; baseline finish none → 2025-09-18 |
| 2224 | Non-SIT LDSO & SIT MVC Service Activation Implementation MDD Completed | 2022-11-07 → 2025-09-18 (+1046d) | 2022-11-07 → 2025-09-18 (+1046d) |  |  | 1274d → 590d |  | constraint none → finish no earlier than 2025-09-18; baseline start none → 2025-09-18; baseline finish none → 2025-09-18 |
| 2227 | Monitoring | 2022-11-08 → 2025-09-18 (+1045d) | 2023-01-20 → 2025-12-02 (+1047d) |  |  | 1274d → 537d | 2224 → none | constraint none → finish no earlier than 2025-12-02; baseline start none → 2025-09-18; baseline finish none → 2025-12-02 |
| 2228 | Reporting | 2022-11-08 → 2025-09-18 (+1045d) | 2023-01-20 → 2025-12-02 (+1047d) |  |  | 1274d → 537d | 2224 → none | constraint none → start no earlier than 2025-09-18; baseline start none → 2025-09-18; baseline finish none → 2025-12-02 |
| 2229 | Issue Management | 2022-11-08 → 2025-09-18 (+1045d) | 2023-01-20 → 2025-12-02 (+1047d) |  |  | 1274d → 537d | 2224 → none | constraint none → finish no earlier than 2025-12-02; baseline start none → 2025-09-18; baseline finish none → 2025-12-02 |
| 2230 | Closed Down Activities | 2022-11-08 → 2025-09-19 (+1046d) | 2022-11-08 → 2025-09-19 (+1046d) |  |  | 1327d → 589d |  | constraint none → finish no earlier than 2025-09-19; baseline start none → 2025-09-19; baseline finish none → 2025-09-19 |
| 2231 | Inform MHHSP | 2022-11-08 → 2025-09-19 (+1046d) | 2022-11-08 → 2025-09-19 (+1046d) |  |  | 1327d → 589d |  | constraint none → finish no earlier than 2025-09-19; baseline start none → 2025-09-19; baseline finish none → 2025-09-19 |
| 2245 | Identify Resources | 2022-10-31 → 2025-10-06 (+1071d) | 2022-10-31 → 2025-10-06 (+1071d) |  |  | 1343d → 578d |  | constraint none → start no earlier than 2025-10-06; baseline start none → 2025-10-06; baseline finish none → 2025-10-06 |
| 2246 | Agree & Understand Support Model | 2022-10-31 → 2025-10-07 (+1072d) | 2022-11-01 → 2025-10-07 (+1071d) | 2d → 1d |  | 1342d → 577d |  | constraint none → start no earlier than 2025-10-07; baseline start none → 2025-10-07; baseline finish none → 2025-10-07 |
| 2247 | Confirm Training complete | 2022-10-31 → 2025-10-08 (+1073d) | 2022-10-31 → 2025-10-08 (+1073d) | 1d → 0d |  | 1343d → 577d |  | constraint none → start no earlier than 2025-10-08; baseline start none → 2025-10-08; baseline finish none → 2025-10-08 |
| 2248 | Engagement / Communications with Participants | 2022-10-31 → 2025-10-09 (+1074d) | 2022-10-31 → 2025-10-09 (+1074d) |  |  | 1343d → 575d |  | constraint none → start no earlier than 2025-10-09; baseline start none → 2025-10-09; baseline finish none → 2025-10-09 |
| 2249 | Validate User Access | 2022-10-31 → 2025-10-13 (+1078d) | 2022-10-31 → 2025-10-13 (+1078d) |  |  | 1334d → 573d |  | constraint none → start no earlier than 2025-10-13; baseline start none → 2025-10-13; baseline finish none → 2025-10-13 |
| 2250 | Target Systems and Environments Ready | 2022-10-31 → 2025-10-14 (+1079d) | 2022-10-31 → 2025-10-14 (+1079d) |  |  | 1334d → 572d |  | constraint none → start no earlier than 2025-10-14; baseline start none → 2025-10-14; baseline finish none → 2025-10-14 |
| 2251 | Provide LWIs | 2022-10-31 → 2025-10-15 (+1080d) | 2022-10-31 → 2025-10-15 (+1080d) | 1d → 1d? |  | 1334d → 570d |  | constraint none → start no earlier than 2025-10-15; baseline start none → 2025-10-15; baseline finish none → 2025-10-15 |
| 2252 | Business Readiness Governance Approval | 2022-10-31 → 2025-10-16 (+1081d) | 2022-10-31 → 2025-10-16 (+1081d) |  |  | 1334d → 570d | none → 2251 | constraint none → start no earlier than 2025-09-05; baseline start none → 2025-10-16; baseline finish none → 2025-10-16 |
| 2257 | MHHSP Enabled Confirmation | 2022-10-31 → 2025-09-25 (+1060d) | 2022-10-31 → 2025-09-25 (+1060d) | 1d → 0d |  | 1334d → 579d | none → 2507, 2510 | constraint none → start no earlier than 2025-09-25; baseline start none → 2025-10-15; baseline finish none → 2025-10-15 |
| 2259 | DIP Promoted to Production | 2025-09-09 → 2025-09-26 (+17d) | 2025-09-09 → 2025-09-26 (+17d) |  |  | 597d → 584d | 2209 → 2258 | constraint none → start no earlier than 2025-09-12; baseline start none → 2025-10-17; baseline finish none → 2025-10-17 |
| 2260 | Create M16 in Customer Solution | 2022-10-31 → 2025-09-25 (+1060d) | 2022-10-31 → 2025-09-25 (+1060d) | 1d → 0d |  | 1336d → 584d | none → 2257 | baseline start none → 2025-10-16; baseline finish none → 2025-10-16 |
| 2261 | DIP Production Success Checks | 2022-11-03 → 2025-09-26 (+1058d) | 2022-11-11 → 2025-09-26 (+1050d) | 7d → 1d? |  | 1334d → 584d | Add EFD(ISD Calendar Date) to DIP, 2260 → 2258, 2260 | baseline start none → 2025-10-17; baseline finish none → 2025-10-17 |
| 2262 | Publish ISD | 2022-11-01 → 2025-09-26 (+1060d) | 2022-11-07 → 2025-10-03 (+1061d) | 5d → 6d |  | 1338d → 579d | Add EFD(ISD Calendar Date) to DIPSS → 2257 | constraint none → start no earlier than 2025-09-26; baseline start none → 2025-10-15; baseline finish none → 2025-10-22 |
| 2265 | MDD Go Live | 2022-11-04 → 2025-10-03 (+1064d) | 2022-11-04 → 2025-10-03 (+1064d) |  |  | 1339d → 579d | 2282 → 2264 | baseline start none → 2025-10-03; baseline finish none → 2025-10-03 |
| 2269 | MHHSP Enabled Confirmation | 2025-09-01 → 2025-10-15 (+44d) | 2025-09-02 → 2025-10-15 (+43d) | 2d → 0d |  | 602d → 566d | MHHSP Confirms SIT Non-MVC PPs MHHS Enabled → 2510 | constraint finish no earlier than 2025-09-02 → start no earlier than 2025-09-08; baseline start 2025-09-01 → 2025-10-15; baseline finish 2025-09-02 → 2025-10-15 |
| 2271 | DIP Promoted to Production | 2022-11-01 → 2025-10-16 (+1080d) | 2022-11-01 → 2025-10-16 (+1080d) |  |  | 1342d → 570d | Add EFD(ISD Calendar Date) to DIPSS → 2270 | constraint none → start no earlier than 2025-09-12; baseline start none → 2025-10-17; baseline finish none → 2025-10-17 |
| 2272 | Create M16 in Customer Solution | 2025-09-16 → 2025-10-16 (+30d) | 2025-09-17 → 2025-10-16 (+29d) | 2d → 0d |  | 5d → 570d | 2308 → 2269 | constraint finish no earlier than 2025-03-07 → start no earlier than 2025-10-16; baseline start 2025-09-16 → 2025-10-16; baseline finish 2025-09-17 → 2025-10-16 |
| 2274 | Publish ISD | 2025-09-18 → 2025-10-16 (+28d) | 2025-09-19 → 2025-10-22 (+33d) | 2d → 5d |  | 5d → 566d | 2272 → 2269 | constraint finish no earlier than 2025-03-07 → start no earlier than 2025-10-15; baseline start 2025-09-18 → 2025-10-15; baseline finish 2025-09-19 → 2025-10-22 |
| 2281 | MDD Manual Update | 2022-10-31 → 2025-10-13 (+1078d) | 2022-11-02 → 2025-10-15 (+1078d) |  |  | 1341d → 571d | 2327SF → 2280FF | constraint none → finish no earlier than 2025-09-15; baseline start none → 2025-10-13; baseline finish none → 2025-10-15 |
| 2282 | MDD Publish | 2022-10-31 → 2025-10-13 (+1078d) | 2022-11-04 → 2025-10-17 (+1078d) |  |  | 1339d → 569d |  | constraint none → start no earlier than 2025-10-13; baseline start none → 2025-10-13; baseline finish none → 2025-10-17 |
| 2286 | Monitoring | 2022-10-31 → 2025-10-15 (+1080d) | 2022-11-14 → 2025-10-29 (+1080d) |  |  | 1333d → 561d |  | constraint none → start no earlier than 2025-10-15; baseline start none → 2025-10-15; baseline finish none → 2025-10-29 |
| 2287 | Reporting | 2022-10-31 → 2025-10-15 (+1080d) | 2022-11-14 → 2025-10-29 (+1080d) |  |  | 1333d → 561d |  | constraint none → start no earlier than 2025-10-15; baseline start none → 2025-11-18; baseline finish none → 2025-12-02 |
| 2288 | Issue Management | 2022-10-31 → 2025-10-15 (+1080d) | 2022-11-14 → 2025-10-29 (+1080d) |  |  | 1333d → 556d |  | constraint none → start no earlier than 2025-10-15; baseline start none → 2025-10-15; baseline finish none → 2025-10-29 |
| 2289 | Closed Down Activities | 2022-10-31 → 2025-10-30 (+1095d) | 2022-11-02 → 2025-11-03 (+1097d) |  |  | 1341d → 556d | 2286SS, 2287SS, 2288SS → 2288 | constraint none → finish no earlier than 2025-09-19; baseline start none → 2025-11-18; baseline finish none → 2025-11-20 |
| 2290 | Inform MHHSP | 2022-10-31 → 2025-11-04 (+1100d) | 2022-11-01 → 2025-11-05 (+1100d) |  |  | 1342d → 556d | 2289SS → 2289 | constraint none → finish no earlier than 2025-09-19; baseline start none → 2025-11-18; baseline finish none → 2025-11-19 |
| 2298 | Validate User Access | 2025-02-17 → 2025-10-13 (+238d) | 2025-02-21 → 2025-10-13 (+234d) | 5d → 1d |  | 739d → 573d |  | constraint finish no earlier than 2025-02-21 → start no earlier than 2025-10-13; baseline start 2025-02-17 → 2025-12-08; baseline finish 2025-02-21 → 2025-12-08 |
| 2299 | Target Systems and Environments Ready | 2025-02-20 → 2025-12-09 (+292d) | 2025-02-24 → 2025-12-09 (+288d) | 3d → 1d |  | 738d → 532d |  | constraint finish no earlier than 2025-02-24 → start no earlier than 2025-12-09; baseline start 2025-02-20 → 2025-12-09; baseline finish 2025-02-24 → 2025-12-09 |
| 2301 | Business Readiness Governance Approval | 2025-02-17 → 2025-12-11 (+297d) | 2025-02-19 → 2025-12-11 (+295d) | 3d → 1d |  | 741d → 530d | none → 2300 | constraint finish no earlier than 2025-02-19 → start no earlier than 2025-09-05; baseline start 2025-02-17 → 2025-12-11; baseline finish 2025-02-19 → 2025-12-11 |
| 2306 | MHHSP Enabled Confirmation | 2025-11-03 → 2025-10-30 (-4d) | 2025-11-04 → 2025-10-30 (-5d) | 2d → 0d |  | 557d → 553d | none → 2518, 2520 | constraint finish no earlier than 2025-11-04 → start no earlier than 2025-09-08; baseline start 2025-11-03 → 2025-12-17; baseline finish 2025-11-04 → 2025-12-17 |
| 2308 | DIP Promoted to Production | 2025-09-15 → 2025-10-31 (+46d) | 2025-09-15 → 2025-10-31 (+46d) | 1d? → 1d |  | 5d → 559d | 3418 → 2307 | constraint none → start no earlier than 2025-09-12; baseline start 2025-09-15 → 2025-12-22; baseline finish 2025-09-15 → 2025-12-22 |
| 2309 | Create M16 in Customer Solution | 2025-12-22 → 2025-12-19 (-3d) | 2025-12-23 → 2025-12-19 (-4d) | 2d → 0d |  | 505d → 524d | 3419 → 2311SS | constraint finish no earlier than 2025-06-06 → start no earlier than 2025-12-19; baseline start 2025-12-29 → 2025-12-22; baseline finish 2025-12-30 → 2025-12-22 |
| 2311 | Publish ISD | 2025-12-24 → 2025-10-31 (-54d) | 2025-12-25 → 2025-11-07 (-48d) | 2d → 6d |  | 505d → 554d | 2309 → 2306, 2307SS | constraint finish no earlier than 2025-06-06 → none; baseline start 2025-12-31 → 2025-12-22; baseline finish 2026-01-01 → 2025-12-26 |
| 2317 | MHHSP Enabled Confirmation | 2025-12-22 → 2025-12-17 (-5d) | 2025-12-23 → 2025-12-17 (-6d) | 2d → 0d |  | 522d → 517d | none → 2520 | constraint finish no earlier than 2025-12-23 → start no earlier than 2025-09-08; baseline start 2025-12-22 → 2025-12-17; baseline finish 2025-12-23 → 2025-12-17 |
| 2319 | Create M16 in Customer Solution | 2026-04-22 → 2025-12-22 (-121d) | 2026-04-23 → 2025-12-22 (-122d) | 2d → 0d |  | 422d → 523d | 3443 → 2321SS | constraint finish no earlier than 2025-09-05 → start no earlier than 2025-12-19; baseline start 2025-09-04 → 2025-12-22; baseline finish 2025-09-05 → 2025-12-22 |
| 2321 | Publish ISD | 2026-04-24 → 2025-12-22 (-123d) | 2026-04-27 → 2025-12-30 (-118d) | 2d → 7d |  | 422d → 517d | 2319 → 2317FS+2d | constraint finish no earlier than 2025-09-05 → none; baseline start 2025-09-04 → 2025-12-22; baseline finish 2025-09-05 → 2025-12-30 |
| 2327 | MDD Final Circular | 2022-10-31 → 2025-12-17 (+1143d) | 2022-10-31 → 2025-12-17 (+1143d) |  |  | 1344d → 519d | 3417 → 2306, 2317 | constraint none → finish no earlier than 2025-09-10; baseline start none → 2025-12-17; baseline finish none → 2025-12-17 |
| 2335 | Issue Management | 2025-09-12 → 2025-12-17 (+96d) | 2025-10-07 → 2025-12-31 (+85d) | 18d → 11d |  | 577d → 516d | 3418SS → none | constraint finish no earlier than 2025-03-26 → start no earlier than 2025-12-17; baseline start 2025-03-03 → 2025-12-17; baseline finish 2025-03-26 → 2025-12-31 |
| 2342 | **Helix E2E Settlement Assurance Testing (SAT)** |  | 2025-07-03 → 2025-08-07 (+35d) | 229d? → 254d? | 60% → 93% | 645d → 620d |  |  |
| 2351 | **Execution** |  | 2025-07-03 → 2025-08-07 (+35d) | 169d → 194d | 46% → 84% | 645d → 620d |  |  |
| 2420 | **S & A QUALIFICATION** |  |  |  | 63% → 66% |  |  |  |
| 2421 | **MHHS Qualification - Qualification Deliverables** |  |  |  | 96% → 97% | 305d → 315d |  |  |
| 2449 | **Qualification Assessment Document** |  |  |  | 90% → 94% | 305d → 315d |  |  |
| 2468 | **Qualification Assessment Document Portal** |  |  |  | 82% → 88% | 305d → 315d |  |  |
| 2477 | QT Wave 2 Participant QAD Application Creation in Portal | 2025-05-26 A | 2025-06-06 A |  | 0% → 100% | 386d → none |  |  |
| 2482 | **MHHS Qualification - SIT Participants** |  |  |  | 44% → 63% |  |  |  |
| 2487 | **MHHS Qualification - M10-Ready** |  |  |  | 66% → 96% |  |  |  |
| 2490 | Completion of Code Bodies review of Final QAD (M10-Ready) |  | 2025-06-06 A |  | 30% → 100% | 60d → none |  |  |
| 2494 | **SIT / LDSO Pathway 2** |  |  |  |  | 605d → 599d | none → 1588 |  |
| 2497 | **SIT / LDSO Pathway 3** |  |  |  |  | 5d → 590d | none → 1591 |  |
| 2501 | **MHHS Qualification - M11-Ready** |  |  |  | 47% → 80% |  |  |  |
| 2503 | SIT M11-ready Participants submit Final QAD (exc Test Reports) |  | 2025-06-06 A |  | 68% → 100% | 628d → none |  |  |
| 2504 | Completion of Code Bodies review of Final QAD (M11-Ready) | 2025-06-09 A |  |  | 0% → 35% | 628d → 622d |  |  |
| 2512 | **MHHS Qualification - Not M11-Ready** |  |  |  | 1% → 19% | 505d → 526d |  |  |
| 2514 | SIT Not M11-Ready Participants submit Final QAD |  |  |  | 1% → 24% | 524d → 564d |  |  |
| 2516 | **SIT Pathway 6** | 2025-11-27 → 2025-10-09 (-49d) |  | 15d → 50d |  | 505d → 519d |  |  |
| 2521 | SIT Participants are Qualified |  |  |  |  | 505d → 526d | QAD Sign Off Deadline (Not M11-Ready)FS+14d → none | constraint none → finish no earlier than 2025-12-17 |
| 2522 | **MHHS Qualification - Non-SIT LDSO (M10-Ready)** |  |  |  | 58% → 74% | 9d → 596d |  |  |
| 2529 | Non-SIT LDSO Participants submit Final QAD |  | 2025-05-23 A |  | 89% → 100% | 9d → none |  |  |
| 2530 | Non-SIT LDSO QT Participants have submitted their final QAD | 2025-05-23 A | 2025-05-23 A |  | 0% → 100% | 9d → none |  |  |
| 2531 | Completion of Code Bodies review of the Final QAD | 2025-05-26 A | 2025-06-20 A |  | 0% → 100% | 9d → none |  |  |

| ID | Task | Start | Finish | Duration | Complete | Total float | Predecessors | Other |
| --- | --- | --- | --- | --- | --- | --- | --- | --- |
| 2532 | QAD Finalisation | 2025-06-23 A |  |  | 0% → 4% | 9d → 596d |  |  |
| 2535 | **MHHS Qualification - Qualification Waves** |  |  |  | 58% → 60% |  |  |  |
| 2716 | **Qualification Wave 1** |  |  |  | 0% → 14% | 419d → 441d |  |  |
| 2717 | **Qualification Wave 1 QAD Prep** |  |  |  | 0% → 46% | 419d → 441d |  |  |
| 2719 | Qualification Wave 1 Participants Submit Initial QAD | 2025-05-05 A |  |  | 0% → 74% | 419d → 441d |  |  |
| 2723 | **Qualification Wave 1 Test Prep** | 2025-05-26 A |  |  | 0% → 22% | 425d → 614d |  |  |
| 2724 | Confirmation from Qualification Wave 1 Participants that DIP onboarding has commenced | 2025-05-26 A | 2025-05-26 A |  | 0% → 100% | 444d → none |  |  |
| 2725 | Qualification Wave 1 Participants DIP Onboarding Window | 2025-05-26 A |  |  | 0% → 63% | 444d → 466d |  |  |
| 2727 | Qualification Wave 1 Participants' to provide status of PIT completion and submit QT Test Plan | 2025-06-13 → 2025-07-14 (+31d) | 2025-06-13 → 2025-07-14 (+31d) |  |  | 450d → 639d |  | constraint start no earlier than 2025-06-13 → start no earlier than 2025-07-14; baseline start 2025-06-16 → 2025-07-14; baseline finish 2025-06-16 → 2025-07-14 |
| 2728 | Review of Participants' PIT Status and QT Test Plan | 2025-06-13 → 2025-06-16 A (+3d) | 2025-07-03 → 2025-08-15 (+43d) | 15d → 45d | 0% → 16% | 450d → 441d | 2727 → none | constraint none → start no earlier than 2025-06-16; baseline finish 2025-07-04 → 2025-08-15 |
| 2729 | Qualification Test Plans for Wave 1 Participants approved | 2025-07-03 → 2025-08-15 (+43d) | 2025-07-03 → 2025-08-15 (+43d) |  |  | 450d → 441d |  | baseline start 2025-07-04 → 2025-08-15; baseline finish 2025-07-04 → 2025-08-15 |
| 2746 | **Qualification Wave 2** | 2025-06-09 A |  |  | 0% → 3% | 386d → 410d |  |  |
| 2747 | **Qualification Wave 2 QAD Prep** | 2025-06-09 A |  |  | 0% → 13% | 386d → 410d |  |  |
| 2748 | Initial QAD Submission window opens | 2025-06-09 A | 2025-06-09 A |  | 0% → 100% | 386d → none |  |  |
| 2749 | Qualification Wave 2 Participants Submit Initial QAD | 2025-06-09 A |  |  | 0% → 17% | 386d → 410d |  |  |
| 2847 | PAB295 | 2025-05-29 A | 2025-05-29 A |  | 0% → 100% | 671d → none |  |  |
| 2848 | PAB296 | 2025-06-11 A | 2025-06-11 A |  | 0% → 100% | 662d → none |  |  |
| 2849 | PAB297 | 2025-06-26 A | 2025-06-26 A |  | 0% → 100% | 651d → none |  |  |
| 2993 | CDWG Endorsement | 2025-06-10 A | 2025-06-10 A |  | 0% → 100% | 662d → none |  |  |
| 2994 | CCAG Endorsement | 2025-06-25 A | 2025-06-25 A |  | 0% → 100% | 651d → none |  |  |
| 2995 | Send to Ofgem for SCR Direction | 2025-06-25 A | 2025-06-25 A |  | 0% → 100% | 651d → none |  |  |
| 2996 | Freeze M8 Change Control Log 1.0 and create V2.0 | 2025-07-02 A | 2025-07-02 A |  | 0% → 100% | 646d → none |  |  |
| 2997 | Agree Fast Track Code Change Process | 2025-07-02 A | 2025-07-02 A |  | 0% → 100% | 646d → none |  |  |
| 2998 | Ofgem direct SCR Code change | 2025-07-03 A | 2025-07-03 A |  | 0% → 100% | 645d → none |  |  |
| 3006 | Code changes delivered (M8) |  |  |  |  |  | 2986, 2965, 1885SS-3d, 3002 → 2986, 2965, 1885SS-3d, 3002, 2107 |  |
| 3012 | **MIGRATION** |  |  |  | 62% → 70% |  |  |  |
| 3013 | **Regulatory Governance** |  | 2025-06-27 → 2025-09-26 (+91d) | 325d → 390d | 83% → 96% | 649d → 584d |  |  |
| 3015 | BSC Panel Ruling | 2025-03-31 A → 2025-06-12 A (+73d) | 2025-06-27 → 2025-06-12 A (-15d) | 65d → 0d | 55% → 100% | 649d → none |  | was named Incentives Implemented; constraint start no earlier than 2025-03-31 → finish no earlier than 2025-06-12; baseline start 2025-03-31 → 2025-06-12; baseline finish 2025-06-27 → 2025-06-12 |
| 3060 | **Supplier Submission Support** |  | 2025-06-04 → 2025-06-18 (+14d) | 29d? → 38d? |  | 666d → 657d |  |  |
| 3065 | Drop-in session 2 | 2025-05-28 A | 2025-05-28 A |  | 0% → 100% | 666d → none |  |  |
| 3066 | Drop-in session 3 | 2025-06-04 → 2025-06-11 A (+7d) | 2025-06-04 → 2025-06-11 A (+7d) |  | 0% → 100% | 666d → none |  | constraint none → start no earlier than 2025-06-11; baseline start 2025-06-04 → 2025-06-11; baseline finish 2025-06-04 → 2025-06-11 |
| 3068 | Q+A documents from sessions published | 2025-06-04 → 2025-06-18 (+14d) | 2025-06-04 → 2025-06-18 (+14d) |  |  | 666d → 657d | 3066 → 3067 | baseline start 2025-06-04 → 2025-06-18; baseline finish 2025-06-04 → 2025-06-18 |
| 3069 | **MCC Stood up** |  |  |  | 49% → 59% |  |  |  |
| 3070 | Migration Planning Management Tool Delivery |  |  |  | 49% → 59% |  |  |  |
| 3071 | **MCC Operational** |  |  |  | 0% → 47% |  |  |  |
| 3072 | **MCC Dress Rehersal 1 - Initialise Schedule (Weekly) Drop 1, 2** |  | 2025-07-15 → 2025-07-22 (+7d) | 60d → 65d | 0% → 47% | 637d → 632d |  |  |
| 3073 | Issue Dress Rehearsal support information to all Suppliers (SIT & Non-SIT) |  |  |  |  |  |  | was named Issue Dress Rehearsal support information to Participants |
| 3084 | Dress rehearsal completion report |  |  |  |  |  | 3083 → 3083, 3080 |  |
| 3096 | M11 Readiness Checkpoint |  | 2025-09-26 → 2025-08-28 (-29d) | 45d → 24d |  | 584d → 570d |  | constraint finish no earlier than 2025-09-26 → finish no earlier than 2025-08-28 |
| 3099 | **Migration Artefact Development and Publication** |  |  |  | 67% → 81% |  |  |  |
| 3142 | **Data Cleanse Plan** |  |  |  | 93% → 98% |  |  |  |
| 3147 | **MTDs** |  | 2025-07-21 → 2025-07-18 (-3d) | 241d → 240d | 79% → 95% | 633d → 634d |  |  |
| 3148 | **ESME ID** |  | 2025-05-16 A |  | 93% → 100% | 679d → none |  |  |
| 3152 | Suppliers complete Work Off plans |  | 2025-05-16 A |  | 92% → 100% | 679d → none |  |  |
| 3153 | ESME ID Complete | 2025-05-16 A | 2025-05-16 A |  | 0% → 100% | 679d → none |  |  |
| 3154 | **Meter Location and Number of Displayed Register Digits** |  | 2025-07-21 → 2025-07-18 (-3d) | 222d → 221d | 67% → 91% | 633d → 634d |  |  |
| 3158 | Suppliers complete Work Off plans |  | 2025-07-21 → 2025-07-18 (-3d) | 124d → 123d | 60% → 89% | 633d → 634d |  |  |
| 3159 | Meter Location and Number of Displayed Register Digits Complete | 2025-07-21 → 2025-07-18 (-3d) | 2025-07-21 → 2025-07-18 (-3d) |  |  | 633d → 634d |  |  |
| 3170 | The DCC to extract Domestic Premises Indicator from the CSS and provide a file to each LDSO and EES. |  |  |  |  |  | 1885FS-14d → none |  |
| 3173 | **Connection Type and Meter Type Misalignments** |  |  |  | 35% → 62% |  |  |  |
| 3174 | **Traditional Meters installed on Current Transformers** |  |  |  | 11% → 30% |  |  |  |
| 3175 | Suppliers investigate all MPANs with Traditional Meters installed on a Current Transformer Connection Type |  | 2025-05-30 A |  | 80% → 100% | 301d → none |  |  |
| 3176 | Suppliers to raise the relevant SDEP cases with LDSOs in pot 3 | 2025-05-30 A | 2025-05-30 A |  | 0% → 100% | 629d → none |  |  |
| 3177 | Suppliers to have ensured that Meter Operators have sent the necessary D0312s for MPANs in pot 2 | 2025-06-02 A | 2025-06-30 A |  | 0% → 100% | 648d → none |  |  |
| 3178 | LDSOs will be required to have corrected all of these Connection Types in pot 3 | 2025-06-02 A | 2025-07-25 A |  | 0% → 100% | 629d → none |  |  |
| 3179 | Suppliers to have completed meter exchanges for those MPANs in pot 1 | 2025-06-02 A |  |  | 0% → 6% |  |  |  |
| 3181 | **CHECK Meters** |  | 2025-06-02 A |  | 80% → 100% | 668d → none |  |  |
| 3182 | Suppliers and their appointed Meter Operator investigate MPANs within their portfolio that have incorrectly populated meters with the Meter Type CHECK within MPRS. Meter Operators are required to send a D0312 to remove the CHECK meter from MPRS. |  | 2025-05-30 A |  | 80% → 100% | 669d → none |  |  |
| 3183 | Once CHECK meters are either removed from MPRS or the Meter Type is changed to a valid Meter Type, the LDSO should check that the Connection Type assigned to the MPAN is still valid. |  | 2025-05-30 A |  | 80% → 100% | 669d → none |  |  |
| 3184 | Suppliers confirm to the Programme that they have completed this activity | 2025-06-02 A | 2025-06-02 A |  | 0% → 100% | 668d → none |  |  |
| 3185 | CHECK Meters complete | 2025-06-02 A | 2025-06-02 A |  | 0% → 100% | 668d → none |  |  |
| 3186 | **Smart Meter Types installed on CT Connection Types** |  |  |  | 41% → 80% |  |  |  |
| 3188 | LDSOs investigate Connection Type misalignments and correct where appropriate |  | 2025-05-30 A |  | 74% → 100% | 629d → none |  |  |
| 3189 | LDSOs raise SDEP queries with Suppliers where they believe there is an issue | 2025-05-30 A | 2025-05-30 A |  | 0% → 100% | 629d → none |  |  |
| 3190 | Suppliers resolve all issues | 2025-06-02 A |  |  | 0% → 55% |  |  |  |
| 3192 | **Linked Import / Export MPANs** |  | 2025-07-28 → 2025-07-25 (-3d) | 106d → 105d | 49% → 83% | 628d → 629d |  |  |
| 3193 | LDSOs review and correct linked Import / Export MPANs with Different Connection Types |  | 2025-07-28 → 2025-07-25 (-3d) | 106d → 105d | 49% → 83% | 628d → 629d |  |  |
| 3194 | LDSOs, Import and Export Suppliers review and correct linked Import / Export MPANs with meters in the Advanced and Traditional or Smart Meter Groups |  | 2025-07-28 → 2025-07-25 (-3d) | 106d → 105d | 49% → 83% | 628d → 629d |  |  |
| 3195 | Linked Import / Export MPANs complete | 2025-07-28 → 2025-07-25 (-3d) | 2025-07-28 → 2025-07-25 (-3d) |  |  | 628d → 629d |  |  |
| 3196 | **Related MPANs** |  |  |  | 50% → 83% |  |  |  |

| ID | Task | Start | Finish | Duration | Complete | Total float | Predecessors | Other |
| --- | --- | --- | --- | --- | --- | --- | --- | --- |
| 3197 | LDSOs review and correct related MPANs with different Connection Types |  | 2025-06-20 A |  | 65% → 100% | 629d → none |  |  |
| 3198 | Suppliers unrelate any MPANs required | 2025-06-23 A |  |  | 0% → 28% |  |  |  |
| 3199 | Suppliers should investigate Related MPANs within different meter groups and verify that they are correct or request that their Meter Operators update the Meter Types where they are incorrect |  |  |  | 50% → 83% |  |  |  |
| 3231 | **Preparation for Cutover to Live** |  |  |  | 11% → 27% |  |  |  |
| 3232 | **Central Systems Prepare for Cutover to Live** |  |  |  | 31% → 74% |  |  |  |
| 3234 | **Development of Comms Approach and Declaration Guidance** |  |  |  | 20% → 80% |  |  | baseline start 2025-03-03 → 2025-04-28; baseline finish 2025-06-19 → 2025-08-14 |
| 3235 | Draft Cutover Comms Approach |  |  |  | 20% → 80% |  |  |  |
| 3238 | **Development of Cutover Plan requirements with Participants** |  |  |  | 33% → 73% |  |  |  |
| 3239 | Development of Central Parties Cutover Plans |  | 2025-05-16 A |  | 88% → 100% | 659d → none |  | baseline start 2025-04-28 → 2025-04-11; baseline finish 2025-07-17 → 2025-05-16 |
| 3240 | Development of Programme Participant Cutover Plans |  | 2025-06-30 → 2025-07-11 (+11d) | 57d → 66d | 40% → 80% | 67d → 28d |  | constraint finish no earlier than 2025-06-27 → finish no earlier than 2025-07-11; baseline start 2025-07-17 → 2025-04-11; baseline finish 2025-07-17 → 2025-07-11 |
| 3241 | Central Party Cutover Plan Assurance |  | 2025-06-13 A |  | 49% → 100% | 659d → none |  |  |
| 3242 | Consolidated MHHS Cutover Plan Developed | 2025-05-19 A | 2025-06-13 → 2025-06-27 A (+14d) | 20d → 30d | 0% → 100% | 659d → none |  | baseline finish 2025-06-13 → 2025-06-27 |
| 3243 | LDSO Cutover Plan Assurance | 2025-06-30 → 2025-07-14 (+14d) | 2025-07-18 → 2025-08-01 (+14d) |  |  | 634d → 624d | 3240FF → 3240 |  |
| 3244 | SIT Supplier and SIT Agent Cutover Plan Assurance | 2025-06-30 → 2025-07-14 (+14d) |  | 40d → 30d |  |  | 3240FF → 3240 |  |
| 3248 | Completion of the pre-M10 MHHS Data Cleanse | 2025-09-24 → 2025-09-22 (-2d) | 2025-09-24 → 2025-09-22 (-2d) |  |  | 586d → 588d |  |  |
| 3249 | Market-wide Participant MHHS Supporting Functionality Ready - Confirmation from Code Bodies |  |  |  |  | 594d → 593d | 1885FS-8d → none | constraint none → finish no earlier than 2025-09-15 |
| 3250 | Market-wide Participant MHHS Supporting Functionality Ready |  |  |  |  | 589d → 588d | 1885FS-3d → 1885 |  |
| 3267 | Confirmation that Market Segment has been populated for 95% of LDSO portfolios |  |  |  |  | 5d → 7d |  | baseline start none → 2025-09-12; baseline finish none → 2025-09-12 |
| 3275 | TORWG (Recommendation from TORWG that the Programme should enter M10) |  |  |  |  | 5d → 7d | 3266FS+1d, 3270FS+1d, 3272FS+3d, 3246FS+1d, 3247FS+1d, SIT LDSOs Create Certificates and Test ConnectivityFS+1d, 3268FS+3d, 3269FS+3d, 3271FS+3d, 3273, 3274 → 3266FS+1d, 3270FS+1d, 3272FS+3d, 3246FS+1d, 3247FS+1d, 3268FS+3d, 3269FS+3d, 3271FS+3d, 3273, 3274 |  |
| 3276 | MCAG (Confirm that the Programme can Enter M10) |  |  |  |  | 5d → 7d | 3275FS+2d, SIT MVC Service Activation Implementation Complete → 3275FS+2d |  |
| 3281 | Recommendation from TORWG that PSG should approve M10 |  |  |  |  |  | 3277FS+1d, 3278FS+1d, 3279FS+1d, 3280FS+1d, SIT LDSOs to update systems with ISD → 3277FS+1d, 3278FS+1d, 3279FS+1d, 3280FS+1d |  |
| 3287 | TORWG (Confirmation of Qualified Parties from TORWG) |  |  |  |  |  | 3284FS+1d, 3285FS+1d, 3286FS+1d, 3262, SIT MVC S&As Create Certificates and Test Connectivity, SIT MVC S&As to update systems with ISD → 3284FS+1d, 3285FS+1d, 3286FS+1d, 3262 |  |
| 3297 | Sprint Execution Start |  |  |  |  |  | 3296FS+5d, SIT MVC Service Activation Implementation Complete, 3389 → 3296FS+5d, 3389 | constraint none → start no earlier than 2025-10-22 |
| 3317 | Non-SIT Participants Migration Start |  |  |  |  |  | 3414FS+1d → none | constraint none → finish no earlier than 2026-05-15 |
| 3384 | Assurance of DCC capacity upgrade to ensure suitability to support migration |  |  |  |  |  | 1885FF-23d → 1885FF-21d |  |
| 3386 | **Migration - Tier 1 Milestones** | 2025-09-24 → 2025-09-22 (-2d) |  | 488d → 490d |  | 25d → 27d |  |  |
| 3387 | Load Shaping Service switched on (M13) | 2025-09-24 → 2025-09-22 (-2d) | 2025-09-24 → 2025-09-22 (-2d) |  |  | 25d → 27d |  |  |
| 3388 | Load Shaping Service switched on (M13*) - Late Exit |  |  |  |  |  | 3387FS+65d → 3387FS+67d |  |
| 3389 | Start of 18-month migration for UMS / Advanced (M11) |  |  |  |  |  | 3387, 3288, 3289, SIT MVC Service Activation Implementation Complete, 1885FS+20d → 3387, 3288, 3289, 1885FS+20d |  |
| 3391 | Start of 18-month migration for Smart / Non-smart (M12) |  |  |  |  |  | 3387, 1885FS+20d → 3387, 1885FS+22d |  |
| 3395 | **BUSINESS & OPERATIONAL READINESS** |  |  | 1344d? → 1344d | 18% → 36% |  |  |  |
| 3396 | **Service Management** |  | 2026-01-14 → 2026-03-26 (+71d) | 838d → 889d | 42% → 22% | 506d → 455d |  |  |
| 3408 | Hypercare post M10 | 2025-09-25 → 2025-09-23 (-2d) |  | 80d → 82d |  |  |  |  |
| 3410 | **Wave 1** |  | 2026-05-14 → 2025-09-26 (-230d) | 924d → 760d |  | 420d → 584d |  |  |
| 3411 | **SIT Non-MVC Service Activation Preparation Tasks** |  | 2025-02-28 → 2022-11-29 (-822d) | 610d → 22d |  | 734d → 1322d |  | baseline finish 2022-10-31 → 2026-05-14 |
| 3412 | Helix Preparatory Activities Complete | 2025-02-28 → 2022-10-31 (-851d) | 2025-02-28 → 2022-10-31 (-851d) |  |  | 734d → 1344d | SIT MVC Service Activation Preparation Tasks Complete → none |  |
| 3414 | Wave 1 Service Activation | 2026-04-16 → 2022-11-01 (-1262d) | 2026-05-14 → 2022-11-29 (-1262d) |  |  | 419d → 1322d | 2745, 3413 → 3413 |  |
| 3415 | **Wave 1 - Service Activation Implementation** |  | 2026-04-27 → 2025-09-11 (-228d) | 171d → 9d |  | 433d → 585d |  |  |
| 3416 | MHHSP Enabled Confirmation | 2026-03-02 → 2025-09-01 (-182d) | 2026-03-03 → 2025-09-02 (-182d) |  |  | 472d → 602d |  | constraint finish no earlier than 2026-03-03 → finish no earlier than 2025-09-02; baseline start 2026-03-02 → 2025-09-01; baseline finish 2026-03-03 → 2025-09-02 |
| 3417 | PAB Approval | 2022-10-31 → 2025-09-01 (+1036d) | 2022-10-31 → 2025-09-02 (+1037d) | 0d → 2d |  | 1335d → 602d |  | constraint none → finish no earlier than 2025-09-02; baseline start none → 2025-09-01; baseline finish none → 2025-09-02 |
| 3418 | Add EFD to DIP | 2025-09-12 → 2025-09-02 (-10d) | 2025-09-12 → 2025-09-03 (-9d) | 1d → 2d |  | 5d → 584d | MHHSP Confirms SIT MVC PPs MHHS Enabled, SIT MVC Service Activation Preparation Tasks Complete, 2499SS+3d → none | constraint none → finish no earlier than 2025-09-03; baseline start 2025-09-12 → 2025-09-02; baseline finish 2025-09-12 → 2025-09-03 |
| 3419 | DIP Promoted to Production | 2025-12-19 → 2025-09-04 (-106d) | 2025-12-19 → 2025-09-05 (-105d) | 1d → 2d |  | 505d → 584d | Add EDF to DIP → 3418 | constraint finish no earlier than 2025-06-05 → finish no earlier than 2025-09-04; baseline start 2025-12-25 → 2025-09-03; baseline finish 2025-12-26 → 2025-09-04 |
| 3420 | Create M16 in Customer Solution | 2026-06-04 → 2025-09-08 (-269d) | 2026-06-05 → 2025-09-09 (-269d) |  |  | 402d → 584d | 3467 → 3419 | constraint finish no earlier than 2025-11-07 → finish no earlier than 2025-09-05; baseline start 2025-11-06 → 2025-09-04; baseline finish 2025-11-07 → 2025-09-05 |
| 3421 | Publish ISD | 2026-06-08 → 2025-09-10 (-271d) | 2026-06-09 → 2025-09-11 (-271d) |  |  | 402d → 584d |  | constraint finish no earlier than 2025-11-07 → finish no earlier than 2025-09-05; baseline start 2025-11-06 → 2025-09-04; baseline finish 2025-11-07 → 2025-09-05 |
| 3422 | Wave 1 - Service Activation Implementation Complete (M) | 2026-04-27 → 2025-09-11 (-228d) | 2026-04-27 → 2025-09-11 (-228d) |  |  | 433d → 595d | 2321 → 3421 |  |
| 3423 | **Wave 1 - Service Activation Implementation MDD** | 2026-04-28 → 2025-09-12 (-228d) | 2026-05-12 → 2025-09-26 (-228d) |  |  | 422d → 584d |  |  |
| 3424 | MDD Manual Load | 2025-09-22 → 2025-09-12 (-10d) | 2025-09-30 → 2025-09-18 (-12d) | 7d → 5d |  | 574d → 584d | 2274 → 3421 | constraint finish no earlier than 2025-03-14 → finish no earlier than 2025-09-10; baseline start 2025-03-06 → 2025-09-04; baseline finish 2025-03-14 → 2025-09-10 |
| 3425 | MDD Update | 2025-10-01 → 2025-09-19 (-12d) | 2025-10-10 → 2025-09-26 (-14d) | 8d → 6d |  | 574d → 584d |  | constraint finish no earlier than 2025-03-25 → finish no earlier than 2025-09-17; baseline start 2025-03-14 → 2025-09-10; baseline finish 2025-03-25 → 2025-09-17 |
| 3426 | Wave 1 - Service Activation Implementation MDD Complete (M) | 2026-05-12 → 2025-09-26 (-228d) | 2026-05-12 → 2025-09-26 (-228d) |  |  | 422d → 584d | 3473 → 3425 |  |
| 3427 | **Wave 1 - Service Activation Hypercare** |  | 2026-05-05 → 2025-09-24 (-223d) | 177d → 18d |  | 427d → 586d |  |  |
| 3428 | Service& Process Monitoring | 2025-12-18 → 2025-09-02 (-107d) | 2026-01-12 → 2025-09-19 (-115d) | 18d → 14d |  | 508d → 589d | Add EDF to DIPSS → 3418SS | constraint finish no earlier than 2025-06-25 → finish no earlier than 2025-09-18; baseline start 2025-06-02 → 2025-09-01; baseline finish 2025-06-25 → 2025-09-18 |
| 3429 | Daily Reporting | 2025-09-12 → 2025-09-02 (-10d) | 2025-10-07 → 2025-09-19 (-18d) | 18d → 14d |  | 577d → 589d |  | constraint finish no earlier than 2025-03-26 → finish no earlier than 2025-09-18; baseline start 2025-03-03 → 2025-09-01; baseline finish 2025-03-26 → 2025-09-18 |
| 3430 | Issue Management | 2025-12-18 → 2025-09-02 (-107d) | 2026-01-12 → 2025-09-19 (-115d) | 18d → 14d |  | 508d → 589d | Add EDF to DIPSS → 3418SS | constraint finish no earlier than 2025-06-25 → finish no earlier than 2025-09-18; baseline start 2025-06-02 → 2025-09-01; baseline finish 2025-06-25 → 2025-09-18 |
| 3431 | SA Hypercare Close Down Activities | 2025-09-12 → 2025-09-01 (-11d) | 2025-10-07 → 2025-09-18 (-19d) | 18d → 14d |  | 574d → 586d | 3418SS → none | constraint finish no earlier than 2025-03-26 → finish no earlier than 2025-09-18; baseline start 2025-03-03 → 2025-09-01; baseline finish 2025-03-26 → 2025-09-18 |
| 3432 | Handover to MHHSP | 2025-10-08 → 2025-09-19 (-19d) | 2025-10-10 → 2025-09-24 (-16d) | 3d → 4d |  | 574d → 586d |  | constraint finish no earlier than 2025-03-25 → finish no earlier than 2025-09-18; baseline start 2025-03-21 → 2025-09-15; baseline finish 2025-03-25 → 2025-09-18 |
| 3433 | Non-SIT LDSO Service Activation Hypercare Complete (M) |  |  |  |  |  | 3480 → 3432 |  |
| 3434 | **Wave 2** |  | 2026-07-01 → 2025-11-20 (-223d) | 958d → 799d |  | 386d → 545d |  |  |
| 3435 | **SIT Non-MVC Service Activation Preparation Tasks** |  | 2026-05-14 → 2022-12-02 (-1259d) | 924d → 25d |  | 420d → 1319d |  | baseline finish 2026-05-14 → 2026-06-30 |
| 3438 | Wave 2 Service Activation | 2026-05-29 → 2022-11-01 (-1305d) | 2026-07-01 → 2022-12-02 (-1307d) |  |  | 386d → 1319d | 2775, 3437 → 3437 |  |
| 3439 | **Wave 2 - Service Activation Implementation** |  | 2026-06-09 → 2025-11-13 (-208d) | 157d → 9d |  | 402d → 550d |  |  |
| 3440 | MHHSP Enabled Confirmation | 2025-02-24 → 2025-11-03 (+252d) | 2025-02-25 → 2025-11-04 (+252d) |  |  | 737d → 557d |  | constraint finish no earlier than 2025-02-25 → finish no earlier than 2025-11-04; baseline start 2025-02-24 → 2025-11-03; baseline finish 2025-02-25 → 2025-11-04 |
| 3441 | PAB Approval | 2026-04-16 → 2025-11-03 (-164d) | 2026-04-17 → 2025-11-04 (-164d) |  |  | 439d → 557d | 2745 → none | constraint finish no earlier than 2025-09-02 → finish no earlier than 2025-11-04; baseline start 2025-09-01 → 2025-11-03; baseline finish 2025-09-02 → 2025-11-04 |
| 3442 | Add EFD to DIP | 2026-04-16 → 2025-11-04 (-163d) | 2026-04-17 → 2025-11-05 (-163d) |  |  | 422d → 550d | 2745 → none | constraint finish no earlier than 2025-09-03 → finish no earlier than 2025-11-05; baseline start 2025-09-02 → 2025-11-04; baseline finish 2025-09-03 → 2025-11-05 |
| 3443 | DIP Promoted to Production | 2026-04-20 → 2025-11-06 (-165d) | 2026-04-21 → 2025-11-07 (-165d) |  |  | 422d → 550d |  | constraint finish no earlier than 2025-09-04 → finish no earlier than 2025-11-06; baseline start 2025-09-03 → 2025-11-05; baseline finish 2025-09-04 → 2025-11-06 |
| 3444 | Create M16 in Customer Solution | 2026-08-10 → 2025-11-10 (-273d) | 2026-08-11 → 2025-11-11 (-273d) |  |  | 355d → 550d | 3491 → 3443 | constraint finish no earlier than 2025-12-30 → finish no earlier than 2025-11-07; baseline start 2025-12-29 → 2025-11-06; baseline finish 2025-12-30 → 2025-11-07 |
| 3445 | Publish ISD | 2026-08-12 → 2025-11-12 (-273d) | 2026-08-13 → 2025-11-13 (-273d) |  |  | 355d → 550d |  | constraint finish no earlier than 2025-12-30 → finish no earlier than 2025-11-07; baseline start 2025-12-29 → 2025-11-06; baseline finish 2025-12-30 → 2025-11-07 |
| 3446 | Wave 2 - Service Activation Implementation Complete (M) | 2026-06-09 → 2025-11-13 (-208d) | 2026-06-09 → 2025-11-13 (-208d) |  |  | 402d → 550d | 3421 → 3445 |  |
| 3448 | MDD Manual Load | 2025-12-26 → 2025-11-06 (-50d) | 2026-01-05 → 2025-11-12 (-54d) | 7d → 5d |  | 505d → 551d | 2311 → none | constraint finish no earlier than 2025-06-13 → finish no earlier than 2025-11-12; baseline start 2025-06-05 → 2025-11-06; baseline finish 2025-06-13 → 2025-11-12 |
| 3449 | MDD Update | 2026-01-06 → 2025-11-12 (-55d) | 2026-01-15 → 2025-11-19 (-57d) | 8d → 6d |  | 505d → 546d | 3448 → none | constraint finish no earlier than 2025-06-24 → finish no earlier than 2025-11-19; baseline start 2025-06-13 → 2025-11-12; baseline finish 2025-06-24 → 2025-11-19 |
| 3452 | Service& Process Monitoring | 2026-04-16 → 2025-11-03 (-164d) | 2026-05-05 → 2025-11-20 (-166d) |  |  | 427d → 545d | 3442SS → none | constraint finish no earlier than 2025-09-18 → finish no earlier than 2025-11-20; baseline start 2025-09-01 → 2025-11-03; baseline finish 2025-09-18 → 2025-11-20 |

| ID | Task | Start | Finish | Duration | Complete | Total float | Predecessors | Other |
| --- | --- | --- | --- | --- | --- | --- | --- | --- |
| 3453 | Daily Reporting | 2025-12-18 → 2025-11-03 (-45d) | 2026-01-12 → 2025-11-20 (-53d) | 18d → 14d |  | 508d → 545d | Add EDF to DIPSS → none | constraint finish no earlier than 2025-06-25 → finish no earlier than 2025-11-20; baseline start 2025-06-02 → 2025-11-03; baseline finish 2025-06-25 → 2025-11-20 |
| 3454 | Issue Management | 2026-04-16 → 2025-11-03 (-164d) | 2026-05-05 → 2025-11-20 (-166d) |  |  | 427d → 545d | 3442SS → none | constraint finish no earlier than 2025-09-18 → finish no earlier than 2025-11-20; baseline start 2025-09-01 → 2025-11-03; baseline finish 2025-09-18 → 2025-11-20 |
| 3455 | SA Hypercare Close Down Activities | 2025-12-18 → 2025-11-03 (-45d) | 2026-01-12 → 2025-11-20 (-53d) | 18d → 14d |  | 504d → 545d | Add EDF to DIPSS → none | constraint finish no earlier than 2025-06-25 → finish no earlier than 2025-11-20; baseline start 2025-06-02 → 2025-11-03; baseline finish 2025-06-25 → 2025-11-20 |
| 3456 | Handover to MHHSP | 2026-01-13 → 2025-11-17 (-57d) | 2026-01-16 → 2025-11-20 (-57d) |  |  | 504d → 545d | 3455 → none | constraint finish no earlier than 2025-06-26 → finish no earlier than 2025-11-20; baseline start 2025-06-23 → 2025-11-17; baseline finish 2025-06-26 → 2025-11-20 |
| 3458 | **Wave 3** |  | 2026-08-13 → 2026-01-16 (-209d) | 989d → 840d |  | 355d → 504d |  |  |
| 3459 | **SIT Non-MVC Service Activation Preparation Tasks** |  | 2026-07-01 → 2022-11-14 (-1325d) | 958d → 11d |  | 386d → 1333d |  | baseline finish 2026-06-30 → 2026-08-26 |
| 3462 | Wave 3 Service Activation | 2026-07-31 → 2022-11-01 (-1368d) | 2026-08-13 → 2022-11-14 (-1368d) |  |  | 355d → 1333d | 2805, 3461 → 3461 |  |
| 3463 | **Wave 3 - Service Activation Implementation** |  | 2026-08-13 → 2026-01-05 (-220d) | 169d → 11d |  | 355d → 513d |  |  |
| 3465 | PAB Approval | 2026-05-29 → 2025-12-22 (-158d) | 2026-06-01 → 2025-12-23 (-160d) |  |  | 408d → 514d | 2775 → none | constraint finish no earlier than 2025-11-04 → finish no earlier than 2025-12-23; baseline start 2025-11-03 → 2025-12-22; baseline finish 2025-11-04 → 2025-12-23 |
| 3466 | Add EFD to DIP | 2026-05-29 → 2025-12-24 (-156d) | 2026-06-01 → 2025-12-25 (-158d) |  |  | 402d → 514d | 2775 → 3465 | constraint finish no earlier than 2025-11-05 → finish no earlier than 2025-12-24; baseline start 2025-11-04 → 2025-12-23; baseline finish 2025-11-05 → 2025-12-24 |
| 3467 | DIP Promoted to Production | 2026-06-02 → 2025-12-29 (-155d) | 2026-06-03 → 2025-12-30 (-155d) |  |  | 402d → 513d |  | constraint finish no earlier than 2025-11-06 → finish no earlier than 2025-12-30; baseline start 2025-11-05 → 2025-12-29; baseline finish 2025-11-06 → 2025-12-30 |
| 3468 | Create M16 in Customer Solution | 2026-10-02 → 2025-12-31 (-275d) | 2026-10-05 → 2026-01-01 (-277d) |  |  | 316d → 513d | 3525 → 3467 | constraint finish no earlier than 2026-03-06 → finish no earlier than 2025-12-30; baseline start 2026-03-05 → 2025-12-29; baseline finish 2026-03-06 → 2025-12-30 |
| 3469 | Publish ISD | 2026-10-06 → 2026-01-02 (-277d) | 2026-10-07 → 2026-01-05 (-275d) |  |  | 316d → 513d |  | constraint finish no earlier than 2026-03-06 → finish no earlier than 2025-12-30; baseline start 2026-03-05 → 2025-12-29; baseline finish 2026-03-06 → 2025-12-30 |
| 3470 | Wave 3 - Service Activation Implementation Complete (M) | 2026-08-13 → 2026-01-05 (-220d) | 2026-08-13 → 2026-01-05 (-220d) |  |  | 355d → 513d | 3445 → 3469 |  |
| 3472 | MDD Manual Load | 2026-04-28 → 2025-12-29 (-120d) | 2026-05-04 → 2026-01-06 (-118d) | 5d → 7d |  | 422d → 512d | 2321 → none | constraint finish no earlier than 2025-09-10 → finish no earlier than 2026-01-06; baseline start 2025-09-04 → 2025-12-29; baseline finish 2025-09-10 → 2026-01-06 |
| 3473 | MDD Update | 2026-05-05 → 2025-01-06 (-484d) | 2026-05-12 → 2026-01-15 (-117d) | 6d → 269d |  | 422d → 505d | 3472 → none | constraint finish no earlier than 2025-09-17 → finish no earlier than 2026-01-15; baseline start 2025-09-10 → 2025-01-06; baseline finish 2025-09-17 → 2026-01-15 |
| 3476 | Service& Process Monitoring | 2025-11-03 → 2025-12-22 (+49d) | 2025-11-20 → 2026-01-16 (+57d) | 14d → 20d |  | 545d → 504d |  | constraint finish no earlier than 2025-11-20 → finish no earlier than 2026-01-16; baseline start 2025-11-03 → 2025-12-22; baseline finish 2025-11-20 → 2026-01-16 |
| 3477 | Daily Reporting | 2026-04-16 → 2025-12-22 (-115d) | 2026-05-05 → 2026-01-16 (-109d) | 14d → 20d |  | 427d → 504d | 3442SS → none | constraint finish no earlier than 2025-09-18 → finish no earlier than 2026-01-16; baseline start 2025-09-01 → 2025-12-22; baseline finish 2025-09-18 → 2026-01-16 |
| 3478 | Issue Management | 2025-11-03 → 2025-12-22 (+49d) | 2025-11-20 → 2026-01-16 (+57d) | 14d → 20d |  | 545d → 504d |  | constraint finish no earlier than 2025-11-20 → finish no earlier than 2026-01-16; baseline start 2025-11-03 → 2025-12-22; baseline finish 2025-11-20 → 2026-01-16 |
| 3479 | SA Hypercare Close Down Activities | 2025-09-01 → 2025-12-22 (+112d) | 2025-09-18 → 2026-01-16 (+120d) | 14d → 20d |  | 586d → 504d |  | constraint finish no earlier than 2025-09-18 → finish no earlier than 2026-01-16; baseline start 2025-09-01 → 2025-12-22; baseline finish 2025-09-18 → 2026-01-16 |
| 3480 | Handover to MHHSP | 2025-09-19 → 2026-01-12 (+115d) | 2025-09-24 → 2026-01-15 (+113d) |  |  | 586d → 505d | 3479 → none | constraint finish no earlier than 2025-09-18 → finish no earlier than 2026-01-15; baseline start 2025-09-15 → 2026-01-12; baseline finish 2025-09-18 → 2026-01-15 |
| 3482 | **Wave 4** |  | 2026-10-28 → 2026-03-26 (-216d) | 1043d → 889d |  | 301d → 455d |  |  |
| 3483 | **SIT Non-MVC Service Activation Preparation Tasks** |  | 2026-08-13 → 2022-12-02 (-1350d) | 989d → 25d |  | 355d → 1319d |  | baseline finish 2026-08-26 → 2026-10-22 |
| 3486 | Wave 4 Service Activation | 2026-09-25 → 2022-11-01 (-1424d) | 2026-10-28 → 2022-12-02 (-1426d) |  |  | 301d → 1319d | 2835, 3485 → 3485 |  |
| 3487 | **Wave 4 - Service Activation Implementation** | 2026-03-02 → 2025-03-03 (-364d) | 2026-10-07 → 2026-03-12 (-209d) | 158d → 269d |  | 316d → 465d |  |  |
| 3489 | PAB Approval | 2026-07-31 → 2025-03-03 (-515d) | 2026-08-03 → 2025-03-03 (-518d) | 2d → 1d |  | 355d → 725d | 2805 → none | constraint finish no earlier than 2025-12-23 → finish no earlier than 2025-03-03; baseline start 2025-12-22 → 2025-03-03; baseline finish 2025-12-23 → 2025-03-03 |
| 3490 | Add EFD to DIP | 2026-08-04 → 2026-03-03 (-154d) | 2026-08-05 → 2026-03-04 (-154d) |  |  | 355d → 465d | 2805, 3489 → 3489 | constraint finish no earlier than 2025-12-24 → finish no earlier than 2026-03-04; baseline start 2025-12-23 → 2026-03-03; baseline finish 2025-12-24 → 2026-03-04 |
| 3491 | DIP Promoted to Production | 2026-08-06 → 2026-03-05 (-154d) | 2026-08-07 → 2026-03-06 (-154d) |  |  | 355d → 465d |  | constraint finish no earlier than 2025-12-30 → finish no earlier than 2026-03-05; baseline start 2025-12-29 → 2026-03-04; baseline finish 2025-12-30 → 2026-03-05 |
| 3492 | Create M16 in Customer Solution | 2025-02-26 → 2026-03-09 (+376d) | 2025-02-27 → 2026-03-10 (+376d) |  |  | 735d → 465d | none → 3491 | constraint finish no earlier than 2025-02-27 → finish no earlier than 2026-03-06; baseline start 2025-02-26 → 2026-03-05; baseline finish 2025-02-27 → 2026-03-06 |
| 3493 | Publish ISD | 2025-02-26 → 2026-03-11 (+378d) | 2025-02-27 → 2026-03-12 (+378d) |  |  | 735d → 465d | none → 3492 | constraint finish no earlier than 2025-02-27 → finish no earlier than 2026-03-06; baseline start 2025-02-26 → 2026-03-05; baseline finish 2025-02-27 → 2026-03-06 |
| 3494 | Wave 4 - Service Activation Implementation Complete (M) | 2026-10-07 → 2026-03-12 (-209d) | 2026-10-07 → 2026-03-12 (-209d) |  |  | 316d → 465d | 3469 → 3493 |  |
| 3496 | MDD Manual Load | 2025-11-06 → 2026-03-06 (+120d) | 2025-11-12 → 2026-03-16 (+124d) | 5d → 7d |  | 551d → 463d |  | constraint finish no earlier than 2025-11-12 → finish no earlier than 2026-03-16; baseline start 2025-11-06 → 2026-03-06; baseline finish 2025-11-12 → 2026-03-16 |
| 3497 | MDD Update | 2025-11-12 → 2026-03-16 (+124d) | 2025-11-19 → 2026-03-26 (+127d) | 6d → 9d |  | 546d → 455d |  | constraint finish no earlier than 2025-11-19 → finish no earlier than 2026-03-26; baseline start 2025-11-12 → 2026-03-16; baseline finish 2025-11-19 → 2026-03-26 |
| 3500 | Service& Process Monitoring | 2025-12-22 → 2026-03-02 (+70d) | 2026-01-16 → 2026-03-26 (+69d) | 20d → 19d |  | 504d → 455d |  | constraint finish no earlier than 2026-01-16 → finish no earlier than 2026-03-26; baseline start 2025-12-22 → 2026-03-02; baseline finish 2026-01-16 → 2026-03-26 |
| 3501 | Daily Reporting | 2025-11-03 → 2026-03-02 (+119d) | 2025-11-20 → 2026-03-26 (+126d) | 14d → 19d |  | 545d → 455d |  | constraint finish no earlier than 2025-11-20 → finish no earlier than 2026-03-26; baseline start 2025-11-03 → 2026-03-02; baseline finish 2025-11-20 → 2026-03-26 |
| 3502 | Issue Management | 2025-12-22 → 2026-03-02 (+70d) | 2026-01-16 → 2026-03-26 (+69d) | 20d → 19d |  | 504d → 455d |  | constraint finish no earlier than 2026-01-16 → finish no earlier than 2026-03-26; baseline start 2025-12-22 → 2026-03-02; baseline finish 2026-01-16 → 2026-03-26 |
| 3503 | SA Hypercare Close Down Activities | 2025-11-03 → 2026-03-02 (+119d) | 2025-11-20 → 2026-03-26 (+126d) | 14d → 19d |  | 545d → 455d |  | constraint finish no earlier than 2025-11-20 → finish no earlier than 2026-03-26; baseline start 2025-11-03 → 2026-03-02; baseline finish 2025-11-20 → 2026-03-26 |
| 3504 | Handover to MHHSP | 2025-11-17 → 2026-03-02 (+105d) | 2025-11-20 → 2026-03-05 (+105d) |  |  | 545d → 470d |  | constraint finish no earlier than 2025-11-20 → finish no earlier than 2026-03-05; baseline start 2025-11-17 → 2026-03-02; baseline finish 2025-11-20 → 2026-03-05 |
| 3506 | **Non-SIT LDSO** |  | 2025-09-18 → 2025-03-19 (-183d) | 754d → 623d |  | 590d → 721d |  |  |
| 3510 | Create Entity Forms in Customer Solution | 2025-08-22 → 2025-02-03 (-200d) | 2025-08-25 → 2025-02-05 (-201d) | 2d → 3d |  | 606d → 751d |  | constraint start no earlier than 2025-08-22 → finish no earlier than 2025-02-05; baseline start none → 2025-02-03; baseline finish none → 2025-02-05 |
| 3512 | DIP - Enable Technology capabilities for participants | 2025-08-15 → 2025-02-03 (-193d) | 2025-08-18 → 2025-02-05 (-194d) | 2d → 3d |  | 611d → 751d |  | constraint start no earlier than 2025-08-15 → finish no earlier than 2025-02-05; baseline start none → 2025-02-03; baseline finish none → 2025-02-05 |
| 3513 | DIP - Add EFD to DIP | 2025-08-15 → 2025-02-03 (-193d) | 2025-08-18 → 2025-02-05 (-194d) | 2d → 3d |  | 609d → 751d |  | constraint start no earlier than 2025-08-15 → finish no earlier than 2025-02-05; baseline start none → 2025-02-03; baseline finish none → 2025-02-05 |
| 3514 | ISD - Replicate Entity Forms from CS | 2025-08-15 → 2025-02-06 (-190d) | 2025-08-18 → 2025-02-07 (-192d) |  |  | 611d → 749d |  | constraint start no earlier than 2025-08-15 → finish no earlier than 2025-02-07; baseline start none → 2025-02-06; baseline finish none → 2025-02-07 |
| 3515 | MDD - Load MHHS roles | 2025-08-15 → 2025-02-03 (-193d) | 2025-08-18 → 2025-02-05 (-194d) | 2d → 3d |  | 611d → 751d |  | constraint start no earlier than 2025-08-15 → finish no earlier than 2025-02-05; baseline start none → 2025-02-03; baseline finish none → 2025-02-05 |
| 3517 | **SIT Non-MVC Service Activation Preparation Tasks** |  | 2026-10-28 → 2022-11-08 (-1450d) | 1043d → 7d |  | 301d → 1337d |  | baseline finish 2026-10-22 → 2025-09-01 |
| 3520 | Non-SIT LDSO Service Activation | 2025-09-11 → 2022-11-01 (-1045d) | 2025-09-18 → 2022-11-08 (-1045d) |  |  | 9d → 1337d | 3519, 2534 → 3519 |  |
| 3523 | PAB Approval | 2026-09-25 → 2025-02-24 (-578d) | 2026-09-25 → 2025-02-25 (-577d) | 1d → 2d |  | 316d → 737d | 2835 → none | constraint finish no earlier than 2025-03-03 → finish no earlier than 2025-02-25; baseline start 2025-03-03 → 2025-02-24; baseline finish 2025-03-03 → 2025-02-25 |
| 3524 | Add EFD to DIP | 2026-09-28 → 2025-02-25 (-580d) | 2026-09-29 → 2025-02-26 (-580d) |  |  | 316d → 736d | 3523 → none | constraint finish no earlier than 2026-03-04 → finish no earlier than 2025-02-26; baseline start 2026-03-03 → 2025-02-25; baseline finish 2026-03-04 → 2025-02-26 |
| 3525 | DIP Promoted to Production | 2026-09-30 → 2025-02-26 (-581d) | 2026-10-01 → 2025-02-27 (-581d) |  |  | 316d → 735d | 3524 → none | constraint finish no earlier than 2026-03-05 → finish no earlier than 2025-02-27; baseline start 2026-03-04 → 2025-02-26; baseline finish 2026-03-05 → 2025-02-27 |
| 3530 | MDD Manual Load | 2025-12-29 → 2025-02-27 (-305d) | 2026-01-06 → 2025-03-07 (-305d) |  |  | 512d → 729d |  | constraint finish no earlier than 2026-01-06 → finish no earlier than 2025-03-07; baseline start 2025-12-29 → 2025-02-27; baseline finish 2026-01-06 → 2025-03-07 |
| 3531 | MDD Update | 2025-01-06 → 2025-03-07 (+60d) | 2026-01-15 → 2025-03-18 (-303d) | 269d → 8d |  | 505d → 722d |  | constraint finish no earlier than 2026-01-15 → finish no earlier than 2025-03-18; baseline start 2025-01-06 → 2025-03-07; baseline finish 2026-01-15 → 2025-03-18 |
| 3535 | Service& Process Monitoring | 2026-03-02 → 2025-02-24 (-371d) | 2026-03-26 → 2025-03-19 (-372d) | 19d → 18d |  | 455d → 721d |  | constraint finish no earlier than 2026-03-26 → finish no earlier than 2025-03-19; baseline start 2026-03-02 → 2025-02-24; baseline finish 2026-03-26 → 2025-03-19 |
| 3536 | Daily Reporting | 2025-12-22 → 2025-02-24 (-301d) | 2026-01-16 → 2025-03-19 (-303d) | 20d → 18d |  | 504d → 721d |  | constraint finish no earlier than 2026-01-16 → finish no earlier than 2025-03-19; baseline start 2025-12-22 → 2025-02-24; baseline finish 2026-01-16 → 2025-03-19 |
| 3537 | Issue Management | 2026-03-02 → 2025-02-24 (-371d) | 2026-03-26 → 2025-03-19 (-372d) | 19d → 18d |  | 455d → 721d |  | constraint finish no earlier than 2026-03-26 → finish no earlier than 2025-03-19; baseline start 2026-03-02 → 2025-02-24; baseline finish 2026-03-26 → 2025-03-19 |
| 3538 | SA Hypercare Close Down Activities | 2025-12-22 → 2025-02-24 (-301d) | 2026-01-16 → 2025-03-19 (-303d) | 20d → 18d |  | 504d → 721d |  | constraint finish no earlier than 2026-01-16 → finish no earlier than 2025-03-19; baseline start 2025-12-22 → 2025-02-24; baseline finish 2026-01-16 → 2025-03-19 |
| 3539 | Handover to MHHSP | 2026-01-12 → 2025-03-14 (-304d) | 2026-01-15 → 2025-03-18 (-303d) | 4d → 3d |  | 505d → 722d |  | constraint finish no earlier than 2026-01-15 → finish no earlier than 2025-03-18; baseline start 2026-01-12 → 2025-03-14; baseline finish 2026-01-15 → 2025-03-18 |
| 3550 | **PP Business Change** | 2025-02-03 A | 2025-07-31 A |  | 0% → 100% | 625d → none |  |  |
| 3551 | Plan stakeholder management | 2025-02-03 A | 2025-07-31 A |  | 0% → 100% | 625d → none |  |  |
| 3552 | Manage stakeholders | 2025-02-03 A | 2025-07-31 A |  | 0% → 100% | 625d → none |  |  |
| 3553 | Develop & implement changes to KPIs, organisation & people management | 2025-02-03 A | 2025-07-31 A |  | 0% → 100% | 625d → none |  |  |
| 3554 | Develop & test changes to business processes | 2025-02-03 A | 2025-07-31 A |  | 0% → 100% | 625d → none |  |  |
| 3555 | Develop and deliver training | 2025-02-03 A | 2025-07-31 A |  | 0% → 100% | 625d → none |  |  |
| 3556 | Programme support for PP Business Change activities | 2025-02-03 A | 2025-07-31 A |  | 0% → 100% | 625d → none |  |  |
| 3613 | **READINESS ASSESSMENTS** |  |  |  | 23% → 46% |  |  |  |
| 3621 | **Readiness Assessment 5 / 6 - Start of Qualification and Participant Readiness for M10 and M11 and CP3/CP4 check** | 2025-04-28 A |  |  | 0% → 96% |  |  |  |
| 3622 | Launch Readiness Assessment survey | 2025-04-28 A | 2025-04-28 A |  | 0% → 100% | 647d → none |  |  |
| 3623 | PPs submit survey responses | 2025-04-28 A | 2025-05-16 A |  | 0% → 100% | 647d → none |  |  |
| 3624 | Analyse survey responses | 2025-05-19 A | 2025-06-06 → 2025-06-27 (+21d) | 15d → 30d | 0% → 95% | 647d → 649d |  | baseline finish 2025-06-06 → 2025-06-27 |
| 3625 | Conduct deep-dive interviews (sample of PPs) | 2025-05-19 A | 2025-06-06 → 2025-06-27 (+21d) | 15d → 30d | 0% → 95% | 647d → 649d | 3623 → none | constraint none → start no earlier than 2025-05-19; baseline finish 2025-06-06 → 2025-06-27 |
| 3626 | Produce Readiness Assessment Reports (Overall Report & Individual Participant Reports) | 2025-06-09 A |  |  | 0% → 95% |  | 3624, 3625 → none | constraint none → start no earlier than 2025-06-09 |

| ID | Task | Predecessors | Other |
| --- | --- | --- | --- |
| 3627 | Readiness Assessment 5 / 6 - Start of Qualification and Participant Readiness for M10 and M11 and CP3/CP4 check (incl. Readiness Assessment Report approval) Completed |  | constraint none → finish no earlier than 2025-07-01 |
| 3663 | Control Point 3/4 - Readiness for Migration (incl. Control Point Report approval) | 1885FS-5d → 1885FS-3d |  |

## Version 7 (data date 2026-06-17, saved 2026-06-17, file MHHS-DEL1139 - MHHS Plan v6.52.mpp)

Last finish stays 2027-12-23. Complete tasks 1978 → 2716.

Added:

| ID | Task | Duration | Start | Finish | Predecessors | Constraint |
| --- | --- | --- | --- | --- | --- | --- |
| 1569 | Cycle 1 SAT Regression | 10d | 2025-07-21 A | 2025-08-01 A | 1568SS, 2279 |  |
| 1570 | Supplementary Regression Testing | 20d | 2025-07-21 A | 2025-08-15 A | 1569SS |  |
| 1571 | Cycle 2 SAT Regression | 5d | 2025-08-04 A | 2025-08-08 A | 1568SS, 2289 | start no earlier than 2025-08-04 |
| 1662 | Programme drafts Pathway 4 PP Exit Report (when Participant completes Operational testing) | 10d | 2025-08-04 A | 2025-08-15 A | 1667 |  |
| 1663 | All Pathway 4 Operational Exit Reports and Exit Declarations shared with PPs | 0d | 2025-08-15 A | 2025-08-15 A | 1662 |  |
| 1664 | Pathway 4 PPs have reviewed Exit Report and signed Exit Declaration | 5d | 2025-08-18 A | 2025-08-22 A | 1663 |  |
| 1972 | **LDSO Onboarding - Phase 1** | 28d | 2025-06-23 A | 2025-07-30 A |  |  |
| 1973 | LDSO Communication and Information Gathering - Phase 1 | 18d | 2025-06-23 A | 2025-07-16 A |  | start no earlier than 2025-06-23 |
| 1974 | LDSO Communication and Information Gathering Completed - Phase 1 | 0d | 2025-07-16 A | 2025-07-16 A |  | start no earlier than 2025-07-16 |
| 1975 | LDSO ServiceNow Configuration - Phase 1/2 | 10d | 2025-07-10 A | 2025-07-23 A | 1973SS+13d |  |
| 1976 | LDSO ServiceNow Configuration Completed - Phase 1/2 | 0d | 2025-07-16 A | 2025-07-16 A |  | finish no earlier than 2025-07-16 |
| 1977 | LDSO Testing and Further Communication - Phase 1 | 6d | 2025-07-23 A | 2025-07-30 A | 1975SS+9d |  |
| 1978 | LDSO Testing and Further Communication Completed - Phase 1 | 0d | 2025-07-30 A | 2025-07-30 A |  | start no earlier than 2025-07-30 |
| 1979 | LDSOs Onboarded into Elexon ServiceNow - Phase 1 | 0d | 2025-07-30 A | 2025-07-30 A | 1977 |  |
| 1980 | **LDSO Onboarding - Phase 2** | 27d | 2025-07-31 A | 2025-09-05 A |  |  |
| 1981 | LDSO Resources Enrolled in Authenticator - Phase 2 | 20d | 2025-07-31 A | 2025-08-27 A |  | start no earlier than 2025-07-31 |
| 1982 | LDSO Resources Enrolled in Authenticator Completed - Phase 2 | 0d | 2025-08-27 A | 2025-08-27 A |  | start no earlier than 2025-08-27 |
| 1983 | Elexon Phase 2 Resources Setup in Portal - Phase 2 | 7d | 2025-08-28 A | 2025-09-05 A | 1981 |  |
| 1984 | Elexon Phase 2 Resources Setup in Portal Completed - Phase 2 | 0d | 2025-09-05 A | 2025-09-05 A | 1983 |  |
| 2028 | DIP Code Change Presented at DCAB | 0d | 2025-08-12 A | 2025-08-12 A |  | start no earlier than 2025-08-12 |
| 2033 | **Non-LDSO SIT PPs ServiceNow Onboarding** | 12d | 2025-09-05 A | 2025-09-24 A |  |  |
| 2034 | Pathway 2 | 0d | 2025-09-05 A | 2025-09-05 A |  | finish no earlier than 2025-09-05 |
| 2035 | Pathway 3 | 0d | 2025-09-09 A | 2025-09-09 A |  | start no earlier than 2025-09-09 |
| 2036 | Pathway 4 | 0d | 2025-09-24 A | 2025-09-24 A |  | start no earlier than 2025-09-24 |
| 2052 | **DIP UIT Onboarding** | 837d? | 2022-10-31 | 2026-01-13 A |  |  |
| 2053 | **LDSOs** | 0d | 2025-07-25 A | 2025-07-25 A |  |  |
| 2054 | Date to be Onboarded by | 0d | 2025-07-25 A | 2025-07-25 A |  | start no earlier than 2025-07-25 |
| 2055 | **Pathway 2** | 23d | 2025-07-25 A | 2025-08-27 A |  |  |
| 2056 | Proforma Issued | 0d | 2025-07-25 A | 2025-07-25 A |  | start no earlier than 2025-07-25 |
| 2057 | Invite to Onbaord Issued | 0d | 2025-08-08 A | 2025-08-08 A |  | start no earlier than 2025-08-08 |
| 2058 | Date to be Onboarded by | 0d | 2025-08-27 A | 2025-08-27 A |  | start no earlier than 2025-08-27 |
| 2059 | **Pathway 3** | 0d | 2022-10-31 | 2022-10-31 |  |  |
| 2060 | Proforma Issued | 0d | 2025-08-04 A | 2025-08-04 A |  | start no earlier than 2025-08-04 |
| 2061 | Invite to Onbaord Issued | 0d | 2025-08-18 A | 2025-08-18 A |  | start no earlier than 2025-08-18 |
| 2062 | Date to be Onboarded by | 0d | 2025-09-09 A | 2025-09-09 A |  | start no earlier than 2025-09-09 |
| 2063 | **Pathway 4** | 0d | 2022-10-31 | 2022-10-31 |  |  |
| 2064 | Proforma Issued | 0d | 2025-08-22 A | 2025-08-22 A |  | start no earlier than 2025-08-22 |
| 2065 | Invite to Onbaord Issued | 0d | 2025-09-05 A | 2025-09-05 A |  | start no earlier than 2025-09-05 |
| 2066 | Date to be Onboarded by | 0d | 2025-09-24 A | 2025-09-24 A |  | start no earlier than 2025-09-24 |
| 2113 | SOLR consultation | 81d? | 2025-04-10 A | 2025-07-31 A |  | start no earlier than 2025-04-10 |
| 2118 | Process Refinement | 33d | 2025-06-17 A | 2025-07-31 A |  | start no earlier than 2025-06-17 |
| 2119 | Process Test | 26d | 2025-08-01 A | 2025-09-05 A | 2118 |  |
| 2309 | **ELEXON / HELIX M10 - M16** | 65d | 2026-04-01 A | 2026-06-30 |  |  |
| 2310 | **SAT M16 Test Case Execution** | 65d | 2026-04-01 A | 2026-06-30 |  |  |
| 2311 | SAT Prep / Analysis | 22d | 2026-04-01 A | 2026-04-30 A |  | start no earlier than 2026-04-01 |
| 2312 | SAT Functional Work / Bug Dependency | 21d | 2026-05-01 A | 2026-05-29 A | 2311 | start no earlier than 2026-05-01 |
| 2313 | SAT Test & Sign-off of Two Cases (Elexon Internal Sign-off) | 22d | 2026-06-01 A | 2026-06-30 | 2312 | start no earlier than 2026-06-01 |
| 2314 | SAT Programme Assurance Review of Test Results | 65d | 2026-04-01 A | 2026-06-30 |  | start no earlier than 2026-04-01 |
| 2315 | LSS provides Load Shape data that is publicly accessible - Business Requirement MHHSP-37 | 0d | 2026-04-08 A | 2026-04-08 A | 3374FS+120d |  |
| 2614 | All Qualification Wave 1 Participants have submitted their initial QAD | 0d | 2025-07-14 A | 2025-07-14 A | 2613 | start no earlier than 2025-07-14 |
| 2622 | All Qualification Wave 1 Participants' to provide status of PIT completion and submit QT Test Plan | 0d | 2025-07-14 A | 2025-07-14 A | 2621 | start no earlier than 2025-07-14 |
| 2625 | All Qualification Test Plans for Wave 1 Participants approved | 0d | 2025-08-15 A | 2025-08-15 A | 2624 | start no earlier than 2025-08-15 |
| 2626 | Minimum threshold of Qualification Wave 1 Participants required for QT start have submitted PIT Test Completion Report and evidence for QT Entry | 0d | 2025-07-14 A | 2025-07-14 A |  | start no earlier than 2025-07-14 |
| 2633 | All Qualification Wave 1 Participant Test Readiness Confirmed | 0d | 2025-08-22 A | 2025-08-22 A | 2632 | start no earlier than 2025-08-22 |
| 2638 | Assurance on PP Test Completion Report | 10d | 2026-01-05 A | 2026-01-16 A | 2636 |  |
| 2642 | All Qualification Wave 1 Participants have submitted their final QAD | 0d | 2026-01-16 A | 2026-01-16 A | 2641 | start no earlier than 2026-01-16 |
| 2645 | 80% of M14 Critical Wave 1 Participants Qualification approved by BSC PAB and REC Manager | 0d | 2026-04-15 A | 2026-04-15 A |  | finish no earlier than 2026-04-15 |
| 2652 | All Qualification Wave 2 Participants have submitted their initial QAD | 0d | 2025-09-12 A | 2025-09-12 A | 2651 | start no earlier than 2025-09-12 |
| 2660 | All Qualification Wave 2 Participants' to provide status of PIT completion and submit QT Test Plan | 0d | 2025-08-18 A | 2025-08-18 A | 2659 |  |
| 2663 | All Qualification Test Plans for Wave 2 Participants approved | 0d | 2025-09-05 A | 2025-09-05 A | 2662 |  |
| 2665 | All Qualification Wave 2 Participants have submitted PIT Test Completion Report and evidence for QT entry | 0d | 2025-09-08 A | 2025-09-08 A | 2664 |  |
| 2671 | All Qualification Wave 2 Participant Test Readiness Confirmed | 0d | 2025-10-17 A | 2025-10-17 A | 2670 |  |
| 2676 | Assurance on PP Test Completion Report | 10d | 2026-02-23 A | 2026-03-06 A | 2674 |  |
| 2680 | All Qualification Wave 2 Participants have submitted their final QAD | 0d | 2026-03-06 A | 2026-03-06 A | 2679 |  |
| 2683 | 80% of M14 Critical Wave 2 Participants Qualification approved by BSC PAB and REC Manager | 0d | 2026-05-28 A | 2026-05-28 A |  | start no earlier than 2026-05-28 |
| 2690 | All Qualification Wave 3 Participants have submitted their initial QAD | 0d | 2025-11-07 A | 2025-11-07 A | 2689 | start no earlier than 2025-11-07 |
| 2698 | All Qualification Wave 3 Participants' to provide status of PIT completion and submit QT Test Plan | 0d | 2025-10-20 A | 2025-10-20 A | 2697 | start no earlier than 2025-10-20 |
| 2701 | All Qualification Test Plans for Wave 3 Participants approved | 0d | 2025-11-07 A | 2025-11-07 A | 2700 | start no earlier than 2025-11-07 |
| 2703 | All Qualification Wave 3 Participants have submitted PIT Test Completion Report and evidence for QT Entry | 0d | 2025-11-10 A | 2025-11-10 A | 2702 | start no earlier than 2025-11-10 |
| 2709 | All Qualification Wave 3 Participant Test Readiness confirmed | 0d | 2025-12-19 A | 2025-12-19 A | 2708 |  |
| 2714 | Assurance on PP Test Completion Report | 10d | 2026-05-11 A | 2026-05-22 A | 2712 |  |
| 2718 | All Qualification Wave 3 Participants have submitted their Final QAD | 0d | 2026-05-22 | 2026-05-22 | 2717 | finish no earlier than 2026-05-22 |
| 2721 | 80% of M14 Critical Wave 3 Participants Qualification approved by BSC PAB and REC Manager | 0d | 2026-07-30 | 2026-07-30 |  | start no earlier than 2026-07-30 |
| 2747 | Assurance on PP Test Completion Report | 10d | 2026-07-13 | 2026-07-24 | 2745 |  |
| 2779 | PAB2026/01 | 0d | 2026-01-29 A | 2026-01-29 A |  | finish no earlier than 2026-01-29 |
| 2780 | PAB2026/02 | 0d | 2026-02-11 A | 2026-02-11 A |  | finish no earlier than 2026-02-11 |
| 2781 | PAB2026/03 | 0d | 2026-02-26 A | 2026-02-26 A |  | finish no earlier than 2026-02-26 |
| 2782 | PAB2026/04 | 0d | 2026-03-11 A | 2026-03-11 A |  | finish no earlier than 2026-03-11 |
| 2783 | PAB2026/05 | 0d | 2026-03-26 A | 2026-03-26 A |  | finish no earlier than 2026-03-26 |
| 2784 | PAB2026/06 | 0d | 2026-04-15 A | 2026-04-15 A |  | finish no earlier than 2026-04-15 |
| 2785 | PAB2026/07 | 0d | 2026-04-30 A | 2026-04-30 A |  | finish no earlier than 2026-04-30 |
| 2786 | PAB2026/08 | 0d | 2026-05-13 A | 2026-05-13 A |  | finish no earlier than 2026-05-13 |
| 2787 | PAB2026/09 | 0d | 2026-05-28 A | 2026-05-28 A |  | finish no earlier than 2026-05-28 |
| 2788 | PAB2026/10 | 0d | 2026-06-10 A | 2026-06-10 A |  | finish no earlier than 2026-06-10 |
| 2789 | PAB2026/11 | 0d | 2026-06-25 | 2026-06-25 |  | finish no earlier than 2026-06-25 |
| 2790 | PAB2026/12 | 0d | 2026-07-15 | 2026-07-15 |  | finish no earlier than 2026-07-15 |
| 2791 | PAB2026/13 | 0d | 2026-07-30 | 2026-07-30 |  | finish no earlier than 2026-07-30 |
| 2792 | PAB2026/14 | 0d | 2026-08-12 | 2026-08-12 |  | finish no earlier than 2026-08-12 |
| 2793 | PAB2026/15 | 0d | 2026-08-27 | 2026-08-27 |  | finish no earlier than 2026-08-27 |
| 2794 | PAB2026/16 | 0d | 2026-09-09 | 2026-09-09 |  | finish no earlier than 2026-09-09 |
| 2795 | PAB2026/17 | 0d | 2026-09-24 | 2026-09-24 |  | finish no earlier than 2026-09-24 |
| 2796 | PAB2026/18 | 0d | 2026-10-14 | 2026-10-14 |  | finish no earlier than 2026-10-14 |
| 2797 | PAB2026/19 | 0d | 2026-10-29 | 2026-10-29 |  | finish no earlier than 2026-10-29 |
| 2798 | PAB2026/20 | 0d | 2026-11-11 | 2026-11-11 |  | finish no earlier than 2026-11-11 |
| 2799 | PAB2026/21 | 0d | 2026-11-26 | 2026-11-26 |  | finish no earlier than 2026-11-26 |
| 2800 | PAB2026/22 | 0d | 2026-12-09 | 2026-12-09 |  | finish no earlier than 2026-12-09 |
| 2958 | CR065 Webinar | 1d | 2026-06-01 A | 2026-06-01 A |  | start no earlier than 2026-06-01 |
| 2959 | CR065 Impact Assessment Window | 10d | 2026-06-01 A | 2026-06-12 A |  | start no earlier than 2026-06-01 |
| 2960 | CR065 PSG Approval | 0d | 2026-07-01 | 2026-07-01 |  | start no earlier than 2026-07-01 |
| 3030 | Kestrel Webinar 1 | 0d | 2025-07-14 A | 2025-07-14 A | 3029 |  |
| 3034 | MCC Dress Rehersal 2 start | 1d | 2025-08-11 A | 2025-08-11 A |  | finish no earlier than 2025-08-11 |
| 3037 | PPs return test scripts | 0d | 2025-09-05 A | 2025-09-05 A |  | finish no earlier than 2025-09-05 |
| 3042 | MCAG Approve Sprint 0 Day 1 Baseline Schedule | 0d | 2025-10-20 A | 2025-10-20 A |  | start no earlier than 2025-10-20 |
| 3044 | Legacy Settlement run stability assessment | 16d | 2025-09-26 A | 2025-10-17 A | 1802, 2306 | start no earlier than 2025-09-26 |
| 3045 | Checkpoint 1 | 0d | 2025-10-03 A | 2025-10-03 A |  | finish no earlier than 2025-10-03 |
| 3046 | Checkpoint 2 | 0d | 2025-10-10 A | 2025-10-10 A |  | finish no earlier than 2025-10-10 |
| 3047 | Checkpoint 3 | 0d | 2025-10-17 A | 2025-10-17 A |  | finish no earlier than 2025-10-17 |
| 3188 | Monitor Participant Cutover Plan reporting | 56d | 2025-08-06 A | 2025-10-22 A |  | start no earlier than 2025-08-06 |
| 3190 | Load Shaping Service (LSS) | 10d | 2025-07-14 A | 2025-07-25 A |  | start no earlier than 2025-07-14 |
| 3191 | Volume Allocation Service (VAS) | 10d | 2025-07-14 A | 2025-07-25 A |  | start no earlier than 2025-07-14 |
| 3192 | Market-wide Data Service (MDS) | 10d | 2025-07-14 A | 2025-07-25 A |  | start no earlier than 2025-07-14 |
| 3193 | Deployment of Industry Standing Data (ISD) Work Package (WP3) source code | 10d | 2025-07-14 A | 2025-07-25 A |  | start no earlier than 2025-07-14 |
| 3194 | ISD Service Activation | 0d | 2025-08-05 A | 2025-08-05 A | 3193 | start no earlier than 2025-08-05 |
| 3195 | ISD Data Migration (PR-3) | 14d | 2025-08-05 A | 2025-08-22 A | 3194 | start no earlier than 2025-08-05 |
| 3196 | ISD Data Migration (PR-4) | 11d | 2025-08-15 A | 2025-08-29 A |  | start no earlier than 2025-08-15 |
| 3197 | ISD Catalogue Published | 0d | 2025-09-11 A | 2025-09-11 A | 3196 | start no earlier than 2025-09-11 |
| 3198 | DIP Production Environment stood up | 0d | 2025-07-18 A | 2025-07-18 A |  | start no earlier than 2025-07-18 |
| 3202 | DIP Onboarding | 15d | 2025-08-04 A | 2025-08-22 A |  | start no earlier than 2025-08-04 |
| 3203 | Deployment of MPRS 9 | 19d | 2025-08-06 A | 2025-09-01 A |  | start no earlier than 2025-08-06 |
| 3204 | ISD Population | 0d | 2025-09-11 A | 2025-09-11 A |  | start no earlier than 2025-09-11 |
| 3205 | Population of Market Segment (95%) | 28d | 2025-08-06 A | 2025-09-12 A | 3203SS | start no earlier than 2025-08-06 |
| 3206 | Population of Market Segment (100%) | 7d | 2025-09-12 A | 2025-09-22 A | 3205FS-1d | start no earlier than 2025-09-12 |
| 3207 | Population of Domestic Premises Indicator (Weekend start) | 2d | 2025-09-05 A | 2025-09-08 A |  | start no earlier than 2025-09-05 |
| 3213 | Pre-M10 Service Activation - LDSOs | 6d | 2025-09-11 A | 2025-09-18 A |  | start no earlier than 2025-09-11 |
| 3214 | Pre-M10 Service Activation - Suppliers and Agents | 25d | 2025-09-11 A | 2025-10-15 A |  | start no earlier than 2025-09-11 |
| 3215 | Load Shaping Service (LSS) | 2d | 2025-09-19 A | 2025-09-22 A | 3190 | start no earlier than 2025-09-19 |
| 3216 | Volume Allocation Service (VAS) | 2d | 2025-09-19 A | 2025-09-22 A | 3191 | start no earlier than 2025-09-19 |
| 3217 | Market-wide Data Service (MDS) | 2d | 2025-09-19 A | 2025-09-22 A | 3192 | start no earlier than 2025-09-19 |
| 3218 | DTS | 2d | 2025-09-19 A | 2025-09-22 A |  | start no earlier than 2025-09-19 |
| 3219 | EES | 2d | 2025-09-19 A | 2025-09-22 A |  | start no earlier than 2025-09-19 |
| 3220 | DCC | 20d | 2024-06-03 A | 2024-06-28 A |  | start no earlier than 2024-06-01 |
| 3221 | MPRS – Registration Services, UMSO Role, LDSO Role | 2d | 2025-09-19 A | 2025-09-22 A |  | start no earlier than 2025-09-19 |
| 3222 | Qualification Pathway 4 Service Activation | 6d | 2025-09-26 A | 2025-10-03 A |  | start no earlier than 2025-09-26 |
| 3223 | Qualification Pathway 5 Service Activation | 5d | 2025-10-16 A | 2025-10-22 A |  | start no earlier than 2025-10-16 |
| 3225 | IF-047 sent at 9am on Monday 22nd September by Elexon via the DIP to all LDSOs and EES | 0d | 2025-09-22 A | 2025-09-22 A |  | start no earlier than 2025-09-22 |
| 3226 | All LDSOs and EES to load ISD files via the URL published within the IF-047 via the Elexon data store (note, this should contain the same ISD file as uploaded to the Elexon portal following 11th September, therefore it may not need to be applied by each p | 0d | 2025-09-22 A | 2025-09-22 A |  | start no earlier than 2025-09-22 |
| 3227 | Following successful loading of ISD data LDSOs can process New Connections via their DB01 interface to MPRS | 0d | 2025-09-22 A | 2025-09-22 A | 3226 | start no earlier than 2025-09-22 |
| 3228 | Each LDSO will track successful sending of the IF-050 message to the DIP | 0d | 2025-09-22 A | 2025-09-22 A | 3227 | start no earlier than 2025-09-22 |
| 3229 | EES will track successful receipt and processing of the IF-050 | 0d | 2025-09-22 A | 2025-09-22 A | 3228 | start no earlier than 2025-09-22 |
| 3230 | IF-047 sent at 9am on Wednesday 22nd October by Elexon via the DIP | 0d | 2025-10-22 A | 2025-10-22 A |  | start no earlier than 2025-10-22 |
| 3232 | Confirmation from all LDSOs that DIP onboarding has taken place | 0d | 2025-08-22 A | 2025-08-22 A |  | start no earlier than 2025-08-22 |
| 3236 | Confirmation of all pre-M10 parties | 0d | 2025-09-15 A | 2025-09-15 A |  | start no earlier than 2025-09-15 |
| 3237 | Confirmation that all LDSOs have populated the ISD | 0d | 2025-09-15 A | 2025-09-15 A |  | start no earlier than 2025-09-15 |
| 3239 | Market-wide Participant MHHS Migration Supporting Functionality is ready to be deployed | 0d | 2025-09-15 A | 2025-09-15 A |  | start no earlier than 2025-09-15 |
| 3240 | Recommendation from TORWG that the Programme should enter M10 | 0d | 2025-09-17 A | 2025-09-17 A |  | start no earlier than 2025-09-17 |
| 3241 | Production Service Activation Activities have taken place for all pre-M10 qualified parties | 0d | 2025-09-18 A | 2025-09-18 A |  | start no earlier than 2025-09-18 |
| 3242 | Early Life Support model is in place | 0d | 2025-09-19 A | 2025-09-19 A |  | start no earlier than 2025-09-19 |
| 3247 | Confirmation that Market Segment has been populated for 100% of LDSO portfolios | 0d | 2025-09-22 A | 2025-09-22 A |  | start no earlier than 2025-09-22 |
| 3248 | IF-047 message has been sent | 0d | 2025-09-22 A | 2025-09-22 A |  | start no earlier than 2025-09-22 |
| 3249 | LDSOs have received the IF-047 message | 0d | 2025-09-22 A | 2025-09-22 A |  | start no earlier than 2025-09-22 |
| 3250 | EES has received the IF-047 message and loaded the ISD file | 0d | 2025-09-22 A | 2025-09-22 A |  | start no earlier than 2025-09-22 |
| 3251 | Confirmation that the IF-050 has been sent and the number sent | 0d | 2025-09-22 A | 2025-09-22 A |  | start no earlier than 2025-09-22 |
| 3252 | Confirmation of the number of IF-050s | 0d | 2025-09-22 A | 2025-09-22 A |  | start no earlier than 2025-09-22 |
| 3253 | Recommendation from TORWG that the M10 acceptance criteria have been met | 0d | 2025-09-23 A | 2025-09-23 A |  | start no earlier than 2025-09-23 |
| 3257 | Qualification of all pre-M11 parties | 0d | 2025-10-16 A | 2025-10-16 A |  | start no earlier than 2025-10-16 |
| 3258 | Self-Declaration that ISD file has been manually accessed and applied by all qualified Suppliers and Agents | 0d | 2025-10-16 A | 2025-10-16 A |  | start no earlier than 2025-10-16 |
| 3259 | Confirmation of Qualified Parties from TORWG and their readiness | 0d | 2025-10-17 A | 2025-10-17 A |  | start no earlier than 2025-10-17 |
| 3260 | Recommendation from MCAG that the Programme can approve M11 / M12 | 0d | 2025-10-20 A | 2025-10-20 A |  | start no earlier than 2025-10-20 |
| 3262 | **Migration Exclusion PPIR** | 20d | 2026-02-16 A | 2026-03-13 A |  |  |
| 3263 | Publication of migration exclusion PPIR | 0d | 2026-02-16 A | 2026-02-16 A |  | start no earlier than 2026-02-16 |
| 3264 | Participant response window for PPIR | 20d | 2026-02-16 A | 2026-03-13 A | 3263 |  |
| 3265 | PPIR consultation window closed | 0d | 2026-03-13 A | 2026-03-13 A | 3264 |  |
| 3276 | Sprint 0 Retro | 10d | 2026-02-04 A | 2026-02-17 A | 3275 | start no earlier than 2026-02-04 |
| 3286 | Sprint 1 Retro | 10d | 2026-04-01 A | 2026-04-14 A | 3285 | start no earlier than 2026-04-01 |
| 3297 | Sprint 2 Retro | 10d | 2026-06-03 A | 2026-06-16 A | 3296 |  |
| 3307 | Sprint 3 Retro | 10d | 2026-08-05 | 2026-08-18 | 3306 |  |
| 3317 | Sprint 4 Retro | 10d | 2026-10-07 | 2026-10-20 | 3316 |  |
| 3327 | Sprint 5 Retro | 10d | 2026-12-02 | 2026-12-15 | 3326 |  |
| 3337 | Sprint 6 Retro | 10d | 2027-02-03 | 2027-02-16 | 3336 |  |
| 3347 | Sprint 7 Retro | 10d | 2027-04-07 | 2027-04-20 | 3346 |  |
| 3357 | Sprint 8 Retro | 10d | 2027-05-07 | 2027-05-20 | 3356 | start no earlier than 2027-05-07 |
| 3396 | **MP1 and MP2 - Service Activation Preparation Tasks** | 9d | 2026-03-31 A | 2026-04-10 A |  |  |
| 3397 | Review Entry/Exit Criteria & Lessons Learned | 0d | 2026-03-31 A | 2026-03-31 A |  | finish no earlier than 2026-03-31 |
| 3399 | Confirmation from Qualification of Wave Participants Complete | 0d | 2026-03-31 A | 2026-03-31 A |  | finish no earlier than 2026-03-31 |
| 3401 | Training Confirmation | 1d | 2026-04-02 A | 2026-04-02 A |  | start no earlier than 2026-04-02 |
| 3402 | Training Confirmation Completed | 0d | 2026-04-02 A | 2026-04-02 A |  | finish no earlier than 2026-04-02 |
| 3403 | Engagement / Communications with Participants Completed | 0d | 2026-04-03 A | 2026-04-03 A |  | finish no earlier than 2026-04-03 |
| 3404 | **Internal Communications** | 1d | 2026-04-06 A | 2026-04-06 A |  |  |
| 3405 | Agree Content for Livewire | 1d | 2026-04-06 A | 2026-04-06 A |  | start no earlier than 2026-04-06 |
| 3406 | Publish Content for Livewire | 0d | 2026-04-06 A | 2026-04-06 A |  | finish no earlier than 2026-04-06 |
| 3407 | Validate User Access | 1d | 2026-04-07 A | 2026-04-07 A |  | start no earlier than 2026-04-07 |
| 3411 | MP1 and MP2 - Service Activation Preparation Tasks (M) | 0d | 2026-04-10 A | 2026-04-10 A |  | finish no earlier than 2026-04-10 |
| 3413 | Market Entry to confirm PP's Effective from Date | 1d | 2026-04-02 A | 2026-04-02 A |  | start no earlier than 2026-04-02 |
| 3418 | MDD & ISD Go-Live | 1d | 2026-05-14 A | 2026-05-14 A | 3417FS+5d | start no earlier than 2026-05-14 |
| 3425 | PP to agree Effective from Date 40WD ahead of target PAB | 1d | 2026-03-27 A | 2026-03-27 A |  | start no earlier than 2026-04-02 |
| 3426 | Market Entry to confirm PP's Effective from Date | 1d | 2026-05-13 A | 2026-05-13 A |  |  |
| 3431 | ISD Go-Live | 0d | 2026-06-08 A | 2026-06-08 A | 3430FS+5d | start no earlier than 2026-06-05 |
| 3435 | PP to agree Effective from Date 40WD ahead of target PAB | 1d | 2026-04-24 A | 2026-04-24 A |  | start no earlier than 2026-04-24 |
| 3436 | Market Entry to obtain Effective from Date from PP | 1d | 2026-06-11 A | 2026-06-11 A |  | start no earlier than 2026-06-11 |
| 3441 | ISD Go-Live | 0d | 2026-07-06 | 2026-07-06 | 3440FS+5d | start no earlier than 2026-07-06 |
| 3443 | **Migration Pathway 7 (MP7)** | 48d | 2026-05-21 A | 2026-07-28 |  |  |
| 3444 | **MP7 - Service Activation Implementation** | 48d | 2026-05-21 A | 2026-07-28 |  |  |
| 3445 | PP to agree Effective from Date 40WD ahead of target PAB | 1d | 2026-05-21 A | 2026-05-21 A |  | start no earlier than 2026-05-21 |
| 3446 | PP to submit MDD Change Request | 5d | 2026-05-21 A | 2026-05-27 A |  | start no earlier than 2026-05-21 |
| 3447 | Market Entry to obtain Effective from Date from PP | 1d | 2026-07-01 | 2026-07-01 |  | start no earlier than 2026-07-01 |
| 3448 | PP Qualified by Code Bodies | 0d | 2026-07-15 | 2026-07-15 | 2753 | start no earlier than 2026-07-15 |
| 3451 | MDD & ISD Publish | 1d | 2026-07-20 | 2026-07-20 | 3450SS | start no earlier than 2026-07-20 |
| 3452 | MDD & ISD Go-Live | 0d | 2026-07-27 | 2026-07-27 | 3451FS+5d |  |
| 3453 | MP7 - Service Activation Implementation Complete (M) | 0d | 2026-07-28 | 2026-07-28 | 3451 | start no earlier than 2026-07-28 |
| 3454 | **MP7 - Service Activation Implementation MDD** | 2d | 2026-07-16 | 2026-07-17 |  |  |
| 3455 | MDD Final Circular Completed | 0d | 2026-07-17 | 2026-07-17 |  | start no earlier than 2026-07-17 |
| 3457 | **Migration Pathway 8 (MP8)** | 48d | 2026-06-04 A | 2026-08-11 |  |  |
| 3458 | **MP8 - Service Activation Implementation** | 48d | 2026-06-04 A | 2026-08-11 |  |  |
| 3459 | PP to agree Effective from Date 40WD ahead of target PAB | 1d | 2026-06-04 A | 2026-06-04 A |  | start no earlier than 2026-06-04 |
| 3460 | Market Entry to obtain Effective from Date from PP | 1d | 2026-07-16 | 2026-07-16 |  | start no earlier than 2026-07-16 |
| 3461 | PP Qualified by Code Bodies | 0d | 2026-07-30 | 2026-07-30 | 2753 | start no earlier than 2026-07-30 |
| 3464 | ISD Publish | 1d | 2026-08-03 | 2026-08-03 | 3463SS | start no earlier than 2026-08-03 |
| 3465 | ISD Go-Live | 0d | 2026-08-10 | 2026-08-10 | 3464FS+5d |  |
| 3466 | MP8 - Service Activation Implementation Complete (M) | 0d | 2026-08-11 | 2026-08-11 | 3464 | start no earlier than 2026-08-11 |
| 3467 | **Migration Pathway 9 (MP9)** | 48d | 2026-06-18 | 2026-08-25 |  |  |
| 3468 | **MP9 - Service Activation Implementation** | 48d | 2026-06-18 | 2026-08-25 |  |  |
| 3469 | PP to agree Effective from Date 40WD ahead of target PAB | 1d | 2026-06-18 | 2026-06-18 |  | start no earlier than 2026-06-18 |
| 3470 | PP to submit MDD Change Request | 5d | 2026-06-18 | 2026-06-24 |  | start no earlier than 2026-06-18 |
| 3471 | Market Entry to obtain Effective from Date from PP | 1d | 2026-07-29 | 2026-07-29 |  | start no earlier than 2026-07-29 |
| 3472 | PP Qualified by Code Bodies | 0d | 2026-08-12 | 2026-08-12 | 2753 | start no earlier than 2026-08-12 |
| 3474 | Create M16 in Customer Solution | 1d | 2026-08-13 | 2026-08-13 | 3472 | start no earlier than 2026-08-13 |
| 3475 | MDD & ISD Publish | 1d | 2026-08-17 | 2026-08-17 | 3474SS | start no earlier than 2026-08-17 |
| 3476 | MDD & ISD Go-Live | 0d | 2026-08-24 | 2026-08-24 | 3475FS+5d |  |
| 3477 | MP9 - Service Activation Implementation Complete (M) | 0d | 2026-08-25 | 2026-08-25 | 3475 | start no earlier than 2026-08-25 |
| 3478 | **MP9 - Service Activation Implementation MDD** | 2d | 2026-08-13 | 2026-08-14 |  |  |
| 3479 | MDD Final Circular Completed | 0d | 2026-08-14 | 2026-08-14 |  | start no earlier than 2026-08-14 |
| 3480 | MDD Manual Update | 2d | 2026-08-13 | 2026-08-14 |  | start no earlier than 2026-08-13 |
| 3481 | **Migration Pathway 10 (MP10)** | 48d | 2026-07-03 | 2026-09-08 |  |  |
| 3482 | **MP10 - Service Activation Implementation** | 48d | 2026-07-03 | 2026-09-08 |  |  |
| 3483 | PP to agree Effective from Date 40WD ahead of target PAB | 1d | 2026-07-03 | 2026-07-03 |  | start no earlier than 2026-07-03 |
| 3484 | Market Entry to obtain Effective from Date from PP | 1d | 2026-08-13 | 2026-08-13 |  | start no earlier than 2026-08-13 |
| 3485 | PP Qualified by Code Bodies | 0d | 2026-08-27 | 2026-08-27 | 2753 | start no earlier than 2026-08-27 |
| 3487 | Create M16 in Customer Solution | 1d | 2026-08-28 | 2026-08-28 | 3485 | start no earlier than 2026-08-28 |
| 3488 | ISD Publish | 1d | 2026-09-01 | 2026-09-01 | 3487SS | start no earlier than 2026-09-01 |
| 3489 | ISD Go-Live | 0d | 2026-09-08 | 2026-09-08 | 3488FS+5d | start no earlier than 2026-09-08 |
| 3490 | MP10 - Service Activation Implementation Complete (M) | 0d | 2026-09-09 | 2026-09-09 | 3488 | start no earlier than 2026-09-09 |
| 3491 | **Migration Pathway 11 (MP11)** | 51d | 2026-07-13 | 2026-09-22 |  |  |
| 3492 | **MP11 - Service Activation Implementation** | 51d | 2026-07-13 | 2026-09-22 |  |  |
| 3493 | PP to agree Effective from Date 40WD ahead of target PAB | 1d | 2026-07-13 | 2026-07-13 |  | start no earlier than 2026-07-13 |
| 3494 | PP to submit MDD Change Request | 5d | 2026-07-13 | 2026-07-17 |  | start no earlier than 2026-07-13 |
| 3495 | Market Entry to obtain Effective from Date from PP | 1d | 2026-08-25 | 2026-08-25 |  | start no earlier than 2026-08-25 |
| 3496 | PP Qualified by Code Bodies | 0d | 2026-09-09 | 2026-09-09 | 2753 | start no earlier than 2026-09-09 |
| 3498 | Create M16 in Customer Solution | 1d | 2026-09-10 | 2026-09-10 | 3496 | start no earlier than 2026-09-10 |
| 3499 | MDD & ISD Publish | 1d | 2026-09-14 | 2026-09-14 | 3498SS | start no earlier than 2026-09-14 |
| 3500 | MDD & ISD Go-Live | 0d | 2026-09-21 | 2026-09-21 | 3499FS+5d | start no earlier than 2026-09-21 |
| 3501 | MP11 - Service Activation Implementation Complete (M) | 0d | 2026-09-22 | 2026-09-22 | 3499 | start no earlier than 2026-09-22 |
| 3502 | **MP11 - Service Activation Implementation MDD** | 2d | 2026-08-13 | 2026-08-14 |  |  |
| 3503 | MDD Final Circular Completed | 0d | 2026-09-11 | 2026-09-11 |  | start no earlier than 2026-09-11 |
| 3504 | MDD Manual Update | 2d | 2026-08-13 | 2026-08-14 |  | finish no earlier than 2026-08-14 |
| 3505 | **Migration Pathway 12a (MP12a)** | 49d | 2026-07-29 | 2026-10-06 |  |  |
| 3506 | **MP12a - Service Activation Implementation** | 49d | 2026-07-29 | 2026-10-06 |  |  |
| 3507 | PP to agree Effective from Date 40WD ahead of target PAB | 1d | 2026-07-29 | 2026-07-29 |  | start no earlier than 2026-07-29 |
| 3508 | Market Entry to obtain Effective from Date from PP | 1d | 2026-09-10 | 2026-09-10 |  | start no earlier than 2026-09-10 |
| 3509 | PP Qualified by Code Bodies | 0d | 2026-09-24 | 2026-09-24 | 2753 | start no earlier than 2026-09-23 |
| 3510 | DIP Promoted to Production | 5d | 2026-09-25 | 2026-10-01 | 3509 | finish no earlier than 2026-03-05 |
| 3511 | Create M16 in Customer Solution | 1d | 2026-09-25 | 2026-09-25 | 3509 | start no earlier than 2026-09-25 |
| 3512 | ISD Publish | 1d | 2026-09-28 | 2026-09-28 | 3511SS | start no earlier than 2026-09-28 |
| 3513 | ISD Go-Live | 0d | 2026-10-05 | 2026-10-05 | 3512FS+5d |  |
| 3514 | MP12a - Service Activation Implementation Complete (M) | 0d | 2026-10-06 | 2026-10-06 | 3512 | start no earlier than 2026-10-06 |
| 3515 | **Migration Pathway 12b (MP12b)** | 64d | 2026-07-29 | 2026-10-27 |  |  |
| 3516 | **MP12b - Service Activation Implementation** | 64d | 2026-07-29 | 2026-10-27 |  |  |
| 3517 | PP to agree Effective from Date 40WD ahead of target PAB | 1d | 2026-07-29 | 2026-07-29 |  | start no earlier than 2026-07-29 |
| 3518 | PP to submit MDD Change Request | 5d | 2026-07-29 | 2026-08-04 |  | start no earlier than 2026-07-29 |
| 3519 | Market Entry to obtain Effective from Date from PP | 1d | 2026-09-10 | 2026-09-10 |  | start no earlier than 2026-09-10 |
| 3520 | PP Qualified by Code Bodies | 0d | 2026-09-24 | 2026-09-24 | 2753 | start no earlier than 2026-09-23 |
| 3521 | DIP Promoted to Production | 5d | 2026-09-25 | 2026-10-01 | 3520 | finish no earlier than 2026-03-05 |
| 3522 | Create M16 in Customer Solution | 1d | 2026-09-25 | 2026-09-25 | 3520 | start no earlier than 2026-09-25 |
| 3523 | MDD & ISD Publish | 1d | 2026-10-19 | 2026-10-19 | 3522SS | start no earlier than 2026-10-19 |
| 3524 | MDD & ISD Go-Live | 0d | 2026-10-26 | 2026-10-26 | 3523FS+5d | start no earlier than 2026-10-26 |
| 3525 | MP12a - Service Activation Implementation Complete (M) | 0d | 2026-10-27 | 2026-10-27 | 3523 | start no earlier than 2026-10-27 |
| 3526 | **MP12b - Service Activation Implementation MDD** | 2d | 2026-10-15 | 2026-10-16 |  |  |
| 3527 | MDD Final Circular Completed | 0d | 2026-10-16 | 2026-10-16 |  | start no earlier than 2026-10-16 |
| 3528 | MDD Manual Update | 2d | 2026-10-15 | 2026-10-16 |  | start no earlier than 2026-10-15 |
| 3531 | **Early Life Support Phase** | 81d | 2025-10-23 A | 2026-02-12 A |  |  |
| 3532 | Phase 1 End | 26d | 2025-10-23 A | 2025-11-27 A | 3374 |  |
| 3533 | Phase 2 End | 20d | 2025-11-21 A | 2025-12-18 A | 3532SS | start no earlier than 2025-11-21 |
| 3534 | Phase 3 End/Early Life Exit | 40d | 2025-12-19 A | 2026-02-12 A | 3533 | finish no earlier than 2026-02-12 |
| 3545 | **M16: Decision Approach** | 95d | 2026-01-09 A | 2026-05-21 |  |  |
| 3546 | **Agree Approach M16 Decision Proposal** | 75d | 2026-01-09 A | 2026-04-23 A |  |  |
| 3547 | M16 Decision Proposal Agreed | 0d | 2026-01-09 A | 2026-01-09 A |  | start no earlier than 2026-01-09 |
| 3548 | M16 Decision Approach Approved | 0d | 2026-04-23 A | 2026-04-23 A |  | start no earlier than 2026-04-23 |
| 3549 | 2026 Settlement Calendar Produced | 0d | 2026-04-01 A | 2026-04-01 A |  | start no earlier than 2026-04-01 |
| 3550 | **Consult and Agree with Industry** | 94d | 2026-01-12 A | 2026-05-21 |  |  |
| 3551 | **M16 Working Group 1** | 39d | 2026-01-12 A | 2026-03-05 A |  |  |
| 3552 | Materials Prepared and Shared | 13d | 2026-01-12 A | 2026-01-28 A | 3547FS+1d | finish no earlier than 2026-01-28 |
| 3553 | M16 Working Group 1 Completed | 0d | 2026-02-06 A | 2026-02-06 A |  | start no earlier than 2026-02-06 |
| 3554 | Outline Work Packages and Activities for Tracking and Decision Choreography for Decision 1 | 20d | 2026-02-06 A | 2026-03-05 A | 3553 | finish no earlier than 2026-03-05 |
| 3555 | Replanning Session Post M16 Workshop 1 | 0d | 2026-02-09 A | 2026-02-09 A | 3553FS+2d | finish no earlier than 2026-02-09 |
| 3556 | **M16 Working Group 2** | 17d | 2026-02-06 A | 2026-03-02 A |  |  |
| 3557 | 2 Materials Prepared and Shared | 15d | 2026-02-06 A | 2026-02-26 A | 3553 | finish no earlier than 2026-02-26 |
| 3558 | M16 Working Group 2 Completed | 0d | 2026-02-26 A | 2026-02-26 A |  | finish no earlier than 2026-02-26 |
| 3559 | Replanning Session Post M16 Workshop 2 | 0d | 2026-03-02 A | 2026-03-02 A | 3558FS+2d | finish no earlier than 2026-03-02 |
| 3560 | **M16 Working Group 3** | 8d | 2026-03-03 A | 2026-03-12 A |  |  |
| 3561 | Materials Prepared and Shared | 3d | 2026-03-03 A | 2026-03-05 A | 3559 | finish no earlier than 2026-03-05 |
| 3562 | M16 Working Group 3 Completed | 0d | 2026-03-12 A | 2026-03-12 A |  | finish no earlier than 2026-03-12 |
| 3563 | **M16 Working Group 4** | 10d | 2026-03-13 A | 2026-03-26 A |  |  |
| 3564 | Materials Prepared and Shared | 5d | 2026-03-13 A | 2026-03-19 A | 3562 | finish no earlier than 2026-03-19 |
| 3565 | M16 Working Group 4 Completed | 0d | 2026-03-26 A | 2026-03-26 A |  | finish no earlier than 2026-03-26 |
| 3566 | **M16 Decision Making and Monitoring Criteria Consultation** | 62d | 2026-03-27 A | 2026-06-23 |  |  |
| 3567 | Prepare consultation material | 10d | 2026-03-27 A | 2026-04-09 A | 3565 | finish no earlier than 2026-04-09 |
| 3568 | Issue Consultation | 0d | 2026-04-29 A | 2026-04-29 A | 3567FS+1d | start no earlier than 2026-04-29 |
| 3569 | Consultation Period | 20d | 2026-04-29 A | 2026-05-26 A | 3568FS-1d | start no earlier than 2026-04-29 |
| 3570 | Consultation Period Completed | 0d | 2026-05-26 A | 2026-05-26 A | 3569 | finish no earlier than 2026-05-07 |
| 3571 | Materials Issued for Approval at MCAG | 0d | 2026-06-16 | 2026-06-16 | 3570FS+5d | start no earlier than 2026-06-16 |
| 3572 | M16 Approach Approved at MCAG | 0d | 2026-06-23 | 2026-06-23 | 3571FS+5d | start no earlier than 2026-06-23 |
| 3573 | **M16: Monitoring Period** | 306d | 2026-04-15 A | 2027-06-16 | 3572FS+1d |  |
| 3574 | STEG 1 | 0d | 2026-04-15 A | 2026-04-15 A |  | start no earlier than 2026-04-15 |
| 3575 | STEG 2 | 0d | 2026-05-13 A | 2026-05-13 A |  | start no earlier than 2026-05-13 |
| 3576 | STEG 3 | 0d | 2026-06-10 A | 2026-06-10 A |  | start no earlier than 2026-06-10 |
| 3577 | STEG 4 | 0d | 2026-06-24 | 2026-06-24 |  | start no earlier than 2026-06-24 |
| 3578 | STEG 5 | 0d | 2026-07-08 | 2026-07-08 |  | start no earlier than 2026-07-08 |
| 3579 | STEG 6 | 0d | 2026-07-22 | 2026-07-22 |  | start no earlier than 2026-07-22 |
| 3580 | STEG 7 | 0d | 2026-08-05 | 2026-08-05 |  | start no earlier than 2026-08-05 |
| 3581 | STEG 8 | 0d | 2026-08-19 | 2026-08-19 |  | start no earlier than 2026-08-19 |
| 3582 | STEG 9 | 0d | 2026-09-02 | 2026-09-02 |  | start no earlier than 2026-09-02 |
| 3583 | STEG 10 | 0d | 2026-09-16 | 2026-09-16 |  | start no earlier than 2026-09-16 |
| 3584 | STEG 11 | 0d | 2026-09-30 | 2026-09-30 |  | start no earlier than 2026-09-30 |
| 3585 | STEG 12 | 0d | 2026-10-14 | 2026-10-14 |  | start no earlier than 2026-10-14 |
| 3586 | STEG 13 | 0d | 2026-10-28 | 2026-10-28 |  | start no earlier than 2026-10-28 |
| 3587 | STEG 14 | 0d | 2026-11-11 | 2026-11-11 |  | start no earlier than 2026-11-11 |
| 3588 | STEG 15 | 0d | 2026-11-25 | 2026-11-25 |  | start no earlier than 2026-11-25 |
| 3589 | STEG 16 | 0d | 2026-12-09 | 2026-12-09 |  | start no earlier than 2026-12-09 |
| 3590 | STEG 17 | 0d | 2026-12-23 | 2026-12-23 |  | start no earlier than 2026-12-23 |
| 3591 | STEG 18 | 0d | 2027-01-06 | 2027-01-06 |  | start no earlier than 2027-01-06 |
| 3592 | STEG 19 | 0d | 2027-01-20 | 2027-01-20 |  | start no earlier than 2027-01-20 |
| 3593 | STEG 20 | 0d | 2027-02-03 | 2027-02-03 |  | start no earlier than 2027-02-03 |
| 3594 | STEG 21 | 0d | 2027-02-17 | 2027-02-17 |  | start no earlier than 2027-02-17 |
| 3595 | STEG 22 | 0d | 2027-03-03 | 2027-03-03 |  | start no earlier than 2027-03-03 |
| 3596 | STEG 23 | 0d | 2027-03-17 | 2027-03-17 |  | start no earlier than 2027-03-17 |
| 3597 | STEG 24 | 0d | 2027-03-31 | 2027-03-31 |  | start no earlier than 2027-03-31 |
| 3598 | STEG 25 | 0d | 2027-04-14 | 2027-04-14 |  | start no earlier than 2027-04-14 |
| 3599 | STEG 26 | 0d | 2027-04-28 | 2027-04-28 |  | start no earlier than 2027-04-28 |
| 3600 | STEG May - M16 Checkpoint 2 | 0d | 2027-05-17 | 2027-05-17 |  | start no earlier than 2027-05-17 |
| 3601 | STEG June | 0d | 2027-06-16 | 2027-06-16 |  | start no earlier than 2027-06-16 |
| 3602 | **M16: Decision Points** | 245d | 2026-07-13 | 2027-06-18 |  |  |
| 3603 | **STEG to Assess Monitoring Report and recommend interim position to MCAG on Decision 1** | 5d | 2026-07-13 | 2026-07-17 |  |  |
| 3604 | STEG Issue position to MCAG notifying Decision Checkpoint 1 On-track | 0d | 2026-07-15 | 2026-07-15 | 3578 | start no earlier than 2026-07-15 |
| 3605 | MCAG Endorses Assessment | 0d | 2026-07-17 | 2026-07-17 | 3604FS+3d | start no earlier than 2026-07-15 |
| 3607 | **Prepare Readiness Assessment - Material Describing Transition Design and Queries to PPs guaging understanding an organisational readiness** | 31d | 2026-07-17 | 2026-08-28 | 3605FS-15d |  |
| 3608 | Issue Readiness Assessment Following Interim Recommendation | 0d | 2026-07-17 | 2026-07-17 | 3605 | finish no earlier than 2026-07-17 |
| 3609 | Readiness Assessment 8 Consultation Period Complete | 0d | 2026-08-14 | 2026-08-14 | 3608FS+20d | finish no earlier than 2026-08-14 |
| 3610 | Readiness Assessment 8 Complete | 0d | 2026-08-14 | 2026-08-14 | 3609 | finish no earlier than 2026-08-14 |
| 3611 | Assess Readiness Assessment 8 and Plan further enagement activity if required | 10d | 2026-08-17 | 2026-08-28 | 3609 | finish no earlier than 2026-08-28 |
| 3612 | **Decision 1 RF Change to 7 months from Settlement Day 01/10** | 5d | 2026-09-14 | 2026-09-18 |  |  |
| 3613 | STEG to compare Monitoring report against agreed assessment criteria | 0d | 2026-09-14 | 2026-09-14 | 3582 | start no earlier than 2026-09-14 |
| 3614 | STEG Issue recommendation to MCAG | 0d | 2026-09-14 | 2026-09-14 | 3613 | start no earlier than 2026-09-14 |
| 3615 | MCAG Approve Recommendation to change to RF 7 months calendar | 0d | 2026-09-18 | 2026-09-18 | 3613FS+5d | finish no earlier than 2026-09-18 |
| 3616 | Decision 1 - RF 7 Months | 0d | 2026-09-18 | 2026-09-18 | 3615 | finish no earlier than 2026-09-18 |
| 3617 | **Decision 2 RF Change to 4 months from Settlement Date 01/04** | 5d | 2027-03-15 | 2027-03-19 |  |  |
| 3618 | STEG to compare Monitoring report against agreed assessment criteria | 0d | 2027-03-15 | 2027-03-15 | 3595 | start no earlier than 2027-03-15 |
| 3619 | STEG Issue recommendation to MCAG | 0d | 2027-03-19 | 2027-03-19 | 3618FS+5d | finish no earlier than 2027-03-19 |
| 3620 | MCAG Approve recommendation | 0d | 2027-03-19 | 2027-03-19 | 3619 | finish no earlier than 2027-03-19 |
| 3621 | Decision 2 - RF 4 Months | 0d | 2027-03-19 | 2027-03-19 | 3620 | finish no earlier than 2027-03-19 |
| 3622 | **Decision 3 SF Change from 15WD to 7WD from Settlement Date 02/07** | 5d | 2027-06-14 | 2027-06-18 |  |  |
| 3623 | STEG to compare Monitoring report against agreed assessment criteria | 0d | 2027-06-14 | 2027-06-14 |  | start no earlier than 2027-06-14 |
| 3624 | STEG Issue recommendation to MCAG | 0d | 2027-06-18 | 2027-06-18 | 3623FS+5d | finish no earlier than 2027-06-18 |
| 3625 | MCAG Approve Recommendation - Confirm M16 Date | 0d | 2027-06-18 | 2027-06-18 | 3624 | finish no earlier than 2027-06-18 |
| 3626 | Decision 3 - SF 7WD | 0d | 2027-06-18 | 2027-06-18 | 3625 | finish no earlier than 2027-06-18 |
| 3627 | **M16: Creation & Implementation of Updated Settlement Calendars** | 334d | 2026-03-09 | 2027-06-17 |  |  |
| 3628 | **Post Decision 1 & 2** | 55d | 2027-01-04 | 2027-03-19 |  |  |
| 3629 | **Prepare Calendars** | 20d | 2027-01-04 | 2027-01-29 |  |  |
| 3630 | Prepare Variant a) April-Jun 2027 Including change RF to 7& 4 Months | 20d | 2027-01-04 | 2027-01-29 |  | start no earlier than 2027-01-04 |
| 3631 | Prepare Variant b) April-Jun 2027 7 Month only where decision 2 Fails | 20d | 2027-01-04 | 2027-01-29 |  | start no earlier than 2027-01-04 |
| 3632 | Prepare Variant c) April-Jun 2027"No Change" Where both decisions fail | 20d | 2027-01-04 | 2027-01-29 |  | start no earlier than 2027-01-04 |
| 3633 | SVG Approval of Appropriate Calendar | 0d | 2027-02-26 | 2027-02-26 | 3629FS+20d | start no earlier than 2027-02-26 |
| 3634 | Implementation of April - Jun 2027 Calendar | 0d | 2027-03-19 | 2027-03-19 | 3615, 3620, 3633FS+10d | finish no earlier than 2027-03-19 |
| 3635 | **Post Decision 3** | 20d | 2027-03-08 | 2027-04-02 |  |  |
| 3636 | Prepare Variant Jul-27 - Mar-28 Including 4/7 Month and 7 Day SF | 20d | 2027-03-08 | 2027-04-02 |  | start no earlier than 2027-03-08 |
| 3637 | Prepare Variant Jul-27 - Sep-28 Excluding SF Change Contingency | 20d | 2027-03-08 | 2027-04-02 |  | start no earlier than 2027-03-08 |
| 3638 | SVG Approval of Appropriate Calendar | 0d | 2027-06-03 | 2027-06-03 | 3378FS+19d | finish no earlier than 2027-06-03 |
| 3639 | Implementation of Jul - Mar 2027 Calendar | 0d | 2027-06-17 | 2027-06-17 | 3638FS+10d | finish no earlier than 2027-06-17 |
| 3701 | Readiness Assessment 7 survey issued | 0d | 2026-03-02 A | 2026-03-02 A |  | start no earlier than 2026-03-02 |
| 3702 | Draft response review point | 3d | 2026-03-06 A | 2026-03-10 A | 3701FS+4d |  |
| 3703 | Evidence asessment | 19d | 2026-03-06 A | 2026-04-01 A |  | start no earlier than 2026-03-06 |
| 3704 | Readiness Assessment 7 survey closes | 0d | 2026-03-16 A | 2026-03-16 A | 3701FS+11d | start no earlier than 2026-03-11 |
| 3705 | Report on Readiness Assessment 7 findings at PSG | 0d | 2026-04-01 A | 2026-04-01 A | 3704FS+12d |  |

Removed: 466 DBT Progress Monitoring of Consequential Change; 467 Monitor & report data cleanse progress; 1573 Regression Contingency Week; 1574 SIT Functional Testing End; 1587 All Settlement and Regression Pathway 2 PP Exit Reports shared with PPs; 1593 Pathway 3 PPs Exit Report and Regression Exit Decleration submission deadline; 1598 SI SIT Migration Testing End (incl. confirmation that PPs have submitted their Test Exit Reports to Programme for assurance); 1627 SIT Migration Regression Testing (code freeze); 1628 Regression Test Execution Start; 1629 Regression Execution; 1630 Regression Sprint 1; 1631 Regression Sprint 2; 1632 Regression Sprint 3; 1633 Regression Contingency Week; 1634 SIT Migration Testing End (incl. confirmation that PPs have submitted their Test Completion Reports to Programme for assurance); 1635 SIT Functional & Migration Test Exit Report; 1636 Programme drafts Functional & Migration PP Exit Report; 1637 SRO Review PP Exit Reports; 1638 Functional & Migration PP Exit Reports shared with PPs; 1639 PPs complete and return Exit Reports; 1640 PPs Exit Report submission deadline; 1641 Programme drafts SI SIT Functional & Migration Overarching Exit Report; 1642 SITWG Review status of Functional & Migration Overarching Completion Report; 1643 SIT Settlement and Regression Test Exit Report; 1644 Programme drafts Settlement and Regression PP Exit Report (when Participant completes Regression testing); 1645 All Settlement and Regression PP Exit Reports shared with PPs; 1646 PPs complete and return PP Exit Reports; 1647 PPs Exit Report and Regression Exit Deceleration submission deadline; 1648 Programme drafts SI SIT Settlement and Regression Overarching Exit Report; 1649 SRO Review SI SIT Settlement and Regression Overarching Exit Report; 1650 SITWG Review status of SI SIT Settlement and Regression Overarching Exit Report; 1651 SIT Migration Testing Test Exit Report Approved; 1652 SIT Migration Testing End (incl. confirmation that PPs have submitted their Test Exit Reports to Programme for assurance); 1653 SITAG Approves SI SIT Functional & Migration (Post-Regression) Overarching Test Exit Report; 1664 PPs Exit Report submission deadline; 1691 PPs Exit Report submission deadline; 1695 PPs Exit Report submission deadline; 1704 SIT (Contingency); 1705 SIT Functional Testing (Contingency); 1706 SIT Functional Testing Execution (Contingency); 1707 Test Execution (Cycle 3 Completion and Regression Testing); 1708 SIT Functional Testing End (Contingency) (incl. confirmation that PPs have submitted their Test Exit Reports to Programme for assurance); 1709 Assurance of PPs Test Exit Reports; 1710 SIT Functional Testing Test Completion Report (Contingency); 1711 Develop document; 1712 Review & agree document; 1713 SIT Functional Testing Test Exit Report (Contingency) Approved; 1714 SIT Migration Testing (Contingency); 1715 Test Execution (Cycle 3 Completion and Regression Testing); 1716 SIT Migration Testing End (Contingency) (incl. confirmation that PPs have submitted their Test Exit Reports to Programme for assurance); 1717 Assurance of PPs Test Exit Reports; 1718 SIT Migration Testing Test Completion Report (Contingency); 1719 Develop document; 1720 Review & agree document; 1721 SIT Migration Testing Test Exit Report (Contingency) Approved; 1722 SIT Contingency Test Exit Report; 1723 Develop document; 1724 Review & agree document; 1725 SIT Contingency Complete; 1777 E2E Sandbox Participants (UIT); 1778 E2E Sandbox Participants environment preparation (incl. security certificates and security compliance); 1779 Submit self-declaration of environment preparation complete (incl. security certificates and security compliance) to Programme for assurance; 1780 E2E Sandbox Participants UIT environment connectivity proving; 1781 Deployment of MHHS solution code to UIT environments; 1782 Coordinate E2E Sandbox Participants' UIT environment preparation (for E2E Sandbox Testing Start); 1786 Central Parties (for E2E Sandbox & Qualification); 1787 Central Parties' UIT environment test data loading & verification (& data cleansing, if required); 1788 Submit self-declaration to Programme to confirm loading & verification of test data; 1789 E2E Sandbox Participants; 1790 UIT environment test data loading and verification (and data cleansing, if required) (for E2E Sandbox Testing Start); 1791 SI Test Data; 1792 Coordinate Central Parties' UIT environment test data loading and verification (and data cleansing, if required); 1793 Assure evidence of Central Parties' UIT environment test data load and verification; 1794 Coordinate E2E Sandbox Participants' UIT environment test data loading and verification (and data cleansing, if required) (for E2E Sandbox Testing Start); 1795 Other Preparation; 1796 SI Other Preparation; 1797 Onboarding of UIT E2E Sandbox Participants to Test Management Tool for E2E Sandbox Testing Start (onboarding of participants will be ongoing hereafter); 1798 Other Preparation (for Central Parties & E2E Sandbox Participants); 1799 Test Management Tool onboarding for E2E Sandbox Testing Start (onboarding will be ongoing hereafter); 1800 Other Preparation (incl. test execution planning); 1801 UIT E2E Sandbox Test Readiness Report; 1802 Central Parties E2E Sandbox Test Readiness Report; 1803 Develop draft Test Readiness Report and submit to Programme for assurance; 1804 Finalise Test Readiness Report and submit to Programme for assurance; 1805 SI E2E Sandbox Test Readiness Report; 1806 Assure Central Parties' E2E Sandbox Test Readiness Reports; 1807 Develop Overarching E2E Sandbox Test Readiness Report; 1808 Artefact review (via SITAG) and updates; 1809 UIT E2E Sandbox Preparation Complete; 2098 "Codify Service Management" - Item raised; 2099 "Codify Service Management" Item Preparation; 2100 Committee Views Ahead of Panel; 2101 Initial Panel Committee Views; 2102 Consultation on Codify Service Management; 2103 Committee Views Ahead of Final Panel; 2104 Final Panel Committee Views; 2105 Submission for Decision to Ofgem ("Codify Service Management"); 2106 "Codify Service Management" Final Decision Process; 2107 "Codify Service Management" Decision Due (TBC and Indicitavely by End of Aug); 2109 Service Management Go/No Go Decision; 2111 Registration of LDSOs into ServiceNow; 2207 PAB Approval Completed; 2218 Non-SIT LDSO Service Activation Data Loading Completed; 2225 Non-SIT LDSO & SIT MVC Service Activation Implementation MDD Completed; 2232 DIP Guidance Notes; 2233 GN/LWI creation & publication; 2234 Tranche 1 GN/LWI created & published (critical for M10); 2235 Tranche 2 GN/LWI created & published; 2236 Tranche 3 GN/LWI created & published; 2237 DIP Reporting (M11); 2238 Functional Training Execution; 2239 Operational Readiness E2E Testing; 2240 Phase 1 Test Execution (Service Activation and Participant Management); 2241 Phase 2 Test Execution (S&I); 2242 Phase 3 Test Execution (Assurance & mop-up); 2243 E2E Operational Testing Completed; 2247 Confirm Training complete; 2256 PAB Approval Completed; 2264 Publish MDD; 2265 MDD Go Live; 2268 PAB Approval Completed; 2279 M11-Ready Service Activation Implementation MDD; 2282 MDD Publish; 2283 MDD Go Live; 2284 M11-Ready Service Activation Implementation MDD Completed; 2293 Review Entry / Exit Criteria & Lessons Learned; 2294 Identify Resources; 2295 Agree & Understand Support Model; 2296 Confirm Training complete; 2299 Target Systems and Environments Ready; 2300 Provide LWIs; 2301 Business Readiness Governance Approval; 2302 Not M11-Ready Participants Service Activation Preparation Completed; 2305 PAB Approval Completed; 2326 Not M11-Ready Service Activation Implementation MDD; 2327 MDD Final Circular; 2329 MDD Publish; 2330 MDD Go Live; 2331 Non-SIT LDSO & SIT MVC Service Activation Implementation MDD Completed; 2411 DIP Technical Onboarding for LDSOs; 2412 ISD Dress Rehearsals; 2414 Service Activation Implementation; 2491 SIT / LDSO Pathway 1; 2492 QAD Sign Off Deadline + Test Reports; 2493 REC Code Manager / BSC PAB Approval of Qualification; 3068 Q+A documents from sessions published; 3076 Dress rehearsal start; 3225 M16 Methodology; 3226 Draft Document; 3227 Share Document with SRO; 3228 Industry Consultation; 3229 Assurance Meeting; 3230 M16 methodology approved; 3251 Elexon Central Services Deployment; 3253 Data Transfer Service (DTS) New Functionality Deployment; 3254 Electricity Enquiry Service (EES) Deployment; 3255 MPRS, UMSO Role, LDSO Role Operational; 3256 Population of Domestic Premises Indicator; 3257 Population of Market Segment; 3262 SIT Participant Qualification - The final date by which participant qualification status can be confirmed for participants to be ready for the start of Migration at M11.; 3266 Confirmation that Pre-migration Data Cleanse Activities have successfully taken place; 3268 Confirmation of Helix E2E Settlement Testing Complete; 3269 Confirmation of assurance of Helix E2E Settlement Testing; 3270 Confirmation of Qualification Status for SIT MVC; 3271 Confirmation of Qualification Status for Non-SIT LDSOs; 3272 Confirmation of Qualification Status of at least one Supplier and their contracted Agents; 3274 Market-wide Participant MHHS Migration Supporting Functionality is Live; 3275 TORWG (Recommendation from TORWG that the Programme should enter M10); 3279 Self-Declarations against all M10 Data Cleanse Activities; 3280 IF-047 has been sent; 3281 Recommendation from TORWG that PSG should approve M10; 3284 Confirmation of Qualified Parties from Code Bodies; 3286 Production Service Activation Activities have taken place; 3287 TORWG (Confirmation of Qualified Parties from TORWG); 3288 MCAG (Provide recommendation to PSG on M11 decision); 3411 SIT Non-MVC Service Activation Preparation Tasks; 3412 Helix Preparatory Activities Complete; 3413 MHHSP Confirms Wave 1 PPs MHHS Enabled; 3414 Wave 1 Service Activation; 3417 PAB Approval; 3418 Add EFD to DIP; 3424 MDD Manual Load; 3425 MDD Update; 3426 Wave 1 - Service Activation Implementation MDD Complete (M); 3427 Wave 1 - Service Activation Hypercare; 3428 Service& Process Monitoring; 3429 Daily Reporting; 3430 Issue Management; 3431 SA Hypercare Close Down Activities; 3432 Handover to MHHSP; 3433 Non-SIT LDSO Service Activation Hypercare Complete (M); 3435 SIT Non-MVC Service Activation Preparation Tasks; 3436 Helix Preparatory Activities Complete; 3437 MHHSP Confirms Wave 2 PPs MHHS Enabled; 3438 Wave 2 Service Activation; 3441 PAB Approval; 3442 Add EFD to DIP; 3447 Wave 2 - Service Activation Implementation MDD; 3448 MDD Manual Load; 3449 MDD Update; 3450 Wave 2 - Service Activation Implementation MDD Complete (M); 3451 Wave 2 - Service Activation Hypercare; 3452 Service& Process Monitoring; 3453 Daily Reporting; 3454 Issue Management; 3455 SA Hypercare Close Down Activities; 3456 Handover to MHHSP; 3457 Wave 2 - Service Activation Hypercare Complete (M); 3458 Wave 3; 3459 SIT Non-MVC Service Activation Preparation Tasks; 3460 Helix Preparatory Activities Complete; 3461 MHHSP Confirms Wave 3 PPs MHHS Enabled; 3462 Wave 3 Service Activation; 3463 Wave 3 - Service Activation Implementation; 3464 MHHSP Enabled Confirmation; 3465 PAB Approval; 3466 Add EFD to DIP; 3469 Publish ISD; 3470 Wave 3 - Service Activation Implementation Complete (M); 3471 Wave 3 - Service Activation Implementation MDD; 3472 MDD Manual Load; 3473 MDD Update; 3474 Wave 3 - Service Activation Implementation MDD Complete (M); 3475 Wave 3 - Service Activation Hypercare; 3476 Service& Process Monitoring; 3477 Daily Reporting; 3478 Issue Management; 3479 SA Hypercare Close Down Activities; 3480 Handover to MHHSP; 3481 Wave 3 Service Activation Hypercare Complete (M); 3483 SIT Non-MVC Service Activation Preparation Tasks; 3484 Helix Preparatory Activities Complete; 3485 MHHSP Confirms Wave 4 PPs MHHS Enabled; 3486 Wave 4 Service Activation; 3489 PAB Approval; 3490 Add EFD to DIP; 3495 Wave 4 - Service Activation Implementation MDD; 3496 MDD Manual Load; 3497 MDD Update; 3498 Wave 4 - Service Activation Implementation MDD Complete; 3499 Wave 4 - Service Activation Hypercare; 3500 Service& Process Monitoring; 3501 Daily Reporting; 3502 Issue Management; 3503 SA Hypercare Close Down Activities; 3504 Handover to MHHSP; 3505 Wave 4 - Service Activation Hypercare Complete (M); 3506 Non-SIT LDSO; 3507 Non-SIT LDSO Service Activation Data Loading; 3508 Define pre Non-SIT LDSO upfront activities; 3509 Execute Non-SIT LDSO Activities; 3510 Create Entity Forms in Customer Solution; 3511 DIP - Promote to Production Environment; 3512 DIP - Enable Technology capabilities for participants; 3513 DIP - Add EFD to DIP; 3514 ISD - Replicate Entity Forms from CS; 3515 MDD - Load MHHS roles; 3516 Non-SIT LDSO Service Activation Data Loading Completed (M); 3517 SIT Non-MVC Service Activation Preparation Tasks; 3518 Helix Preparatory Activities Complete; 3519 MHHSP Confirms Non-SIT LDSO PPs MHHS Enabled; 3520 Non-SIT LDSO Service Activation; 3521 Non-SIT LDSO Service Activation Implementation; 3522 MHHSP Enabled Confirmation; 3523 PAB Approval; 3524 Add EFD to DIP; 3527 Publish ISD; 3528 Non-SIT LDSO Service Activation Implementation Completed (M); 3529 Non-SIT LDSO Service Activation Implementation MDD; 3530 MDD Manual Load; 3531 MDD Update; 3532 Non-SIT LDSO Service Activation Implementation MDD Complete (M); 3533 Non-SIT LDSO Service Activation Hypercare; 3534 Non-SIT LDSO Service Activation Hypercare Support; 3535 Service& Process Monitoring; 3536 Daily Reporting; 3537 Issue Management; 3538 SA Hypercare Close Down Activities; 3539 Handover to MHHSP; 3540 Non-SIT LDSO Service Activation Hypercare Complete (M); 3546 Training and Support Materials; 3547 Develop document; 3548 Document review and update; 3549 Training and Support Materials approved; 3557 Transition to New Settlement Timetable (M16); 3558 Elexon to produce Settlement Calendar for Settlement Year 2025/2026; 3559 Elexon monitor settlement data of migrated MPANs; 3561 Confirm if M16 date retained as 07/12/2026; 3562 Readiness assessment of participants' readiness to transition to new Settlement Timetable; 3563 Elexon to produce Settlement Calendar for Settlement Year 2026 up until day before M16 cutover; 3564 M16 Checkpoint 2; 3565 Readiness assessment of participants' readiness to transition to new Settlement Timetable; 3566 Confirm M16 Date; 3567 Raise fast track change to ISD (November publish); 3629 Launch Readiness Assessment survey; 3630 PPs submit survey responses; 3631 Analyse survey responses; 3632 Conduct deep-dive interviews (sample of PPs); 3633 Produce Readiness Assessment Reports (Overall Report & Individual Participant Reports); 3679 M16 milestone checkpoint; 3680 M16 milestone checkpoint - date approval

Changed:

| ID | Task | Start | Finish | Duration | Complete | Total float | Other |
| --- | --- | --- | --- | --- | --- | --- | --- |
| 1 | **PROGRAMME PLAN.** |  |  |  | 69% → 93% |  |  |
| 3 | **PROGRAMME MANAGEMENT** |  |  |  | 57% → 87% |  |  |
| 4 | **Programme Management** |  |  |  | 56% → 87% |  |  |
| 5 | Sprint-based prioritisation planning and execution |  |  |  | 56% → 87% |  |  |
| 6 | Programme governance secretariat |  |  |  | 56% → 87% |  |  |
| 7 | RAID management and reporting |  |  |  | 56% → 87% |  |  |
| 8 | Tracking against Programme outcomes and KPIs |  |  |  | 56% → 87% |  |  |
| 9 | Change control and reporting |  |  |  | 56% → 87% |  |  |
| 10 | Ongoing identification of lessons learned relating to the PMO and implementation of improvements |  |  |  | 56% → 87% |  |  |
| 11 | **Programme Internal Assurance Reviews** |  |  |  | 56% → 87% |  |  |
| 12 | Programme Internal Assurance Reviews |  |  |  | 56% → 87% |  |  |
| 13 | **Engagement with PPs** |  |  |  | 56% → 87% |  |  |
| 14 | Ongoing PP liaison activities |  |  |  | 56% → 87% |  |  |
| 15 | Milestone and Control Point objective setting |  |  |  | 56% → 87% |  |  |
| 16 | Reporting |  |  |  | 56% → 87% |  |  |
| 17 | **PP Engagement Events** |  |  |  | 56% → 87% |  |  |
| 18 | Bilateral meetings |  |  |  | 56% → 87% |  |  |
| 19 | Monthly webinars |  |  |  | 56% → 87% |  |  |
| 20 | Open days |  |  |  | 56% → 87% |  |  |
| 21 | **PP Communications** |  |  |  | 56% → 87% |  |  |
| 22 | The Clock updates (weekly) |  |  |  | 56% → 87% |  | constraint none → finish no earlier than 2026-12-30 |
| 23 | Maintain and update content on public-facing Portal (and ongoing feedback reviews to identify and implement Portal improvements) |  |  |  | 56% → 87% |  |  |
| 24 | **Code Change Support / Other Programme Alignment** |  |  |  | 56% → 87% |  |  |
| 25 | Support DCC/BEIS on SEC change |  |  |  | 56% → 87% |  |  |
| 26 | Support on Smart Meters Act changes |  |  |  | 56% → 87% |  |  |
| 27 | Support DCC/RECCo on CSS change |  |  |  | 56% → 87% |  |  |
| 28 | Support Elexon on BSC change |  |  |  | 56% → 87% |  |  |
| 29 | Support code change inside & outside CCIAG |  |  |  | 56% → 87% |  |  |
| 30 | Support code change inside & outside CCAG |  |  |  | 56% → 87% |  |  |
| 45 | **DESIGN, BUILD & TEST (PIT)** |  |  |  | 89% → 98% |  |  |
| 46 | **Design Baseline & Enduring PP Support** |  |  |  | 79% → 93% |  |  |
| 56 | **Establish Design Change Management Processes** |  |  |  | 54% → 86% |  |  |
| 61 | Maintain E2E MHHS Design (post-M5 design change management processes operational) |  |  |  | 52% → 85% |  |  |
| 187 | **PP Design, Build & Test (DBT)** |  | 2025-02-21 A |  | 96% → 100% | 739d → none |  |
| 291 | **SIT Participants DBT** |  | 2025-02-21 A |  | 89% → 100% | 739d → none |  |
| 326 | **All SIT Programme Participants PIT (SIT Functional)** |  | 2025-02-21 A |  | 79% → 100% | 739d → none |  |
| 378 | **SIT Programme Participants PIT (SIT Operational Theme 1, 2, 3 (Batch 2))** |  | 2025-01-31 A |  | 90% → 100% | 754d → none |  |
| 379 | **Test Approach & Plan** |  | 2024-11-21 A |  | 0% → 100% | 805d → none |  |
| 381 | SIT Operational Test approach and plan MHHS Review Completed | 2024-11-21 A | 2024-11-21 A |  | 0% → 100% | 805d → none |  |
| 382 | **Test Readiness Report** |  | 2024-10-22 A |  | 90% → 100% | 18d → none |  |
| 383 | Test readiness reporting |  | 2024-10-22 A |  | 90% → 100% | 18d → none |  |
| 384 | **Requirements to test Traceability Matrix (RTTM)** | 2024-11-01 A | 2024-11-29 A |  | 0% → 100% | 799d → none |  |
| 385 | SIT Operational PIT RTTM submitted to Programme for assurance | 2024-11-01 A | 2024-11-01 A |  | 0% → 100% | 799d → none |  |
| 386 | SIT Operational RTTM MHHS Review Completed | 2024-11-29 A | 2024-11-29 A |  | 0% → 100% | 799d → none |  |
| 387 | **Test Scenarios** | 2024-11-01 A | 2024-11-29 A |  | 0% → 100% | 16.1d → none |  |
| 388 | SIT Operational PIT test scenarios submitted to Programme for assurance | 2024-11-01 A | 2024-11-01 A |  | 0% → 100% | 16.1d → none |  |
| 389 | SIT Operational Test scenarios MHHS Review Completed | 2024-11-29 A | 2024-11-29 A |  | 0% → 100% | 799d → none |  |
| 390 | **PIT execution** |  | 2025-01-31 A |  | 90% → 100% | 754d → none |  |
| 391 | PIT Test Execution Progress Report |  | 2024-11-21 A |  | 90% → 100% | 792d → none |  |
| 392 | PIT Execution |  | 2024-11-29 A |  | 90% → 100% | 754d → none |  |
| 393 | SIT Operational Theme 1, 2, 3 (Batch 2) PIT Completion Report submitted to Programme for assurance | 2025-01-14 A | 2025-01-14 A |  | 0% → 100% | 754d → none |  |
| 394 | SIT Operational Theme 1, 2, 3 (Batch 2) PIT Completion Report MHHS Review Completed | 2025-01-31 A | 2025-01-31 A |  | 0% → 100% | 754d → none |  |
| 395 | **SIT Programme Participants PIT (SIT Operational Theme 3 (Batch 1))** |  | 2025-01-10 A |  | 0% → 100% | 769d → none |  |
| 399 | **Test Readiness Report** | 2024-10-04 A | 2024-10-22 A |  | 0% → 100% | 787d → none |  |
| 400 | Test readiness reporting | 2024-10-04 A | 2024-10-22 A |  | 0% → 100% | 787d → none |  |
| 407 | **PIT execution** |  | 2025-01-10 A |  | 0% → 100% | 769d → none |  |
| 408 | PIT Test Execution Progress Report | 2024-10-23 A | 2024-12-17 A |  | 0% → 100% | 787d → none |  |
| 409 | PIT Execution | 2024-11-04 A | 2024-12-26 A |  | 0% → 100% | 780d → none |  |
| 463 | **DBT Monitoring and Assurance** |  | 2026-01-20 → 2025-08-06 A (-167d) | 842d → 723d | 85% → 100% | 502d → none |  |
| 464 | **Planning and DBT Progress Monitoring of PPs** |  | 2025-06-30 A |  | 89% → 100% | 648d → none |  |
| 465 | Monitor Non-SIT PPs Planning and DBT1 progress (to inform confirmation of Qualification Testing Tranche participants milestones) |  | 2025-06-30 A |  | 89% → 100% | 648d → none |  |
| 466 | **Design Assurance** |  | 2025-08-06 A |  | 89% → 100% | 621d → none |  |
| 497 | **Non-SIT PPs design assurance** |  | 2025-08-06 A |  | 75% → 100% | 621d → none |  |
| 498 | Non-SIT PPs design assurance (risk-based sample) |  | 2025-08-06 A |  | 75% → 100% | 621d → none |  |
| 499 | **Test Assurance** |  | 2025-06-30 A |  | 87% → 100% | 648d → none |  |
| 500 | Non-SIT PPs test assurance |  | 2025-06-30 A |  | 87% → 100% | 648d → none |  |
| 507 | **SYSTEMS INTEGRATION TESTING (SIT)** |  |  |  | 77% → 99% |  |  |
| 508 | **SIT Preparation** |  | 2025-05-23 A |  | 99% → 100% | 674d → none |  |
| 589 | **SIT Stage-Specific Preparation** |  | 2025-05-23 A |  | 99% → 100% | 674d → none |  |
| 1156 | **SIT Operational Preparation** |  | 2025-05-23 A |  | 98% → 100% | 674d → none |  |

| ID | Task | Start | Finish | Duration | Complete | Total float | Other |
| --- | --- | --- | --- | --- | --- | --- | --- |
| 1325 | **SIT Operational Programme RTTM (Theme 1, 2 & 3 (Batch 2))** |  | 2025-05-23 A |  | 75% → 100% | 674d → none |  |
| 1328 | DIP Manager / Code Bodies / Full SRO to review |  | 2025-04-24 A |  | 90% → 100% | 694d → none |  |
| 1329 | Incorporate feedback |  | 2025-04-24 A |  | 26% → 100% | 695d → none |  |
| 1330 | DIP Manager / Code Bodies / SRO acceptance of (Theme 1, 2 & 3 (Batch 2)) Operational RTTM | 2025-04-25 A | 2025-04-25 A |  | 0% → 100% | 694d → none |  |
| 1331 | SIT Operational (Theme 1, 2 & 3 (Batch 2)) RTTM Complete | 2025-05-23 A | 2025-05-23 A |  | 0% → 100% | 674d → none |  |
| 1435 | Create test plans and suites in master project |  |  | 2d? → 2d |  |  |  |
| 1436 | Create area paths / iterations |  |  | 2d? → 2d |  |  |  |
| 1437 | Create IAM roles |  |  | 2d? → 2d |  |  |  |
| 1438 | Add users to roles |  |  | 1d? → 1d |  |  |  |
| 1439 | **Testing permissions** |  |  | 2d? → 2d |  |  |  |
| 1440 | Adding tests |  |  | 2d? → 2d |  |  |  |
| 1441 | Deleting tests |  |  | 2d? → 2d |  |  |  |
| 1442 | Adding tests to incorrect Cohort |  |  | 2d? → 2d |  |  |  |
| 1443 | Add / delete defects |  |  | 2d? → 2d |  |  |  |
| 1445 | Testing Permissions - Evidence attachment security |  |  | 10d? → 10d |  |  |  |
| 1452 | Update SIT Dashboards for Sprints 4.1 & 4.2 across all Cohorts |  |  | 1d? → 1d |  |  |  |
| 1471 | **ADO Changes - Review Stage** |  |  | 19d? → 19d |  |  |  |
| 1472 | Review implementation with SI LDP leads |  |  | 1d? → 1d |  |  |  |
| 1473 | Review implementation with SRO |  |  | 1d? → 1d |  |  |  |
| 1475 | SRO Review - ADO User Guide, Training Materials |  |  | 1d? → 1d |  |  |  |
| 1476 | LDP Review - Config doc |  |  | 1d? → 1d |  |  |  |
| 1477 | SRO Review - Config doc |  |  | 1d? → 1d |  |  |  |
| 1478 | SRO Sign-off of all changes |  |  | 1d? → 1d |  |  |  |
| 1480 | Final task rollout |  |  | 1d? → 1d |  |  |  |
| 1481 | ADO Training Drop-in Session ahead of Cycle 3 |  |  | 1d? → 1d |  |  |  |
| 1482 | **SIT Execution** |  | 2025-12-10 → 2025-09-19 A (-82d) | 553d? → 495d? | 65% → 100% | 531d → none |  |
| 1499 | **SIT** |  | 2025-09-19 A |  | 72% → 100% | 589d → none |  |
| 1500 | **SIT Functional Testing (MVC)** |  | 2025-09-19 A |  | 78% → 100% | 589d → none |  |
| 1539 | **SIT Functional Settlement Testing** |  |  |  | 62% → 100% |  |  |
| 1564 | **SIT Functional & Migration Regression Testing (code freeze)** |  | 2025-09-19 → 2025-09-12 A (-7d) | 60d? → 55d? | 3% → 100% | 589d → none |  |
| 1566 | Regression Execution |  | 2025-07-04 A |  | 40% → 100% | -97d → none |  |
| 1567 | Regression Sprint 1 | 2025-07-07 A | 2025-07-18 A |  | 0% → 100% | -97d → none |  |
| 1568 | Regression Sprint 2 | 2025-07-21 A | 2025-08-08 A |  | 0% → 100% | -97d → none |  |
| 1572 | Regression Sprint 3 | 2025-08-11 A | 2025-08-22 A |  | 0% → 100% | 589d → none |  |
| 1573 | Regression Sprint 4 | 2025-08-25 A | 2025-09-12 A |  | 0% → 100% | 589d → none |  |
| 1574 | **SIT Functional & Migration Overarching Exit Report** |  | 2025-07-17 A |  | 84% → 100% | 635d → none |  |
| 1580 | SRO/Code Bodies Review SI SIT Funcational & Migration Overarching Exit Report |  | 2025-07-02 A |  | 50% → 100% | 636d → none |  |
| 1581 | SITWG Review status of SI SIT Functional & Migration Overarching Exit Report | 2025-07-03 A | 2025-07-03 A |  | 0% → 100% | 635d → none |  |
| 1582 | SI SIT Functional & Migration Overarching Exit Report Industry Review | 2025-07-04 A | 2025-07-17 A |  | 0% → 100% | 635d → none |  |
| 1583 | **SIT Settlement and Regression Test Exit Report** | 2025-07-07 A | 2025-09-19 A |  | 0% → 100% | 30d → none |  |
| 1584 | Programme drafts Settlement and Regression Pathway 2 PP Exit Reports | 2025-07-07 A | 2025-07-23 A |  | 0% → 100% | 616d → none |  |
| 1585 | SRO Review Settlement and Regression Pathway 2 PP Exit Reports | 2025-07-17 A | 2025-07-23 A |  | 0% → 100% | 631d → none |  |
| 1586 | Pathway 2 PPs review and sign off Regression Exit Declaration | 2025-07-21 A | 2025-07-28 A |  | 0% → 100% | 606d → none |  |
| 1587 | Programme drafts Settlement and Regression Pathway 3 PP Exit Reports | 2025-07-28 A | 2025-08-13 A |  | 0% → 100% | 605d → none |  |
| 1588 | SRO Review Settlement and Regression Pathway 3 PP Exit Reports | 2025-08-07 A | 2025-08-13 A |  | 0% → 100% | 616d → none |  |
| 1589 | Pathway 3 PPs review and sign off Exit Reports | 2025-08-11 A | 2025-08-15 A |  | 0% → 100% | 595d → none |  |
| 1590 | Programme drafts Settlement and Regression Pathway 4, 5 & 6 PP Exit Reports | 2025-08-18 A | 2025-09-19 A |  | 0% → 100% | 589d → none |  |
| 1591 | Programme drafts SI SIT Settlement and Regression Addendum | 2025-07-21 A | 2025-08-08 A |  | 0% → 100% | 20d → none |  |
| 1592 | SRO/Code Bodies Review SI SIT Settlement and Regression Addendum | 2025-08-04 A | 2025-08-08 A |  | 0% → 100% | 619d → none |  |
| 1593 | SI SIT Migration Testing Test Exit Report Approved | 2025-08-15 A | 2025-08-15 A |  | 0% → 100% | 16d → none |  |
| 1594 | SI SIT Functional Testing Test Exit Report Approved | 2025-08-15 A | 2025-08-15 A |  | 0% → 100% | 15d → none |  |
| 1595 | eSITAG Approves SI SIT Functional & Migration (Post-Regression) Overarching Test Exit Report | 2025-08-15 A | 2025-08-15 A |  | 0% → 100% | 615d → none |  |
| 1596 | **SIT Migration Testing** |  | 2025-08-22 → 2025-04-25 A (-119d) | 380d? → 295d? | 71% → 100% | 609d → none |  |
| 1598 | **SIT Migration Testing Execution** |  | 2025-08-22 → 2025-04-25 A (-119d) | 380d? → 295d? | 71% → 100% | 609d → none |  |
| 1623 | **SIT Non-Functional Testing (all SIT PPs)** |  | 2025-08-06 A |  | 68% → 100% | 622d → none |  |
| 1629 | **SIT Non-Functional Testing Test Exit Report (all SIT PPs)** |  | 2025-08-06 A |  | 43% → 100% | 622d → none |  |
| 1632 | PPs review Exit Report and Sign PP Exit Declaration |  | 2025-07-11 A |  | 27% → 100% | 639d → none |  |
| 1633 | Programme drafts SI SIT Non-Functional Overarching Exit Report |  | 2025-07-18 A |  | 19% → 100% | 25d → none |  |
| 1634 | Draft of SI SIT Non-Functional Overarching Exit Report available for SRO review | 2025-07-07 A | 2025-07-11 A |  | 0% → 100% | 634d → none |  |
| 1635 | SRO / Code Bodies / DIP Manager formal review SI SIT Non-Functional Overarching Exit Report | 2025-07-14 A | 2025-07-18 A |  | 0% → 100% | 634d → none |  |
| 1636 | eSITWG Review status of SI SIT Non-Functional Overarching Exit Report | 2025-07-18 A | 2025-07-18 A |  | 0% → 100% | 25d → none | was named SITWG Review status of SI SIT Non-Functional Overarching Exit Report |
| 1637 | SI SIT Non-Functional Overarching Exit Report published to PPs for industry review | 2025-07-18 A | 2025-07-18 A |  | 0% → 100% | 25d → none |  |
| 1638 | SI SIT Non-Functional Overarching Exit Report industry review | 2025-07-21 A | 2025-08-01 A |  | 0% → 100% | 25d → none |  |
| 1639 | SIT Non-Functional Testing Test Exit Report (all SIT PPs) Approved | 2025-08-06 A | 2025-08-06 A |  | 0% → 100% | 23d → none |  |
| 1640 | eSITAG Approves SI SIT Non-Functional Overarching Test Exit Report | 2025-08-06 A | 2025-08-06 A |  | 0% → 100% | 23d → none | was named SITAG Approves SI SIT Non-Functional Overarching Test Exit Report |
| 1641 | **SIT Operational Testing (all SIT PPs)** |  | 2025-08-29 A |  | 60% → 100% | 604d → none |  |
| 1645 | **SIT B Testing** |  | 2025-07-04 A |  | 89% → 100% | 644d → none |  |
| 1648 | SIT Operational Testing Execution Theme 2 |  | 2025-07-04 A |  | 90% → 100% | 644d → none |  |
| 1649 | SIT Operational Testing Execution Theme 3 Batch 2 |  | 2025-07-04 A |  | 35% → 100% | 644d → none |  |
| 1654 | SIT Operational Testing End (all SIT PPs) (incl. confirmation that PPs have submitted their Test Completion Reports to Programme for assurance) | 2025-07-04 A | 2025-07-04 A |  | 0% → 100% | 644d → none |  |

| ID | Task | Start | Finish | Duration | Complete | Total float | Predecessors | Other |
| --- | --- | --- | --- | --- | --- | --- | --- | --- |
| 1655 | **SIT Operational Testing Test Exit Report (all SIT PPs)** |  | 2025-08-29 A | 50d? → 50d | 7% → 100% | 604d → none |  |  |
| 1656 | Programme drafts Pathway 2 PP Exit Report (when Participant completes Operational testing) | 2025-06-30 A | 2025-07-18 A |  | 0% → 100% | 604d → none |  |  |
| 1657 | All Pathway 2 Operational Exit Reports and Exit Declarations shared with PPs | 2025-07-21 A | 2025-07-21 A |  | 0% → 100% | 633d → none |  |  |
| 1658 | Pathway 2 PPs have reviewed Exit Report and signed Exit Declaration | 2025-07-21 A | 2025-07-25 A |  | 0% → 100% | 629d → none |  |  |
| 1659 | Programme drafts Pathway 3 PP Exit Report (when Participant completes Operational testing) | 2025-07-21 A | 2025-08-08 A |  | 0% → 100% | 604d → none |  |  |
| 1660 | All Pathway 3 Operational Exit Reports and Exit Declarations shared with PPs | 2025-08-08 A | 2025-08-08 A |  | 0% → 100% | 613d → none |  |  |
| 1661 | Pathway 3 PPs have reviewed Exit Report and signed Exit Declaration | 2025-08-11 A | 2025-08-15 A |  | 0% → 100% | 613d → none |  |  |
| 1665 | Programme drafts Pathway 5 & 6 PP Exit Report (when Participant completes Operational testing) | 2025-08-11 A | 2025-08-29 A |  | 0% → 100% | 604d → none |  | was named Programme drafts Pathway 4, 5 & 6 PP Exit Report (when Participant completes Operational testing) |
| 1666 | Programme drafts SI SIT Operational Overarching Exit Report |  | 2025-08-01 A |  | 23% → 100% | 621d → none |  |  |
| 1667 | SRO/Code Bodies/DIP Manager Review SI SIT Operational Overarching Exit Report | 2025-07-28 A | 2025-08-01 A |  | 0% → 100% | 624d → none |  |  |
| 1668 | eSITWG Review SI SIT Operational Overarching Exit Report | 2025-08-01 A | 2025-08-01 A |  | 0% → 100% | 614d → none |  |  |
| 1669 | SI SIT Operational Overarching Exit Report industry review | 2025-08-04 → 2025-08-05 A (+1d) | 2025-08-15 → 2025-08-12 A (-3d) | 10d → 6d | 0% → 100% | 614d → none |  |  |
| 1670 | SIT Operational Testing Test Exit Report (all SIT PPs) Approved | 2025-08-15 A | 2025-08-15 A |  | 0% → 100% | 614d → none |  |  |
| 1671 | eSITAG Approves SI SIT Operational Testing Test Exit Report | 2025-08-15 A | 2025-08-15 A |  | 0% → 100% | 614d → none |  |  |
| 1672 | SIT Complete (SIT Test Exit Report Approved) | 2025-08-22 A | 2025-08-22 A |  | 0% → 100% | 10d → none | 1498, 1639, SIT Migration Testing Test Exit Report Approved, 1640, 1593, 1594 → 1498, 1639, 1640, 1593, 1594 |  |
| 1673 | **UIT Environment Preparation** | 2022-10-31 A → 2022-11-16 A (+16d) |  | 1000d → 988d | 50% → 98% |  |  |  |
| 1710 | **Environments (UIT)** | 2022-10-31 A → 2022-11-16 A (+16d) | 2025-06-06 → 2024-09-30 A (-249d) | 680d → 489d | 51% → 100% | 664d → none |  |  |
| 1724 | **Onboarding and Test Data (Sandbox UIT)** | 2024-08-26 A → 2025-06-02 A (+280d) |  | 525d → 325d | 2% → 88% |  |  |  |
| 1725 | LDSO Onboarding and Test Data Creation and Support |  | 2026-01-22 A |  | 7% → 100% | 500d → none |  |  |
| 1726 | Supplier & Agent Onboarding and Test Data Creation and Support | 2025-09-01 A |  |  | 0% → 80% |  |  |  |
| 1727 | **Sandbox Execution** |  |  |  | 2% → 89% |  |  |  |
| 1728 | **SIT PPs Early Sandbox Testing Execution (SIT-A)** | 2025-08-08 A | 2025-11-13 → 2025-10-24 A (-20d) | 70d → 56d | 0% → 100% | 550d → none |  | baseline start 2025-07-21 → 2025-08-08 |
| 1729 | SIT PPs E2E Sandbox Testing Start | 2025-08-08 A | 2025-08-08 A |  | 0% → 100% | 619d → none | UIT E2E Sandbox Preparation CompleteFS+5d, 1568 → 1568 | baseline start 2025-07-21 → 2025-08-08; baseline finish 2025-07-21 → 2025-08-08 |
| 1730 | SIT PPs E2E Sandbox Testing Execution | 2025-08-08 A | 2025-11-13 → 2025-10-24 A (-20d) | 70d → 56d | 0% → 100% | 550d → none |  | baseline start 2025-07-21 → 2025-08-08 |
| 1731 | SIT PPs E2E Sandbox Testing End | 2025-11-13 → 2025-10-24 A (-20d) | 2025-11-13 → 2025-10-24 A (-20d) |  | 0% → 100% | 550d → none |  |  |
| 1732 | **Sandbox Testing Execution (UIT) - LDSO Participants** |  | 2026-01-22 A |  | 7% → 100% | 500d → none |  | baseline start 2025-02-07 → 2025-05-26; baseline finish 2026-04-24 → 2026-01-22 |
| 1733 | UIT E2E Sandbox Preparation Complete |  |  |  |  |  |  | baseline start 2025-01-31 → 2025-05-26; baseline finish 2025-01-31 → 2025-05-26 |
| 1734 | Sandbox Testing Start (UIT) - LDSO Participants |  |  |  |  |  | UIT E2E Sandbox Preparation Complete, 1733 → 1733 |  |
| 1735 | Sandbox Testing Execution (UIT) - LDSO Participants |  | 2026-01-22 A |  | 7% → 100% | 500d → none |  |  |
| 1736 | Sandbox Testing End (UIT) - LDSO Participants | 2026-01-22 A | 2026-01-22 A |  | 0% → 100% | 500d → none |  |  |
| 1737 | **Sandbox Testing Execution (UIT) - Supplier & Agent Participants** | 2025-08-25 → 2025-09-01 A (+7d) |  | 265d → 260d | 0% → 80% |  |  | baseline start 2025-02-07 → 2025-09-01; baseline finish 2026-04-24 → 2026-08-28 |
| 1738 | UIT E2E Sandbox Preparation Complete - Supplier and Agent | 2025-08-25 → 2025-09-01 A (+7d) | 2025-08-25 → 2025-09-01 A (+7d) |  | 0% → 100% | 609d → none |  | constraint start no earlier than 2025-08-25 → finish no earlier than 2025-09-01; baseline start none → 2025-09-01; baseline finish none → 2025-09-01 |
| 1739 | Sandbox Testing Start (UIT) - Supplier & Agent Participants | 2025-09-01 A | 2025-09-01 A |  | 0% → 100% | 603d → none | 1672, 2634FS+5d, UIT E2E Sandbox Preparation Complete, 1738 → 1672, 2634FS+5d, 1738 |  |
| 1740 | Sandbox Testing Execution (UIT) - Supplier & Agent Participants | 2025-09-01 A |  |  | 0% → 80% |  |  |  |
| 1742 | **System Integration Testing - Tier 1 Milestones** |  | 2025-12-24 A |  | 99% → 100% | 521d → none |  |  |
| 1769 | **M10 Acceptance Criteria** |  | 2025-10-10 A |  | 0% → 100% | 574d → none |  |  |
| 1770 | End of SIT MVC testing | 2025-08-22 A | 2025-08-22 A |  | 0% → 100% | 609d → none | 1672 → none |  |
| 1771 | IPA M10 Assurance Report developed and agreed | 2025-09-19 A | 2025-09-19 A |  | 0% → 100% | 589d → none |  |  |
| 1773 | A minimum of 1 supplier & required contracted agents are qualified and ready to operate under new MHHS arrangements | 2025-09-12 A | 2025-09-12 A |  | 0% → 100% | 594d → none |  |  |
| 1774 | All LDSOs qualified | 2025-09-10 A | 2025-09-10 A |  | 0% → 100% | 596d → none |  |  |
| 1775 | All pre-migration data cleanse activities complete | 2025-08-13 → 2025-09-22 A (+40d) | 2025-08-13 → 2025-09-22 A (+40d) |  | 0% → 100% | 616d → none |  | constraint finish no earlier than 2025-08-13 → start no earlier than 2025-09-22; baseline start 2025-08-13 → 2025-09-22; baseline finish 2025-08-13 → 2025-09-22 |
| 1776 | All data migration activities set out in the cutover plan complete | 2025-09-24 A | 2025-09-24 A |  | 0% → 100% | 586d → none |  |  |
| 1777 | ISD fully populated by Elexon | 2025-09-22 A | 2025-09-22 A |  | 0% → 100% | 588d → none |  |  |
| 1779 | Migration Schedule approved | 2025-08-19 A | 2025-08-19 A |  | 0% → 100% | 612d → none |  |  |
| 1783 | MCC tested and ready to operate | 2025-09-19 A | 2025-09-19 A |  | 0% → 100% | 589d → none |  |  |
| 1784 | Service Delivery Operating Model in place | 2025-09-19 A | 2025-09-19 A |  | 0% → 100% | 589d → none |  |  |
| 1785 | Service Delivery Operating Model in place (Self-Certification) | 2025-07-03 A | 2025-07-03 A |  | 0% → 100% | 645d → none |  |  |
| 1787 | Early Life Support Model arrangements in place and operational | 2025-09-12 A | 2025-09-12 A |  | 0% → 100% | 594d → none |  |  |
| 1788 | Early Life Support Model arrangements in place and operational (Self-Certification) | 2025-09-12 A | 2025-09-12 A |  | 0% → 100% | 594d → none |  |  |
| 1790 | Central Programme Party Cutover Plans in place | 2025-07-15 A | 2025-07-15 A |  | 0% → 100% | 637d → none |  |  |
| 1791 | Production environment in place for LDSOs and Central Parties | 2025-09-22 A | 2025-09-22 A |  | 0% → 100% | 588d → none |  |  |
| 1792 | Service activation complete to DIP Production environment for Central Parties and LDSOs | 2025-10-10 A | 2025-10-10 A |  | 0% → 100% | 574d → none |  |  |
| 1793 | Cutover Plan executed | 2025-09-23 A | 2025-09-23 A |  | 0% → 100% | 587d → none |  |  |
| 1794 | M10 Risk Assessment undertaken | 2025-09-03 A | 2025-09-03 A |  | 0% → 100% | 601d → none |  |  |
| 1795 | Roles and responsibilities post-M10 agreed and accepted | 2025-09-19 A | 2025-09-19 A |  | 0% → 100% | 589d → none |  |  |
| 1796 | M10 Work off plan agreed (if required) | 2025-09-19 A | 2025-09-19 A |  | 0% → 100% | 589d → none |  |  |
| 1797 | Qualification Operating Model in place and operational for all post-M10 activities | 2025-09-19 A | 2025-09-19 A |  | 0% → 100% | 589d → none |  |  |
| 1798 | Programme Governance updated to reflect required changes to support Programme delivery post-M10. | 2025-07-01 → 2025-09-03 A (+64d) | 2025-07-01 → 2025-09-03 A (+64d) |  | 0% → 100% | 647d → none |  | constraint finish no earlier than 2025-07-01 → start no earlier than 2025-09-03; baseline start 2025-07-01 → 2025-09-03; baseline finish 2025-07-01 → 2025-09-03 |
| 1799 | All Suppliers and Agents have made the necessary changes to support losing an MPAN via the Forward Migration Process and gaining an MPAN via the Reverse Migration Process. | 2025-09-19 A | 2025-09-19 A |  | 0% → 100% | 589d → none |  |  |
| 1800 | Performance Assurance measures are understood and in place to maintain BAU performance during the Migration period. | 2025-09-12 A | 2025-09-12 A |  | 0% → 100% | 594d → none |  |  |
| 1801 | Programme monitoring, assurance and escalation process for beyond M10 is in place and operational | 2025-09-12 A | 2025-09-12 A |  | 0% → 100% | 594d → none |  |  |
| 1802 | Central systems ready for migrating MPANs (M10) | 2025-09-22 A | 2025-09-22 A |  | 0% → 100% | 7d → none | 1672FS+18d, 3224, 3209, 3244, 3180, 3187, 2307 → 1672, 3180, 3187, 2307, 3224 |  |
| 1803 | M10 Acceptance Criteria Ratification | 2025-09-24 A | 2025-09-24 A |  | 0% → 100% | 586d → none |  |  |
| 1804 | Central systems ready for migrating MPANs (M10*) - Late Exit | 2025-12-24 A | 2025-12-24 A |  | 0% → 100% | 521d → none |  |  |
| 1815 | **NON SIT LDSO QUALIFICATION** |  | 2025-08-22 A |  | 98% → 100% | 609d → none |  |  |
| 1875 | **Pre-Integration Testing** |  | 2025-01-31 A |  | 97% → 100% | 754d → none |  |  |
| 1880 | PIT Execution (Non-Functional and Operational) |  | 2025-01-31 A |  | 85% → 100% | 754d → none |  |  |
| 1882 | Non-SIT LDSO Participants have submitted non-functional PIT Test Completion Report | 2025-01-31 A | 2025-01-31 A |  | 0% → 100% | 754d → none |  |  |
| 1910 | **Test Window** |  | 2025-08-22 A |  | 94% → 100% | 609d → none |  |  |
| 1923 | Potential for non-SIT LDSO QT Regression for Qualification |  | 2025-08-22 A |  | 31% → 100% | 609d → none |  |  |

| ID | Task | Start | Finish | Duration | Complete | Total float | Predecessors | Other |
| --- | --- | --- | --- | --- | --- | --- | --- | --- |
| 1927 | **Non-SIT LDSO Qualification Closure** |  | 2025-06-27 A |  | 94% → 100% | 649d → none |  |  |
| 1930 | Non-SIT LDSO Qualification Closure Down |  | 2025-06-27 A |  | 50% → 100% | 649d → none |  |  |
| 1931 | **HELIX / ELEXON M10 READINESS** | 2024-04-02 A → 2022-10-31 (-519d) | 2027-07-30 → 2026-01-13 A (-563d) | 869d? → 837d? | 53% → 100% | 104d → none |  |  |
| 1932 | **Service Management - M10 Readiness** |  | 2027-07-30 → 2025-09-24 A (-674d) | 630d → 147d | 31% → 100% | 104d → none |  |  |
| 1933 | **Service Model Design (Cross Party Service Desk)** |  | 2025-08-13 → 2025-09-05 A (+23d) | 118d → 135d | 86% → 100% | 616d → none |  |  |
| 1949 | **Service Documentation** |  | 2025-08-13 A |  | 79% → 100% | 616d → none |  |  |
| 1954 | Service User LLSD Updates Post Consultation |  |  |  |  |  |  | baseline start none → 2025-05-19; baseline finish none → 2025-06-04 |
| 1955 | Service User LLSD Version 1.2 (ORT) (TORWG Paper Day) |  |  |  |  |  |  | baseline start none → 2025-06-04; baseline finish none → 2025-06-04 |
| 1956 | CPSD Scenarios and Runbook |  |  |  |  |  |  | baseline start none → 2025-04-29; baseline finish none → 2025-05-23 |
| 1957 | CPSD Scenarios and Runbook Shared with MHHS Team for Review |  |  |  |  |  |  | baseline start none → 2025-05-23; baseline finish none → 2025-05-23 |
| 1958 | CPSD Scenarios and Runbook Review Window |  |  |  |  |  |  | baseline start none → 2025-05-26; baseline finish none → 2025-06-04 |
| 1959 | CPSD Scenarios and Runbook Released for TORWG (Paper Day) |  |  |  |  |  |  | baseline start none → 2025-06-04; baseline finish none → 2025-06-04 |
| 1960 | Parent/Child Industry Engagement Session |  |  |  |  |  |  | baseline start none → 2025-06-06; baseline finish none → 2025-06-06 |
| 1961 | CPSD Runbook Completed |  |  |  |  |  |  | baseline start none → 2025-06-11; baseline finish none → 2025-06-11 |
| 1962 | **Service Documentation V2** | 2025-07-14 A | 2025-08-13 A |  | 0% → 100% | 616d → none |  | baseline start none → 2025-07-14; baseline finish none → 2025-08-13 |
| 1963 | Post-ORT Operations Manual and LLSD Updates | 2025-07-14 A | 2025-07-16 A |  | 0% → 100% | 616d → none |  | baseline finish 2025-07-25 → 2025-07-16 |
| 1964 | M10 Operations Manual Version 2.0 & LLSD Issued for Consultation | 2025-07-16 A | 2025-07-16 A |  | 0% → 100% | 616d → none |  | baseline start 2025-07-25 → 2025-07-16; baseline finish 2025-07-25 → 2025-07-16 |
| 1965 | Operations Manual and LLSD v2 Consultation | 2025-07-17 A | 2025-07-30 A |  | 0% → 100% | 616d → none |  | baseline start none → 2025-07-17; baseline finish none → 2025-07-30 |
| 1966 | Operations Manual and LLSD v2 Consultation Completed | 2025-07-30 A | 2025-07-30 A |  | 0% → 100% | 616d → none |  | baseline start none → 2025-07-30; baseline finish none → 2025-07-30 |
| 1967 | Consultation Feedback Implemented Operations Manual and LLSD v2 | 2025-07-31 A | 2025-08-06 A |  | 0% → 100% | 616d → none |  | baseline start none → 2025-07-31; baseline finish none → 2025-08-06 |
| 1968 | Operations Manual and LLSD v2 Feedback Implemented | 2025-08-06 A | 2025-08-06 A |  | 0% → 100% | 616d → none |  | baseline start none → 2025-08-06; baseline finish none → 2025-08-06 |
| 1969 | TORWG Paper Day | 2025-08-06 A | 2025-08-06 A |  | 0% → 100% | 616d → none |  | baseline start none → 2025-08-06; baseline finish none → 2025-08-06 |
| 1970 | TORWG Operations Manual and LLSD v2 Approval | 2025-08-13 A | 2025-08-13 A |  | 0% → 100% | 616d → none |  | baseline start none → 2025-08-13; baseline finish none → 2025-08-13 |
| 1971 | Operations Manual and LLSD v2 Approved and Completed | 2025-08-13 A | 2025-08-13 A |  | 0% → 100% | 616d → none |  | baseline start none → 2025-08-13; baseline finish none → 2025-08-13 |
| 1985 | **Operational Readiness Testing** |  | 2025-08-29 → 2025-08-12 A (-17d) | 130d → 116d | 66% → 100% | 571d → none |  |  |
| 2017 | **ORT Execution** |  | 2025-07-11 A |  | 55% → 100% | 592d → none |  |  |
| 2018 | ORT Execution |  | 2025-07-11 A |  | 55% → 100% | 592d → none |  |  |
| 2019 | ORT Execution Completed | 2025-07-11 A | 2025-07-11 A |  | 0% → 100% | 592d → none |  |  |
| 2020 | **ORT Exit** | 2025-07-14 A | 2025-07-31 A |  | 0% → 100% | 592d → none |  |  |
| 2021 | ORT Wrap Up | 2025-07-14 A | 2025-07-18 A |  | 0% → 100% | 598d → none |  |  |
| 2022 | ORT Exit Report | 2025-07-14 A | 2025-07-25 A |  | 0% → 100% | 592d → none |  |  |
| 2023 | ORT Exit Report Shared with Participants | 2025-07-25 A | 2025-07-25 A |  | 0% → 100% | 592d → none |  |  |
| 2024 | ORT eSITWG Exit Report Endorsement | 2025-07-31 A | 2025-07-31 A |  | 0% → 100% | 592d → none |  | was named ORT eSITAG Exit Report Endorsement |
| 2025 | **Codification of Service** |  | 2025-08-29 → 2025-08-12 A (-17d) | 81d → 67d | 33% → 100% | 537d → none |  |  |
| 2029 | **Service Go-Live** | 2025-07-31 A | 2027-07-30 → 2025-09-15 A (-683d) | 522d → 32d | 0% → 100% | 104d → none |  |  |
| 2030 | Service Management Ready (inc. Partners) | 2025-07-31 A | 2025-07-31 A |  | 0% → 100% | 590d → none | Service Management Go/No Go Decision → none | was named Helix Service Management Live |
| 2031 | Helix Service Management Live for LDSO DIP Onboarding | 2025-08-04 A | 2025-08-04 A |  | 0% → 100% | 590d → none | Registration of LDSOs into ServiceNow → 1979 |  |
| 2032 | Helix Service Management Live for MHHS Enduring Arrangements | 2025-09-01 → 2025-09-15 A (+14d) | 2027-07-30 → 2025-09-15 A (-683d) | 500d → 0d | 0% → 100% | 104d → none |  | constraint start no earlier than 2025-09-01 → start no earlier than 2025-09-15; baseline start 2025-09-01 → 2025-09-15; baseline finish 2027-07-30 → 2025-09-15 |
| 2037 | **Business Readiness (inc DIP)** | 2024-04-02 A → 2025-04-07 A (+370d) | 2025-12-31 → 2025-10-17 A (-75d) | 457d? → 140d? | 49% → 100% | 516d → none |  |  |
| 2039 | Elexon Leading Triage |  | 2025-08-29 → 2025-09-01 A (+3d) | 55d → 56d | 20% → 100% | 104d → none |  | baseline finish 2025-08-29 → 2025-09-01 |
| 2040 | MHHS Transition (Knowledge Transfer) |  | 2025-08-01 A |  | 56% → 100% | 624d → none |  |  |
| 2041 | Artefact Handshake with MHHS | 2025-08-01 → 2025-09-01 A (+31d) | 2025-08-01 → 2025-09-01 A (+31d) |  | 0% → 100% | 624d → none |  | constraint none → finish no earlier than 2025-09-01 |
| 2042 | Operational Control Centre (OCC) Development |  | 2025-08-01 A |  | 72% → 100% | -83d → none |  |  |
| 2043 | Operational Control Centre (OCC) Live (Service and ULT Triage) | 2025-08-04 A | 2025-08-04 A |  | 0% → 100% | -83d → none |  |  |
| 2044 | Operational Control Centre (OCC) Live | 2025-08-29 A | 2025-08-29 A |  | 0% → 100% | 604d → none |  |  |
| 2045 | **DIP Guidance Notes** |  | 2025-07-18 A |  | 75% → 100% | 634d → none |  |  |
| 2046 | GN/LWI creation & publication |  | 2025-07-18 A |  | 75% → 100% | 634d → none |  |  |
| 2048 | Tranche 2 GN/LWI created & published | 2025-07-04 A | 2025-07-04 A |  | 0% → 100% | 611d → none |  |  |
| 2049 | Tranche 3 GN/LWI created & published | 2025-07-18 A | 2025-07-18 A |  | 0% → 100% | 601d → none |  |  |
| 2050 | DIP Reporting (M11) |  | 2025-08-08 → 2025-10-17 A (+70d) | 65d → 115d | 28% → 100% | 619d → none |  | baseline finish 2025-08-08 → 2025-10-17 |
| 2051 | Functional Training Execution |  | 2025-08-29 → 2025-09-12 A (+14d) | 85d → 95d | 44% → 100% | 604d → none |  |  |
| 2067 | **Operational Readiness E2E Testing** |  |  |  | 34% → 100% |  |  |  |
| 2068 | Phase 1 Test Execution (Service Activation and Participant Management) |  | 2025-07-18 → 2025-08-13 A (+26d) | 48d → 66d | 37% → 100% | 633d → none |  |  |
| 2069 | Phase 2 Test Execution (S&I) |  | 2025-07-11 → 2025-08-20 A (+40d) | 17d → 45d | 56% → 100% | 638d → none |  | baseline start 2025-06-10 → 2025-06-11; baseline finish 2025-07-18 → 2025-07-11 |
| 2070 | Phase 3 Test Execution (Assurance & mop-up) | 2025-07-02 → 2025-07-21 A (+19d) | 2025-07-18 → 2025-08-22 A (+35d) | 13d → 25d | 0% → 100% | 633d → none |  | constraint start no earlier than 2025-07-02 → start no earlier than 2025-07-21 |
| 2071 | E2E Operational Testing Completed | 2025-08-08 → 2025-09-05 A (+28d) | 2025-08-08 → 2025-09-05 A (+28d) | 1d → 0d | 0% → 100% | 619d → none |  | constraint finish no earlier than 2025-08-08 → finish no earlier than 2025-09-05; baseline start 2025-08-08 → 2025-07-18; baseline finish 2025-08-08 → 2025-07-18 |
| 2072 | **Service Activation Readiness** |  | 2025-12-31 → 2026-01-13 A (+13d) | 457d? → 466d? | 49% → 100% | 516d → none |  |  |
| 2073 | **Phase 1 - Preparation** |  | 2025-08-29 → 2025-09-05 A (+7d) | 369d? → 374d? | 85% → 100% | 604d → none |  |  |
| 2093 | **Operational Training for Service Activation** |  | 2025-08-29 → 2025-08-25 A (-4d) | 77d → 73d | 43% → 100% | 604d → none |  |  |
| 2094 | Training Execution [Placeholder] |  | 2025-08-29 → 2025-08-25 A (-4d) | 77d → 73d | 43% → 100% | 604d → none |  |  |
| 2095 | Service Activation Training Completed | 2025-08-29 → 2025-08-25 A (-4d) | 2025-08-29 → 2025-08-25 A (-4d) |  | 0% → 100% | 604d → none |  |  |
| 2096 | **Service Activation Readiness** | 2025-08-04 A | 2025-08-12 A |  | 0% → 100% | -89d → none |  |  |
| 2097 | Dress Rehearsal 1 | 2025-08-04 A | 2025-08-05 A |  | 0% → 100% | -89d → none |  |  |
| 2098 | Dress Rehearsal 1 Complete | 2025-08-05 A | 2025-08-05 A |  | 0% → 100% | -89d → none |  |  |
| 2099 | Dress Rehearsal 2 | 2025-08-11 A | 2025-08-12 A |  | 0% → 100% | -89d → none |  |  |
| 2100 | Dress Rehearsal 2 Complete | 2025-08-12 A | 2025-08-12 A |  | 0% → 100% | -89d → none |  |  |
| 2101 | **Service Activation Go / No Go** | 2025-08-22 A | 2025-08-22 A |  | 0% → 100% | -96d → none |  |  |
| 2102 | **Final Service Activation Go/No Go Decision** | 2025-08-22 A | 2025-08-22 A |  | 0% → 100% | -96d → none |  |  |
| 2103 | DIP Team Ready | 2025-08-22 A | 2025-08-22 A |  | 0% → 100% | 609d → none |  |  |
| 2104 | DIP Technical Onboarding Processes Completed | 2025-08-22 A | 2025-08-22 A |  | 0% → 100% | -96d → none |  |  |

| ID | Task | Start | Finish | Duration | Complete | Total float | Predecessors | Other |
| --- | --- | --- | --- | --- | --- | --- | --- | --- |
| 2105 | PM Team Ready | 2025-08-22 A | 2025-08-22 A |  | 0% → 100% | -96d → none |  |  |
| 2106 | Operational Support Ready (Ops Control Centre, Account Managers) | 2025-08-22 A | 2025-08-22 A |  | 0% → 100% | -96d → none |  |  |
| 2107 | Service Management Activity Completed (Resolver Groups) | 2025-08-22 A | 2025-08-22 A |  | 0% → 100% | -96d → none |  |  |
| 2108 | Process 1.1.1 ISD and Related LWIs Completed | 2025-08-22 A | 2025-08-22 A |  | 0% → 100% | -96d → none |  |  |
| 2109 | **SOLR Consultation** |  | 2025-08-26 → 2025-09-05 A (+10d) | 99d → 107d? | 67% → 100% | 607d → none |  |  |
| 2112 | **SOLR consultation** | 2025-04-10 A |  | 81d → 81d? | 0% → 100% |  |  |  |
| 2114 | LDSO Workshop | 2025-06-30 A | 2025-06-30 A |  | 0% → 100% | 649d → none |  |  |
| 2115 | GLIG | 2025-07-04 A | 2025-07-04 A |  | 0% → 100% | 645d → none |  |  |
| 2116 | QWG | 2025-07-08 A | 2025-07-08 A |  | 0% → 100% | 643d → none |  |  |
| 2117 | GLIG (Second presentation) | 2025-07-18 A | 2025-07-18 A |  | 0% → 100% | 635d → none |  |  |
| 2120 | SOLR comms to MHHS for review | 2025-08-26 → 2025-08-27 A (+1d) | 2025-08-26 → 2025-08-27 A (+1d) |  | 0% → 100% | 607d → none |  |  |
| 2121 | **MDR Process** |  | 2025-07-31 A |  | 58% → 100% | 625d → none |  |  |
| 2126 | MDR consultation ongoing actions |  | 2025-07-31 A |  | 48% → 100% | 625d → none |  |  |
| 2127 | Service Activation Go / No Go | 2025-08-22 A | 2025-08-22 A |  | 0% → 100% | -97d → none | 2104FF, 2105FF, 2106FF, 2107FF, 2043FF, 2108FF, Service Activation Implementation, 2304 → 2104, 2105, 2106FF, 2107FF, 2043FF, 2108 | constraint finish no earlier than 2025-08-22 → none |
| 2128 | **Phase 2 - Implementation** |  | 2025-12-31 → 2026-01-13 A (+13d) | 409d? → 418d? | 19% → 100% | 516d → none |  |  |
| 2131 | **M10-Ready Activation Preparation Tasks** | 2025-08-25 A | 2025-09-08 → 2025-09-12 A (+4d) | 11d? → 15d? | 0% → 100% | 598d → none |  |  |
| 2132 | Identify Resources | 2025-08-25 A | 2025-08-25 A |  | 0% → 100% | 608d → none | 2127 → none |  |
| 2133 | Confirmation from Qualification of Wave Participants Complete | 2025-08-25 A | 2025-08-25 A |  | 0% → 100% | 609d → none |  |  |
| 2134 | Agree & Understand Support Model | 2025-08-26 A | 2025-08-26 A |  | 0% → 100% | 607d → none |  |  |
| 2135 | Confirm Training complete | 2025-08-27 A | 2025-08-27 A |  | 0% → 100% | 607d → none |  |  |
| 2136 | Confirm IDNOs global sign completed prior to M10 | 2025-08-28 A | 2025-08-28 → 2025-09-05 A (+8d) | 1d → 7d | 0% → 100% | 605d → none |  | was named Confirm IDNOs gobal sigin comleted prior to M10; constraint start no earlier than 2025-08-28 → finish no earlier than 2025-09-05 |
| 2137 | Engagement / Communications with Participants | 2025-08-29 A | 2025-08-29 → 2025-09-10 A (+12d) | 1d → 9d | 0% → 100% | 604d → none |  | constraint start no earlier than 2025-08-29 → finish no earlier than 2025-09-10 |
| 2138 | **Internal Communications** | 2025-09-01 A | 2025-09-01 A |  | 0% → 100% | 603d → none |  |  |
| 2139 | Agree Content for Livewire | 2025-09-01 A | 2025-09-01 A |  | 0% → 100% | 603d → none |  |  |
| 2140 | Publish Content for Livewire | 2025-09-01 A | 2025-09-01 A |  | 0% → 100% | 604d → none |  |  |
| 2141 | Validate User Access | 2025-09-02 A | 2025-09-02 A |  | 0% → 100% | 596d → none |  |  |
| 2142 | Target Systems and Environments Ready | 2025-09-03 A | 2025-09-03 A |  | 0% → 100% | 595d → none |  |  |
| 2143 | Publish the guidence with Parties | 2025-09-04 → 2025-09-12 A (+8d) | 2025-09-04 → 2025-09-12 A (+8d) |  | 0% → 100% | 592d → none |  | constraint start no earlier than 2025-09-04 → start no earlier than 2025-09-12 |
| 2144 | Provide LWIs | 2025-09-05 → 2025-09-12 A (+7d) | 2025-09-05 → 2025-09-12 A (+7d) |  | 0% → 100% | 592d → none | 2143 → none | constraint none → finish no earlier than 2025-09-12 |
| 2145 | Business Readiness Governance Approval | 2025-09-08 A | 2025-09-08 A |  | 0% → 100% | 592d → none |  |  |
| 2146 | M10-Ready Participants Service Activation Preparation Completed | 2025-09-08 A | 2025-09-08 A |  | 0% → 100% | 598d → none | 2132, 2134, 2135, 2136, 2137, 2138, 2141, 2142, 2143, 2145 → 2132, 2134, 2135, 2136, 2138, 2141, 2142, 2145 |  |
| 2147 | **M10-Ready (Inlcuding Non-SIT LDSOs) Service Activation Implementation** | 2025-08-06 → 2025-09-10 A (+35d) | 2025-09-19 A | 31d? → 6d | 0% → 100% | 590d → none |  |  |
| 2148 | MHHSP Enabled Confirmation | 2025-09-10 A | 2025-09-10 A |  | 0% → 100% | 590d → none | REC Code Manager / BSC PAB Approval of Qualification, 2389, 2392 → 2389, 2392 |  |
| 2149 | Add EFD (ISD Calendar Date) to DIP | 2025-09-11 A | 2025-09-11 A |  | 0% → 100% | 590d → none | 2141, 2142, 2145, 2148, PAB Approval Completed → 2141, 2142, 2145, 2148 |  |
| 2150 | Non-SIT LDSO PP DIP User Promoted to Production | 2025-09-12 A | 2025-09-12 A |  | 0% → 100% | 594d → none |  | was named Non-LDSO SIT PP DIP User Promoted to Production |
| 2151 | Create M16 in Customer Solution Started | 2025-09-11 A | 2025-09-11 A |  | 0% → 100% | 594d → none |  |  |
| 2152 | Create M16 in Customer Solution | 2025-09-11 A | 2025-09-11 A |  | 0% → 100% | 594d → none |  |  |
| 2153 | DIP Production Success Checks | 2025-09-12 A | 2025-09-12 A | 1d? → 1d | 0% → 100% | 594d → none |  |  |
| 2154 | 1st ISD Publish Started | 2025-09-11 A | 2025-09-11 A |  | 0% → 100% | 590d → none |  |  |
| 2155 | 1st ISD Publish (7 day window for this activity is consistent with Code requirements) | 2025-09-11 A | 2025-09-18 A |  | 0% → 100% | 590d → none |  |  |
| 2156 | Go Live ISD | 2025-09-18 A | 2025-09-18 A | 1d? → 1d | 0% → 100% | 590d → none |  |  |
| 2157 | M10-Ready Service Activation Implementation Completed | 2025-09-19 A | 2025-09-19 A |  | 0% → 100% | 590d → none | 2148, PAB Approval Completed, 2149, 2150, 2152, 2155, 2156 → 2148, 2149, 2150, 2152, 2155, 2156 |  |
| 2158 | **M10-Ready Service Activation Implementation MDD** | 2025-09-10 A | 2025-09-19 → 2025-09-18 A (-1d) | 7d → 6d | 0% → 100% | 589d → none |  |  |
| 2159 | MDD Final Circular Completed | 2025-09-10 A | 2025-09-10 A |  | 0% → 100% | 596d → none |  |  |
| 2160 | MDD Manual Update | 2025-09-11 A | 2025-09-15 A |  | 0% → 100% | 593d → none |  |  |
| 2161 | MDD Publish | 2025-09-11 A | 2025-09-18 A |  | 0% → 100% | 590d → none |  |  |
| 2162 | MDD Go Live | 2025-09-18 A | 2025-09-18 A |  | 0% → 100% | 590d → none |  |  |
| 2163 | Non-SIT LDSO & SIT MVC Service Activation Implementation MDD Completed | 2025-09-18 A | 2025-09-18 A |  | 0% → 100% | 590d → none |  |  |
| 2164 | **Non-SIT LDSO & SIT Service Activation Hypercare (M10 Ready)** | 2025-09-18 A | 2025-12-02 A |  | 0% → 100% | 537d → none |  |  |
| 2165 | Monitoring | 2025-09-18 A | 2025-12-02 A |  | 0% → 100% | 537d → none |  |  |
| 2166 | Reporting | 2025-09-18 A | 2025-12-02 A |  | 0% → 100% | 537d → none |  |  |
| 2167 | Issue Management | 2025-09-18 A | 2025-12-02 A |  | 0% → 100% | 537d → none |  |  |
| 2168 | Closed Down Activities | 2025-09-19 A | 2025-09-19 A |  | 0% → 100% | 589d → none |  |  |
| 2169 | Inform MHHSP | 2025-09-19 A | 2025-09-19 A |  | 0% → 100% | 589d → none |  |  |
| 2170 | **M11-Ready Activation Preparation Tasks** | 2025-10-06 → 2025-10-09 A (+3d) | 2025-10-16 → 2025-10-13 A (-3d) | 9d? → 3d | 0% → 100% | 570d → none |  |  |
| 2171 | Engagement / Communications with Participants | 2025-10-09 A | 2025-10-09 A |  | 0% → 100% | 575d → none |  |  |
| 2172 | Validate User Access | 2025-10-13 A | 2025-10-13 A |  | 0% → 100% | 573d → none |  |  |
| 2173 | M11-Ready Participants Service Activation Preparation Completed | 2025-10-16 → 2025-10-13 A (-3d) | 2025-10-16 → 2025-10-13 A (-3d) |  | 0% → 100% | 570d → none | 3398, 3400, Confirm Training complete, 2171, 2172, 3408, 3410 → 2171, 2172 |  |
| 2174 | **M11-Ready Service Activation Implementation** | 2025-09-25 A | 2025-10-22 A |  | 0% → 100% | 566d → none |  |  |
| 2175 | **Pathway 4 PPs** | 2025-09-25 A | 2025-10-03 A |  | 0% → 100% | 579d → none |  |  |
| 2176 | MHHSP Enabled Confirmation | 2025-09-25 A | 2025-09-25 A |  | 0% → 100% | 579d → none | 2400, 2403 → 2400 |  |
| 2177 | Add EFD (ISD Calendar Date) to DIP | 2025-09-25 A | 2025-09-25 A |  | 0% → 100% | 584d → none |  |  |
| 2178 | Create M16 in Customer Solution | 2025-09-25 A | 2025-09-25 A |  | 0% → 100% | 584d → none |  |  |
| 2179 | DIP Production Success Checks | 2025-09-26 A | 2025-09-26 A |  | 0% → 100% | 584d → none |  |  |
| 2180 | Publish ISD | 2025-09-26 A | 2025-10-03 A |  | 0% → 100% | 579d → none |  |  |
| 2181 | Go Live ISD | 2025-10-03 A | 2025-10-03 A |  | 0% → 100% | 579d → none |  |  |
| 2182 | Pathway 4 Service Activation Implementation Completed | 2025-10-03 A | 2025-10-03 A |  | 0% → 100% | 579d → none | 2177, 3449, 2178, 2181, MDD Go Live → 2177, 2178, 2181 |  |
| 2183 | **Pathway 5 PPs** | 2025-10-15 A | 2025-10-22 A |  | 0% → 100% | 566d → none |  |  |
| 2184 | MHHSP Enabled Confirmation | 2025-10-15 A | 2025-10-15 A |  | 0% → 100% | 566d → none |  |  |
| 2185 | Add EFD (ISD Calendar Date) to DIP | 2025-10-15 A | 2025-10-15 A |  | 0% → 100% | 570d → none |  |  |

| ID | Task | Start | Finish | Duration | Complete | Total float | Predecessors | Other |
| --- | --- | --- | --- | --- | --- | --- | --- | --- |
| 2186 | Create M16 in Customer Solution | 2025-10-16 A | 2025-10-16 A |  | 0% → 100% | 570d → none |  |  |
| 2187 | DIP Production Success Checks | 2025-10-16 A | 2025-10-16 A |  | 0% → 100% | 570d → none |  |  |
| 2188 | Publish ISD | 2025-10-16 A | 2025-10-22 A |  | 0% → 100% | 566d → none |  |  |
| 2189 | Go Live ISD | 2025-10-22 A | 2025-10-22 A |  | 0% → 100% | 566d → none |  |  |
| 2190 | Publish MDD | 2025-10-16 A | 2025-10-22 A |  | 0% → 100% | 566d → none |  |  |
| 2191 | MDD Go Live | 2025-10-22 A | 2025-10-22 A |  | 0% → 100% | 566d → none |  |  |
| 2192 | Pathway 5 Service Activation Implementation Completed | 2025-10-22 A | 2025-10-22 A |  | 0% → 100% | 566d → none | 2184, PAB Approval Completed, 2185, 3462, 2186, 2189 → 2184, 2185, 2186, 2189 |  |
| 2193 | **M11-Ready Service Activation Hypercare** | 2025-10-15 A | 2025-11-05 A |  | 0% → 100% | 556d → none |  |  |
| 2194 | Monitoring | 2025-10-15 A | 2025-10-29 A |  | 0% → 100% | 561d → none |  |  |
| 2195 | Reporting | 2025-10-15 A | 2025-10-29 A |  | 0% → 100% | 561d → none |  |  |
| 2196 | Issue Management | 2025-10-15 A | 2025-10-29 A |  | 0% → 100% | 556d → none |  |  |
| 2197 | Closed Down Activities | 2025-10-30 A | 2025-11-03 A |  | 0% → 100% | 556d → none |  |  |
| 2198 | Inform MHHSP | 2025-11-04 A | 2025-11-05 A |  | 0% → 100% | 556d → none |  |  |
| 2199 | M11-Ready Service Activation Hypercare Completed | 2025-11-05 A | 2025-11-05 A |  | 0% → 100% | 556d → none |  |  |
| 2200 | **Not M11-Ready Service Activation Preparation Tasks** | 2025-10-13 A | 2025-12-11 → 2025-10-16 A (-56d) | 44d? → 4d | 0% → 100% | 530d → none |  |  |
| 2201 | Engagement / Communications with Participants | 2025-10-16 A | 2025-10-16 A |  | 0% → 100% | 570d → none | Confirm Training complete → none |  |
| 2202 | Validate User Access | 2025-10-13 A | 2025-10-13 A |  | 0% → 100% | 573d → none |  |  |
| 2203 | **Not M11-Ready Service Activation Implementation** | 2025-10-30 A | 2025-12-30 → 2026-01-13 A (+14d) | 43d? → 53d | 0% → 100% | 517d → none |  |  |
| 2204 | **First Pathway 6 PAB** | 2025-10-30 A | 2025-12-23 → 2025-11-21 A (-32d) | 38d? → 16d | 0% → 100% | 522d → none |  |  |
| 2205 | MHHSP Enabled Confirmation | 2025-10-30 A | 2025-10-30 A |  | 0% → 100% | 553d → none | 2411, 2413 → 2411 |  |
| 2206 | Add EFD (ISD Calendar Date) to DIP | 2025-10-30 A | 2025-10-30 A |  | 0% → 100% | 559d → none | 2205, PAB Approval Completed → 2205 |  |
| 2207 | Create M16 in Customer Solution | 2025-12-19 → 2025-10-31 A (-49d) | 2025-12-19 → 2025-10-31 A (-49d) |  | 0% → 100% | 524d → none | 2209SS → 2205FS+1d | constraint start no earlier than 2025-12-19 → finish no earlier than 2025-10-31 |
| 2208 | DIP Production Success Checks | 2025-12-23 → 2025-10-31 A (-53d) | 2025-12-23 → 2025-10-31 A (-53d) | 1d? → 0d | 0% → 100% | 522d → none | 2206, 2207 → 2207 | constraint start no earlier than 2025-12-23 → finish no earlier than 2025-10-31 |
| 2209 | Publish ISD | 2025-10-31 → 2025-11-14 A (+14d) | 2025-11-07 → 2025-11-21 A (+14d) |  | 0% → 100% | 554d → none | 2205, 2206SS → none | constraint none → start no earlier than 2025-11-14; baseline start 2025-12-22 → 2025-11-14; baseline finish 2025-12-26 → 2025-11-21 |
| 2210 | Go Live ISD | 2025-11-07 → 2025-11-21 A (+14d) | 2025-11-07 → 2025-11-21 A (+14d) |  | 0% → 100% | 554d → none |  | baseline start 2025-12-26 → 2025-11-21; baseline finish 2025-12-26 → 2025-11-21 |
| 2211 | Publish MDD | 2025-10-31 → 2025-11-14 A (+14d) | 2025-11-07 → 2025-11-21 A (+14d) |  | 0% → 100% | 554d → none | 2205 → none | constraint none → start no earlier than 2025-11-14; baseline start none → 2025-11-14; baseline finish none → 2025-11-21 |
| 2212 | MDD Go Live | 2025-11-07 → 2025-11-21 A (+14d) | 2025-11-07 → 2025-11-21 A (+14d) |  | 0% → 100% | 554d → none |  | baseline start none → 2025-11-21; baseline finish none → 2025-11-21 |
| 2213 | Service Activation Implementation Completed | 2025-11-07 → 2025-11-21 A (+14d) | 2025-11-07 → 2025-11-21 A (+14d) |  | 0% → 100% | 554d → none | 2210, 2212, 2206, 3473, 2207, 2209 → 2210, 2212 | baseline start 2025-12-31 → 2025-11-21; baseline finish 2025-12-31 → 2025-11-21 |
| 2214 | **Final Pathway 6 PAB** | 2025-12-17 → 2025-12-18 A (+1d) | 2025-12-30 → 2026-01-13 A (+14d) | 9d? → 19d | 0% → 100% | 517d → none |  |  |
| 2215 | MHHSP Enabled Confirmation | 2025-12-17 → 2025-12-18 A (+1d) | 2025-12-17 → 2025-12-18 A (+1d) |  | 0% → 100% | 517d → none |  | constraint start no earlier than 2025-09-08 → start no earlier than 2025-12-18; baseline start 2025-12-17 → 2025-12-18; baseline finish 2025-12-17 → 2025-12-18 |
| 2216 | Add EFD (ISD Calendar Date) to DIP | 2025-12-17 → 2025-12-18 A (+1d) | 2025-12-17 → 2025-12-18 A (+1d) |  | 0% → 100% | 525d → none |  | baseline start 2025-12-17 → 2025-12-18; baseline finish 2025-12-17 → 2025-12-18 |
| 2217 | Create M16 in Customer Solution | 2025-12-22 → 2025-12-18 A (-4d) | 2025-12-22 → 2025-12-18 A (-4d) |  | 0% → 100% | 523d → none | 2219SS → 2215FS+1d | constraint start no earlier than 2025-12-19 → start no earlier than 2025-12-17 |
| 2218 | DIP Production Success Checks | 2025-12-23 → 2025-12-18 A (-5d) | 2025-12-23 → 2025-12-18 A (-5d) | 1d? → 0d | 0% → 100% | 522d → none |  | constraint start no earlier than 2025-12-23 → none |
| 2219 | Publish ISD | 2025-12-22 → 2026-01-05 A (+14d) | 2025-12-30 → 2026-01-13 A (+14d) |  | 0% → 100% | 517d → none | 2215FS+2d → 2215FS+12d | baseline start 2025-12-22 → 2026-01-05; baseline finish 2025-12-30 → 2026-01-13 |
| 2220 | Go Live ISD | 2025-12-30 → 2026-01-13 A (+14d) | 2025-12-30 → 2026-01-13 A (+14d) |  | 0% → 100% | 517d → none |  | baseline start 2025-12-30 → 2026-01-13; baseline finish 2025-12-30 → 2026-01-13 |
| 2221 | Publish MDD | 2025-12-22 A | 2025-12-30 A |  | 0% → 100% | 517d → none |  |  |
| 2222 | MDD Go Live | 2025-12-30 A | 2025-12-30 A |  | 0% → 100% | 517d → none |  |  |
| 2223 | Service Activation Implementation Completed | 2025-12-30 → 2026-01-13 A (+14d) | 2025-12-30 → 2026-01-13 A (+14d) |  | 0% → 100% | 517d → none |  | baseline start 2025-12-30 → 2026-01-13; baseline finish 2025-12-30 → 2026-01-13 |
| 2224 | **Not M11-Ready Service Activation Hypercare** | 2025-12-17 A | 2025-12-31 A |  | 0% → 100% | 516d → none |  |  |
| 2225 | Monitoring | 2025-12-17 A | 2025-12-31 A |  | 0% → 100% | 516d → none |  |  |
| 2226 | Reporting | 2025-12-17 A | 2025-12-31 A |  | 0% → 100% | 516d → none |  |  |
| 2227 | Issue Management | 2025-12-17 A | 2025-12-31 A |  | 0% → 100% | 516d → none |  |  |
| 2228 | Closed Down Activities | 2025-12-29 A | 2025-12-31 A |  | 0% → 100% | 516d → none |  |  |
| 2229 | Inform MHHSP | 2025-12-30 A | 2025-12-31 A |  | 0% → 100% | 516d → none |  |  |
| 2230 | Not M11-Ready Service Activation Hypercare Completed | 2025-12-31 A | 2025-12-31 A |  | 0% → 100% | 516d → none |  |  |
| 2231 | **Helix Solution Build** |  | 2025-08-08 → 2025-09-18 A (+41d) | 255d? → 284d? | 87% → 100% | 619d → none |  |  |
| 2232 | M10 Build Candidate |  | 2025-07-08 → 2025-08-15 A (+38d) | 52d → 80d | 71% → 100% | 619d → none |  |  |
| 2233 | Helix Code Uplifts | 2025-07-09 → 2025-08-18 A (+40d) | 2025-08-08 → 2025-09-18 A (+41d) | 23d → 24d | 0% → 100% | 619d → none |  | was named Helix Code Uplifts (TBC); baseline start 2025-07-09 → 2025-08-18; baseline finish 2025-08-08 → 2025-09-18 |
| 2234 | **Helix E2E Settlement Assurance Testing (SAT)** |  | 2025-08-07 → 2025-08-15 A (+8d) | 254d? → 260d? | 93% → 100% | 620d → none |  |  |
| 2243 | **Execution** |  | 2025-08-07 → 2025-08-15 A (+8d) | 194d → 200d | 84% → 100% | 620d → none |  |  |
| 2248 | **SAT Cycle 1** |  | 2025-07-16 A |  | 91% → 100% | 636d → none |  |  |
| 2262 | **Transition** |  | 2025-07-16 A |  | 71% → 100% | 636d → none |  |  |
| 2263 | GMT |  | 2025-06-23 A |  | 96% → 100% | 653d → none |  |  |
| 2266 | Long |  | 2025-06-27 A |  | 82% → 100% | 649d → none |  |  |
| 2269 | BST |  | 2025-07-01 A |  | 82% → 100% | 647d → none |  |  |
| 2271 | NESO Validation Period (BST) |  | 2025-07-09 A |  | 50% → 100% | 641d → none |  |  |
| 2272 | Short |  | 2025-07-03 → 2025-07-09 A (+6d) | 3d → 7d | 49% → 100% | 640d → none |  |  |
| 2273 | P0210 file shared for NESO Validation |  | 2025-07-03 A |  | 25% → 100% | 640d → none |  |  |
| 2274 | NESO Validation Period (Short) | 2025-07-04 → 2025-07-08 A (+4d) | 2025-07-10 → 2025-07-14 A (+4d) |  | 0% → 100% | 640d → none |  | constraint start no earlier than 2025-07-04 → start no earlier than 2025-07-08 |
| 2276 | ISD | 2025-07-01 A | 2025-07-03 A |  | 0% → 100% | 645d → none |  |  |
| 2277 | Data Agg |  | 2025-07-11 A |  | 25% → 100% | 639d → none |  |  |
| 2279 | End of Cycle 1 | 2025-07-16 A | 2025-07-16 A |  | 0% → 100% | 637d → none |  |  |
| 2280 | **SAT Cycle 2** | 2025-07-17 A | 2025-08-01 A |  | 0% → 100% | -81d → none |  |  |
| 2281 | **Legacy** | 2025-07-17 A | 2025-08-01 A |  | 0% → 100% | 624d → none |  |  |
| 2282 | Pre-M10 | 2025-07-17 A | 2025-07-17 A |  | 0% → 100% | 635d → none |  |  |
| 2283 | GMT & BST & Long | 2025-07-18 A | 2025-07-25 A |  | 0% → 100% | 624d → none |  |  |
| 2284 | NESO Validation Period (GMT & BST & Long) | 2025-07-28 A | 2025-08-01 A |  | 0% → 100% | 624d → none |  |  |
| 2285 | Trading Dispute | 2025-07-28 A | 2025-07-29 A |  | 0% → 100% | 627d → none |  |  |
| 2286 | **Transition** | 2025-07-24 A | 2025-07-29 A |  | 0% → 100% | 627d → none |  |  |
| 2287 | ISD | 2025-07-24 A | 2025-07-29 A |  | 0% → 100% | 627d → none |  |  |

| ID | Task | Start | Finish | Duration | Complete | Total float | Predecessors | Other |
| --- | --- | --- | --- | --- | --- | --- | --- | --- |
| 2288 | Data Agg | 2025-07-24 A | 2025-07-28 A |  | 0% → 100% | 628d → none |  |  |
| 2289 | End of Cycle 2 | 2025-08-01 A | 2025-08-01 A |  | 0% → 100% | -92d → none |  |  |
| 2290 | SAT Exit Report | 2025-08-01 A | 2025-08-07 → 2025-08-15 A (+8d) | 5d → 11d | 0% → 100% | -92d → none |  | baseline finish 2025-08-07 → 2025-08-15 |
| 2291 | SAT Complete | 2025-08-01 A | 2025-08-01 A |  | 0% → 100% | -91d → none |  |  |
| 2292 | DR Testing |  | 2025-06-27 → 2025-08-29 A (+63d) | 45d → 90d | 93% → 100% | 649d → none |  |  |
| 2294 | Production Environment Build | 2025-06-30 A | 2025-07-31 → 2025-08-15 A (+15d) | 24d → 35d | 0% → 100% | -91d → none |  |  |
| 2295 | Production Environment Base Platform Sign-off | 2025-08-08 → 2025-08-15 A (+7d) | 2025-08-08 → 2025-08-15 A (+7d) |  | 0% → 100% | -97d → none |  | baseline start 2025-07-31 → 2025-08-08; baseline finish 2025-07-31 → 2025-08-08 |
| 2296 | **Implementation (Helix & DIP)** |  | 2025-10-06 A |  | 40% → 100% | 578d → none |  |  |
| 2297 | Go / No-Go (DIP & SM) | 2025-07-31 A | 2025-07-31 A |  | 0% → 100% | 592d → none |  |  |
| 2298 | Implementation Readiness (inc Technical Readiness, Approach and Runbook, Walkthrough / Rehearsals |  | 2025-08-04 A |  | 59% → 100% | 623d → none |  | baseline finish 2025-07-31 → 2025-08-04 |
| 2299 | M10 Implementation Approach & Go-Live Runbook |  | 2025-06-30 A |  | 91% → 100% | 648d → none |  |  |
| 2300 | DIP Production Build |  | 2025-06-27 A |  | 80% → 100% | 649d → none |  |  |
| 2301 | Final Production Deployment | 2025-07-07 A | 2025-07-31 → 2025-08-15 A (+15d) | 19d → 30d | 0% → 100% | 591d → none |  | baseline finish 2025-08-01 → 2025-07-31 |
| 2302 | DIP Portal Available | 2025-08-04 A | 2025-08-04 A |  | 0% → 100% | 590d → none |  |  |
| 2303 | Go / No-Go (Helix Central Systems) | 2025-08-08 → 2025-08-12 A (+4d) | 2025-08-08 → 2025-08-12 A (+4d) |  | 0% → 100% | -97d → none |  | constraint finish no earlier than 2025-08-08 → start no earlier than 2025-08-12; baseline start 2025-08-11 → 2025-08-08; baseline finish 2025-08-11 → 2025-08-08 |
| 2304 | ISD Data Migration | 2025-08-15 → 2025-08-18 A (+3d) | 2025-08-22 → 2025-08-29 A (+7d) | 6d → 10d | 0% → 100% | -97d → none | 2303FS+4d, 2290, ISD Dress Rehearsals → 2303, 2290 |  |
| 2305 | DAH & ISD Dark Mode | 2025-08-26 → 2025-09-01 A (+6d) | 2025-08-26 → 2025-09-01 A (+6d) |  | 0% → 100% | 24d → none | 2304FS+2d → 2304 | constraint none → start no earlier than 2025-09-01 |
| 2306 | VAS Inspection pre-prod | 2025-08-27 A | 2025-09-17 A |  | 0% → 100% | 8d → none | 2305SS-1d → none | was named Dual Run (Pre-Prod); baseline finish 2025-09-16 → 2025-09-17 |
| 2307 | M10 Cutover Weekend (20/09 and 21/09) | 2025-09-19 A | 2025-09-22 A |  | 0% → 100% | 7d → none |  |  |
| 2308 | Post Implementation Review | 2025-10-06 A | 2025-10-06 A |  | 0% → 100% | 578d → none |  |  |
| 2316 | **S & A QUALIFICATION** |  |  |  | 66% → 98% |  |  |  |
| 2317 | **MHHS Qualification - Qualification Deliverables** |  | 2025-10-17 A |  | 97% → 100% | 315d → none |  |  |
| 2345 | **Qualification Assessment Document** |  | 2025-10-17 A |  | 94% → 100% | 315d → none |  |  |
| 2364 | **Qualification Assessment Document Portal** |  | 2025-10-17 A |  | 88% → 100% | 315d → none |  |  |
| 2374 | QT Wave 3 Participant QAD Application Creation in Portal | 2025-07-28 A | 2025-08-08 A |  | 0% → 100% | 365d → none |  |  |
| 2375 | QT Wave 4 Participant QAD Application Creation in Portal | 2025-10-06 A | 2025-10-17 A |  | 0% → 100% | 235d → none |  |  |
| 2378 | **MHHS Qualification - SIT Participants** |  | 2025-12-17 → 2026-07-30 (+225d) | 248d? → 408d? | 63% → 99% | 526d → 366d |  |  |
| 2383 | **MHHS Qualification - M10-Ready** |  | 2025-09-10 A |  | 96% → 100% | 596d → none |  |  |
| 2387 | **SIT / LDSO Pathway 2** | 2025-08-07 A | 2025-08-28 A |  | 0% → 100% | 599d → none |  |  |
| 2388 | QAD Sign Off Deadline + Test Reports | 2025-08-07 A | 2025-08-07 A |  | 0% → 100% | 599d → none | 2386, Regression Sprint 1FF → 2386 |  |
| 2389 | REC Code Manager / BSC PAB Approval of Qualification (M10-Ready) | 2025-08-28 A | 2025-08-28 A |  | 0% → 100% | 599d → none |  |  |
| 2390 | **SIT / LDSO Pathway 3** | 2025-08-22 A | 2025-09-10 A |  | 0% → 100% | 590d → none |  |  |
| 2391 | QAD Sign Off Deadline + Test Reports | 2025-08-22 A | 2025-08-22 A |  | 0% → 100% | 590d → none | 2386, 1672, Regression Sprint 1FF → 2386 | constraint none → finish no earlier than 2025-08-22 |
| 2392 | REC Code Manager / BSC PAB Approval of Qualification (M10-Ready) | 2025-09-09 A | 2025-09-10 A |  | 0% → 100% | 590d → none |  | constraint none → start no earlier than 2025-09-09 |
| 2393 | M10-Ready SIT Participants are qualified | 2025-09-10 A | 2025-09-10 A |  | 0% → 100% | 596d → none |  | constraint none → finish no earlier than 2025-09-10 |
| 2394 | **MHHS Qualification - M11-Ready** |  | 2025-10-15 A |  | 80% → 100% | 571d → none |  |  |
| 2397 | Completion of Code Bodies review of Final QAD (M11-Ready) |  | 2025-07-04 A |  | 35% → 100% | 622d → none |  |  |
| 2398 | **SIT Pathway 4** | 2025-09-04 A | 2025-09-25 A |  | 0% → 100% | 579d → none |  |  |
| 2399 | QAD Sign Off Deadline + Test Reports | 2025-09-04 A | 2025-09-04 A |  | 0% → 100% | 579d → none | 2397, Regression Sprint 1FF → 2397 |  |
| 2400 | REC Code Manager / BSC PAB Approval of Qualification (M11-Ready) | 2025-09-25 A | 2025-09-25 A |  | 0% → 100% | 579d → none |  |  |
| 2401 | **SIT Pathway 5** | 2025-09-24 A | 2025-10-15 A |  | 0% → 100% | 566d → none |  |  |
| 2402 | QAD Sign Off Deadline + Test Reports | 2025-09-24 A | 2025-09-24 A |  | 0% → 100% | 566d → none | 2397, Regression Sprint 1FF → 2397 |  |
| 2403 | REC Code Manager / BSC PAB Approval of Qualification | 2025-10-15 A | 2025-10-15 A |  | 0% → 100% | 566d → none |  |  |
| 2404 | 'M11-Ready SIT Participants are qualified' | 2025-10-15 A | 2025-10-15 A |  | 0% → 100% | 571d → none |  |  |
| 2405 | **MHHS Qualification - Not M11-Ready** |  | 2025-12-17 → 2026-07-30 (+225d) | 153d → 313d | 19% → 99% | 526d → 366d |  |  |
| 2407 | SIT Not M11-Ready Participants submit Final QAD |  | 2025-09-19 A |  | 24% → 100% | 564d → none |  |  |
| 2408 | Completion of Code Bodies review of Final QAD (Not M11-Ready) | 2025-09-22 A | 2025-10-24 A |  | 0% → 100% | 564d → none |  |  |
| 2409 | **SIT Pathway 6** | 2025-10-09 A | 2025-12-17 → 2025-12-18 A (+1d) |  | 0% → 100% | 519d → none |  |  |
| 2410 | QAD Sign Off Deadline + Test Reports | 2025-10-09 A | 2025-10-09 A |  | 0% → 100% | 553d → none |  |  |
| 2411 | REC Code Manager / BSC PAB Approval of Qualification (first Pathway 6 PAB) | 2025-10-30 A | 2025-10-30 A |  | 0% → 100% | 553d → none |  |  |
| 2412 | QAD Sign Off Deadline + Test Reports | 2025-11-26 A | 2025-11-26 A |  | 0% → 100% | 517d → none |  |  |
| 2413 | REC Code Manager / BSC PAB Approval of Qualification (final Pathway 6 PAB) | 2025-12-17 → 2025-12-18 A (+1d) | 2025-12-17 → 2025-12-18 A (+1d) |  | 0% → 100% | 517d → none |  | constraint none → start no earlier than 2025-12-18 |
| 2414 | SIT Participants are Qualified | 2025-12-17 → 2026-07-30 (+225d) | 2025-12-17 → 2026-07-30 (+225d) |  |  | 526d → 366d |  | constraint finish no earlier than 2025-12-17 → start no earlier than 2026-07-30; baseline start 2025-12-17 → 2026-07-30; baseline finish 2025-12-17 → 2026-07-30 |
| 2415 | **MHHS Qualification - Non-SIT LDSO (M10-Ready)** |  | 2025-09-10 → 2025-09-11 A (+1d) | 178d → 179d | 74% → 100% | 596d → none |  |  |
| 2425 | QAD Finalisation |  | 2025-08-22 → 2025-08-19 A (-3d) | 45d → 42d | 4% → 100% | 596d → none |  | baseline finish 2025-08-22 → 2025-08-19 |
| 2426 | QAD Sign Off Deadline (Non-SIT LDSOs) | 2025-08-22 A | 2025-08-22 A |  | 0% → 100% | 596d → none | 2424FS+5d, 1672, 1922, 2425 → 2424FS+5d, 1922, 2425 | constraint none → finish no earlier than 2025-08-22 |
| 2427 | BSC PAB & REC Manager approval of Qualification for Non-SIT LDSOs | 2025-09-10 → 2025-09-11 A (+1d) | 2025-09-10 → 2025-09-11 A (+1d) |  | 0% → 100% | 596d → none |  | constraint none → finish no earlier than 2025-09-11 |
| 2428 | **MHHS Qualification - Qualification Waves** |  |  |  | 60% → 97% |  |  |  |
| 2429 | **Qualification Wave Prep** |  | 2026-02-19 A |  | 96% → 100% | 480d → none |  |  |
| 2467 | **Qualification Testing Framework (Test Stubs and Supporting UI)** |  | 2026-02-19 A |  | 96% → 100% | 480d → none |  |  |
| 2533 | **MPANs, DIP Messages, Settlement, Consumption, Reference** |  |  |  | 88% → 100% |  |  |  |
| 2573 | **Wave 1 Test Data** |  |  |  | 0% → 100% |  |  |  |
| 2574 | Test Data Request + Templates Completed | 2025-07-14 A | 2025-07-15 A |  | 0% → 100% | 448d → none |  |  |
| 2575 | Test Data Generated | 2025-07-16 A | 2025-07-17 A |  | 0% → 100% | 448d → none |  |  |
| 2576 | Test Data Loaded into QP Systems | 2025-07-18 A | 2025-08-07 A |  | 0% → 100% | 448d → none |  |  |
| 2577 | Test Data Loaded into QTF + ADO | 2025-08-11 A | 2025-08-15 A |  | 0% → 100% | 447d → none |  |  |
| 2578 | **Wave 2 Test Data** |  |  |  | 0% → 100% |  |  |  |
| 2579 | Test Data Request + Templates Completed | 2025-09-17 A | 2025-09-18 A |  | 0% → 100% | 411d → none |  |  |
| 2580 | Test Data Generated | 2025-09-19 A | 2025-09-22 A |  | 0% → 100% | 411d → none |  |  |
| 2581 | Test Data Loaded into QP Systems | 2025-09-23 A | 2025-10-13 A |  | 0% → 100% | 411d → none |  |  |

| ID | Task | Start | Finish | Duration | Complete | Total float | Predecessors | Other |
| --- | --- | --- | --- | --- | --- | --- | --- | --- |
| 2582 | Test Data Loaded into QTF + ADO | 2025-10-14 A | 2025-10-17 A |  | 0% → 100% | 411d → none |  |  |
| 2583 | **Wave 3 Test Data** |  |  |  | 0% → 100% |  |  |  |
| 2584 | Test Data Request + Templates Completed | 2025-11-10 A | 2025-11-11 A |  | 0% → 100% | 387d → none |  |  |
| 2585 | Test Data Generated | 2025-11-12 A | 2025-11-13 A |  | 0% → 100% | 387d → none |  |  |
| 2586 | Test Data Loaded into QP Systems | 2025-11-14 A | 2025-12-04 A |  | 0% → 100% | 387d → none |  |  |
| 2587 | Test Data Loaded into QTF + ADO | 2025-12-05 A | 2025-12-11 A |  | 0% → 100% | 387d → none |  |  |
| 2588 | **Wave 4 Test Data** | 2025-11-06 → 2026-01-19 A (+74d) | 2026-01-08 → 2026-02-19 A (+42d) | 45d → 24d | 0% → 100% |  |  |  |
| 2589 | Test Data Request + Templates Completed | 2026-01-19 A | 2026-01-20 A |  | 0% → 100% | 247d → none |  |  |
| 2590 | Test Data Generated | 2026-01-21 A | 2026-01-22 A |  | 0% → 100% | 247d → none |  |  |
| 2591 | Test Data Loaded into QP Systems | 2026-01-23 A | 2026-02-12 A |  | 0% → 100% | 247d → none |  |  |
| 2592 | Test Data Loaded into QTF + ADO | 2026-02-13 A | 2026-02-19 A |  | 0% → 100% | 247d → none |  |  |
| 2600 | Qualification Testing Wave Readiness Confirmed | 2025-08-21 A | 2025-08-21 A |  | 0% → 100% | 611d → none |  |  |
| 2609 | **Qualification Wave 1** |  | 2026-04-15 A |  | 14% → 100% | 441d → none |  |  |
| 2610 | **Qualification Wave 1 QAD Prep** |  | 2025-08-22 A |  | 46% → 100% | 441d → none |  |  |
| 2612 | Qualification Wave 1 Participants Submit Initial QAD |  | 2025-07-11 A |  | 74% → 100% | 441d → none |  |  |
| 2613 | Minimum threshold of Qualification Wave 1 Participants required for QT start have submitted their initial QAD | 2025-07-14 A | 2025-07-14 A |  | 0% → 100% | 441d → none |  | was named Qualification Wave 1 Participants have submitted their initial QAD |
| 2615 | Code Bodies review of Wave 1 Participants Initial QAD | 2025-07-14 A | 2025-08-22 A |  | 0% → 100% | 441d → none |  |  |
| 2616 | Completion of Code Bodies review of Initial QAD | 2025-08-22 A | 2025-08-22 A |  | 0% → 100% | 441d → none |  |  |
| 2617 | **Qualification Wave 1 Test Prep** |  | 2025-08-15 A |  | 22% → 100% | 614d → none |  |  |
| 2619 | Qualification Wave 1 Participants DIP Onboarding Window |  | 2025-07-11 A |  | 63% → 100% | 466d → none |  |  |
| 2620 | Confirmation from Qualification Wave 1 Participants that DIP onboarding has completed | 2025-07-11 A | 2025-07-11 A |  | 0% → 100% | 466d → none |  |  |
| 2621 | Minimum threshold of Qualification Wave 1 Participants' required for QT start to provide status of PIT completion and submit QT Test Plan | 2025-07-14 A | 2025-07-14 A |  | 0% → 100% | 639d → none |  | was named Qualification Wave 1 Participants' to provide status of PIT completion and submit QT Test Plan |
| 2623 | Review of Participants' PIT Status and QT Test Plan |  | 2025-08-15 A |  | 16% → 100% | 441d → none |  |  |
| 2624 | Minimum threshold of Qualification Test Plans for Wave 1 Participants required for QT start approved | 2025-08-15 A | 2025-08-15 A |  | 0% → 100% | 441d → none |  | was named Qualification Test Plans for Wave 1 Participants approved |
| 2627 | Qualification Wave 1 Participants have submitted PIT Test Completion Report and evidence for QT Entry | 2025-07-14 A | 2025-07-14 A |  | 0% → 100% | 441d → none | none → 2626 |  |
| 2628 | Review of Participants PIT Test Completion Report | 2025-07-14 A | 2025-08-15 A |  | 0% → 100% | 441d → none | 2627 → 2626 |  |
| 2629 | Onboarding to QTF & ADO | 2025-07-14 A | 2025-08-15 A |  | 0% → 100% | 447d → none |  |  |
| 2630 | **Qualification Wave 1 QT Execution** | 2025-08-18 A | 2026-01-09 → 2026-01-02 A (-7d) | 105d → 100d | 0% → 100% | 441d → none |  |  |
| 2631 | Review Entry Criteria Evidence for each Wave 1 Participant | 2025-08-18 A | 2025-08-22 A |  | 0% → 100% | 441d → none |  |  |
| 2632 | Minimum threshold of Qualification Wave 1 Participant Test required for QT start Readiness Confirmed | 2025-08-22 A | 2025-08-22 A |  | 0% → 100% | 441d → none |  | was named Qualification Wave 1 Participant Test Readiness Confirmed |
| 2634 | Qualification Wave 1 QT Execution Start | 2025-08-25 A | 2025-08-25 A |  | 0% → 100% | 441d → none |  |  |
| 2635 | Qualification Wave 1 QT Execution Window | 2025-08-25 A | 2026-01-09 → 2026-01-02 A (-7d) | 100d → 95d | 0% → 100% | 446d → none |  |  |
| 2636 | Qualification Wave 1 QT Projected Execution End | 2026-01-09 → 2026-01-02 A (-7d) | 2026-01-09 → 2026-01-02 A (-7d) |  | 0% → 100% | 446d → none |  |  |
| 2637 | **Qualification Wave 1 Exit** | 2025-08-25 A | 2026-04-15 A |  | 0% → 100% | 441d → none |  |  |
| 2639 | Final QAD Submission window opens | 2025-08-25 A | 2025-08-25 A |  | 0% → 100% | 441d → none |  |  |
| 2640 | Qualification Wave 1 Participants submit their Final QAD | 2025-08-25 A | 2026-01-16 A |  | 0% → 100% | 441d → none | 2639FS-1d → 2639FS-1d, 2638FF |  |
| 2641 | 80% of M14 Critical Qualification Wave 1 Participants have submitted their final QAD | 2026-01-16 A | 2026-01-16 A |  | 0% → 100% | 441d → none |  | was named Qualification Wave 1 Participants have submitted their final QAD |
| 2643 | Completion of Code Bodies review of Final QAD | 2026-01-19 A | 2026-03-06 A |  | 0% → 100% | 441d → none |  |  |
| 2644 | QAD Sign Off deadline | 2026-03-20 A | 2026-03-20 A |  | 0% → 100% | 441d → none |  |  |
| 2646 | All M14 Critical Wave 1 Participants Qualification approved by BSC PAB and REC Manager | 2026-04-15 A | 2026-04-15 A |  | 0% → 100% | 441d → none | 2644FS+18d → 2644FS+18d, 2614, 2633, 2642 | was named Qualification Wave 1 Participants Qualification approved by BSC PAB and REC Manager |
| 2647 | **Qualification Wave 2** |  | 2026-05-28 A |  | 3% → 100% | 410d → none |  |  |
| 2648 | **Qualification Wave 2 QAD Prep** |  | 2025-10-17 A |  | 13% → 100% | 410d → none |  |  |
| 2650 | Qualification Wave 2 Participants Submit Initial QAD |  | 2025-09-12 A |  | 17% → 100% | 410d → none |  |  |
| 2651 | Minimum threshold of Qualification Wave 2 Participants required for QT start have submitted their initial QAD | 2025-09-12 A | 2025-09-12 A |  | 0% → 100% | 410d → none |  | was named Qualification Wave 2 Participants have submitted their initial QAD |
| 2653 | Code Bodies review of Wave 2 Participants' Initial QAD | 2025-09-15 A | 2025-10-17 A |  | 0% → 100% | 410d → none |  |  |
| 2654 | Completion of Code Bodies review of Initial QAD | 2025-10-17 A | 2025-10-17 A |  | 0% → 100% | 410d → none |  |  |
| 2655 | **Qualification Wave 2 Test Prep** | 2025-07-21 A | 2025-10-10 A |  | 0% → 100% | 416d → none |  |  |
| 2656 | Confirmation from Qualification Wave 2 Participants that DIP Onboarding has commenced | 2025-07-21 A | 2025-07-21 A |  | 0% → 100% | 435d → none |  |  |
| 2657 | Qualification Wave 2 Participants DIP Onboarding Window | 2025-07-21 A | 2025-09-05 A |  | 0% → 100% | 435d → none |  |  |
| 2658 | Confirmation from Qualificiation Wave 2 Participants that DIP onboarding has completed | 2025-09-05 A | 2025-09-05 A |  | 0% → 100% | 435d → none |  |  |
| 2659 | Minimum threshold of Qualification Wave 2 Participants' required for QT start to provide status of PIT completion and submit QT Test Plan | 2025-08-18 A | 2025-08-18 A |  | 0% → 100% | 435d → none |  | was named Qualification Wave 2 Participants' to provide status of PIT completion and submit QT Test Plan |
| 2661 | Review of Participants' PIT Status and QT Test Plan | 2025-08-18 A | 2025-09-05 A |  | 0% → 100% | 435d → none |  |  |
| 2662 | Minimum threshold of Qualification Test Plans for Wave 2 Participants required for QT start approved | 2025-09-05 A | 2025-09-05 A |  | 0% → 100% | 435d → none |  | was named Qualification Test Plans for Wave 2 Participants approved |
| 2664 | Minimum threshold of Qualification Wave 2 Participants required for QT start have submitted PIT Test Completion Report and evidence for QT entry | 2025-09-08 A | 2025-09-08 A |  | 0% → 100% | 410d → none |  | was named Qualification Wave 2 Participants have submitted PIT Test Completion Report and evidence for QT entry |
| 2666 | Review of Participants' PIT Test Completion Report | 2025-09-08 A | 2025-10-10 A |  | 0% → 100% | 410d → none |  |  |
| 2667 | Onboarding to QTF & ADO | 2025-09-08 A | 2025-10-10 A |  | 0% → 100% | 416d → none |  |  |
| 2668 | **Qualification Wave 2 QT Execution** | 2025-10-13 A | 2026-02-27 → 2026-02-20 A (-7d) | 100d → 95d | 0% → 100% | 410d → none |  |  |
| 2669 | Review Entry Criteria Evidence for each Wave 2 Participant | 2025-10-13 A | 2025-10-17 A |  | 0% → 100% | 410d → none |  |  |
| 2670 | Minimum threshold of Qualification Wave 2 Participant required for QT start Test Readiness Confirmed | 2025-10-17 A | 2025-10-17 A |  | 0% → 100% | 410d → none |  | was named Qualification Wave 2 Participant Test Readiness Confirmed |
| 2672 | Qualification Wave 2 Execution Start | 2025-10-20 A | 2025-10-20 A |  | 0% → 100% | 410d → none |  |  |
| 2673 | Qualification Wave 2 QT Execution Window | 2025-10-20 A | 2026-02-27 → 2026-02-20 A (-7d) | 95d → 90d | 0% → 100% | 415d → none |  |  |
| 2674 | Qualification Wave 2 QT Projected Execution End | 2026-02-27 → 2026-02-20 A (-7d) | 2026-02-27 → 2026-02-20 A (-7d) | 0d → 1d | 0% → 100% | 415d → none |  | was named Qualfication Wave 2 QT Execution End |
| 2675 | **Qualification Wave 2 Exit** | 2025-10-20 A | 2026-05-28 A |  | 0% → 100% | 410d → none |  |  |
| 2677 | Final QAD Submission window opens | 2025-10-20 A | 2025-10-20 A |  | 0% → 100% | 410d → none |  |  |
| 2678 | Qualification Wave 2 Participants submit their Final QAD | 2025-10-20 A | 2026-03-06 A |  | 0% → 100% | 410d → none | 2677FS-1d → 2677FS-1d, 2676FF |  |
| 2679 | 80% of M14 Critical Qualification Wave 2 Participants have submitted their final QAD | 2026-03-06 A | 2026-03-06 A |  | 0% → 100% | 410d → none |  | was named Qualification Wave 2 Participants have submitted their final QAD |
| 2681 | Completion of Code Bodies review of Final QAD | 2026-03-09 A | 2026-04-13 A |  | 0% → 100% | 410d → none |  |  |
| 2682 | QAD Sign Off deadline | 2026-04-20 A | 2026-04-20 A |  | 0% → 100% | 410d → none |  |  |
| 2684 | All M14 Critical Wave 2 Participants Qualification approved by BSC PAB and REC Manager | 2026-05-28 A | 2026-05-28 A |  | 0% → 100% | 410d → none | 2682FS+28d → 2682FS+28d, 2652, 2660, 2665, 2671, 2680 | was named Qualification Wave 2 Participants Qualification approved by BSC PAB and REC Manager |
| 2685 | **Qualification Wave 3** | 2025-08-11 A |  | 254d → 254d? | 0% → 94% | 60d → 365d |  |  |

| ID | Task | Start | Finish | Duration | Complete | Total float | Predecessors | Other |
| --- | --- | --- | --- | --- | --- | --- | --- | --- |
| 2686 | **Qualification Wave 3 QAD Prep** | 2025-08-11 A | 2025-12-19 A |  | 0% → 100% | 365d → none |  |  |
| 2687 | Initial QAD Submission window opens | 2025-08-11 A | 2025-08-11 A |  | 0% → 100% | 365d → none |  |  |
| 2688 | Qualification Wave 3 Participants Submit Initial QAD | 2025-08-11 A | 2025-11-07 A |  | 0% → 100% | 365d → none |  |  |
| 2689 | Minimum threshold of Qualification Wave 3 Participants required for QT start have submitted their initial QAD | 2025-11-07 A | 2025-11-07 A |  | 0% → 100% | 365d → none |  | was named Qualification Wave 3 Participants have submitted their initial QAD |
| 2691 | Code Bodies review of Wave 3 Participants' Initial QAD | 2025-11-10 A | 2025-12-19 A |  | 0% → 100% | 365d → none |  |  |
| 2692 | Completion of Code Bodies review of Initial QAD | 2025-12-19 A | 2025-12-19 A |  | 0% → 100% | 365d → none |  |  |
| 2693 | **Qualification Wave 3 Test Prep** | 2025-09-15 A | 2025-12-12 A |  | 0% → 100% | 395d → none |  |  |
| 2694 | Confirmation from Qualification Wave 3 Participants that DIP Onboarding has commenced | 2025-09-15 A | 2025-09-15 A |  | 0% → 100% | 395d → none |  |  |
| 2695 | Qualification Wave 3 Participants DIP Onboarding window | 2025-09-15 A | 2025-10-31 A |  | 0% → 100% | 395d → none |  |  |
| 2696 | Confirmation from Qualification Wave 3 Participants that DIP onboarding has completed | 2025-10-31 A | 2025-10-31 A |  | 0% → 100% | 395d → none |  |  |
| 2697 | Minimum threshold of Qualification Wave 3 Participants' required for QT start to provide status of PIT completion and submit QT Test Plan | 2025-10-20 A | 2025-10-20 A |  | 0% → 100% | 554d → none |  | was named Qualification Wave 3 Participants' to provide status of PIT completion and submit QT Test Plan |
| 2699 | Review of Participants' PIT Status and QT Test Plan | 2025-10-20 A | 2025-11-07 A |  | 0% → 100% | 554d → none |  |  |
| 2700 | Minimum threshold of Qualification Test Plans for Wave 3 Participants required for QT start approved | 2025-11-07 A | 2025-11-07 A |  | 0% → 100% | 554d → none |  | was named Qualification Test Plans for Wave 3 Participants approved |
| 2702 | Minimum threshold of Qualification Wave 3 Participants required for QT start have submitted PIT Test Completion Report and evidence for QT Entry | 2025-11-10 A | 2025-11-10 A |  | 0% → 100% | 365d → none |  | was named Qualification Wave 3 Participants have submitted PIT Test Completion Report and evidence for QT Entry |
| 2704 | Review of Participants' PIT Test Completion Report | 2025-11-10 A | 2025-12-12 A |  | 0% → 100% | 365d → none |  |  |
| 2705 | Onboarding to QTF & ADO | 2025-11-10 A | 2025-12-12 A |  | 0% → 100% | 365d → none |  |  |
| 2706 | **Qualification Wave 3 QT Execution** | 2025-11-03 → 2025-12-15 A (+42d) | 2026-03-24 → 2026-05-15 (+52d) | 102d → 110d? | 0% → 100% |  |  |  |
| 2707 | Review Entry Criteria Evidence for each Wave 3 Participant | 2025-12-15 A | 2025-12-19 A |  | 0% → 100% | 365d → none |  |  |
| 2708 | Minimum threshold of Qualification Wave 3 Participant required for QT start Test Readiness confirmed | 2025-12-19 A | 2025-12-19 A |  | 0% → 100% | 365d → none |  | was named Qualification Wave 3 Participant Test Readiness confirmed |
| 2710 | Qualification Wave 3 Execution Start | 2026-01-12 A | 2026-01-12 A |  | 0% → 100% | 365d → none |  |  |
| 2711 | Qualification Wave 3 QT Execution Window | 2026-01-12 A | 2026-05-15 → 2026-05-08 A (-7d) | 90d → 85d | 0% → 100% | 370d → none |  |  |
| 2712 | Qualification Wave 3 Projected Execution End | 2026-05-15 → 2026-05-08 A (-7d) | 2026-05-15 → 2026-05-08 A (-7d) |  | 0% → 100% | 370d → none |  |  |
| 2713 | **Qualification Wave 3 Exit** | 2026-01-12 A |  |  | 0% → 81% |  |  |  |
| 2715 | Final QAD Submission window opens | 2026-01-12 A | 2026-01-12 A |  | 0% → 100% | 365d → none |  |  |
| 2716 | Qualification Wave 3 Participants submit their Final QAD | 2026-01-12 A |  |  | 0% → 97% | 365d → 414d | 2715FS-1d → 2715FS-1d, 2714FF |  |
| 2717 | 80% of M14 Critical Qualification Wave 3 Participants have submitted their Final QAD | 2026-05-22 A | 2026-05-22 A |  | 0% → 100% | 365d → none |  | was named Qualification Wave 3 Participants have submitted their Final QAD |
| 2722 | All M14 Critical Wave 3 Participants Qualification approved by BSC PAB and REC Manager |  |  |  |  |  | 2720FS+24d → 2720FS+24d, 2690, 2698, 2703, 2709, 2718 | was named Qualification Wave 3 Participants Qualification approved by BSC PAB and REC Manager |
| 2723 | **Qualification Wave 4** |  |  |  | 0% → 74% |  |  |  |
| 2724 | **Qualification Wave 4 QAD Prep** | 2025-10-20 A |  |  | 0% → 99% | 235d → 474d |  |  |
| 2725 | Initial QAD Submission window opens | 2025-10-20 A | 2025-10-20 A |  | 0% → 100% | 235d → none |  |  |
| 2726 | Qualification Wave 4 Participants Submit Initial QAD | 2025-10-20 A | 2026-01-16 A |  | 0% → 100% | 235d → none |  |  |
| 2727 | Qualification Wave 4 Participants have submitted their Initial QAD | 2026-01-16 A | 2026-01-16 A |  | 0% → 100% | 235d → none |  |  |
| 2728 | Code Bodies review of Wave 4 Participants' Initial QAD | 2026-01-19 A | 2026-02-27 A |  | 0% → 100% | 235d → none |  |  |
| 2730 | **Qualification Wave 4 Test Prep** | 2025-11-03 A | 2026-02-13 A |  | 0% → 100% | 251d → none |  |  |
| 2731 | Confirmation from Qualification 4 Participants that DIP Onboarding has commenced | 2025-11-03 A | 2025-11-03 A |  | 0% → 100% | 285d → none |  |  |
| 2732 | Qualification Wave 4 Participants DIP Onboarding Window | 2025-11-03 A | 2025-12-19 A |  | 0% → 100% | 285d → none |  |  |
| 2733 | Confirmation from Qualification Wave 4 Participants that DIP onboarding has completed | 2025-12-19 A | 2025-12-19 A |  | 0% → 100% | 285d → none |  |  |
| 2734 | Qualification Wave 4 Participants' to provide status of PIT completion and submit QT Test Plan | 2025-12-08 A | 2025-12-08 A |  | 0% → 100% | 251d → none |  |  |
| 2735 | Review of Participants' PIT Status and QT Test Plan | 2025-12-08 A | 2026-01-09 A |  | 0% → 100% | 251d → none |  |  |
| 2736 | Qualification Test Plans for Qualification Wave 4 Participants approved | 2026-01-09 A | 2026-01-09 A |  | 0% → 100% | 251d → none |  |  |
| 2737 | Qualification Wave 4 Participants have submitted PIT Test Completion Report and evidence for QT entry | 2026-01-09 A | 2026-01-09 A |  | 0% → 100% | 251d → none |  |  |
| 2738 | Review of Participants' PIT Test Completion Report | 2026-01-12 A | 2026-02-13 A |  | 0% → 100% | 251d → none |  |  |
| 2739 | Onboarding to QTF & ADO | 2026-01-12 A | 2026-02-13 A |  | 0% → 100% | 251d → none |  |  |
| 2740 | **Qualification Wave 4 QT Execution** | 2026-03-02 A | 2026-07-17 → 2026-07-10 A (-7d) | 100d → 95d | 0% → 100% | 235d → none |  |  |
| 2741 | Review Entry Criteria Evidence for each Wave 4 Participant | 2026-03-02 A | 2026-03-06 A |  | 0% → 100% | 235d → none |  |  |
| 2742 | Qualification Wave 4 Participant Test Readiness Confirmed | 2026-03-06 A | 2026-03-06 A |  | 0% → 100% | 235d → none |  |  |
| 2743 | Qualification Wave 4 QT Execution Start | 2026-03-09 A | 2026-03-09 A |  | 0% → 100% | 235d → none |  |  |
| 2744 | Qualification Wave 4 QT Execution Window | 2026-03-09 A | 2026-07-17 → 2026-07-10 A (-7d) | 95d → 90d | 0% → 100% | 240d → none |  |  |
| 2745 | Qualification Wave 4 Projected Execution End | 2026-07-17 → 2026-07-10 A (-7d) | 2026-07-17 → 2026-07-10 A (-7d) |  | 0% → 100% | 240d → none |  | baseline start 2026-07-17 → 2026-07-10; baseline finish 2026-07-17 → 2026-07-10 |
| 2746 | **Qualification Wave 4 Exit** | 2026-03-09 A |  |  | 0% → 13% |  |  |  |
| 2748 | Final QAD Submission window opens | 2026-03-09 A | 2026-03-09 A |  | 0% → 100% | 235d → none |  |  |
| 2749 | Qualification Wave 4 Participants submit their Final QAD | 2026-03-09 A |  |  | 0% → 16% | 235d → 1.4d | 2748FS-1d → 2748FS-1d, 2747FF |  |
| 2751 | Completion of Code Bodies review of Final QAD | 2026-07-27 A |  |  | 0% → 7% |  |  |  |
| 2757 | **PAB dates** |  | 2025-12-18 → 2026-12-09 (+356d) | 235d → 490d |  | 526d → 271d |  | baseline start none → 2025-01-23; baseline finish none → 2025-12-18 |
| 2768 | PAB298 | 2025-07-16 A | 2025-07-16 A |  | 0% → 100% | 637d → none |  |  |
| 2769 | PAB299 | 2025-07-31 A | 2025-07-31 A |  | 0% → 100% | 626d → none |  |  |
| 2770 | PAB300 | 2025-08-13 A | 2025-08-13 A |  | 0% → 100% | 617d → none |  |  |
| 2771 | PAB301 | 2025-08-28 → 2025-08-27 A (-1d) | 2025-08-28 A | 0d → 2d | 0% → 100% | 606d → none |  | constraint start no earlier than 2025-08-28 → start no earlier than 2025-08-27 |
| 2772 | PAB302 | 2025-09-10 A | 2025-09-10 A |  | 0% → 100% | 597d → none |  |  |
| 2773 | PAB303 | 2025-09-25 A | 2025-09-25 A |  | 0% → 100% | 8d → none |  |  |
| 2774 | PAB304 | 2025-10-15 A | 2025-10-15 A |  | 0% → 100% | 572d → none |  |  |
| 2775 | PAB305 | 2025-10-30 A | 2025-10-30 A |  | 0% → 100% | 561d → none |  |  |
| 2776 | PAB306 | 2025-11-12 A | 2025-11-12 A |  | 0% → 100% | 552d → none |  |  |
| 2777 | PAB307 | 2025-11-27 A | 2025-11-27 A |  | 0% → 100% | 541d → none |  |  |
| 2778 | PAB308 | 2025-12-18 A | 2025-12-18 A |  | 0% → 100% | 526d → none |  |  |
| 2801 | **REGULATORY** |  | 2025-12-24 A |  | 99% → 100% | 521d → none |  |  |
| 2928 | **Deliver MHHS Code Changes** |  | 2025-12-24 A |  | 93% → 100% | 521d → none |  |  |
| 2931 | **M8 Code Change Preperation** |  | 2025-09-05 A |  | 0% → 100% | 599d → none |  |  |
| 2939 | Present to Panel | 2025-07-10 A | 2025-07-10 A |  | 0% → 100% | 640d → none |  |  |
| 2940 | Code Change Industry Consultation | 2025-07-29 A | 2025-07-29 A |  | 0% → 100% | 627d → none |  |  |

| ID | Task | Start | Finish | Duration | Complete | Total float | Predecessors | Other |
| --- | --- | --- | --- | --- | --- | --- | --- | --- |
| 2941 | Panel Recommendation | 2025-08-14 A | 2025-08-14 A |  | 0% → 100% | 615d → none |  |  |
| 2942 | Ofgem Decision | 2025-09-05 A | 2025-09-05 A |  | 0% → 100% | 532d → none |  |  |
| 2943 | **Main Code Release** | 2025-09-15 A | 2025-12-24 A |  | 0% → 100% | 521d → none |  |  |
| 2944 | Release preparation (e.g. preparing release documentation) | 2025-09-15 A | 2025-09-22 A |  | 0% → 100% | 588d → none |  |  |
| 2945 | Implement new code on day of code release | 2025-09-22 A | 2025-09-22 A |  | 0% → 100% | 588d → none |  |  |
| 2946 | Code changes delivered (M8) | 2025-09-22 A | 2025-09-22 A |  | 0% → 100% | 521d → none | 2926, 2905, 1802SS-3d, 2942, "Codify Service Management" Decision Due (TBC and Indicitavely by End of Aug) → 2926, 2905, 1802SS-3d, 2942 |  |
| 2947 | Code changes delivered (M8*) late exit | 2025-12-24 A | 2025-12-24 A |  | 0% → 100% | 521d → none |  |  |
| 2952 | **MIGRATION** |  |  |  | 70% → 95% |  |  |  |
| 2953 | **Regulatory Governance** |  | 2025-09-26 → 2026-07-01 (+278d) | 390d → 587d | 96% → 99% | 584d → 387d |  |  |
| 2956 | Ofgem Incentives Approval | 2025-09-22 → 2025-06-13 A (-101d) | 2025-09-22 → 2026-04-30 A (+220d) | 0d → 230d | 0% → 100% | 584d → none | none → 2955 | constraint start no earlier than 2025-09-22 → finish no earlier than 2026-04-30; baseline start 2025-09-22 → 2025-06-13; baseline finish 2025-09-22 → 2026-04-30 |
| 2957 | Incentives Implementation | 2025-09-22 → 2026-06-25 (+276d) | 2025-09-26 → 2026-06-25 (+272d) | 5d → 0d |  | 584d → 390d |  | was named Incnentives Implementation; constraint none → finish no earlier than 2026-06-25; baseline start 2025-09-22 → 2026-06-25; baseline finish 2025-09-26 → 2026-06-25 |
| 3000 | **V1.0 of Migration Schedule Baseline** |  | 2025-07-22 A |  | 0% → 100% | 632d → none |  |  |
| 3002 | V1.0 of Migration Schedule Baseline Approved at MCAG | 2025-07-22 A | 2025-07-22 A |  | 0% → 100% | 632d → none |  |  |
| 3003 | **Supplier Submission Support** |  | 2025-06-18 A |  | 99% → 100% | 657d → none |  |  |
| 3011 | **MCC Stood up** |  | 2025-11-21 A |  | 59% → 100% |  |  |  |
| 3012 | Migration Planning Management Tool Delivery |  | 2025-11-21 A |  | 59% → 100% |  |  |  |
| 3013 | **MCC Operational** |  | 2025-08-29 → 2025-09-05 A (+7d) | 93d → 98d | 47% → 100% | 604d → none |  |  |
| 3014 | **MCC Dress Rehersal 1 - Initialise Schedule (Weekly) Drop 1, 2** |  | 2025-07-22 A |  | 47% → 100% | 632d → none |  |  |
| 3021 | Consolidate baseline schedule |  | 2025-07-11 A |  | 47% → 100% | 638d → none |  |  |
| 3022 | Consolidated baseline schedule published to industry | 2025-07-11 A | 2025-07-11 A |  | 0% → 100% | 638d → none |  |  |
| 3023 | Baselined Schedule available for download | 2025-07-14 A | 2025-07-14 A |  | 0% → 100% | 638d → none |  |  |
| 3024 | Test execution report (weekly) | 2025-07-15 A | 2025-07-15 A |  | 0% → 100% | 637d → none | Dress rehearsal startFS+56d → none |  |
| 3025 | Dress rehearsal completion report | 2025-07-15 A | 2025-07-15 A |  | 0% → 100% | 637d → none |  |  |
| 3026 | MCC Dress Rehersal 1 - complete | 2025-07-15 A | 2025-07-15 A |  | 0% → 100% | 637d → none |  |  |
| 3027 | MCAG approval of Baseline Migration schedule | 2025-07-22 A | 2025-07-22 A |  | 0% → 100% | 632d → none |  |  |
| 3028 | **MCC Dress Rehersal 2 - complete** | 2025-07-14 A | 2025-08-29 → 2025-09-05 A (+7d) | 35d → 40d | 0% → 100% | 604d → none |  |  |
| 3029 | Issue Dress Rehearsal support information to Participants | 2025-07-14 A | 2025-07-14 A |  | 0% → 100% | 604d → none |  |  |
| 3031 | Kestrel Webinar 2 | 2025-07-14 → 2025-08-06 A (+23d) | 2025-07-14 → 2025-08-06 A (+23d) |  | 0% → 100% | 604d → none | 3029 → none | constraint none → finish no earlier than 2025-08-06; baseline start 2025-07-14 → 2025-08-06; baseline finish 2025-07-14 → 2025-08-06 |
| 3032 | Onboard and connectivity testing - Dress Rehearsal with Suppliers (remaining suppliers and non-supplier PPs) | 2025-07-21 → 2025-08-11 A (+21d) | 2025-07-21 → 2025-08-11 A (+21d) |  | 0% → 100% | 604d → none | 3031FS+6d → 3030FS+6d | constraint none → start no earlier than 2025-08-11; baseline start 2025-07-21 → 2025-08-11; baseline finish 2025-07-21 → 2025-08-11 |
| 3033 | **MCC Dress Rehersal 2** | 2025-07-21 → 2025-08-11 A (+21d) | 2025-07-21 → 2025-09-05 A (+46d) | 0d → 20d | 0% → 100% | 604d → none |  | was named Dress rehearsal start; baseline start 2025-07-21 → 2025-08-11; baseline finish 2025-07-21 → 2025-08-11 |
| 3035 | Test execution report (weekly) | 2025-08-29 → 2025-08-11 A (-18d) | 2025-08-29 → 2025-09-05 A (+7d) | 0d → 20d | 0% → 100% | 604d → none | 3033FS+29d → none | constraint none → finish no earlier than 2025-08-11 |
| 3036 | Dress rehearsal completion report available | 2025-08-29 → 2025-09-05 A (+7d) | 2025-08-29 → 2025-09-05 A (+7d) |  | 0% → 100% | 604d → none |  | was named Dress rehearsal completion report; constraint none → finish no earlier than 2025-08-29 |
| 3038 | MCC Dress Rehearsal 2 - complete | 2025-08-29 → 2025-09-05 A (+7d) | 2025-08-29 → 2025-09-05 A (+7d) |  | 0% → 100% | 604d → none |  | was named MCC Dress Rehersal 2 - complete; constraint none → finish no earlier than 2025-09-05 |
| 3039 | MCC Operational Complete | 2025-08-29 → 2025-09-05 A (+7d) | 2025-08-29 → 2025-09-05 A (+7d) |  | 0% → 100% | 604d → none |  | constraint none → finish no earlier than 2025-08-29 |
| 3040 | **M11 Readiness Checkpoint** | 2025-07-28 → 2025-08-29 A (+32d) | 2025-08-28 → 2025-10-20 A (+53d) | 24d → 36d | 0% → 100% | 570d → none |  | constraint finish no earlier than 2025-08-28 → none; baseline start none → 2025-07-28; baseline finish none → 2025-08-28 |
| 3041 | Supplier Readiness Assessments for Sprint 0 Day 1 | 2025-08-29 A | 2025-09-25 A |  | 0% → 100% | 570d → none | 3040 → none | was named Supplier Readiness Assessments for Sprint 0; constraint none → start no earlier than 2025-08-29; baseline start none → 2025-08-29; baseline finish none → 2025-09-25 |
| 3043 | **Legacy Settlement run stability assessment** | 2025-09-25 → 2025-09-26 A (+1d) | 2025-10-16 → 2025-10-17 A (+1d) |  | 0% → 100% | 570d → none | 3041FS-1d → none | constraint start no earlier than 2025-09-25 → none; baseline start none → 2025-09-26; baseline finish none → 2025-10-17 |
| 3048 | **Migration Artefact Development and Publication** |  | 2026-10-28 A |  | 81% → 100% | 301d → none |  |  |
| 3091 | **Data Cleanse Plan** |  | 2025-09-24 A |  | 98% → 100% | 586d → none |  |  |
| 3096 | **MTDs** |  | 2025-07-18 → 2025-07-21 A (+3d) | 240d → 241d | 95% → 100% | 634d → none |  |  |
| 3103 | **Meter Location and Number of Displayed Register Digits** |  | 2025-07-18 → 2025-07-21 A (+3d) | 221d → 222d | 91% → 100% | 634d → none |  |  |
| 3107 | Suppliers complete Work Off plans |  | 2025-07-18 A |  | 89% → 100% | 634d → none |  |  |
| 3108 | Meter Location and Number of Displayed Register Digits Complete | 2025-07-18 → 2025-07-21 A (+3d) | 2025-07-18 → 2025-07-21 A (+3d) | 0d → 1d | 0% → 100% | 634d → none |  |  |
| 3109 | **Registration Data** |  | 2025-09-24 A |  | 85% → 100% | 586d → none |  |  |
| 3118 | **Domestic Premises Indicator** | 2025-09-05 A | 2025-09-24 A |  | 0% → 100% | 586d → none |  |  |
| 3119 | The DCC to extract Domestic Premises Indicator from the CSS and provide a file to each LDSO and EES. | 2025-09-05 A | 2025-09-08 A |  | 0% → 100% | 597d → none |  |  |
| 3120 | Each LDSO notifies the MHHS Programme SI of any exceptions which have occurred because of the data load and the reason for that exception | 2025-09-24 A | 2025-09-24 A |  | 0% → 100% | 586d → none |  |  |
| 3121 | Domestic Premises Indicator Complete | 2025-09-24 A | 2025-09-24 A |  | 0% → 100% | 586d → none |  |  |
| 3122 | **Connection Type and Meter Type Misalignments** |  | 2026-10-28 A |  | 62% → 100% | 301d → none |  |  |
| 3123 | **Traditional Meters installed on Current Transformers** |  | 2026-10-28 A |  | 30% → 100% | 301d → none |  |  |
| 3128 | Suppliers to have completed meter exchanges for those MPANs in pot 1 |  | 2026-10-28 A |  | 6% → 100% | 301d → none |  |  |
| 3129 | Traditional Meters installed on Current Transformers complete | 2026-10-28 A | 2026-10-28 A |  | 0% → 100% | 301d → none |  |  |
| 3135 | **Smart Meter Types installed on CT Connection Types** |  | 2025-07-25 A |  | 80% → 100% | 629d → none |  |  |
| 3139 | Suppliers resolve all issues |  | 2025-07-25 A |  | 55% → 100% | 629d → none |  |  |
| 3140 | Smart Meter Types installed on CT Connection Types complete | 2025-07-25 A | 2025-07-25 A |  | 0% → 100% | 629d → none |  |  |
| 3141 | **Linked Import / Export MPANs** |  | 2025-07-25 A |  | 83% → 100% | 629d → none |  |  |
| 3142 | LDSOs review and correct linked Import / Export MPANs with Different Connection Types |  | 2025-07-25 A |  | 83% → 100% | 629d → none |  |  |
| 3143 | LDSOs, Import and Export Suppliers review and correct linked Import / Export MPANs with meters in the Advanced and Traditional or Smart Meter Groups |  | 2025-07-25 A |  | 83% → 100% | 629d → none |  |  |
| 3144 | Linked Import / Export MPANs complete | 2025-07-25 A | 2025-07-25 A |  | 0% → 100% | 629d → none |  |  |
| 3145 | **Related MPANs** |  | 2025-07-25 A |  | 83% → 100% | 629d → none |  |  |
| 3147 | Suppliers unrelate any MPANs required |  | 2025-07-25 A |  | 28% → 100% | 629d → none |  |  |
| 3148 | Suppliers should investigate Related MPANs within different meter groups and verify that they are correct or request that their Meter Operators update the Meter Types where they are incorrect |  | 2025-07-25 A |  | 83% → 100% | 629d → none |  |  |
| 3149 | Related MPANs complete | 2025-07-25 A | 2025-07-25 A |  | 0% → 100% | 629d → none |  |  |
| 3150 | **Export / Import MPANs** |  | 2025-08-13 → 2025-09-22 A (+40d) | 363d → 392d | 99% → 100% | 617d → none |  |  |
| 3157 | Pre-migration data cleanse complete | 2025-08-13 → 2025-09-22 A (+40d) | 2025-08-13 → 2025-09-22 A (+40d) |  | 0% → 100% | 617d → none |  | constraint start no earlier than 2025-08-13 → finish no earlier than 2025-09-22; baseline start 2025-08-13 → 2025-09-22; baseline finish 2025-08-13 → 2025-09-22 |
| 3158 | **Migration Period Planning** |  | 2024-11-26 → 2024-06-04 A (-175d) | 367d → 242d | 83% → 100% | 678d → none |  |  |
| 3159 | **Migration Implementation Plan (incl. Migration Exit Criteria)** |  | 2024-11-26 → 2024-06-04 A (-175d) | 367d → 242d | 83% → 100% | 678d → none |  |  |
| 3174 | **Preparation for Cutover to Live** | 2024-06-28 A → 2024-06-03 A (-25d) | 2027-05-05 → 2027-05-20 (+15d) | 744d → 774d? | 27% → 71% | 166d → 155d |  |  |
| 3175 | **Central Systems Prepare for Cutover to Live** | 2024-06-28 A → 2024-06-03 A (-25d) | 2025-09-26 → 2025-10-22 A (+26d) | 326d → 363d? | 74% → 100% | 584d → none |  |  |
| 3177 | **Development of Comms Approach and Declaration Guidance** |  | 2025-08-14 A |  | 80% → 100% | 34d → none |  |  |

| ID | Task | Start | Finish | Duration | Complete | Total float | Predecessors | Other |
| --- | --- | --- | --- | --- | --- | --- | --- | --- |
| 3178 | Draft Cutover Comms Approach |  | 2025-07-17 A |  | 80% → 100% | 34d → none |  |  |
| 3179 | Draft Cutover Comms Approach shared | 2025-07-17 A | 2025-07-17 A |  | 0% → 100% | 34d → none |  |  |
| 3180 | Finalised Cutover Comms Approach shared | 2025-08-14 A | 2025-08-14 A |  | 0% → 100% | 34d → none |  |  |
| 3181 | **Development of Cutover Plan requirements with Participants** |  | 2025-08-22 → 2025-10-22 A (+61d) | 96d → 139d | 73% → 100% | 609d → none |  |  |
| 3183 | Development of Programme Participant Cutover Plans |  | 2025-07-11 A |  | 80% → 100% | 28d → none |  |  |
| 3186 | LDSO Cutover Plan Assurance | 2025-07-14 A | 2025-08-01 A |  | 0% → 100% | 624d → none |  | baseline start 2025-06-30 → 2025-07-14; baseline finish 2025-07-18 → 2025-08-01 |
| 3187 | SIT Supplier and SIT Agent Cutover Plan Assurance | 2025-07-14 A | 2025-08-22 A |  | 0% → 100% | 28d → none |  |  |
| 3189 | **M10/M11 Cutover Activities** | 2025-09-05 → 2025-04-14 (-144d) |  | 15d → 120d? | 0% → 100% | 14d → none |  |  |
| 3199 | Production DIP Portal (DIP Deployment) | 2025-09-05 → 2025-08-01 A (-35d) | 2025-09-05 → 2025-08-04 A (-32d) | 0d → 2d | 0% → 100% | 14d → none | 1672FS+10d → none | constraint none → start no earlier than 2025-08-01; baseline start 2025-09-05 → 2025-08-01; baseline finish 2025-09-05 → 2025-08-04 |
| 3200 | Production Certificates (DIP Deployment) | 2025-09-05 → 2025-08-01 A (-35d) | 2025-09-05 → 2025-08-04 A (-32d) | 0d → 2d | 0% → 100% | 14d → none | 1672FS+10d → none | constraint none → start no earlier than 2025-08-01; baseline start 2025-09-05 → 2025-08-01; baseline finish 2025-09-05 → 2025-08-04 |
| 3201 | Service Management Go-Live | 2025-09-19 → 2025-07-31 A (-50d) | 2025-09-19 → 2025-07-31 A (-50d) |  | 0% → 100% | 7d → none | 3244 → none | constraint none → start no earlier than 2025-07-31; baseline start 2025-09-19 → 2025-07-31; baseline finish 2025-09-19 → 2025-07-31 |
| 3208 | Completion of the pre-M10 MHHS Data Cleanse | 2025-09-22 A | 2025-09-22 A |  | 0% → 100% | 588d → none | 1802 → none | constraint none → finish no earlier than 2025-09-22; baseline start 2025-09-24 → 2025-09-22; baseline finish 2025-09-24 → 2025-09-22 |
| 3209 | Early Life Support Implemented | 2025-09-19 A | 2025-09-19 A |  | 0% → 100% | 8d → none | 3244 → none | constraint none → start no earlier than 2025-09-19 |
| 3210 | MCC Tested and Ready to Operate | 2025-09-19 → 2025-08-08 A (-42d) | 2025-09-19 A | 0d → 31d | 0% → 100% | 590d → none |  | constraint start no earlier than 2025-09-19 → start no earlier than 2025-08-08; baseline start 2025-09-19 → 2025-08-08 |
| 3211 | Market-wide Participant MHHS Supporting Functionality Ready - Confirmation from Code Bodies | 2025-09-15 A | 2025-09-15 A |  | 0% → 100% | 593d → none |  | constraint finish no earlier than 2025-09-15 → start no earlier than 2025-09-15 |
| 3212 | Market-wide Participant MHHS Supporting Functionality Ready | 2025-09-22 A | 2025-09-22 A |  | 0% → 100% | 588d → none | 1802 → none | constraint none → start no earlier than 2025-09-22 |
| 3224 | Central Systems live and Codes designated at 00:00 | 2025-09-22 A | 2025-09-22 A |  | 0% → 100% | 7d → none | Elexon Central Services DeploymentFS+1d, 3201FS+1d, Data Transfer Service (DTS) New Functionality DeploymentFS+1d, Electricity Enquiry Service (EES) DeploymentFS+1d, MPRS, UMSO Role, LDSO Role OperationalFS+1d, Population of Domestic Premises IndicatorFS+1d, Population of Market SegmentFS+1d, 3176FS+1d → 3176FS+1d | constraint none → finish no earlier than 2025-09-22 |
| 3231 | **Cutover Governance M10** | 2025-09-01 → 2025-08-22 A (-10d) | 2025-09-24 A | 17d → 23d | 0% → 100% | 7d → none |  |  |
| 3233 | Confirmation that all LDSOs have deployed MPRS 9 to production | 2025-09-01 A | 2025-09-01 A |  | 0% → 100% | 18d → none |  | constraint finish no earlier than 2025-09-01 → start no earlier than 2025-09-01 |
| 3234 | Confirmation that population of Domestic Premises Indicator is complete | 2025-09-08 A | 2025-09-08 A |  | 0% → 100% | 13d → none | 3233 → none | constraint finish no earlier than 2025-09-08 → start no earlier than 2025-09-08 |
| 3235 | Confirmation that Market Segment has been populated for 95% of LDSO portfolios | 2025-09-12 A | 2025-09-12 A |  | 0% → 100% | 7d → none |  | constraint finish no earlier than 2025-09-12 → start no earlier than 2025-09-12 |
| 3238 | Declaration from all Central Services and LDSOs that they are in a position to move forwards | 2025-09-15 A | 2025-09-15 A |  | 0% → 100% | 10d → none |  |  |
| 3243 | MCC Operational | 2025-09-19 A | 2025-09-19 A |  | 0% → 100% | 590d → none | 3210 → none | constraint none → start no earlier than 2025-09-19 |
| 3244 | MCAG (Confirm that the Programme can Enter M10) | 2025-09-19 A | 2025-09-19 A |  | 0% → 100% | 7d → none | TORWG (Recommendation from TORWG that the Programme should enter M10)FS+2d → none | constraint none → start no earlier than 2025-09-19 |
| 3245 | Self-Declaration from all Central Services and LDSOs that Cutover activities have been successfully carried out | 2025-09-22 A | 2025-09-22 A |  | 0% → 100% | 7d → none | 3244FS+1d → none | constraint none → start no earlier than 2025-09-22 |
| 3246 | Confirmation that DIP and ECS have been deployed, Service management is active, ISD has been populated | 2025-09-22 A | 2025-09-22 A |  | 0% → 100% | 7d → none | 3244FS+1d → none | constraint none → start no earlier than 2025-09-22 |
| 3254 | PSG (OFGEM and PSG to Approve That Conditions of M10 and M13 Have Been Met) | 2025-09-24 A | 2025-09-24 A |  | 0% → 100% | 7d → none | Recommendation from TORWG that PSG should approve M10FS+1d → none | constraint none → start no earlier than 2025-09-24 |
| 3255 | **Cutover Governance M11** | 2025-09-26 → 2025-10-14 A (+18d) | 2025-10-22 A | 19d → 6d | 0% → 100% | 5d → none |  |  |
| 3256 | Self-Declaration that MHHS Functionality will be deployed to Production by Qualified parties | 2025-10-14 A | 2025-10-14 A |  | 0% → 100% | 7d → none | 3254FS+12d → none | constraint finish no earlier than 2025-10-14 → start no earlier than 2025-10-14 |
| 3261 | PSG (OFGEM and PSG Decision to Confirm M11 and M12) | 2025-10-22 A | 2025-10-22 A |  | 0% → 100% | 5d → none | MCAG (Provide recommendation to PSG on M11 decision)FS+2d → none | constraint none → start no earlier than 2025-10-22 |
| 3266 | **Migration Sprints** | 2025-09-25 → 2025-09-24 A (-1d) | 2027-05-05 → 2027-05-20 (+15d) | 420d → 432d | 0% → 39% | 166d → 155d |  | baseline start none → 2025-09-24; baseline finish none → 2027-05-05 |
| 3267 | **Migration Sprint 0** | 2025-09-25 → 2025-09-24 A (-1d) | 2026-02-03 → 2026-02-17 A (+14d) | 94d → 105d | 0% → 100% | 492d → none |  |  |
| 3268 | Sprint 0 Planning start date | 2025-09-25 → 2025-09-24 A (-1d) | 2025-10-02 → 2025-10-01 A (-1d) |  | 0% → 100% | 492d → none |  | constraint start no earlier than 2025-09-25 → start no earlier than 2025-09-24 |
| 3269 | Issue Envelope | 2025-10-02 → 2025-10-01 A (-1d) | 2025-10-02 → 2025-10-01 A (-1d) |  | 0% → 100% | 492d → none |  |  |
| 3270 | Supplier Submission Deadline | 2025-10-09 → 2025-10-08 A (-1d) | 2025-10-09 → 2025-10-08 A (-1d) |  | 0% → 100% | 492d → none |  |  |
| 3271 | Baseline Schedule Publication | 2025-10-16 → 2025-10-15 A (-1d) | 2025-10-16 → 2025-10-15 A (-1d) |  | 0% → 100% | 492d → none |  |  |
| 3272 | Migration Sprint 0 Schedule Baselined | 2025-10-16 A | 2025-10-16 A |  | 0% → 100% | 492d → none |  | constraint none → finish no earlier than 2025-10-16 |
| 3273 | Sprint Execution Start | 2025-10-23 → 2025-10-22 A (-1d) | 2025-10-23 → 2025-10-22 A (-1d) |  | 0% → 100% | 492d → none | 3272FS+5d, 3374 → 3272FS+4d, 3374 |  |
| 3274 | Sprint Execution | 2025-10-24 → 2025-10-22 A (-2d) | 2026-02-03 A | 73d → 75d | 0% → 100% | 492d → none | 3273 → none | constraint none → start no earlier than 2025-10-22 |
| 3275 | Sprint Execution End | 2026-02-03 A | 2026-02-03 A |  | 0% → 100% | 492d → none |  |  |
| 3277 | **Migration Sprint 1** | 2026-01-07 A | 2026-03-31 → 2026-04-14 A (+14d) | 60d → 70d | 0% → 100% | 452d → none |  |  |
| 3278 | Sprint 1 Planning start date | 2026-01-07 A | 2026-01-14 A |  | 0% → 100% | 452d → none |  |  |
| 3279 | Issue Envelope | 2026-01-14 A | 2026-01-14 A |  | 0% → 100% | 452d → none |  |  |
| 3280 | Supplier Submission Deadline | 2026-01-21 A | 2026-01-21 A |  | 0% → 100% | 452d → none |  |  |
| 3281 | Baseline Schedule Publication | 2026-01-28 A | 2026-01-28 A |  | 0% → 100% | 452d → none |  |  |
| 3282 | Migration Sprint 1 Schedule Baselined | 2026-01-28 A | 2026-01-28 A |  | 0% → 100% | 452d → none |  |  |
| 3283 | Sprint Execution Start | 2026-02-04 A | 2026-02-04 A |  | 0% → 100% | 452d → none |  |  |
| 3284 | Sprint Execution | 2026-02-05 A | 2026-03-31 A |  | 0% → 100% | 452d → none |  |  |
| 3285 | Sprint Execution End | 2026-03-31 A | 2026-03-31 A |  | 0% → 100% | 452d → none |  |  |
| 3287 | **Migration Sprint 2** | 2026-03-04 A | 2026-06-02 → 2026-06-16 A (+14d) | 65d → 75d | 0% → 100% | 407d → none |  |  |
| 3288 | Sprint 2 Planning start date | 2026-03-04 A | 2026-03-11 A |  | 0% → 100% | 407d → none |  |  |
| 3289 | Issue Envelope | 2026-03-11 A | 2026-03-11 A |  | 0% → 100% | 407d → none |  |  |
| 3290 | Supplier Submission Deadline | 2026-03-18 A | 2026-03-18 A |  | 0% → 100% | 407d → none |  |  |
| 3291 | Baseline Schedule Publication | 2026-03-25 A | 2026-03-25 A |  | 0% → 100% | 407d → none |  |  |
| 3292 | Migration Sprint 2 Schedule Baselined | 2026-03-25 A | 2026-03-25 A |  | 0% → 100% | 407d → none |  |  |
| 3293 | Sprint Execution Start | 2026-04-01 A | 2026-04-01 A |  | 0% → 100% | 407d → none |  |  |
| 3294 | Sprint Execution | 2026-04-02 A | 2026-06-02 A |  | 0% → 100% | 407d → none |  |  |
| 3295 | Non-SIT Participants Migration Start | 2026-05-15 A | 2026-05-15 A |  | 0% → 100% | 419d → none |  |  |
| 3296 | Sprint Execution End | 2026-06-02 A | 2026-06-02 A |  | 0% → 100% | 407d → none |  |  |
| 3298 | **Migration Sprint 3** | 2026-05-06 A | 2026-08-04 → 2026-08-18 (+14d) | 65d → 75d | 0% → 10% | 362d → 352d |  |  |
| 3299 | Sprint 3 Planning start date | 2026-05-06 A | 2026-05-13 A |  | 0% → 100% | 362d → none |  |  |
| 3300 | Issue Envelope | 2026-05-13 A | 2026-05-13 A |  | 0% → 100% | 362d → none |  |  |
| 3301 | Supplier Submission Deadline | 2026-05-20 A | 2026-05-20 A |  | 0% → 100% | 362d → none |  |  |
| 3302 | Baseline Schedule Publication | 2026-05-27 A | 2026-05-27 A |  | 0% → 100% | 362d → none |  |  |
| 3303 | Migration Sprint 3 Schedule Baselined | 2026-05-27 A | 2026-05-27 A |  | 0% → 100% | 362d → none |  |  |
| 3304 | Sprint Execution Start | 2026-06-03 A | 2026-06-03 A |  | 0% → 100% | 362d → none |  |  |
| 3308 | **Migration Sprint 4** |  | 2026-10-06 → 2026-10-20 (+14d) | 65d → 75d |  | 317d → 307d |  |  |
| 3318 | **Migration Sprint 5** |  | 2026-12-01 → 2026-12-15 (+14d) | 60d → 70d |  | 277d → 267d |  |  |
| 3328 | **Migration Sprint 6** |  | 2027-02-02 → 2027-02-16 (+14d) | 65d → 75d |  | 232d → 222d |  |  |
| 3338 | **Migration Sprint 7** |  | 2027-04-06 → 2027-04-20 (+14d) | 65d → 75d |  | 187d → 177d |  |  |

| ID | Task | Start | Finish | Duration | Complete | Total float | Predecessors | Other |
| --- | --- | --- | --- | --- | --- | --- | --- | --- |
| 3348 | **Migration Sprint 8** |  | 2027-05-05 → 2027-05-20 (+15d) | 48d → 59d |  |  |  |  |
| 3358 | **External Programme Dependency Management** |  | 2025-08-29 A |  | 66% → 100% | 604d → none |  |  |
| 3362 | **BSC Mod P434** |  | 2025-07-23 A |  | 57% → 100% | 631d → none |  |  |
| 3364 | Monitor progress and await implementation date |  | 2025-07-23 A |  | 52% → 100% | 631d → none |  |  |
| 3365 | **Elexon System Capacity Upgrade** |  | 2025-07-01 A |  | 58% → 100% | 647d → none |  |  |
| 3366 | Monitor progress to implementation |  | 2025-07-01 A |  | 58% → 100% | 647d → none |  |  |
| 3367 | Implementation date | 2025-07-01 A | 2025-07-01 A |  | 0% → 100% | 647d → none |  |  |
| 3368 | **DCC System Capacity Upgrade** | 2025-07-28 A | 2025-08-29 A |  | 0% → 100% | 604d → none |  |  |
| 3369 | Assurance of DCC capacity upgrade to ensure suitability to support migration | 2025-07-28 A | 2025-08-22 A |  | 0% → 100% | 604d → none |  |  |
| 3370 | DCC Capacity Upgrade Operational | 2025-08-29 A | 2025-08-29 A |  | 0% → 100% | 604d → none |  |  |
| 3371 | **Migration - Tier 1 Milestones** | 2025-09-22 A |  |  |  | 27d → 98d |  |  |
| 3372 | Load Shaping Service switched on (M13) | 2025-09-22 A | 2025-09-22 A |  | 0% → 100% | 27d → none |  | baseline start 2025-09-24 → 2025-09-22; baseline finish 2025-09-24 → 2025-09-22 |
| 3373 | Load Shaping Service switched on (M13*) - Late Exit | 2025-12-24 A | 2025-12-24 A |  | 0% → 100% | 521d → none |  |  |
| 3374 | Start of 18-month migration for UMS / Advanced (M11) | 2025-10-22 A | 2025-10-22 A |  | 0% → 100% | 5d → none | 3372, MCAG (Provide recommendation to PSG on M11 decision), 3261, 1802FS+20d → 3372, 1802FS+22d, 3043 |  |
| 3375 | Start of 18-month migration for UMS / Advanced (M11*) - Late Exit | 2026-01-21 A | 2026-01-21 A |  | 0% → 100% | 501d → none |  |  |
| 3376 | Start of 18-month migration for Smart / Non-smart (M12) | 2025-10-22 A | 2025-10-22 A |  | 0% → 100% | 501d → none |  |  |
| 3377 | Start of 18-month migration for Smart / Non-smart (M12*) - Late Exit | 2026-01-21 A | 2026-01-21 A |  | 0% → 100% | 501d → none |  |  |
| 3380 | **BUSINESS & OPERATIONAL READINESS** |  |  |  | 36% → 86% |  |  |  |
| 3381 | **Service Management** |  | 2026-03-26 → 2026-10-27 (+215d) | 889d → 1041d | 22% → 91% | 455d → 303d |  |  |
| 3392 | **Service Management Arrangements Implementation** | 2022-10-31 A | 2026-01-14 A |  | 0% → 100% | 506d → none |  |  |
| 3393 | Hypercare post M10 | 2025-09-23 A | 2026-01-14 A |  | 0% → 100% | 506d → none |  |  |
| 3394 | Monitor Elexon implementation of Service Management arrangements | 2022-10-31 A | 2024-07-01 A |  | 0% → 100% | 908d → none |  |  |
| 3395 | **Migration Pathway (MP1) and Migration Pathway 2 (MP2)** | 2022-10-31 → 2026-03-31 A (+1247d) | 2025-09-26 → 2026-05-15 A (+231d) | 760d → 33d | 0% → 100% | 584d → none |  | was named Wave 1; baseline start 2022-10-31 → 2026-03-31; baseline finish 2026-05-14 → 2026-05-22 |
| 3398 | Identify Resources | 2025-10-06 → 2026-03-31 A (+176d) | 2025-10-06 → 2026-03-31 A (+176d) |  | 0% → 100% | 578d → none |  | constraint start no earlier than 2025-10-06 → start no earlier than 2026-03-31; baseline start 2025-10-06 → 2026-03-31; baseline finish 2025-10-06 → 2026-03-31 |
| 3400 | Agree & Understand Support Model | 2025-10-07 → 2026-04-01 A (+176d) | 2025-10-07 → 2026-04-01 A (+176d) |  | 0% → 100% | 577d → none |  | constraint start no earlier than 2025-10-07 → start no earlier than 2026-04-01; baseline start 2025-10-07 → 2026-04-01; baseline finish 2025-10-07 → 2026-04-01 |
| 3408 | Target Systems and Environments Ready | 2025-10-14 → 2026-04-08 A (+176d) | 2025-10-14 → 2026-04-08 A (+176d) |  | 0% → 100% | 572d → none |  | constraint start no earlier than 2025-10-14 → start no earlier than 2026-04-08; baseline start 2025-10-14 → 2026-04-08; baseline finish 2025-10-14 → 2026-04-08 |
| 3409 | Provide LWIs | 2025-10-15 → 2026-04-09 A (+176d) | 2025-10-15 → 2026-04-09 A (+176d) | 1d? → 1d | 0% → 100% | 570d → none |  | constraint start no earlier than 2025-10-15 → start no earlier than 2026-04-09; baseline start 2025-10-15 → 2026-04-09; baseline finish 2025-10-15 → 2026-04-09 |
| 3410 | Business Readiness Governance Approval | 2025-10-16 → 2026-04-10 A (+176d) | 2025-10-16 → 2026-04-10 A (+176d) |  | 0% → 100% | 570d → none | 3409 → none | constraint start no earlier than 2025-09-05 → start no earlier than 2026-04-10; baseline start 2025-10-16 → 2026-04-10; baseline finish 2025-10-16 → 2026-04-10 |
| 3412 | **MP1 and MP2 - Service Activation Implementation** | 2025-09-01 → 2026-04-02 A (+213d) | 2025-09-11 → 2026-05-15 A (+246d) | 9d → 31d | 0% → 100% | 585d → none |  | was named Wave 1 - Service Activation Implementation; baseline start 2025-09-01 → 2026-04-02; baseline finish 2025-09-05 → 2026-05-15 |
| 3414 | PP is Qualified by Code Bodies | 2025-09-01 → 2026-04-15 A (+226d) | 2025-09-02 → 2026-04-15 A (+225d) | 2d → 0d | 0% → 100% | 602d → none | none → 2646 | was named MHHSP Enabled Confirmation; constraint finish no earlier than 2025-09-02 → finish no earlier than 2026-04-14; baseline start 2025-09-01 → 2026-04-15; baseline finish 2025-09-02 → 2026-04-15 |
| 3415 | DIP Promoted to Production | 2025-09-04 → 2026-04-16 A (+224d) | 2025-09-05 → 2026-04-22 A (+229d) | 2d → 5d | 0% → 100% | 584d → none | Add EFD to DIP → 3414 | constraint finish no earlier than 2025-09-04 → start no earlier than 2026-04-16; baseline start 2025-09-03 → 2026-04-20; baseline finish 2025-09-04 → 2026-04-24 |
| 3416 | Create M16 in Customer Solution | 2025-09-08 → 2026-04-16 A (+220d) | 2025-09-09 → 2026-04-16 A (+219d) | 2d → 1d | 0% → 100% | 584d → none | 3415 → none | constraint finish no earlier than 2025-09-05 → start no earlier than 2026-04-16; baseline start 2025-09-04 → 2026-04-17; baseline finish 2025-09-05 → 2026-04-17 |
| 3417 | MDD & ISD Publish | 2025-09-10 → 2026-05-07 A (+239d) | 2025-09-11 → 2026-05-07 A (+238d) | 2d → 1d | 0% → 100% | 584d → none | 3416 → 3414, 3422 | was named Publish ISD; constraint finish no earlier than 2025-09-05 → start no earlier than 2026-05-07; baseline start 2025-09-04 → 2026-05-07; baseline finish 2025-09-05 → 2026-05-07 |
| 3419 | MP1 and MP2 - Service Activation Implementation Complete (M) | 2025-09-11 → 2026-05-15 A (+246d) | 2025-09-11 → 2026-05-15 A (+246d) |  | 0% → 100% | 595d → none | 3417 → 3418 | was named Wave 1 - Service Activation Implementation Complete (M); constraint finish no earlier than 2025-09-05 → start no earlier than 2026-05-15; baseline start 2025-09-05 → 2026-05-15; baseline finish 2025-09-05 → 2026-05-15 |
| 3420 | **MP1 and MP2 - Service Activation Implementation MDD** | 2025-09-12 → 2026-05-06 (+236d) | 2025-09-26 → 2026-05-07 (+223d) | 11d → 2d | 0% → 100% | 584d → none |  | was named Wave 1 - Service Activation Implementation MDD; baseline start 2025-09-04 → 2026-05-06; baseline finish 2025-09-17 → 2026-05-06 |
| 3421 | MDD Final Circular Completed | 2025-10-15 → 2026-05-06 A (+203d) | 2025-10-15 → 2026-05-06 A (+203d) |  | 0% → 100% | 571d → none | 2176, 2184 → none | constraint finish no earlier than 2025-09-10 → start no earlier than 2026-04-15; baseline start 2025-10-15 → 2026-05-06; baseline finish 2025-10-15 → 2026-05-06 |
| 3422 | MDD Manual Update | 2025-10-13 → 2026-05-05 A (+204d) | 2025-10-15 → 2026-05-06 A (+203d) | 3d → 2d | 0% → 100% | 571d → none | 3421FF → 3421 | constraint finish no earlier than 2025-09-15 → none; baseline start 2025-10-13 → 2026-05-05; baseline finish 2025-10-15 → 2026-05-06 |
| 3423 | **Migration Pathway 3 (MP3) and Migration Pathway 4 (MP4)** | 2022-10-31 → 2026-03-27 A (+1243d) | 2025-11-20 → 2026-06-09 A (+201d) | 799d → 52d | 0% → 100% | 545d → none |  | was named Wave 2; baseline start 2022-10-31 → 2026-03-27; baseline finish 2026-06-30 → 2026-06-19 |
| 3424 | **MP3 and MP4 - Service Activation Implementation** | 2025-11-03 → 2026-03-27 A (+144d) | 2025-11-13 → 2026-06-09 A (+208d) | 9d → 52d | 0% → 100% | 550d → none |  | was named Wave 2 - Service Activation Implementation; baseline start 2025-11-03 → 2026-05-15; baseline finish 2025-11-07 → 2026-06-08 |
| 3427 | PP is Qualified by Code Bodies | 2025-11-03 → 2026-05-28 A (+206d) | 2025-11-04 → 2026-05-28 A (+205d) | 2d → 0d | 0% → 100% | 557d → none | none → 2684 | was named MHHSP Enabled Confirmation; constraint finish no earlier than 2025-11-04 → none; baseline start 2025-11-03 → 2026-05-28; baseline finish 2025-11-04 → 2026-05-28 |
| 3428 | DIP Promoted to Production | 2025-11-06 → 2026-05-29 A (+204d) | 2025-11-07 → 2026-06-04 A (+209d) | 2d → 5d | 0% → 100% | 550d → none | Add EFD to DIP → 3427 | baseline start 2025-11-05 → 2026-05-29; baseline finish 2025-11-06 → 2026-06-04 |
| 3429 | Create M16 in Customer Solution | 2025-11-10 → 2026-05-29 A (+200d) | 2025-11-11 → 2026-05-29 A (+199d) | 2d → 1d | 0% → 100% | 550d → none | 3428 → 3427 | baseline start 2025-11-06 → 2026-05-29; baseline finish 2025-11-07 → 2026-05-29 |
| 3430 | ISD Publish | 2025-11-12 → 2026-06-01 A (+201d) | 2025-11-13 → 2026-06-01 A (+200d) | 2d → 1d | 0% → 100% | 550d → none | 3429 → 3427 | was named Publish ISD; constraint finish no earlier than 2025-11-07 → start no earlier than 2026-06-01; baseline start 2025-11-06 → 2026-06-01; baseline finish 2025-11-07 → 2026-06-01 |
| 3432 | MP3 and MP4 - Service Activation Implementation Complete (M) | 2025-11-13 → 2026-06-09 A (+208d) | 2025-11-13 → 2026-06-09 A (+208d) |  | 0% → 100% | 550d → none | 3430 → none | was named Wave 2 - Service Activation Implementation Complete (M); constraint finish no earlier than 2025-11-07 → start no earlier than 2026-06-09; baseline start 2025-11-07 → 2026-06-09; baseline finish 2025-11-07 → 2026-06-09 |
| 3433 | **Migration Pathway 6 (MP6)** | 2022-10-31 → 2026-04-24 A (+1271d) | 2026-03-26 → 2026-07-07 (+103d) | 889d → 53d | 0% → 9% | 455d → none |  | was named Wave 4; baseline start 2022-10-31 → 2026-04-24; baseline finish 2026-10-22 → 2026-07-07 |
| 3434 | **MP6 - Service Activation Implementation** | 2025-03-03 → 2026-04-24 A (+417d) | 2026-03-12 → 2026-07-07 (+117d) | 269d → 53d | 0% → 20% | 465d → none |  | was named Wave 4 - Service Activation Implementation; baseline start 2025-03-03 → 2026-04-24; baseline finish 2026-03-06 → 2026-07-07 |
| 3437 | PP Qualified by Code Bodies | 2026-03-02 → 2026-06-25 (+115d) | 2026-03-03 → 2026-06-25 (+114d) | 2d → 1d |  | 472d → none |  | was named MHHSP Enabled Confirmation; constraint finish no earlier than 2026-03-03 → start no earlier than 2026-06-25; baseline start 2026-03-02 → 2026-06-25; baseline finish 2026-03-03 → 2026-06-25 |
| 3438 | DIP Promoted to Production | 2026-03-05 → 2026-06-26 (+113d) | 2026-03-06 → 2026-07-02 (+118d) | 2d → 5d |  | 465d → none | Add EFD to DIP → 3437 | constraint finish no earlier than 2026-03-05 → start no earlier than 2026-06-26; baseline start 2026-03-04 → 2026-06-26; baseline finish 2026-03-05 → 2026-07-02 |
| 3439 | Create M16 in Customer Solution | 2026-03-09 → 2026-06-26 (+109d) | 2026-03-10 → 2026-06-26 (+108d) | 2d → 1d |  | 465d → none | 3438 → none | constraint finish no earlier than 2026-03-06 → start no earlier than 2026-06-26; baseline start 2026-03-05 → 2026-06-26; baseline finish 2026-03-06 → 2026-06-26 |
| 3440 | ISD Publish | 2026-03-11 → 2026-06-29 (+110d) | 2026-03-12 → 2026-06-29 (+109d) | 2d → 1d |  | 465d → none | 3439 → 3439SS | was named Publish ISD; constraint finish no earlier than 2026-03-06 → start no earlier than 2026-06-29; baseline start 2026-03-05 → 2026-06-29; baseline finish 2026-03-06 → 2026-06-29 |
| 3442 | MP6 - Service Activation Implementation Complete (M) | 2026-03-12 → 2026-07-07 (+117d) | 2026-03-12 → 2026-07-07 (+117d) |  |  | 465d → none |  | was named Wave 4 - Service Activation Implementation Complete (M); constraint finish no earlier than 2026-03-06 → start no earlier than 2026-07-07; baseline start 2026-03-06 → 2026-07-07; baseline finish 2026-03-06 → 2026-07-07 |
| 3449 | DIP Promoted to Production | 2025-09-26 → 2026-07-16 (+293d) | 2025-09-26 → 2026-07-22 (+299d) | 1d → 5d |  | 584d → none | 2177 → 3448 | constraint start no earlier than 2025-09-12 → start no earlier than 2026-07-16; baseline start 2025-10-17 → 2026-07-16; baseline finish 2025-10-17 → 2026-07-22 |
| 3450 | Create M16 in Customer Solution | 2025-12-31 → 2026-07-16 (+197d) | 2026-01-01 → 2026-07-16 (+196d) | 2d → 1d |  | 513d → none | 3486 → 3448 | constraint finish no earlier than 2025-12-30 → start no earlier than 2026-07-16; baseline start 2025-12-29 → 2026-07-16; baseline finish 2025-12-30 → 2026-07-16 |
| 3456 | MDD Manual Update | 2025-12-24 → 2026-07-16 (+204d) | 2025-12-26 → 2026-07-17 (+203d) | 3d → 2d |  | 519d → 374d | MDD Final CircularFS+4d → none | constraint finish no earlier than 2025-09-15 → start no earlier than 2026-07-16; baseline start 2025-12-24 → 2026-07-16; baseline finish 2025-12-26 → 2026-07-17 |
| 3462 | DIP Promoted to Production | 2025-10-16 → 2026-07-31 (+288d) | 2025-10-16 → 2026-08-06 (+294d) | 1d → 5d |  | 570d → 360d | 2185 → 3461 | constraint start no earlier than 2025-09-12 → start no earlier than 2026-07-31; baseline start 2025-10-17 → 2026-07-31; baseline finish 2025-10-17 → 2026-08-06 |
| 3463 | Create M16 in Customer Solution | 2025-02-26 → 2026-07-31 (+520d) | 2025-02-27 → 2026-07-31 (+519d) | 2d → 1d |  | 735d → 359d | none → 3461 | constraint finish no earlier than 2025-02-27 → start no earlier than 2026-07-31; baseline start 2025-02-26 → 2026-09-25; baseline finish 2025-02-27 → 2026-09-25 |
| 3473 | DIP Promoted to Production | 2025-10-31 → 2026-08-13 (+286d) | 2025-10-31 → 2026-08-19 (+292d) | 1d → 5d |  | 559d → 351d | 2206 → 3472 | constraint start no earlier than 2025-09-12 → start no earlier than 2026-08-13; baseline start 2025-12-22 → 2026-09-25; baseline finish 2025-12-22 → 2026-10-01 |
| 3486 | DIP Promoted to Production | 2025-12-29 → 2026-08-28 (+242d) | 2025-12-30 → 2026-09-03 (+247d) | 2d → 5d |  | 513d → 340d | Add EFD to DIP → 3485 | constraint finish no earlier than 2025-12-30 → start no earlier than 2026-08-28; baseline start 2025-12-29 → 2026-08-28; baseline finish 2025-12-30 → 2026-09-03 |
| 3497 | DIP Promoted to Production | 2025-02-26 → 2026-09-10 (+561d) | 2025-02-27 → 2026-09-16 (+566d) | 2d → 5d |  | 735d → 331d | none → 3496 | constraint finish no earlier than 2025-02-27 → start no earlier than 2026-09-10; baseline start 2025-02-26 → 2026-09-25; baseline finish 2025-02-27 → 2026-10-01 |
| 3529 | **Implement Early Life Support Plan** | 2025-07-07 A | 2025-09-19 A |  | 0% → 100% | 589d → none |  |  |
| 3530 | Implement Early Life Support Plan | 2025-07-07 A | 2025-09-19 A |  | 0% → 100% | 589d → none |  |  |
| 3535 | **Business Continuity and Disaster Recovery Plan** | 2025-07-31 A | 2025-09-24 A |  | 0% → 100% | 586d → none |  |  |
| 3536 | Central Parties BCDRs in Place | 2025-07-31 A | 2025-08-27 A |  | 0% → 100% | 586d → none |  |  |
| 3537 | Risk Based Assurance of Cental Party BCDRs | 2025-08-28 A | 2025-09-24 A |  | 0% → 100% | 586d → none |  |  |
| 3606 | M16 Checkpoint 1 | 2026-06-25 → 2026-07-17 (+22d) | 2026-06-25 → 2026-07-17 (+22d) |  |  | 5d → 374d | Elexon to produce Settlement Calendar for Settlement Year 2025/2026FS+176d → 3605 | constraint none → finish no earlier than 2026-07-17; baseline start 2026-06-25 → 2026-07-17; baseline finish 2026-06-25 → 2026-07-17 |
| 3640 | **M16 Approval Window** |  |  |  |  |  |  | baseline start 2027-06-25 → 2027-06-29 |
| 3641 | Panel approval that M16 criteria met |  |  |  |  |  | Confirm M16 DateFS+40d → 3625FS+5d | baseline start 2027-06-25 → 2027-06-29; baseline finish 2027-06-25 → 2027-06-29 |
| 3642 | Cut over to new settlement timetable (M16) |  |  |  |  |  | 3641, 3378FS+40d, Elexon monitor settlement data of migrated MPANs, Raise fast track change to ISD (November publish), M16 methodology approved → 3641, 3378FS+40d, 3639 |  |
| 3685 | **READINESS ASSESSMENTS** |  |  |  | 46% → 60% |  |  |  |
| 3693 | **Readiness Assessment 5 / 6 - Start of Qualification and Participant Readiness for M10 and M11 and CP3/CP4 check** |  | 2025-07-01 A |  | 96% → 100% | 647d → none |  |  |

| ID | Task | Start | Finish | Duration | Complete | Total float | Predecessors | Other |
| --- | --- | --- | --- | --- | --- | --- | --- | --- |
| 3696 | Analyse survey responses |  | 2025-06-27 A |  | 95% → 100% | 649d → none |  |  |
| 3697 | Conduct deep-dive interviews (sample of PPs) |  | 2025-06-27 A |  | 95% → 100% | 649d → none |  |  |
| 3698 | Produce Readiness Assessment Reports (Overall Report & Individual Participant Reports) |  | 2025-06-27 A |  | 95% → 100% | 647d → none |  |  |
| 3699 | Readiness Assessment 5 / 6 - Start of Qualification and Participant Readiness for M10 and M11 and CP3/CP4 check (incl. Readiness Assessment Report approval) Completed | 2025-07-01 A | 2025-07-01 A |  | 0% → 100% | 647d → none |  |  |
| 3700 | **Readiness Assessment 7 - Migration Checkpoint** | 2026-01-12 → 2026-03-02 A (+49d) | 2026-03-19 → 2026-04-01 A (+13d) | 49d → 23d | 0% → 100% | 460d → none |  | baseline start 2026-01-12 → 2026-03-02; baseline finish 2026-03-19 → 2026-04-01 |
| 3706 | Readiness Assessment 7 - Migration Checkpoint - Completed (incl. Readiness Assessment Report approval) | 2026-03-19 → 2026-04-01 A (+13d) | 2026-03-19 → 2026-04-01 A (+13d) |  | 0% → 100% | 460d → none | Produce Readiness Assessment Reports (Overall Report & Individual Participant Reports)FS+4d → 3705 | baseline start 2026-03-19 → 2026-04-01; baseline finish 2026-03-19 → 2026-04-01 |
| 3707 | **Readiness Assessment 8 - Ready for New Settlement Timetable** |  |  |  |  |  |  | was named Readiness Assessment 8 - Ready to Accept New MPANs |
| 3721 | **Readiness Assessments - Tier 1 Milestones** | 2025-07-01 A |  |  |  |  |  |  |
| 3722 | Readiness Assessment 6 - Start of Migration - Completed (incl. Readiness Assessment Report approval) | 2025-07-01 A | 2025-07-01 A |  | 0% → 100% | 647d → none |  |  |
| 3723 | Readiness Assessment 7 - Migration Checkpoint - Completed (incl. Readiness Assessment Report approval) | 2026-03-19 → 2026-04-01 A (+13d) | 2026-03-19 → 2026-04-01 A (+13d) |  | 0% → 100% | 460d → none | 3706 → none | constraint none → finish no earlier than 2026-04-01; baseline start 2026-03-19 → 2026-04-01; baseline finish 2026-03-19 → 2026-04-01 |
| 3724 | Readiness Assessment 8 - Ready for New Settlement Timetable - Completed (incl. Readiness Assessment Report approval) | 2026-10-13 → 2026-08-14 (-60d) | 2026-10-13 → 2026-08-14 (-60d) |  |  | 312d → 355d | 3713 → none | was named Readiness Assessment 8 - Ready to Accept New MPANs - Completed (incl. Readiness Assessment Report approval); constraint none → start no earlier than 2026-08-14; baseline start 2026-10-13 → 2026-08-14; baseline finish 2026-10-13 → 2026-08-14 |
| 3726 | **CONTROL POINTS** |  |  |  | 51% → 79% |  |  |  |
| 3733 | **Control Point 3/4 - Readiness for Migration** | 2025-08-21 A | 2025-09-18 → 2025-09-24 A (+6d) | 20d → 25d | 0% → 100% | 591d → none |  |  |
| 3734 | Control Point 3/4 Preparation (incl. Control Point Report development and review) | 2025-08-21 A | 2025-09-09 → 2025-09-24 A (+15d) | 14d → 25d | 0% → 100% | 597d → none |  |  |
| 3735 | Control Point 3/4 - Readiness for Migration (incl. Control Point Report approval) | 2025-09-18 → 2025-09-24 A (+6d) | 2025-09-18 → 2025-09-24 A (+6d) |  | 0% → 100% | 591d → none |  | constraint none → finish no earlier than 2025-09-24 |
| 3742 | Control Point 3/4 - Readiness for Migration (incl. Control Point Report approval) | 2025-09-18 → 2025-09-24 A (+6d) | 2025-09-18 → 2025-09-24 A (+6d) |  | 0% → 100% | 591d → none |  |  |
| 3744 | **MILESTONE RANGE CHECKPOINTS** | 2025-07-31 A | 2027-04-12 → 2027-02-15 (-56d) | 442d → 402d |  | 184d → 224d |  |  |
| 3745 | **M10, M11, M12 and M13 milestone checkpoint** | 2025-07-31 A | 2025-07-31 A |  | 0% → 100% | 626d → none |  |  |
| 3746 | M10, M11, M12, and M13 milestone checkpoint - date approval | 2025-07-31 A | 2025-07-31 A |  | 0% → 100% | 626d → none |  |  |

## Version 8 (data date 2026-07-01, saved 2026-07-02, file MHHS-DEL1139 - MHHS Plan v6.53.mpp)

Last finish stays 2027-12-23. Complete tasks 2716 → 2731.

Added:

| ID | Task | Duration | Start | Finish | Constraint |
| --- | --- | --- | --- | --- | --- |
| 3613 | Update Monitoring Data to be provided from Performance Assurance and MCC | 1d | 2026-09-01 | 2026-09-01 | start no earlier than 2026-09-01 |
| 3618 | Communication issued to Industry notifying Parties RF will be 7 months | 1d | 2026-09-15 | 2026-09-15 | start no earlier than 2026-09-15 |

Changed:

| ID | Task | Start | Finish | Duration | Complete | Total float | Other |
| --- | --- | --- | --- | --- | --- | --- | --- |
| 1 | **PROGRAMME PLAN.** |  |  |  | 93% → 94% |  |  |
| 3 | **PROGRAMME MANAGEMENT** |  |  |  | 87% → 88% |  |  |
| 4 | **Programme Management** |  |  |  | 87% → 88% |  |  |
| 5 | Sprint-based prioritisation planning and execution |  |  |  | 87% → 88% |  |  |
| 6 | Programme governance secretariat |  |  |  | 87% → 88% |  |  |
| 7 | RAID management and reporting |  |  |  | 87% → 88% |  |  |
| 8 | Tracking against Programme outcomes and KPIs |  |  |  | 87% → 88% |  |  |
| 9 | Change control and reporting |  |  |  | 87% → 88% |  |  |
| 10 | Ongoing identification of lessons learned relating to the PMO and implementation of improvements |  |  |  | 87% → 88% |  |  |
| 11 | **Programme Internal Assurance Reviews** |  |  |  | 87% → 88% |  |  |
| 12 | Programme Internal Assurance Reviews |  |  |  | 87% → 88% |  |  |
| 13 | **Engagement with PPs** |  |  |  | 87% → 88% |  |  |
| 14 | Ongoing PP liaison activities |  |  |  | 87% → 88% |  |  |
| 15 | Milestone and Control Point objective setting |  |  |  | 87% → 88% |  |  |
| 16 | Reporting |  |  |  | 87% → 88% |  |  |
| 17 | **PP Engagement Events** |  |  |  | 87% → 88% |  |  |
| 18 | Bilateral meetings |  |  |  | 87% → 88% |  |  |
| 19 | Monthly webinars |  |  |  | 87% → 88% |  |  |
| 20 | Open days |  |  |  | 87% → 88% |  |  |
| 21 | **PP Communications** |  |  |  | 87% → 88% |  |  |
| 22 | The Clock updates (weekly) |  |  |  | 87% → 88% |  |  |
| 23 | Maintain and update content on public-facing Portal (and ongoing feedback reviews to identify and implement Portal improvements) |  |  |  | 87% → 88% |  |  |
| 24 | **Code Change Support / Other Programme Alignment** |  |  |  | 87% → 88% |  |  |
| 25 | Support DCC/BEIS on SEC change |  |  |  | 87% → 88% |  |  |
| 26 | Support on Smart Meters Act changes |  |  |  | 87% → 88% |  |  |
| 27 | Support DCC/RECCo on CSS change |  |  |  | 87% → 88% |  |  |
| 28 | Support Elexon on BSC change |  |  |  | 87% → 88% |  |  |
| 29 | Support code change inside & outside CCIAG |  |  |  | 87% → 88% |  |  |
| 30 | Support code change inside & outside CCAG |  |  |  | 87% → 88% |  |  |
| 46 | **Design Baseline & Enduring PP Support** |  |  |  | 93% → 94% |  |  |
| 61 | Maintain E2E MHHS Design (post-M5 design change management processes operational) |  |  |  | 85% → 86% |  |  |
| 1724 | **Onboarding and Test Data (Sandbox UIT)** |  |  |  | 88% → 90% |  |  |
| 1726 | Supplier & Agent Onboarding and Test Data Creation and Support |  |  |  | 80% → 84% |  |  |
| 1727 | **Sandbox Execution** |  |  |  | 89% → 91% |  |  |
| 1737 | **Sandbox Testing Execution (UIT) - Supplier & Agent Participants** |  |  |  | 80% → 84% |  |  |
| 1740 | Sandbox Testing Execution (UIT) - Supplier & Agent Participants |  |  |  | 80% → 84% |  |  |
| 2309 | **ELEXON / HELIX M10 - M16** |  | 2026-06-30 A |  | 86% → 100% | 387d → none |  |
| 2310 | **SAT M16 Test Case Execution** |  | 2026-06-30 A |  | 86% → 100% | 387d → none |  |
| 2313 | SAT Test & Sign-off of Two Cases (Elexon Internal Sign-off) |  | 2026-06-30 A |  | 59% → 100% | 387d → none |  |
| 2314 | SAT Programme Assurance Review of Test Results |  | 2026-06-30 A |  | 86% → 100% | 387d → none |  |
| 2428 | **MHHS Qualification - Qualification Waves** |  |  |  | 97% → 98% |  |  |
| 2685 | **Qualification Wave 3** |  |  | 254d? → 254d | 94% → 99% |  |  |
| 2706 | **Qualification Wave 3 QT Execution** |  | 2026-05-15 → 2026-05-08 A (-7d) | 110d? → 105d |  |  | baseline start 2025-11-03 → 2025-12-15; baseline finish 2026-03-24 → 2026-05-15 |
| 2713 | **Qualification Wave 3 Exit** |  |  |  | 81% → 97% |  |  |
| 2718 | All Qualification Wave 3 Participants have submitted their Final QAD | 2026-05-22 A |  |  | 0% → 97% |  |  |
| 2719 | Completion of Code Bodies review of Final QAD | 2026-05-25 A |  |  | 0% → 94% | 365d → 0.9d |  |
| 2720 | QAD Sign Off deadline | 2026-06-26 A |  |  | 0% → 90% |  |  |
| 2723 | **Qualification Wave 4** |  |  |  | 74% → 78% |  |  |
| 2729 | Completion of Code Bodies review of Initial QAD | 2026-02-27 A |  |  | 0% → 60% |  |  |
| 2744 | Qualification Wave 4 QT Execution Window |  |  |  |  |  | baseline finish 2026-07-17 → 2026-07-10 |
| 2746 | **Qualification Wave 4 Exit** |  |  |  | 13% → 28% |  |  |
| 2749 | Qualification Wave 4 Participants submit their Final QAD |  |  |  | 16% → 33% | 1.4d → 3.2d |  |
| 2751 | Completion of Code Bodies review of Final QAD |  |  |  | 7% → 16% |  |  |
| 2789 | PAB2026/11 | 2026-06-25 A | 2026-06-25 A |  | 0% → 100% | 390d → none |  |
| 2953 | **Regulatory Governance** |  | 2026-07-01 A |  | 99% → 100% | 387d → none |  |
| 2957 | Incentives Implementation | 2026-06-25 A | 2026-06-25 A |  | 0% → 100% | 390d → none |  |
| 2960 | CR065 PSG Approval | 2026-07-01 A | 2026-07-01 A |  | 0% → 100% | 387d → none |  |
| 3174 | **Preparation for Cutover to Live** |  |  |  | 71% → 73% |  |  |
| 3266 | **Migration Sprints** |  |  |  | 39% → 43% |  |  |
| 3298 | **Migration Sprint 3** |  |  |  | 10% → 43% |  |  |
| 3305 | Sprint Execution | 2026-06-04 A |  |  | 0% → 45% |  |  |
| 3380 | **BUSINESS & OPERATIONAL READINESS** |  |  | 1344d → 1344d? |  |  |  |
| 3381 | **Service Management** |  |  |  | 91% → 92% |  |  |
| 3433 | **Migration Pathway 6 (MP6)** |  |  |  | 9% → 19% |  |  |
| 3434 | **MP6 - Service Activation Implementation** |  |  |  | 20% → 50% |  |  |
| 3437 | PP Qualified by Code Bodies | 2026-06-25 A | 2026-06-25 A |  | 0% → 100% |  |  |
| 3439 | Create M16 in Customer Solution | 2026-06-26 A | 2026-06-26 A |  | 0% → 100% |  |  |
| 3440 | ISD Publish | 2026-06-29 A | 2026-06-29 A |  | 0% → 100% |  |  |
| 3443 | **Migration Pathway 7 (MP7)** |  |  |  | 38% → 44% |  |  |
| 3444 | **MP7 - Service Activation Implementation** |  |  |  | 43% → 50% |  |  |

| ID | Task | Start | Finish | Duration | Complete | Total float | Predecessors | Other |
| --- | --- | --- | --- | --- | --- | --- | --- | --- |
| 3447 | Market Entry to obtain Effective from Date from PP | 2026-07-01 A | 2026-07-01 A |  | 0% → 100% |  |  |  |
| 3448 | PP Qualified by Code Bodies |  |  |  |  |  | 2753 → none |  |
| 3449 | DIP Promoted to Production |  |  |  |  |  | 3448 → none |  |
| 3461 | PP Qualified by Code Bodies |  |  |  |  |  | 2753 → none |  |
| 3467 | **Migration Pathway 9 (MP9)** | 2026-06-18 A |  |  | 0% → 38% | 40d → 348d |  |  |
| 3468 | **MP9 - Service Activation Implementation** | 2026-06-18 A |  |  | 0% → 43% |  |  |  |
| 3469 | PP to agree Effective from Date 40WD ahead of target PAB | 2026-06-18 A | 2026-06-18 A |  | 0% → 100% | 395d → none |  |  |
| 3470 | PP to submit MDD Change Request | 2026-06-18 A | 2026-06-24 A |  | 0% → 100% | 391d → none |  |  |
| 3472 | PP Qualified by Code Bodies |  |  |  |  |  | 2753 → none |  |
| 3485 | PP Qualified by Code Bodies |  |  |  |  |  | 2753 → none |  |
| 3496 | PP Qualified by Code Bodies |  |  |  |  |  | 2753 → none |  |
| 3566 | **M16 Decision Making and Monitoring Criteria Consultation** |  | 2026-06-23 → 2026-07-07 (+14d) | 62d → 72d |  | -19d → -5d |  |  |
| 3571 | Materials Issued for Approval at eMCAG | 2026-06-16 → 2026-06-30 A (+14d) | 2026-06-16 → 2026-06-30 A (+14d) |  | 0% → 100% | -50d → none |  | was named Materials Issued for Approval at MCAG; constraint start no earlier than 2026-06-16 → start no earlier than 2026-06-30; baseline start 2026-06-16 → 2026-06-30; baseline finish 2026-06-16 → 2026-06-30 |
| 3572 | M16 Approach Approved at eMCAG | 2026-06-23 → 2026-07-07 (+14d) | 2026-06-23 → 2026-07-07 (+14d) |  |  | -50d → -60d |  | was named M16 Approach Approved at MCAG; constraint start no earlier than 2026-06-23 → start no earlier than 2026-07-07; baseline start 2026-06-23 → 2026-07-07; baseline finish 2026-06-23 → 2026-07-07 |
| 3577 | STEG 4 | 2026-06-24 A | 2026-06-24 A |  | 0% → 100% | 392d → none |  |  |
| 3582 | STEG 9 | 2026-09-02 → 2026-09-08 (+6d) | 2026-09-02 → 2026-09-08 (+6d) |  |  | 337d → 333d |  | constraint start no earlier than 2026-09-02 → start no earlier than 2026-09-08; baseline start 2026-09-02 → 2026-09-08; baseline finish 2026-09-02 → 2026-09-08 |
| 3602 | **M16: Decision Points** |  |  | 245d → 245d? |  |  |  |  |
| 3604 | STEG Issue position to MCAG notifying Decision Checkpoint 1 On-track | 2026-07-15 → 2026-08-19 (+35d) | 2026-07-15 → 2026-08-19 (+35d) |  |  | 344d → 352d | 3578 → none | constraint start no earlier than 2026-07-15 → start no earlier than 2026-08-19; baseline start 2026-07-15 → 2026-08-19; baseline finish 2026-07-15 → 2026-08-19 |
| 3605 | MCAG endorses STEG Assessment that M16 likely to be met | 2026-07-17 → 2026-08-25 (+39d) | 2026-07-17 → 2026-08-25 (+39d) |  |  | 344d → 348d | 3604FS+3d → none | was named MCAG Endorses Assessment; constraint start no earlier than 2026-07-15 → start no earlier than 2026-08-25; baseline start 2026-07-17 → 2026-08-25; baseline finish 2026-07-17 → 2026-08-25 |
| 3606 | M16 Checkpoint 1 | 2026-07-17 → 2026-08-25 (+39d) | 2026-07-17 → 2026-08-25 (+39d) |  |  | 374d → 348d |  | constraint finish no earlier than 2026-07-17 → none; baseline start 2026-07-17 → 2026-08-25; baseline finish 2026-07-17 → 2026-08-25 |
| 3607 | **Prepare Readiness Assessment 8 - Ready for New Settlement Timetable** | 2026-07-17 → 2026-07-01 A (-16d) | 2026-08-28 → 2026-09-15 (+18d) | 31d → 55d |  |  | 3605FS-15d → none | was named Prepare Readiness Assessment - Material Describing Transition Design and Queries to PPs guaging understanding an organisational readiness; baseline start 2026-07-17 → 2026-07-01; baseline finish 2026-08-28 → 2026-09-15 |
| 3608 | Issue Readiness Assessment 8 Following Interim Recommendation | 2026-07-17 → 2026-07-01 A (-16d) | 2026-07-17 → 2026-07-01 A (-16d) |  | 0% → 100% | 344d → none | 3605 → none | was named Issue Readiness Assessment Following Interim Recommendation; constraint finish no earlier than 2026-07-17 → start no earlier than 2026-07-01; baseline start 2026-07-17 → 2026-07-01; baseline finish 2026-07-17 → 2026-07-01 |
| 3609 | Readiness Assessment 8 Consultation Period Complete | 2026-08-14 → 2026-07-29 (-16d) | 2026-08-14 → 2026-07-29 (-16d) |  |  | 344d → 357d | 3608FS+20d → none | constraint finish no earlier than 2026-08-14 → start no earlier than 2026-07-29; baseline start 2026-08-14 → 2026-07-29; baseline finish 2026-08-14 → 2026-07-29 |
| 3610 | Readiness Assessment 8 Complete | 2026-08-14 → 2026-09-02 (+19d) | 2026-08-14 → 2026-09-02 (+19d) |  |  | 354d → 342d |  | constraint finish no earlier than 2026-08-14 → start no earlier than 2026-09-02; baseline start 2026-08-14 → 2026-09-02; baseline finish 2026-08-14 → 2026-09-02 |
| 3611 | Assess Readiness Assessment 8 and Plan further enagement activity if required | 2026-08-17 → 2026-09-02 (+16d) | 2026-08-28 → 2026-09-15 (+18d) |  |  | 344d → 332d |  | constraint finish no earlier than 2026-08-28 → start no earlier than 2026-09-02; baseline start 2026-08-17 → 2026-09-02; baseline finish 2026-08-28 → 2026-09-15 |
| 3612 | **Decision 1 RF Change to 7 months from Settlement Day 01/10** | 2026-09-14 → 2026-09-01 (-13d) | 2026-09-18 → 2026-09-15 (-3d) | 5d → 11d |  |  |  |  |
| 3614 | STEG to compare Monitoring report against agreed Assessment Criteria | 2026-09-14 → 2026-09-08 (-6d) | 2026-09-14 → 2026-09-08 (-6d) |  |  | 329d → 333d |  | was named STEG to compare Monitoring report against agreed assessment criteria; constraint start no earlier than 2026-09-14 → start no earlier than 2026-09-08; baseline start 2026-09-14 → 2026-09-08; baseline finish 2026-09-14 → 2026-09-08 |
| 3615 | STEG Issue recommendation to MCAG | 2026-09-14 → 2026-09-08 (-6d) | 2026-09-14 → 2026-09-08 (-6d) |  |  | 334d → 337d |  | constraint start no earlier than 2026-09-14 → finish no earlier than 2026-09-08 |
| 3616 | eMCAG Approve Recommendation to Change to RF 7 Months Calendar | 2026-09-18 → 2026-09-15 (-3d) | 2026-09-18 → 2026-09-15 (-3d) |  |  | 329d → 333d |  | was named MCAG Approve Recommendation to change to RF 7 months calendar; constraint finish no earlier than 2026-09-18 → start no earlier than 2026-09-15; baseline start 2026-09-18 → 2026-09-15; baseline finish 2026-09-18 → 2026-09-15 |
| 3617 | Decision 1 - RF 7 Months | 2026-09-18 → 2026-09-15 (-3d) | 2026-09-18 → 2026-09-15 (-3d) |  |  | 329d → 332d |  | constraint finish no earlier than 2026-09-18 → finish no earlier than 2026-09-15; baseline start 2026-09-18 → 2026-09-15; baseline finish 2026-09-18 → 2026-09-15 |
| 3687 | **READINESS ASSESSMENTS** |  |  |  | 60% → 54% |  |  |  |
| 3709 | **Readiness Assessment 8 - Ready for New Settlement Timetable** | 2026-08-06 → 2026-07-01 A (-36d) | 2026-10-13 → 2026-09-02 (-41d) | 49d → 46d |  | 312d → none |  | baseline start 2026-08-06 → 2026-07-01; baseline finish 2026-10-13 → 2026-09-02 |
| 3710 | Launch Readiness Assessment survey | 2026-08-06 → 2026-07-01 A (-36d) | 2026-08-06 → 2026-07-01 A (-36d) |  | 0% → 100% | 312d → none | 2755FS-60d → none | constraint none → start no earlier than 2026-07-01; baseline start 2026-08-06 → 2026-07-01; baseline finish 2026-08-06 → 2026-07-01 |
| 3711 | PPs submit survey responses | 2026-08-06 → 2026-07-01 (-36d) | 2026-08-26 → 2026-07-29 (-28d) | 15d → 21d |  | 312d → 341d |  | baseline start 2026-08-06 → 2026-07-01; baseline finish 2026-08-26 → 2026-07-29 |
| 3712 | Analyse survey responses | 2026-08-27 → 2026-07-30 (-28d) | 2026-09-16 → 2026-09-02 (-14d) | 15d → 25d |  | 312d → 341d |  | baseline start 2026-08-27 → 2026-07-30; baseline finish 2026-09-16 → 2026-09-02 |
| 3713 | Conduct deep-dive interviews (sample of PPs) | 2026-08-27 → 2026-07-30 (-28d) | 2026-09-16 → 2026-09-02 (-14d) | 15d → 25d |  | 312d → 341d | 3711 → none | constraint none → start no earlier than 2026-07-30; baseline start 2026-08-27 → 2026-07-30; baseline finish 2026-09-16 → 2026-09-02 |
| 3714 | Produce Readiness Assessment Reports (Overall Report & Individual Participant Reports) | 2026-09-17 → 2026-07-30 (-49d) | 2026-10-07 → 2026-09-02 (-35d) | 15d → 25d |  | 312d → 341d | 3712, 3713 → none | constraint none → start no earlier than 2026-07-30; baseline start 2026-09-17 → 2026-07-30; baseline finish 2026-10-07 → 2026-09-02 |
| 3715 | Readiness Assessment 8 - Ready for New Settlement Timetable - Completed (incl. Readiness Assessment Report approval) | 2026-10-13 → 2026-09-02 (-41d) | 2026-10-13 → 2026-09-02 (-41d) |  |  | 312d → 342d | 3714FS+4d → none | was named Readiness Assessment 8 - Ready to Accept New MPANs - Completed (incl. Readiness Assessment Report approval); constraint none → start no earlier than 2026-09-02; baseline start 2026-10-13 → 2026-09-02; baseline finish 2026-10-13 → 2026-09-02 |

## Version 9 (data date 2026-07-15, saved 2026-07-21, file MHHS-DEL1139 - MHHS Plan v6.54 (3).mpp)

Last finish stays 2027-12-23. Complete tasks 2731 → 2738.

Added:

| ID | Task | Duration | Start | Finish | Predecessors | Constraint |
| --- | --- | --- | --- | --- | --- | --- |
| 3719 | M14 checkpoint: QAG to assess M14 delivery confidence against the Acceptance Criteria | 0d | 2026-08-18 | 2026-08-18 | 3718 | start no earlier than 2026-08-18 |
| 3720 | M14 Checkpoint: PSG assesses M14 delivery confidence | 0d | 2026-09-02 | 2026-09-02 | 2720 | start no earlier than 2026-09-02 |
| 3721 | Notification to Ofgem of no central issues as of QA+P Annex 4 | 0d | 2026-09-03 | 2026-09-03 | 3720 | start no earlier than 2026-09-03 |
| 3722 | M14 Recommendation: eQWG to confirm Qualified participants for start of Migration | 0d | 2026-10-23 | 2026-10-23 |  | start no earlier than 2026-10-23 |
| 3723 | M14 Recommendation: eQAG to recommend M14 | 0d | 2026-10-26 | 2026-10-26 | 3722 | start no earlier than 2026-10-26 |
| 3724 | M14 Decision: ePSG to confirm M14 | 0d | 2026-10-27 | 2026-10-27 | 3723 | start no earlier than 2026-10-27 |

Removed: 3574 STEG 1; 3575 STEG 2; 3576 STEG 3; 3577 STEG 4; 3578 STEG 5; 3579 STEG 6; 3580 STEG 7; 3581 STEG 8; 3582 STEG 9; 3583 STEG 10; 3584 STEG 11; 3585 STEG 12; 3586 STEG 13; 3587 STEG 14; 3588 STEG 15; 3589 STEG 16; 3590 STEG 17; 3591 STEG 18; 3592 STEG 19; 3593 STEG 20; 3594 STEG 21; 3595 STEG 22; 3596 STEG 23; 3597 STEG 24; 3598 STEG 25; 3599 STEG 26; 3601 STEG June; 3607 Prepare Readiness Assessment 8 - Ready for New Settlement Timetable; 3608 Issue Readiness Assessment 8 Following Interim Recommendation; 3609 Readiness Assessment 8 Consultation Period Complete; 3610 Readiness Assessment 8 Complete; 3611 Assess Readiness Assessment 8 and Plan further enagement activity if required

Changed:

| ID | Task | Start | Finish | Complete | Total float | Predecessors | Other |
| --- | --- | --- | --- | --- | --- | --- | --- |
| 3 | **PROGRAMME MANAGEMENT** |  |  | 88% → 89% |  |  |  |
| 4 | **Programme Management** |  |  | 88% → 89% |  |  |  |
| 5 | Sprint-based prioritisation planning and execution |  |  | 88% → 89% |  |  |  |
| 6 | Programme governance secretariat |  |  | 88% → 89% |  |  |  |
| 7 | RAID management and reporting |  |  | 88% → 89% |  |  |  |
| 8 | Tracking against Programme outcomes and KPIs |  |  | 88% → 89% |  |  |  |
| 9 | Change control and reporting |  |  | 88% → 89% |  |  |  |
| 10 | Ongoing identification of lessons learned relating to the PMO and implementation of improvements |  |  | 88% → 89% |  |  |  |
| 11 | **Programme Internal Assurance Reviews** |  |  | 88% → 89% |  |  |  |
| 12 | Programme Internal Assurance Reviews |  |  | 88% → 89% |  |  |  |
| 13 | **Engagement with PPs** |  |  | 88% → 89% |  |  |  |
| 14 | Ongoing PP liaison activities |  |  | 88% → 89% |  |  |  |
| 15 | Milestone and Control Point objective setting |  |  | 88% → 89% |  |  |  |
| 16 | Reporting |  |  | 88% → 89% |  |  |  |
| 17 | **PP Engagement Events** |  |  | 88% → 89% |  |  |  |
| 18 | Bilateral meetings |  |  | 88% → 89% |  |  |  |
| 19 | Monthly webinars |  |  | 88% → 89% |  |  |  |
| 20 | Open days |  |  | 88% → 89% |  |  |  |
| 21 | **PP Communications** |  |  | 88% → 89% |  |  |  |
| 22 | The Clock updates (weekly) |  |  | 88% → 89% |  |  |  |
| 23 | Maintain and update content on public-facing Portal (and ongoing feedback reviews to identify and implement Portal improvements) |  |  | 88% → 89% |  |  |  |
| 24 | **Code Change Support / Other Programme Alignment** |  |  | 88% → 89% |  |  |  |
| 25 | Support DCC/BEIS on SEC change |  |  | 88% → 89% |  |  |  |
| 26 | Support on Smart Meters Act changes |  |  | 88% → 89% |  |  |  |
| 27 | Support DCC/RECCo on CSS change |  |  | 88% → 89% |  |  |  |
| 28 | Support Elexon on BSC change |  |  | 88% → 89% |  |  |  |
| 29 | Support code change inside & outside CCIAG |  |  | 88% → 89% |  |  |  |
| 30 | Support code change inside & outside CCAG |  |  | 88% → 89% |  |  |  |
| 45 | **DESIGN, BUILD & TEST (PIT)** |  |  | 98% → 99% |  |  |  |
| 56 | **Establish Design Change Management Processes** |  |  | 86% → 87% |  |  |  |
| 61 | Maintain E2E MHHS Design (post-M5 design change management processes operational) |  |  | 86% → 87% |  |  |  |
| 1673 | **UIT Environment Preparation** |  |  | 98% → 99% |  |  |  |
| 1724 | **Onboarding and Test Data (Sandbox UIT)** |  |  | 90% → 93% |  |  |  |
| 1726 | Supplier & Agent Onboarding and Test Data Creation and Support |  |  | 84% → 88% |  |  |  |
| 1727 | **Sandbox Execution** |  |  | 91% → 93% |  |  |  |
| 1737 | **Sandbox Testing Execution (UIT) - Supplier & Agent Participants** |  |  | 84% → 88% |  |  |  |
| 1740 | Sandbox Testing Execution (UIT) - Supplier & Agent Participants |  |  | 84% → 88% |  |  |  |
| 2316 | **S & A QUALIFICATION** |  |  | 98% → 99% |  |  |  |
| 2713 | **Qualification Wave 3 Exit** |  |  | 97% → 99% |  |  |  |
| 2716 | Qualification Wave 3 Participants submit their Final QAD |  | 2026-05-22 A | 97% → 100% | 414d → none |  |  |
| 2718 | All Qualification Wave 3 Participants have submitted their Final QAD |  | 2026-05-22 A | 97% → 100% | 414d → none |  |  |
| 2720 | QAD Sign Off deadline |  |  | 90% → 94% |  |  |  |
| 2723 | **Qualification Wave 4** |  |  | 78% → 82% |  |  |  |
| 2729 | Completion of Code Bodies review of Initial QAD |  |  | 60% → 74% |  |  |  |
| 2746 | **Qualification Wave 4 Exit** |  |  | 28% → 40% |  |  |  |
| 2749 | Qualification Wave 4 Participants submit their Final QAD |  |  | 33% → 47% | 3.2d → 5.6d |  |  |
| 2751 | Completion of Code Bodies review of Final QAD |  |  | 16% → 28% |  |  |  |
| 2755 | All suppliers must be able to access MPANs under the new TOM (M14) |  |  |  |  | 2753FS+24d → 2753FS+24d, 3724 |  |
| 2756 | All suppliers must be able to access MPANs under the new TOM (M14*) - Late Exit |  |  |  |  | 2755FS+66d → 2755FS+66d, 3724 |  |
| 2790 | PAB2026/12 | 2026-07-15 A | 2026-07-15 A | 0% → 100% | 376d → none |  |  |
| 2952 | **MIGRATION** |  |  | 95% → 96% |  |  |  |
| 3174 | **Preparation for Cutover to Live** |  |  | 73% → 74% |  |  |  |
| 3266 | **Migration Sprints** |  |  | 43% → 46% |  |  |  |
| 3298 | **Migration Sprint 3** |  |  | 43% → 60% |  |  |  |
| 3305 | Sprint Execution |  |  | 45% → 68% |  |  |  |
| 3308 | **Migration Sprint 4** | 2026-07-08 A |  | 0% → 10% |  |  |  |
| 3309 | Sprint 4 Planning start date | 2026-07-08 A | 2026-07-15 A | 0% → 100% | 307d → none |  |  |
| 3310 | Issue Envelope | 2026-07-15 A | 2026-07-15 A | 0% → 100% | 307d → none |  |  |
| 3339 | Sprint 7 Planning start date |  |  |  |  |  | was named Sprint 6 Planning start date |
| 3380 | **BUSINESS & OPERATIONAL READINESS** |  |  | 86% → 87% |  |  |  |
| 3381 | **Service Management** |  |  | 92% → 93% |  |  |  |
| 3433 | **Migration Pathway 6 (MP6)** |  |  | 19% → 29% |  |  |  |
| 3434 | **MP6 - Service Activation Implementation** |  | 2026-07-07 A | 50% → 100% |  |  |  |
| 3438 | DIP Promoted to Production | 2026-06-26 A | 2026-07-02 A | 0% → 100% |  |  |  |
| 3441 | ISD Go-Live | 2026-07-06 A | 2026-07-06 A | 0% → 100% |  |  |  |
| 3442 | MP6 - Service Activation Implementation Complete (M) | 2026-07-07 A | 2026-07-07 A | 0% → 100% |  |  |  |
| 3448 | PP Qualified by Code Bodies | 2026-07-15 A | 2026-07-15 A | 0% → 100% |  |  |  |
| 3481 | **Migration Pathway 10 (MP10)** | 2026-07-03 A |  | 0% → 11% |  |  |  |
| 3482 | **MP10 - Service Activation Implementation** | 2026-07-03 A |  | 0% → 11% |  |  |  |
| 3483 | PP to agree Effective from Date 40WD ahead of target PAB | 2026-07-03 A | 2026-07-03 A | 0% → 100% | 384d → none |  |  |

| ID | Task | Start | Finish | Duration | Complete | Total float | Predecessors | Other |
| --- | --- | --- | --- | --- | --- | --- | --- | --- |
| 3491 | **Migration Pathway 11 (MP11)** | 2026-07-13 A |  |  | 0% → 25% | 23d → 328d |  |  |
| 3492 | **MP11 - Service Activation Implementation** | 2026-07-13 A |  |  | 0% → 29% |  |  |  |
| 3493 | PP to agree Effective from Date 40WD ahead of target PAB | 2026-07-13 A | 2026-07-13 A |  | 0% → 100% | 378d → none |  |  |
| 3494 | PP to submit MDD Change Request | 2026-07-13 A |  |  | 0% → 60% |  |  |  |
| 3545 | **M16: Decision Approach** |  |  |  | 99% → 100% |  |  |  |
| 3550 | **Consult and Agree with Industry** |  |  |  | 99% → 100% |  |  |  |
| 3566 | **M16 Decision Making and Monitoring Criteria Consultation** |  | 2026-07-07 A |  | 99% → 100% | -5d → none |  |  |
| 3572 | M16 Approach Approved at eMCAG | 2026-07-07 A | 2026-07-07 A |  | 0% → 100% | -60d → none |  |  |
| 3573 | **M16: Monitoring Period** | 2026-04-15 A → 2026-04-15 |  |  |  |  |  |  |
| 3582 | STEG to compare Monitoring report against agreed Assessment Criteria |  |  |  |  |  | STEG 9 → none |  |
| 3588 | STEG to compare Monitoring report against agreed assessment criteria |  |  |  |  |  | STEG 22 → none |  |
| 3655 | **READINESS ASSESSMENTS** |  |  |  | 54% → 57% |  |  |  |
| 3677 | **Readiness Assessment 8 - Ready for New Settlement Timetable** |  |  |  | 0% → 11% |  |  |  |
| 3679 | PPs submit survey responses | 2026-07-01 A |  |  | 0% → 52% |  |  |  |
| 3694 | Readiness Assessment 8 - Ready for New Settlement Timetable - Completed (incl. Readiness Assessment Report approval) | 2026-08-14 → 2026-09-02 (+19d) | 2026-08-14 → 2026-09-02 (+19d) |  |  | 355d → 342d |  | constraint start no earlier than 2026-08-14 → start no earlier than 2026-09-02; baseline start 2026-08-14 → 2026-09-02; baseline finish 2026-08-14 → 2026-09-02 |
| 3714 | **MILESTONE RANGE CHECKPOINTS** |  |  | 402d → 402d? |  |  |  |  |
| 3717 | **M14 milestone checkpoint** | 2026-08-06 → 2026-08-11 (+5d) | 2026-08-06 → 2026-10-27 (+82d) | 0d → 56d? |  | 361d → none |  | baseline start 2026-08-06 → 2026-08-11; baseline finish 2026-08-06 → 2026-10-27 |
| 3718 | M14 Checkpoint: QWG to assess M14 delivery confidence against the Acceptance Criteria | 2026-08-06 → 2026-08-11 (+5d) | 2026-08-06 → 2026-08-11 (+5d) |  |  | 361d → 358d | 2755FS-3mo → none | was named M14 milestone checkpoint - date approval; constraint none → start no earlier than 2026-08-11; baseline start 2026-08-06 → 2026-08-11; baseline finish 2026-08-06 → 2026-08-11 |

## Version 10 (data date 2026-07-29, saved 2026-07-29, file MHHS-DEL1139 - MHHS Plan v6.55.mpp)

Last finish stays 2027-12-23. Complete tasks 2738 → 2759.

Changed:

| ID | Task | Start | Finish | Complete | Total float |
| --- | --- | --- | --- | --- | --- |
| 1 | **PROGRAMME PLAN.** |  |  | 94% → 95% |  |
| 3 | **PROGRAMME MANAGEMENT** |  |  | 89% → 90% |  |
| 4 | **Programme Management** |  |  | 89% → 90% |  |
| 5 | Sprint-based prioritisation planning and execution |  |  | 89% → 90% |  |
| 6 | Programme governance secretariat |  |  | 89% → 90% |  |
| 7 | RAID management and reporting |  |  | 89% → 90% |  |
| 8 | Tracking against Programme outcomes and KPIs |  |  | 89% → 90% |  |
| 9 | Change control and reporting |  |  | 89% → 90% |  |
| 10 | Ongoing identification of lessons learned relating to the PMO and implementation of improvements |  |  | 89% → 90% |  |
| 11 | **Programme Internal Assurance Reviews** |  |  | 89% → 90% |  |
| 12 | Programme Internal Assurance Reviews |  |  | 89% → 90% |  |
| 13 | **Engagement with PPs** |  |  | 89% → 90% |  |
| 14 | Ongoing PP liaison activities |  |  | 89% → 90% |  |
| 15 | Milestone and Control Point objective setting |  |  | 89% → 90% |  |
| 16 | Reporting |  |  | 89% → 90% |  |
| 17 | **PP Engagement Events** |  |  | 89% → 90% |  |
| 18 | Bilateral meetings |  |  | 89% → 90% |  |
| 19 | Monthly webinars |  |  | 89% → 90% |  |
| 20 | Open days |  |  | 89% → 90% |  |
| 21 | **PP Communications** |  |  | 89% → 90% |  |
| 22 | The Clock updates (weekly) |  |  | 89% → 90% |  |
| 23 | Maintain and update content on public-facing Portal (and ongoing feedback reviews to identify and implement Portal improvements) |  |  | 89% → 90% |  |
| 24 | **Code Change Support / Other Programme Alignment** |  |  | 89% → 90% |  |
| 25 | Support DCC/BEIS on SEC change |  |  | 89% → 90% |  |
| 26 | Support on Smart Meters Act changes |  |  | 89% → 90% |  |
| 27 | Support DCC/RECCo on CSS change |  |  | 89% → 90% |  |
| 28 | Support Elexon on BSC change |  |  | 89% → 90% |  |
| 29 | Support code change inside & outside CCIAG |  |  | 89% → 90% |  |
| 30 | Support code change inside & outside CCAG |  |  | 89% → 90% |  |
| 46 | **Design Baseline & Enduring PP Support** |  |  | 94% → 95% |  |
| 56 | **Establish Design Change Management Processes** |  |  | 87% → 88% |  |
| 61 | Maintain E2E MHHS Design (post-M5 design change management processes operational) |  |  | 87% → 88% |  |
| 1724 | **Onboarding and Test Data (Sandbox UIT)** |  |  | 93% → 95% |  |
| 1726 | Supplier & Agent Onboarding and Test Data Creation and Support |  |  | 88% → 92% |  |
| 1727 | **Sandbox Execution** |  |  | 93% → 95% |  |
| 1737 | **Sandbox Testing Execution (UIT) - Supplier & Agent Participants** |  |  | 88% → 92% |  |
| 1740 | Sandbox Testing Execution (UIT) - Supplier & Agent Participants |  |  | 88% → 92% |  |
| 2428 | **MHHS Qualification - Qualification Waves** |  |  | 98% → 99% |  |
| 2719 | Completion of Code Bodies review of Final QAD |  | 2026-06-19 A | 94% → 100% | 0.94d → none |
| 2720 | QAD Sign Off deadline |  | 2026-06-26 A | 94% → 100% | 365d → none |
| 2723 | **Qualification Wave 4** |  |  | 82% → 99% |  |
| 2724 | **Qualification Wave 4 QAD Prep** |  | 2026-02-27 A | 99% → 100% | 474d → none |
| 2729 | Completion of Code Bodies review of Initial QAD |  | 2026-02-27 A | 74% → 100% | 474d → none |
| 2746 | **Qualification Wave 4 Exit** |  |  | 40% → 96% |  |
| 2747 | Assurance on PP Test Completion Report | 2026-07-13 A | 2026-07-24 A | 0% → 100% | 5.6d → none |
| 2749 | Qualification Wave 4 Participants submit their Final QAD |  | 2026-07-24 A | 47% → 100% | 5.6d → none |
| 2750 | Qualification Wave 4 Participants have submitted their Final QAD | 2026-07-24 A | 2026-07-24 A | 0% → 100% | 5.6d → none |
| 2751 | Completion of Code Bodies review of Final QAD |  |  | 28% → 78% | 235d → 0.62d |
| 2752 | QAD Sign Off deadline | 2026-08-28 A |  | 0% → 62% |  |
| 3174 | **Preparation for Cutover to Live** |  |  | 74% → 75% |  |
| 3266 | **Migration Sprints** |  |  | 46% → 47% |  |
| 3298 | **Migration Sprint 3** |  |  | 60% → 77% |  |
| 3305 | Sprint Execution |  |  | 68% → 91% |  |
| 3311 | Supplier Submission Deadline | 2026-07-22 A | 2026-07-22 A | 0% → 100% | 307d → none |
| 3312 | Baseline Schedule Publication | 2026-07-29 A | 2026-07-29 A | 0% → 100% | 307d → none |
| 3313 | Migration Sprint 4 Schedule Baselined | 2026-07-29 A | 2026-07-29 A | 0% → 100% | 307d → none |
| 3380 | **BUSINESS & OPERATIONAL READINESS** |  |  | 87% → 88% |  |
| 3381 | **Service Management** |  |  | 93% → 94% |  |
| 3433 | **Migration Pathway 6 (MP6)** |  |  | 29% → 43% |  |
| 3443 | **Migration Pathway 7 (MP7)** |  | 2026-07-28 A | 44% → 100% | 368d → none |
| 3444 | **MP7 - Service Activation Implementation** |  | 2026-07-28 A | 50% → 100% | 0d → none |
| 3449 | DIP Promoted to Production | 2026-07-16 A | 2026-07-22 A | 0% → 100% |  |
| 3450 | Create M16 in Customer Solution | 2026-07-16 A | 2026-07-16 A | 0% → 100% |  |
| 3451 | MDD & ISD Publish | 2026-07-20 A | 2026-07-20 A | 0% → 100% |  |
| 3452 | MDD & ISD Go-Live | 2026-07-27 A | 2026-07-27 A | 0% → 100% |  |
| 3453 | MP7 - Service Activation Implementation Complete (M) | 2026-07-28 A | 2026-07-28 A | 0% → 100% |  |
| 3454 | **MP7 - Service Activation Implementation MDD** | 2026-07-16 A | 2026-07-17 A | 0% → 100% | 374d → none |
| 3455 | MDD Final Circular Completed | 2026-07-17 A | 2026-07-17 A | 0% → 100% | 375d → none |
| 3456 | MDD Manual Update | 2026-07-16 A | 2026-07-17 A | 0% → 100% | 374d → none |
| 3457 | **Migration Pathway 8 (MP8)** |  |  | 11% → 22% |  |

| ID | Task | Start | Finish | Duration | Complete | Total float | Other |
| --- | --- | --- | --- | --- | --- | --- | --- |
| 3458 | **MP8 - Service Activation Implementation** |  |  |  | 11% → 22% |  |  |
| 3460 | Market Entry to obtain Effective from Date from PP | 2026-07-16 A | 2026-07-16 A |  | 0% → 100% | 375d → none |  |
| 3491 | **Migration Pathway 11 (MP11)** |  |  |  | 25% → 38% |  |  |
| 3492 | **MP11 - Service Activation Implementation** |  |  |  | 29% → 43% |  |  |
| 3494 | PP to submit MDD Change Request |  | 2026-07-17 A |  | 60% → 100% | 374d → none |  |
| 3505 | **Migration Pathway 12a (MP12a)** | 2026-07-29 A |  |  | 0% → 11% |  |  |
| 3506 | **MP12a - Service Activation Implementation** | 2026-07-29 A |  |  | 0% → 11% |  |  |
| 3507 | PP to agree Effective from Date 40WD ahead of target PAB | 2026-07-29 A | 2026-07-29 A |  | 0% → 100% | 366d → none |  |
| 3515 | **Migration Pathway 12b (MP12b)** | 2026-07-29 A |  |  | 0% → 6% | 56d → 303d |  |
| 3516 | **MP12b - Service Activation Implementation** | 2026-07-29 A |  |  | 0% → 7% |  |  |
| 3517 | PP to agree Effective from Date 40WD ahead of target PAB | 2026-07-29 A | 2026-07-29 A |  | 0% → 100% | 366d → none |  |
| 3545 | **M16: Decision Approach** |  |  | 95d → 95d? |  |  |  |
| 3550 | **Consult and Agree with Industry** |  |  | 94d → 94d? |  |  |  |
| 3566 | **M16 Decision Making and Monitoring Criteria Consultation - Decisions 1 and 2** |  |  |  |  |  | was named M16 Decision Making and Monitoring Criteria Consultation; baseline start none → 2026-03-27; baseline finish none → 2026-07-07 |
| 3567 | Prepare Consultation material |  |  |  |  |  | was named Prepare consultation material |
| 3572 | Decision 1 (RF to 7 months) and Decision 2 (RF to 4 months) Criteria approved at eMCAG |  |  |  |  |  | was named M16 Approach Approved at eMCAG |
| 3576 | **STEG to Assess Monitoring Report and recommend interim position to MCAG on Decision 1** | 2026-07-13 → 2026-08-19 (+37d) | 2026-07-17 → 2026-08-25 (+39d) |  |  |  | baseline start 2026-07-13 → 2026-08-19; baseline finish 2026-07-17 → 2026-08-25 |
| 3580 | **Decision 1 RF Change to 7 months from Settlement Day 01/10** |  | 2026-09-15 → 2026-09-18 (+3d) | 11d → 14d |  |  | baseline start 2026-09-14 → 2026-09-01 |
| 3593 | STEG to compare Monitoring report against agreed assessment criteria |  |  |  |  |  | baseline start 2027-06-16 → 2027-06-14; baseline finish 2027-06-16 → 2027-06-14 |
| 3594 | STEG Issue recommendation to MCAG |  |  |  |  |  | baseline start 2027-06-22 → 2027-06-18; baseline finish 2027-06-22 → 2027-06-18 |
| 3595 | MCAG Approve Recommendation - Confirm M16 Date |  |  |  |  |  | baseline start 2027-06-22 → 2027-06-18; baseline finish 2027-06-22 → 2027-06-18 |
| 3596 | Decision 3 - SF 7WD |  |  |  |  |  | baseline start 2027-06-22 → 2027-06-18; baseline finish 2027-06-22 → 2027-06-18 |
| 3605 | **Post Decision 3** |  | 2027-04-02 → 2027-06-17 (+76d) | 20d → 74d |  |  | baseline start 2027-04-02 → 2027-03-08 |
| 3655 | **READINESS ASSESSMENTS** |  |  |  | 57% → 60% |  |  |
| 3677 | **Readiness Assessment 8 - Ready for New Settlement Timetable** |  |  |  | 11% → 22% |  |  |
| 3679 | PPs submit survey responses |  | 2026-07-29 A |  | 52% → 100% | 341d → none |  |

## Version 11 (data date 2026-08-12, saved 2026-08-12, file MHHS-DEL1139 - MHHS Plan v6.56.mpp)

Last finish stays 2027-12-23. Complete tasks 2759 → 2776.

Changed:

| ID | Task | Start | Finish | Complete | Total float | Other |
| --- | --- | --- | --- | --- | --- | --- |
| 3 | **PROGRAMME MANAGEMENT** |  |  | 90% → 91% |  |  |
| 4 | **Programme Management** |  |  | 90% → 91% |  |  |
| 5 | Sprint-based prioritisation planning and execution |  |  | 90% → 91% |  |  |
| 6 | Programme governance secretariat |  |  | 90% → 91% |  |  |
| 7 | RAID management and reporting |  |  | 90% → 91% |  |  |
| 8 | Tracking against Programme outcomes and KPIs |  |  | 90% → 91% |  |  |
| 9 | Change control and reporting |  |  | 90% → 91% |  |  |
| 10 | Ongoing identification of lessons learned relating to the PMO and implementation of improvements |  |  | 90% → 91% |  |  |
| 11 | **Programme Internal Assurance Reviews** |  |  | 90% → 91% |  |  |
| 12 | Programme Internal Assurance Reviews |  |  | 90% → 91% |  |  |
| 13 | **Engagement with PPs** |  |  | 90% → 91% |  |  |
| 14 | Ongoing PP liaison activities |  |  | 90% → 91% |  |  |
| 15 | Milestone and Control Point objective setting |  |  | 90% → 91% |  |  |
| 16 | Reporting |  |  | 90% → 91% |  |  |
| 17 | **PP Engagement Events** |  |  | 90% → 91% |  |  |
| 18 | Bilateral meetings |  |  | 90% → 91% |  |  |
| 19 | Monthly webinars |  |  | 90% → 91% |  |  |
| 20 | Open days |  |  | 90% → 91% |  |  |
| 21 | **PP Communications** |  |  | 90% → 91% |  |  |
| 22 | The Clock updates (weekly) |  |  | 90% → 91% |  |  |
| 23 | Maintain and update content on public-facing Portal (and ongoing feedback reviews to identify and implement Portal improvements) |  |  | 90% → 91% |  |  |
| 24 | **Code Change Support / Other Programme Alignment** |  |  | 90% → 91% |  |  |
| 25 | Support DCC/BEIS on SEC change |  |  | 90% → 91% |  |  |
| 26 | Support on Smart Meters Act changes |  |  | 90% → 91% |  |  |
| 27 | Support DCC/RECCo on CSS change |  |  | 90% → 91% |  |  |
| 28 | Support Elexon on BSC change |  |  | 90% → 91% |  |  |
| 29 | Support code change inside & outside CCIAG |  |  | 90% → 91% |  |  |
| 30 | Support code change inside & outside CCAG |  |  | 90% → 91% |  |  |
| 56 | **Establish Design Change Management Processes** |  |  | 88% → 89% |  |  |
| 61 | Maintain E2E MHHS Design (post-M5 design change management processes operational) |  |  | 88% → 89% |  |  |
| 1466 | Update the documents on loading tests into ADO |  |  |  |  | was named Update the documents on loading tests into ADO? |
| 1724 | **Onboarding and Test Data (Sandbox UIT)** |  |  | 95% → 97% |  |  |
| 1726 | Supplier & Agent Onboarding and Test Data Creation and Support |  |  | 92% → 95% |  |  |
| 1727 | **Sandbox Execution** |  |  | 95% → 98% |  |  |
| 1737 | **Sandbox Testing Execution (UIT) - Supplier & Agent Participants** |  |  | 92% → 95% |  |  |
| 1740 | Sandbox Testing Execution (UIT) - Supplier & Agent Participants |  |  | 92% → 95% |  |  |
| 2378 | **MHHS Qualification - SIT Participants** |  | 2026-07-30 A | 99% → 100% | 366d → none |  |
| 2405 | **MHHS Qualification - Not M11-Ready** |  | 2026-07-30 A | 99% → 100% | 366d → none |  |
| 2414 | SIT Participants are Qualified | 2026-07-30 A | 2026-07-30 A | 0% → 100% | 366d → none |  |
| 2721 | 80% of M14 Critical Wave 3 Participants Qualification approved by BSC PAB and REC Manager | 2026-07-30 A | 2026-07-30 A | 0% → 100% | 366d → none |  |
| 2746 | **Qualification Wave 4 Exit** |  |  | 96% → 98% |  |  |
| 2751 | Completion of Code Bodies review of Final QAD |  |  | 78% → 88% | 0.62d → 0.86d |  |
| 2752 | QAD Sign Off deadline |  |  | 62% → 86% |  |  |
| 2791 | PAB2026/13 | 2026-07-30 A | 2026-07-30 A | 0% → 100% | 365d → none |  |
| 2792 | PAB2026/14 | 2026-08-12 A | 2026-08-12 A | 0% → 100% | 356d → none |  |
| 3174 | **Preparation for Cutover to Live** |  |  | 75% → 76% |  |  |
| 3266 | **Migration Sprints** |  |  | 47% → 50% |  |  |
| 3298 | **Migration Sprint 3** |  |  | 77% → 93% |  |  |
| 3305 | Sprint Execution |  | 2026-08-04 A | 91% → 100% | 352d → none |  |
| 3306 | Sprint Execution End | 2026-08-04 A | 2026-08-04 A | 0% → 100% | 352d → none |  |
| 3307 | Sprint 3 Retro | 2026-08-05 A |  | 0% → 60% |  |  |
| 3308 | **Migration Sprint 4** |  |  | 10% → 18% |  |  |
| 3314 | Sprint Execution Start | 2026-08-05 A | 2026-08-05 A | 0% → 100% | 307d → none |  |
| 3315 | Sprint Execution | 2026-08-06 A |  | 0% → 11% |  |  |
| 3381 | **Service Management** |  |  | 94% → 96% |  |  |
| 3433 | **Migration Pathway 6 (MP6)** |  |  | 43% → 55% |  |  |
| 3457 | **Migration Pathway 8 (MP8)** |  | 2026-08-11 A | 22% → 100% | 358d → none |  |
| 3458 | **MP8 - Service Activation Implementation** |  | 2026-08-11 A | 22% → 100% | 358d → none |  |
| 3461 | PP Qualified by Code Bodies | 2026-07-30 A | 2026-07-30 A | 0% → 100% | 360d → none |  |
| 3462 | DIP Promoted to Production | 2026-07-31 A | 2026-08-06 A | 0% → 100% | 360d → none |  |
| 3463 | Create M16 in Customer Solution | 2026-07-31 A | 2026-07-31 A | 0% → 100% | 359d → none |  |
| 3464 | ISD Publish | 2026-08-03 A | 2026-08-03 A | 0% → 100% | 358d → none |  |
| 3465 | ISD Go-Live | 2026-08-10 A | 2026-08-10 A | 0% → 100% | 358d → none |  |
| 3466 | MP8 - Service Activation Implementation Complete (M) | 2026-08-11 A | 2026-08-11 A | 0% → 100% | 358d → none |  |
| 3467 | **Migration Pathway 9 (MP9)** |  |  | 38% → 44% |  |  |
| 3468 | **MP9 - Service Activation Implementation** |  |  | 43% → 50% |  |  |
| 3471 | Market Entry to obtain Effective from Date from PP | 2026-07-29 A | 2026-07-29 A | 0% → 100% | 366d → none |  |
| 3472 | PP Qualified by Code Bodies | 2026-08-12 A | 2026-08-12 A | 0% → 100% | 351d → none |  |
| 3515 | **Migration Pathway 12b (MP12b)** |  |  | 6% → 38% |  |  |
| 3516 | **MP12b - Service Activation Implementation** |  |  | 7% → 43% |  |  |

| ID | Task | Start | Finish | Complete | Total float |
| --- | --- | --- | --- | --- | --- |
| 3518 | PP to submit MDD Change Request | 2026-07-29 A | 2026-08-04 A | 0% → 100% | 362d → none |
| 3655 | **READINESS ASSESSMENTS** |  |  | 60% → 66% |  |
| 3677 | **Readiness Assessment 8 - Ready for New Settlement Timetable** |  |  | 22% → 43% |  |
| 3680 | Analyse survey responses | 2026-07-30 A |  | 0% → 40% |  |
| 3681 | Conduct deep-dive interviews (sample of PPs) | 2026-07-30 A |  | 0% → 40% |  |
| 3717 | **M14 milestone checkpoint** | 2026-08-11 A |  |  |  |
| 3718 | M14 Checkpoint: QWG to assess M14 delivery confidence against the Acceptance Criteria | 2026-08-11 A | 2026-08-11 A | 0% → 100% | 358d → none |

## Version 12 (data date 2026-08-26, saved 2026-08-26, file MHHS-DEL1139 - MHHS Plan v6.57.mpp)

Last finish stays 2027-12-23. Complete tasks 2776 → 2790.

Changed:

| ID | Task | Start | Finish | Complete | Total float | Other |
| --- | --- | --- | --- | --- | --- | --- |
| 1 | **PROGRAMME PLAN.** |  |  | 95% → 96% |  |  |
| 3 | **PROGRAMME MANAGEMENT** |  |  | 91% → 92% |  |  |
| 4 | **Programme Management** |  |  | 91% → 92% |  |  |
| 5 | Sprint-based prioritisation planning and execution |  |  | 91% → 92% |  |  |
| 6 | Programme governance secretariat |  |  | 91% → 92% |  |  |
| 7 | RAID management and reporting |  |  | 91% → 92% |  |  |
| 8 | Tracking against Programme outcomes and KPIs |  |  | 91% → 92% |  |  |
| 9 | Change control and reporting |  |  | 91% → 92% |  |  |
| 10 | Ongoing identification of lessons learned relating to the PMO and implementation of improvements |  |  | 91% → 92% |  |  |
| 11 | **Programme Internal Assurance Reviews** |  |  | 91% → 92% |  |  |
| 12 | Programme Internal Assurance Reviews |  |  | 91% → 92% |  |  |
| 13 | **Engagement with PPs** |  |  | 91% → 92% |  |  |
| 14 | Ongoing PP liaison activities |  |  | 91% → 92% |  |  |
| 15 | Milestone and Control Point objective setting |  |  | 91% → 92% |  |  |
| 16 | Reporting |  |  | 91% → 92% |  |  |
| 17 | **PP Engagement Events** |  |  | 91% → 92% |  |  |
| 18 | Bilateral meetings |  |  | 91% → 92% |  |  |
| 19 | Monthly webinars |  |  | 91% → 92% |  |  |
| 20 | Open days |  |  | 91% → 92% |  |  |
| 21 | **PP Communications** |  |  | 91% → 92% |  |  |
| 22 | The Clock updates (weekly) |  |  | 91% → 92% |  |  |
| 23 | Maintain and update content on public-facing Portal (and ongoing feedback reviews to identify and implement Portal improvements) |  |  | 91% → 92% |  |  |
| 24 | **Code Change Support / Other Programme Alignment** |  |  | 91% → 92% |  |  |
| 25 | Support DCC/BEIS on SEC change |  |  | 91% → 92% |  |  |
| 26 | Support on Smart Meters Act changes |  |  | 91% → 92% |  |  |
| 27 | Support DCC/RECCo on CSS change |  |  | 91% → 92% |  |  |
| 28 | Support Elexon on BSC change |  |  | 91% → 92% |  |  |
| 29 | Support code change inside & outside CCIAG |  |  | 91% → 92% |  |  |
| 30 | Support code change inside & outside CCAG |  |  | 91% → 92% |  |  |
| 46 | **Design Baseline & Enduring PP Support** |  |  | 95% → 96% |  |  |
| 56 | **Establish Design Change Management Processes** |  |  | 89% → 90% |  |  |
| 61 | Maintain E2E MHHS Design (post-M5 design change management processes operational) |  |  | 89% → 90% |  |  |
| 1466 | Update the documents on loading tests into ADO? |  |  |  |  | was named Update the documents on loading tests into ADO |
| 1724 | **Onboarding and Test Data (Sandbox UIT)** |  |  | 97% → 99% |  |  |
| 1726 | Supplier & Agent Onboarding and Test Data Creation and Support |  |  | 95% → 99% |  |  |
| 1727 | **Sandbox Execution** |  |  | 98% → 99% |  |  |
| 1737 | **Sandbox Testing Execution (UIT) - Supplier & Agent Participants** |  |  | 95% → 99% |  |  |
| 1740 | Sandbox Testing Execution (UIT) - Supplier & Agent Participants |  |  | 95% → 99% |  |  |
| 2721 | 80% of M14 Critical Wave 3 Participants Qualification approved by BSC PAB and REC Manager | 2026-07-30 A → 2026-07-30 | 2026-07-30 A → 2026-07-30 | 100% → 0% | none → 366d |  |
| 2746 | **Qualification Wave 4 Exit** |  |  | 98% → 96% |  |  |
| 2751 | Completion of Code Bodies review of Final QAD |  |  | 88% → 78% | 0.86d → 0.62d |  |
| 2752 | QAD Sign Off deadline |  |  | 86% → 62% |  |  |
| 3174 | **Preparation for Cutover to Live** |  |  | 76% → 77% |  |  |
| 3266 | **Migration Sprints** |  |  | 50% → 53% |  |  |
| 3298 | **Migration Sprint 3** |  | 2026-08-18 A | 93% → 100% | 352d → none |  |
| 3307 | Sprint 3 Retro |  | 2026-08-18 A | 60% → 100% | 352d → none |  |
| 3308 | **Migration Sprint 4** |  |  | 18% → 35% |  |  |
| 3315 | Sprint Execution |  |  | 11% → 34% |  |  |
| 3380 | **BUSINESS & OPERATIONAL READINESS** |  |  | 88% → 89% |  |  |
| 3381 | **Service Management** |  |  | 96% → 97% |  |  |
| 3433 | **Migration Pathway 6 (MP6)** |  |  | 55% → 68% |  |  |
| 3467 | **Migration Pathway 9 (MP9)** |  | 2026-08-25 A | 44% → 100% | 348d → none |  |
| 3468 | **MP9 - Service Activation Implementation** |  | 2026-08-25 A | 50% → 100% | 348d → none |  |
| 3473 | DIP Promoted to Production | 2026-08-13 A | 2026-08-19 A | 0% → 100% | 351d → none |  |
| 3474 | Create M16 in Customer Solution | 2026-08-13 A | 2026-08-13 A | 0% → 100% | 350d → none |  |
| 3475 | MDD & ISD Publish | 2026-08-17 A | 2026-08-17 A | 0% → 100% | 348d → none |  |
| 3476 | MDD & ISD Go-Live | 2026-08-24 A | 2026-08-24 A | 0% → 100% | 348d → none |  |
| 3477 | MP9 - Service Activation Implementation Complete (M) | 2026-08-25 A | 2026-08-25 A | 0% → 100% | 348d → none |  |
| 3478 | **MP9 - Service Activation Implementation MDD** | 2026-08-13 A | 2026-08-14 A | 0% → 100% |  |  |
| 3479 | MDD Final Circular Completed | 2026-08-14 A | 2026-08-14 A | 0% → 100% | 355d → none |  |
| 3480 | MDD Manual Update | 2026-08-13 A | 2026-08-14 A | 0% → 100% | 354d → none |  |
| 3481 | **Migration Pathway 10 (MP10)** |  |  | 11% → 22% |  |  |
| 3482 | **MP10 - Service Activation Implementation** |  |  | 11% → 22% |  |  |
| 3484 | Market Entry to obtain Effective from Date from PP | 2026-08-13 A | 2026-08-13 A | 0% → 100% | 355d → none |  |
| 3491 | **Migration Pathway 11 (MP11)** |  |  | 38% → 56% |  |  |
| 3492 | **MP11 - Service Activation Implementation** |  |  | 43% → 50% |  |  |
| 3495 | Market Entry to obtain Effective from Date from PP | 2026-08-25 A | 2026-08-25 A | 0% → 100% | 347d → none |  |
| 3502 | **MP11 - Service Activation Implementation MDD** | 2026-08-13 A |  | 0% → 99% |  |  |
| 3504 | MDD Manual Update | 2026-08-13 A | 2026-08-14 A | 0% → 100% | 354d → none |  |
| 3576 | **STEG to Assess Monitoring Report and recommend interim position to MCAG on Decision 1** | 2026-08-19 A | 2026-08-25 A | 0% → 100% |  |  |

| ID | Task | Start | Finish | Duration | Complete | Total float |
| --- | --- | --- | --- | --- | --- | --- |
| 3577 | STEG Issue position to MCAG notifying Decision Checkpoint 1 On-track | 2026-08-19 A | 2026-08-19 A |  | 0% → 100% | 352d → none |
| 3578 | MCAG endorses STEG Assessment that M16 likely to be met | 2026-08-25 A | 2026-08-25 A |  | 0% → 100% | 348d → none |
| 3579 | M16 Checkpoint 1 | 2026-08-25 A | 2026-08-25 A |  | 0% → 100% | 348d → none |
| 3597 | **M16: Creation & Implementation of Updated Settlement Calendars** | 2026-03-09 → 2027-01-04 (+301d) |  | 334d → 119d |  | none → 0d |
| 3655 | **READINESS ASSESSMENTS** |  |  |  | 66% → 78% |  |
| 3677 | **Readiness Assessment 8 - Ready for New Settlement Timetable** |  |  |  | 43% → 84% |  |
| 3680 | Analyse survey responses |  |  |  | 40% → 80% |  |
| 3681 | Conduct deep-dive interviews (sample of PPs) |  |  |  | 40% → 80% |  |
| 3682 | Produce Readiness Assessment Reports (Overall Report & Individual Participant Reports) | 2026-07-30 A |  |  | 0% → 80% |  |
| 3719 | M14 checkpoint: QAG to assess M14 delivery confidence against the Acceptance Criteria | 2026-08-18 A | 2026-08-18 A |  | 0% → 100% | 353d → none |

## Version 13 (data date 2026-10-07, saved 2026-10-07, file MHHS-DEL1139 - MHHS Plan v6.60.mpp)

Last finish stays 2027-12-23. Complete tasks 2790 → 2846.

Added:

| ID | Task | Duration | Start | Finish | Predecessors | Constraint |
| --- | --- | --- | --- | --- | --- | --- |
| 2958 | **CR065** | 22d | 2026-06-01 A | 2026-07-01 A |  |  |
| 2962 | **CR067** | 63d | 2026-09-28 A | 2026-12-23 |  |  |
| 2963 | CR067 Webinar | 1d | 2026-09-28 A | 2026-09-28 A |  | start no earlier than 2026-09-28 |
| 2964 | CR067 Impact Assessment Window | 10d | 2026-09-28 A | 2026-10-09 |  | start no earlier than 2026-09-28 |
| 2965 | CR067 PSG Approval | 1d | 2026-11-04 | 2026-11-04 |  | start no earlier than 2026-11-04 |
| 2966 | CR067 Ofgem Approval | 1d | 2026-12-23 | 2026-12-23 |  | start no earlier than 2026-12-23 |
| 3364 | **Complex Sites Migration** | 67d | 2026-11-02 A | 2027-02-02 |  |  |
| 3365 | Complex Sites - Phase 1 | 10d | 2026-11-02 A | 2026-11-13 |  |  |
| 3366 | Complex Sites - Phase 2 | 29d | 2026-11-16 A | 2026-12-24 |  | finish no earlier than 2026-12-24 |
| 3367 | Complex Sites - Phase 3 | 22d | 2027-01-04 A | 2027-02-02 |  | finish no earlier than 2027-02-02 |
| 3598 | Transition Design states that RF to 4 months to take effect from 1 April 2027 onwards | 1d? | 2027-04-01 | 2027-04-01 | 3601 | start no earlier than 2027-04-01 |
| 3604 | Transition Design states that SF from 15WD to 7WD to take effect from 2 July 2027 onwards | 1d? | 2027-07-02 | 2027-07-02 | 3607 | start no earlier than 2027-07-02 |

Removed: 3684 Readiness Assessment 9 - Ready for New Settlement Timetable and CP5 Check; 3685 Launch Readiness Assessment survey; 3686 PPs submit survey responses; 3687 Analyse survey responses; 3688 Conduct deep-dive interviews (sample of PPs); 3689 Produce Readiness Assessment Reports (Overall Report & Individual Participant Reports); 3690 Readiness Assessment 9 - Readiness for New Settlement Timetable - Completed (incl. Readiness Assessment Report approval); 3695 Readiness Assessment 9 - Readiness for New Settlement Timetable - Completed (incl. Readiness Assessment Report approval)

Changed:

| ID | Task | Start | Finish | Duration | Complete | Total float | Other |
| --- | --- | --- | --- | --- | --- | --- | --- |
| 1 | **PROGRAMME PLAN.** |  |  |  | 96% → 97% |  |  |
| 3 | **PROGRAMME MANAGEMENT** |  |  |  | 92% → 94% |  |  |
| 4 | **Programme Management** |  |  |  | 92% → 94% |  |  |
| 5 | Sprint-based prioritisation planning and execution |  |  |  | 92% → 94% |  |  |
| 6 | Programme governance secretariat |  |  |  | 92% → 94% |  |  |
| 7 | RAID management and reporting |  |  |  | 92% → 94% |  |  |
| 8 | Tracking against Programme outcomes and KPIs |  |  |  | 92% → 94% |  |  |
| 9 | Change control and reporting |  |  |  | 92% → 94% |  |  |
| 10 | Ongoing identification of lessons learned relating to the PMO and implementation of improvements |  |  |  | 92% → 94% |  |  |
| 11 | **Programme Internal Assurance Reviews** |  |  |  | 92% → 94% |  |  |
| 12 | Programme Internal Assurance Reviews |  |  |  | 92% → 94% |  |  |
| 13 | **Engagement with PPs** |  |  |  | 92% → 94% |  |  |
| 14 | Ongoing PP liaison activities |  |  |  | 92% → 94% |  |  |
| 15 | Milestone and Control Point objective setting |  |  |  | 92% → 94% |  |  |
| 16 | Reporting |  |  |  | 92% → 94% |  |  |
| 17 | **PP Engagement Events** |  |  |  | 92% → 94% |  |  |
| 18 | Bilateral meetings |  |  |  | 92% → 94% |  |  |
| 19 | Monthly webinars |  |  |  | 92% → 94% |  |  |
| 20 | Open days |  |  |  | 92% → 94% |  |  |
| 21 | **PP Communications** |  |  |  | 92% → 94% |  |  |
| 22 | The Clock updates (weekly) |  |  |  | 92% → 94% |  |  |
| 23 | Maintain and update content on public-facing Portal (and ongoing feedback reviews to identify and implement Portal improvements) |  |  |  | 92% → 94% |  |  |
| 24 | **Code Change Support / Other Programme Alignment** |  |  |  | 92% → 94% |  |  |
| 25 | Support DCC/BEIS on SEC change |  |  |  | 92% → 94% |  |  |
| 26 | Support on Smart Meters Act changes |  |  |  | 92% → 94% |  |  |
| 27 | Support DCC/RECCo on CSS change |  |  |  | 92% → 94% |  |  |
| 28 | Support Elexon on BSC change |  |  |  | 92% → 94% |  |  |
| 29 | Support code change inside & outside CCIAG |  |  |  | 92% → 94% |  |  |
| 30 | Support code change inside & outside CCAG |  |  |  | 92% → 94% |  |  |
| 46 | **Design Baseline & Enduring PP Support** |  |  |  | 96% → 97% |  |  |
| 56 | **Establish Design Change Management Processes** |  |  |  | 90% → 93% |  |  |
| 61 | Maintain E2E MHHS Design (post-M5 design change management processes operational) |  |  |  | 90% → 93% |  |  |
| 507 | **SYSTEMS INTEGRATION TESTING (SIT)** |  |  |  | 99% → 100% |  |  |
| 1673 | **UIT Environment Preparation** |  | 2026-08-28 A |  | 99% → 100% | 344d → none |  |
| 1724 | **Onboarding and Test Data (Sandbox UIT)** |  | 2026-08-28 A |  | 99% → 100% | 344d → none |  |
| 1726 | Supplier & Agent Onboarding and Test Data Creation and Support |  | 2026-08-28 A |  | 99% → 100% | 344d → none |  |
| 1727 | **Sandbox Execution** |  | 2026-08-28 A |  | 99% → 100% | 344d → none |  |
| 1737 | **Sandbox Testing Execution (UIT) - Supplier & Agent Participants** |  | 2026-08-28 A |  | 99% → 100% | 344d → none |  |
| 1740 | Sandbox Testing Execution (UIT) - Supplier & Agent Participants |  | 2026-08-28 A |  | 99% → 100% | 344d → none |  |
| 1741 | Sandbox Testing End (UIT) - Supplier & Agent Participants | 2026-08-28 A | 2026-08-28 A |  | 0% → 100% | 344d → none |  |
| 2685 | **Qualification Wave 3** |  | 2026-07-30 A |  | 99% → 100% | 365d → none |  |
| 2713 | **Qualification Wave 3 Exit** |  | 2026-07-30 A |  | 99% → 100% | 365d → none |  |
| 2721 | 80% of M14 Critical Wave 3 Participants Qualification approved by BSC PAB and REC Manager | 2026-07-30 A | 2026-07-30 A |  | 0% → 100% | 366d → none |  |
| 2722 | All M14 Critical Wave 3 Participants Qualification approved by BSC PAB and REC Manager | 2026-07-30 A | 2026-07-30 A |  | 0% → 100% | 365d → none |  |
| 2746 | **Qualification Wave 4 Exit** |  |  |  | 96% → 99% |  |  |
| 2751 | Completion of Code Bodies review of Final QAD |  | 2026-08-21 A |  | 78% → 100% | 0.62d → none |  |
| 2752 | QAD Sign Off deadline |  | 2026-08-28 A |  | 62% → 100% | 235d → none |  |
| 2793 | PAB2026/15 | 2026-08-27 A | 2026-08-27 A |  | 0% → 100% | 345d → none |  |
| 2794 | PAB2026/16 | 2026-09-09 A | 2026-09-09 A |  | 0% → 100% | 336d → none |  |
| 2795 | PAB2026/17 | 2026-09-24 A | 2026-09-24 A |  | 0% → 100% | 325d → none |  |
| 2953 | **Regulatory Governance** |  | 2026-07-01 A → 2026-12-23 (+175d) | 587d → 713d | 100% → 99% | none → 261d |  |
| 3272 | **Migration Sprints** |  |  |  | 53% → 54% |  |  |
| 3314 | **Migration Sprint 4** |  |  |  | 35% → 85% |  |  |
| 3321 | Sprint Execution |  | 2026-10-06 A |  | 34% → 100% | 307d → none |  |
| 3322 | Sprint Execution End | 2026-10-06 A | 2026-10-06 A |  | 0% → 100% | 307d → none |  |
| 3323 | Sprint 4 Retro | 2026-10-07 A |  |  | 0% → 10% |  |  |
| 3324 | **Migration Sprint 5** | 2026-09-09 A |  |  | 0% → 11% |  |  |
| 3325 | Sprint 5 Planning start date | 2026-09-09 A | 2026-09-16 A |  | 0% → 100% | 267d → none |  |
| 3326 | Issue Envelope | 2026-09-16 A | 2026-09-16 A |  | 0% → 100% | 267d → none |  |
| 3327 | Supplier Submission Deadline | 2026-09-23 A | 2026-09-23 A |  | 0% → 100% | 267d → none |  |
| 3328 | Baseline Schedule Publication | 2026-09-30 A | 2026-09-30 A |  | 0% → 100% | 267d → none |  |
| 3329 | Migration Sprint 5 Schedule Baselined | 2026-09-30 A | 2026-09-30 A |  | 0% → 100% | 267d → none |  |
| 3330 | Sprint Execution Start | 2026-10-07 A | 2026-10-07 A |  | 0% → 100% | 267d → none |  |
| 3360 | Sprint Execution Start |  |  |  |  |  | constraint none → start no earlier than 2027-03-29 |
| 3390 | **BUSINESS & OPERATIONAL READINESS** |  |  |  | 89% → 90% |  |  |
| 3391 | **Service Management** |  |  |  | 97% → 99% |  |  |
| 3443 | **Migration Pathway 6 (MP6)** |  |  |  | 68% → 97% |  |  |
| 3491 | **Migration Pathway 10 (MP10)** |  |  |  | 22% → 100% |  |  |
| 3492 | **MP10 - Service Activation Implementation** |  |  |  | 22% → 100% |  |  |
| 3495 | PP Qualified by Code Bodies | 2026-08-27 A | 2026-08-27 A |  | 0% → 100% | 340d → none |  |

| ID | Task | Start | Finish | Duration | Complete | Total float | Predecessors | Other |
| --- | --- | --- | --- | --- | --- | --- | --- | --- |
| 3496 | DIP Promoted to Production | 2026-08-28 A | 2026-09-03 A |  | 0% → 100% | 340d → none |  |  |
| 3497 | Create M16 in Customer Solution | 2026-08-28 A | 2026-08-28 A |  | 0% → 100% | 339d → none |  |  |
| 3498 | ISD Publish | 2026-09-01 A | 2026-09-01 A |  | 0% → 100% | 337d → none |  |  |
| 3499 | ISD Go-Live | 2026-09-08 A | 2026-09-08 A |  | 0% → 100% | 337d → none |  |  |
| 3500 | MP10 - Service Activation Implementation Complete (M) | 2026-09-09 A | 2026-09-09 A |  | 0% → 100% | 337d → none |  |  |
| 3501 | **Migration Pathway 11 (MP11)** |  | 2026-09-22 A |  | 56% → 100% | 328d → none |  |  |
| 3502 | **MP11 - Service Activation Implementation** |  | 2026-09-22 A |  | 50% → 100% | 328d → none |  |  |
| 3506 | PP Qualified by Code Bodies | 2026-09-09 A | 2026-09-09 A |  | 0% → 100% | 331d → none |  |  |
| 3507 | DIP Promoted to Production | 2026-09-10 A | 2026-09-16 A |  | 0% → 100% | 331d → none |  |  |
| 3508 | Create M16 in Customer Solution | 2026-09-10 A | 2026-09-10 A |  | 0% → 100% | 330d → none |  |  |
| 3509 | MDD & ISD Publish | 2026-09-14 A | 2026-09-14 A |  | 0% → 100% | 328d → none |  |  |
| 3510 | MDD & ISD Go-Live | 2026-09-21 A | 2026-09-21 A |  | 0% → 100% | 328d → none |  |  |
| 3511 | MP11 - Service Activation Implementation Complete (M) | 2026-09-22 A | 2026-09-22 A |  | 0% → 100% | 328d → none |  |  |
| 3512 | **MP11 - Service Activation Implementation MDD** |  |  |  | 99% → 100% |  |  |  |
| 3513 | MDD Final Circular Completed | 2026-09-11 A | 2026-09-11 A |  | 0% → 100% | 335d → none |  |  |
| 3515 | **Migration Pathway 12a (MP12a)** |  | 2026-10-06 A |  | 11% → 100% | 318d → none |  |  |
| 3516 | **MP12a - Service Activation Implementation** |  | 2026-10-06 A |  | 11% → 100% | 318d → none |  |  |
| 3518 | Market Entry to obtain Effective from Date from PP | 2026-09-10 A | 2026-09-10 A |  | 0% → 100% | 335d → none |  |  |
| 3519 | PP Qualified by Code Bodies | 2026-09-24 A | 2026-09-24 A |  | 0% → 100% | 319d → none |  |  |
| 3520 | DIP Promoted to Production | 2026-09-25 A | 2026-10-01 A |  | 0% → 100% | 320d → none |  |  |
| 3521 | Create M16 in Customer Solution | 2026-09-25 A | 2026-09-25 A |  | 0% → 100% | 319d → none |  |  |
| 3522 | ISD Publish | 2026-09-28 A | 2026-09-28 A |  | 0% → 100% | 318d → none |  |  |
| 3523 | ISD Go-Live | 2026-10-05 A | 2026-10-05 A |  | 0% → 100% | 318d → none |  |  |
| 3524 | MP12a - Service Activation Implementation Complete (M) | 2026-10-06 A | 2026-10-06 A |  | 0% → 100% | 318d → none |  |  |
| 3525 | **Migration Pathway 12b (MP12b)** |  |  |  | 38% → 81% |  |  |  |
| 3526 | **MP12b - Service Activation Implementation** |  |  |  | 43% → 93% |  |  |  |
| 3529 | Market Entry to obtain Effective from Date from PP | 2026-09-10 A | 2026-09-10 A |  | 0% → 100% | 335d → none |  |  |
| 3530 | PP Qualified by Code Bodies | 2026-09-24 A | 2026-09-24 A |  | 0% → 100% | 319d → none |  |  |
| 3531 | DIP Promoted to Production | 2026-09-25 A | 2026-10-01 A |  | 0% → 100% | 320d → none |  |  |
| 3532 | Create M16 in Customer Solution | 2026-09-25 A | 2026-09-25 A |  | 0% → 100% | 319d → none |  |  |
| 3584 | STEG May - M16 Checkpoint 2 | 2027-05-17 → 2027-05-12 (-5d) | 2027-05-17 → 2027-05-12 (-5d) |  |  | 159d → 162d |  | constraint start no earlier than 2027-05-17 → start no earlier than 2027-05-12 |
| 3585 | **M16: Decision Points** |  |  |  | 0% → 50% |  |  |  |
| 3590 | **Decision 1 RF Change to 7 months from Settlement Day 01/10** | 2026-09-01 → 2026-08-14 A (-18d) | 2026-09-18 → 2026-09-15 A (-3d) | 14d → 23d | 0% → 100% |  |  | baseline start 2026-09-01 → 2026-08-14; baseline finish 2026-09-18 → 2026-09-15 |
| 3591 | Update Monitoring Data to be provided from Performance Assurance and MCC | 2026-09-01 → 2026-08-14 A (-18d) | 2026-09-01 → 2026-08-14 A (-18d) |  | 0% → 100% | 342d → none |  | constraint start no earlier than 2026-09-01 → start no earlier than 2026-08-14 |
| 3592 | STEG to compare Monitoring report against agreed Assessment Criteria | 2026-09-08 → 2026-09-02 A (-6d) | 2026-09-08 → 2026-09-02 A (-6d) |  | 0% → 100% | 333d → none | none → 3591 | constraint start no earlier than 2026-09-08 → start no earlier than 2026-09-02; baseline start 2026-09-08 → 2026-09-02; baseline finish 2026-09-08 → 2026-09-02 |
| 3593 | STEG Issue recommendation to eMCAG | 2026-09-08 A | 2026-09-08 A |  | 0% → 100% | 337d → none |  | was named STEG Issue recommendation to MCAG |
| 3594 | eMCAG Approve Recommendation to Change to RF 7 Months Calendar | 2026-09-15 A | 2026-09-15 A |  | 0% → 100% | 333d → none |  |  |
| 3595 | Decision 1 - RF 7 Months | 2026-09-15 A | 2026-09-15 A |  | 0% → 100% | 332d → none |  |  |
| 3596 | Communication issued to Industry notifying Parties RF will be 7 months | 2026-09-15 A | 2026-09-15 A |  | 0% → 100% | 332d → none |  |  |
| 3597 | **Decision 2 RF Change to 4 months from Settlement Date 01/04** | 2027-03-15 → 2027-03-10 (-5d) | 2027-03-19 → 2027-03-23 (+4d) | 5d → 10d? |  |  |  | baseline start 2027-03-15 → 2027-03-10; baseline finish 2027-03-19 → 2027-03-23 |
| 3599 | STEG to compare Monitoring report against agreed assessment criteria | 2027-03-15 → 2027-03-10 (-5d) | 2027-03-15 → 2027-03-10 (-5d) |  |  | 199d → 201d |  | constraint start no earlier than 2027-03-15 → start no earlier than 2027-03-10; baseline start 2027-03-15 → 2027-03-10; baseline finish 2027-03-15 → 2027-03-10 |
| 3600 | STEG Issue recommendation to MCAG | 2027-03-19 → 2027-03-16 (-3d) | 2027-03-19 → 2027-03-16 (-3d) |  |  | 199d → 201d |  | constraint finish no earlier than 2027-03-19 → start no earlier than 2027-03-16; baseline start 2027-03-19 → 2027-03-16; baseline finish 2027-03-19 → 2027-03-16 |
| 3601 | MCAG Approve Recommendation to Change to RF 4 Months Calendar | 2027-03-19 → 2027-03-23 (+4d) | 2027-03-19 → 2027-03-23 (+4d) |  |  | 199d → 197d |  | was named MCAG Approve recommendation; constraint finish no earlier than 2027-03-19 → start no earlier than 2027-03-23; baseline start 2027-03-19 → 2027-03-23; baseline finish 2027-03-19 → 2027-03-23 |
| 3602 | Decision 2 - RF 4 Months | 2027-03-19 → 2027-03-23 (+4d) | 2027-03-19 → 2027-03-23 (+4d) |  |  | 199d → 198d |  | baseline start 2027-03-19 → 2027-03-23; baseline finish 2027-03-19 → 2027-03-23 |
| 3603 | **Decision 3 SF Change from 15WD to 7WD from Settlement Date 02/07** | 2027-06-14 → 2027-06-02 (-12d) | 2027-06-18 → 2027-06-15 (-3d) | 5d → 10d? |  |  |  | baseline start 2027-06-14 → 2027-06-02; baseline finish 2027-06-18 → 2027-06-15 |
| 3605 | STEG to compare Monitoring report against agreed assessment criteria | 2027-06-14 → 2027-06-02 (-12d) | 2027-06-14 → 2027-06-02 (-12d) |  |  | 5d → 13d |  | constraint start no earlier than 2027-06-14 → start no earlier than 2027-06-02; baseline start 2027-06-14 → 2027-06-02; baseline finish 2027-06-14 → 2027-06-02 |
| 3606 | STEG Issue recommendation to eMCAG | 2027-06-18 → 2027-06-09 (-9d) | 2027-06-18 → 2027-06-09 (-9d) |  |  | 5d → 13d |  | was named STEG Issue recommendation to MCAG; constraint finish no earlier than 2027-06-18 → start no earlier than 2027-06-09; baseline start 2027-06-18 → 2027-06-09; baseline finish 2027-06-18 → 2027-06-09 |
| 3607 | eMCAG Approve Recommendation - Confirm M16 Date | 2027-06-18 → 2027-06-15 (-3d) | 2027-06-18 → 2027-06-15 (-3d) |  |  | 5d → 9d |  | was named MCAG Approve Recommendation - Confirm M16 Date; constraint finish no earlier than 2027-06-18 → start no earlier than 2027-06-15; baseline start 2027-06-18 → 2027-06-15; baseline finish 2027-06-18 → 2027-06-15 |
| 3608 | Decision 3 - SF 7WD | 2027-06-18 → 2027-06-15 (-3d) | 2027-06-18 → 2027-06-15 (-3d) |  |  | 134d → 138d |  | constraint finish no earlier than 2027-06-18 → start no earlier than 2027-06-15; baseline start 2027-06-18 → 2027-06-15; baseline finish 2027-06-18 → 2027-06-15 |
| 3609 | **M16: Creation & Implementation of Updated Settlement Calendars** |  | 2027-06-17 → 2027-07-02 (+15d) | 119d → 130d |  |  |  |  |
| 3616 | Implementation of April - Jun 2027 Calendar | 2027-03-19 → 2027-03-23 (+4d) | 2027-03-19 → 2027-03-23 (+4d) |  |  | 199d → 198d |  | baseline start 2027-03-19 → 2027-03-23; baseline finish 2027-03-19 → 2027-03-23 |
| 3621 | Implementation of July 2027 Calendar | 2027-06-17 → 2027-07-02 (+15d) | 2027-06-17 → 2027-07-02 (+15d) |  |  | 11d → 0d | 3620FS+10d → 3620FS+21d | was named Implementation of Jul - Mar 2027 Calendar; baseline start 2027-06-17 → 2027-07-02; baseline finish 2027-06-17 → 2027-07-02 |
| 3622 | **M16 Approval Window** | 2027-06-25 → 2027-06-21 (-4d) |  | 129d → 133d |  |  |  |  |
| 3623 | Panel approval that M16 criteria met | 2027-06-25 → 2027-06-21 (-4d) | 2027-06-25 → 2027-06-21 (-4d) |  |  | 5d → 9d |  |  |
| 3667 | **READINESS ASSESSMENTS** |  | 2027-06-17 → 2026-09-02 A (-288d) | 988d → 782d | 78% → 100% | 135d → none |  |  |
| 3689 | **Readiness Assessment 8 - Ready for New Settlement Timetable** |  | 2026-09-02 A |  | 84% → 100% |  |  |  |
| 3692 | Analyse survey responses |  | 2026-09-02 A |  | 80% → 100% | 341d → none |  |  |
| 3693 | Conduct deep-dive interviews (sample of PPs) |  | 2026-09-02 A |  | 80% → 100% | 341d → none |  |  |
| 3694 | Produce Readiness Assessment Reports (Overall Report & Individual Participant Reports) |  | 2026-09-02 A |  | 80% → 100% | 341d → none |  |  |
| 3695 | Readiness Assessment 8 - Ready for New Settlement Timetable - Completed (incl. Readiness Assessment Report approval) | 2026-09-02 A | 2026-09-02 A |  | 0% → 100% | 342d → none |  |  |
| 3696 | **Readiness Assessments - Tier 1 Milestones** |  | 2027-06-17 → 2026-09-02 A (-288d) | 512d → 305d | 0% → 100% | 135d → none |  |  |
| 3699 | Readiness Assessment 8 - Ready for New Settlement Timetable - Completed (incl. Readiness Assessment Report approval) | 2026-09-02 A | 2026-09-02 A |  | 0% → 100% | 342d → none |  |  |
| 3724 | M14 Checkpoint: PSG assesses M14 delivery confidence | 2026-09-02 A | 2026-09-02 A |  | 0% → 100% | 342d → none |  |  |
| 3725 | Notification to Ofgem of no central issues as of QA+P Annex 4 | 2026-09-03 A | 2026-09-03 A |  | 0% → 100% | 341d → none |  |  |
